# 3GPP_Release-2000

Schedule from MS Project, 1999-01-01 to 2012-12-07, A marks actual dates.

## Calendars

- Standard: Mon-Fri 08:00-12:00, 13:00-17:00; Sat-Sun off. Exceptions (off unless hours are given): 2000-01-15 08:00-12:00, 13:00-17:00, 2009-05-30 08:00-12:00, 13:00-17:00.

## Resources

| Resource |
| --- |
| NP |
| N1 |
| N2 |
| N3 |
| N4 |
| N5 |
| TP |
| T1 |
| T2 |
| T3 |
| RP |
| R1 |
| R2 |
| R3 |
| R4 |
| SP |
| S1 |
| S2 |
| S3 |
| S4 |
| S5 |
| PCG |
| GP |
| No |
| CN4 |
| ? |
| WG G2 |
| G2 |
| G1 |
| G4 |
| G3 |
| All |
| Generic |
| MLST |
| G5 |
| S3, G2 |
| WG T2 |
| GP,G1 |
| G4,G5 |
| OMA |
| GP-G2 |
| Yes |
| GP, |
| N4, |
| GP, N1 |
| CT5 |
| C5 |
| C1 |
| C4 |
| C3 |
| C6 |
| G1, |
| 4 |
| ct |
| c,s,r |
| CT,RAN,SA |
| G2, |
| G1, G3 |
| CT6 |
| CT1 |
| CT1, CT3, CT4 |
| C1, C3, C4 |
| CP |
| R5 |
| C |
| Rel-8 |
| GP, G2 |
| R1,R4 |
| S5,C1 |
| CT,RAN,SA,GERAN |
| S3,C1,C4 |
| 5 |
| S1,C1,C3,C4,S5 |
| S1,C1,C3,C5 |
| S1,C1,C3,C4 |
| S1,S5 |
| S2,S3 |
| RAN,SA |
| RP,S5 |
| S2,CT |
| S1,CT |
| S1,CT,GERAN |
| S1,C5 |
| S3,CT |
| S4,CT |
| C1,SA |
| S1,S2 |
| S1,S4 |
| S2,S2,S3,CT |
| S2,S3,CT |
| S1,CT,GX |
| S1,S4,CT |
| S2,S2,S3,S5,CT |
| S1,S2,CT |
| S1,S2,S3,CT |
| S1,S2,S3,S5CT |
| S1,S2,S3,S5,CT |
| S2,S5,CT |
| S4,S3 |
| S1,C1 |
| CP,C1 |
| C1,C3 |
| C1,C3,C4 |
| S1,S5,CT |
| C4,C3 |
| CP,RAN,SA,GERAN |
| S1,S2,S3,S5,CP |
| S2,S3,CP |
| S2,CP |
| S1,CP,GX |
| S1,CP |
| S1,S4,CP |
| S1,S2,CP |
| S1,S2,S3,CP |
| S2,S5,CP |
| S3,CP |
| S1,S5,CP |
| RAN,SA,GERAN |
| S1,S2,S3,S5,C1,C3,C4,C6 |
| S2,S3,C1,C3,C4 |
| S2,C4 |
| S2,C1,C3,C4 |
| S2,C1,C4 |
| S2,S3,C1,C4 |
| S1,C1,C4,G2 |
| C1,C4 |
| S1,C1,C3 |
| S1,S4,C1,C3,C4 |
| S1,S2,S3,C1,C3,C4 |
| S2,S5,C3 |
| S1,S2,C1,C4 |
| S2,C1 |
| S2,C1,C3 |
| S3,C1,C3,C4 |
| S1,S5,C1,C3,C4 |
| S2,C3,C4 |
| C3,C1 |
| R2,R4 |
| R2,R5 |
| RP,R5 |
| RP,S5,R5 |
| R1,R5 |
| S1,C1,R5 |
| S1,C1,S4,R5 |
| GERAN |
| G3new |
| G1, G3new |
| C4,C1,C3 |
| R1.R4 |
| R1, R4 |
| R2,R3 |
| C3,C4 |
| S4,C3 |
| S4,C3,C1,C4 |
| S1,S2,C1 |
| S1,S2<C1,C3,C4 |
| S1,S2,C1,C3,C4 |
| S5,C1,C3,C4 |
| GP,C4 |
| C4,C1 |
| S2,S1 |
| RP,SP,GP |
| RP,SP,CP,GP |
| CP,GP,RP,SP |
| GP,C4,S4 |
| S1,C1,C4 |
| S1,S2,C3,C1 |
| R2,R4,R3 |
| CP,GP, RP,SP |
| S2,S1,C1,S5 |
| S2,S1,C1 |
| S1,C1,S4 |
| S1,S2,GP,C4,R2 |
| S1,GP,R2 |
| S1,C6 |
| S1,S2,C1,S4 |
| S2,S3,S5,C1,C3,C4 |
| S2,S5,C1 |
| S2,S3,S5 |
| CP,GP, RP,SP,TP |
| S2,C4,C1 |
| S1,C1,C4,S3 |
| S2,S5 |
| S3,C1 |
| S3,C4 |
| S1,C4 |
| S2,S5,C3,C1 |
| S2,S1,S5,C1,C4 |
| S1,R1,C3 |
| S1,C1,R2 |
| S2,S1,C1,C4 |
| S1,C1,C6 |
| GP,S4,C4,C1,C3 |
| C3,C1,C4 |
| S1,C4,C1 |
| S1,S3 |
| S1,S2,S5,C3,C4 |
| R4,G1 |
| G1,R4 |
| RP,GP |
| R4,GP |
| R3,R2 |
| C6,RP,SP |
| R5,C6 |
| CP,RP,SP |
| RP,SP,CP |
| R3,S5 |
| S1,S2,RP |
| S1,S2,S5,RP |
| S2,S1,RP |
| Rel-9 |
| S3,C6 |
| S1,S2,S3,S5,RP |
| S2,S1,S3 |
| S1,S2,S3 |
| S1,S2,S3,S5 |
| C6,R5 |
| S1,S2,RP,GP |
| S1,S2,S4,S5,RP,GP |
| GP,G2 |
| GP,GP, N1 |
| GP,S2,G1,G2 |
| GP,R2,R3,S2,G1,G2 |
| GP,S2,S5,R2,R3,G2,G1 |
| GP,R3 |
| N4,S2 |
| GP,RP |
| GP,S2,RP |
| G5,G4 |
| G4,R3 |
| S2,R2,R4 |
| S1,S2,R2,R4 |
| GP,S5 |
| S1,S2,S5 |
| R4,R5 |
| R4,R2,R3,R5 |
| S2,S5,N4,RP |
| S1,S2,S3,S5,NP |
| S2,S4,S5 |
| T2,S1,S4,S5 |
| SP,RP |
| S2,RP |
| S1,S2,CP,G2 |
| CP,SP |
| S1,G2 |
| SP,CP |
| S1,S2,S5,C3 |
| S1,C1,S3 |
| G1,G3new |
| C4, C3, C1C4 |
| C4,C3,C1 |
| S1,S2,S3,S5,R2,R3,R4 |
| S1,S2,S3,R2 |
| S2,S3,S5,C4,R2 |
| S1,S5,C1 |
| S1,S2,S3,C1,C3,C4,R2 |
| Ggp |
| S3,S2,C1,C4,G2 G3new |
| R1,R2,R3,R4 |
| R4,R1,R2,R3 |
| R4,R2,R3 |
| S1,C1,C4,R2 |
| R4,R2 |
| S2,C4,R2,R4 |
| S2,C4,R2 |
| S2,S3,S5,C3,C4,R2 |
| S1,S2,S4,T2 |
| S1,S2,S4 |
| S1,S2,S4,R5 |
| S3,S2,C1,C4,G2,G3new |
| GP,C1 |
| S1,S5,C4 |
| S1,S2,S3,S5,R2,R3,R4,GP |
| GP,C4,C3,C1 |
| SMG9 |
| SMG1 |
| SMG2 |
| N3,R5 |
| N1, N2, N4, G1, G2, R3, S1, SMG2 |
| S1,SMG1 |
| SMG1,N4 |
| N1,C1,N4,S1,T2,G2,SMG1,SMG2,SMG3,SMG7,SMG9 |
| SMG1,N2 |
| S1,S2,N2,N4 |
| N4,N2 |
| G1,G2 |
| G1,G2,C1 |
| G1,G2,N1 |
| SMG2, SMG1, SMG3, SMG4, SMG7, SMG9, SMG10, G1, G2, G3, N1, N3, T2 |
| SMG2,G1 |
| S1,G1,G2 |
| SMG1,N1,G1,G2 |
| G2,G1 |
| G1,G2,G3,S1,S2,SMG1,SMG2,SMG7,N1,N2,N3,N4,T2 |
| 23.003, 23.008, 29.060 |
| S1, S2, SMG1, SMG2, SMG12, G2, N1, N2, N4 |
| S1,S2,SMG1,SMG2,SMG12,G2,N1,N2,N4 |
| S1,SMG2,N1,N2,N4 |
| SMG1,T2 |
| S1,N1,N2,N4 |
| S1,S2,N5 |
| SMG2,SMG7,G2,T2 |
| S3,N1,N2,N3 |
| S3,N1,N2,N4 |
| SMG9,T3 |
| SMG2,SMG3,SMG7,G2,N2 |
| SMG2,N1,G1,G2 |
| S1,N2 |
| N1,N3 |
| S2,N1 |
| N1,N2,N4 |
| N2,N1,N4 |
| N2,N4 |
| S1,T3 |
| T2,N3 |
| S3,N2 |
| T2,S1 |
| S1,N4 |
| SMG1,SMG2,SMG7 |
| N1,S1,T1 |
| SMG1,SMG3 |
| N4,S2,N1 |
| S1,S2,SMG1,SMG2,SMG7,G1,G2,G3,N1,N2,N3,N4,T2 |
| SMG1,N3 |
| S1,N3 |
| CP,SP,SMG |
| CP,SP,TP,GP,SMG |
| NP,SP,TP,GP,SMG |
| NP,GP, RP,SP,TP |
| SMG2,SMG1,SMG3,SMG4,SMG7,SMG9,SMG10,G1,G2,G3,N1,N3,T2 |
| S1,N2,N4 |
| S1,S2,S3,C1,C3,C4,R2,R3 |
| R2,R3,R1,R4 |
| R2,R3,R4 |
| R2,R1,R3,R4 |
| S2,C4,R2,R3,R4 |
| S2,C4,R2,R1,R3,R4 |
| S2,S3,S5,C3,C4,R2,R3,R4 |
| R1,R2,R4 |
| R3,R1,R4 |
| S2, |
| S2,G2, |
| S1,S2,G2, |
| S1,S2,G2,R2,R3, |
| S1,S2,C4,G2,R2,R3 |
| S1,S2,N4,G2,R2,R3 |
| S1,S2,SMG1,SMG2,SMG12,G2,N1,N2,N4,R2,R3 |
| S1,SMG1,T2 |
| S1,SMG1,S2 |
| S1,N4,N2 |
| T2,N1,N3 |
| S3,N2,N4 |
| SMG1,SMG2,SMG3,SMG7,SMG9,N1,C1,N4,S1,T2,G2 |
| SMG1,N2,N4 |
| S2,T2,N1,N2,N4 |
| S1,T2 |
| S1,S2,C4 |
| S1,S2,N4,RP |
| S2,N4 |
| S1,S2,N3,N4,RP |
| S1,S2,SMG1,SMG2,SMG12,T2,G2,N1,N2,N4,R2,R3 |
| S1,T2,N1,N3 |
| S1,S2,SMG1,SMG2,SMG12,T2,G2,N1,N2,N3,N4,R2,R3 |
| S1,S2,S3,SMG1,SMG2,SMG12,G2,N1,N2,N4,R2,R3 |
| S1,S2,SMG,G1,G2,G3,N1,N2,N3,N4,T2 |
| S1,S2,SMG,T2,G2,N1,N2,N3,N4,R2,R3 |
| S1,S3,SMG,G1,G2,G3,N1,N2,N3,N4,T2 |
| S1,S3,T2,N2,N4 |
| S1,S2,SMG,T2,G1,G2,G3,N1,N2,N3,N4 |
| G2,S2 |
| T1,R5 |
| R5,T1 |
| S1,S2,S4,T1,R5 |
| S1,S2,S4,S5,T1,RP,GP |
| S1,S2,S3,S5,R2,R3,R4,GP,C1 |
| S1,S2,S3,SMG1,SMG2,SMG12,N1,N2,N4,R2,R3 |
| S1,S2,SMG,T2,N1,N2,N3,N4,R2,R3 |
| NP,SP,TP,SMG |
| S1,S2,SMG,T2,N1,N2,N3,N4 |
| SMG,N1 |
| SMG |
| S1,S2,SMG1,SMG2,SMG7,N1,N2,N3,N4,T2 |
| SMG2,SMG1,SMG3,SMG4,SMG7,SMG9,SMG10,N1,N3,T2 |
| S1,SMG |
| SMG2,SMG7,T2 |
| SMG2,S2 |
| N1,N2,N4,R3,S1,SMG |
| SMG2,SMG3,SMG7,N2 |
| SMG1,SMG2,SMG3,SMG7,SMG9,N1,C1,N4,S1,T2 |
| S1,S2,SMG,N3,N4,RP |
| S1,S2,S4,SMG,N3,N4,RP |
| S2,C1,C4,R2,R1,R3,R4 |
| R2,S2,S4 |
| G3new,R5 |
| GP,R4 |
| S2,S4,R2 |
| SP,GP |
| RP,SP |
| S2,S1,S3,S5 |
| S3,S1 |
| N4,N1,N2,S2 |
| S2,G1,G2,R2,R3 |
| S2,G1,G2 |
| G1,G2,R2,R3 |
| N4,T3 |
| S3,S2,N1,N4,T3,OMA |
| T2,S1,S4,S5,OMA |
| S2,N3 |
| S4,S1 |
| N4,N3,S1 |
| R5,G3new |
| R4,R2,R1 |
| S2,R2 |
| C3, C4,C1 |
| S3,C1,C4,C3 |
| C1,C4,C3 |
| S2,C1,C4,C3 |
| R3,R5 |
| S1,S2,C3 |
| R1,R2 |
| S3,C1,C4,G2,G3new |
| R1,R3 |
| GP,N1 |
| R1,R2,R3 |
| R3,R2,R4 |
| R4,R3 |
| S1,S2,R2,R3 |
| S1,S2,S3,C1,C3,C4,R2,R3,R5 |
| S2,S1,S5 |
| C4, C1 |
| C3, C1, C4 |
| S2,S1,S3,S5,C4,C1 |
| S2,C3,C1,C4 |
| S2,S1,S5,C3 |
| GP,S2,C1 |
| GP,S2,C1,G2 |
| G2,S2,C1 |
| v |
| G3new,G1,G2 |
| G1,G2,C1,G3new |
| S2,S1,S5,C1,C3 |
| C1,C3,C4,R5 |
| R2,R1 |
| S1<S2,N1,R2,R5 |
| S1,S2,N1,R2,R5 |
| S2,R5 |
| S1,S2,S5,R5 |
| S2,C1,C4,R2,R1,R3,R4,R5 |
| S1,S2,S3,S5,NP,R5 |
| S1,S2,S4,S5,RP,R5,GP |
| S1,S2,S3,S5,C1,C6,R2,R3,R4 |
| S1,S2,S3,S5,C1,C6,R2,R3,R4,GP |
| S4,R2 |
| S1,S2,C1,C4,G2 |
| S4,C3,C4 |
| S5,C1,C4 |
| S2,C4,C3,C1 |
| C4, C3, C1 |
| S2,S4,R2,C4,C3,C1 |
| GP1,GP2 |
| GP,GP1,GP2 |
| GP,G1,G2 |
| G2,R3 |
| S1,S2,S3,C1,C3,C4,G2 |
| GP,G1,C1 |
| S1,S2,C4,C3,C1 |
| - |
| GP,G1,G2,G3new |
| S1,S2,S3,C1,C3,C4,G2,R2,R3 |
| S1,S2,C1,C3,C4,G2,R2,R3 |
| C1,C6 |
| GP,G2,C4 |
| S2,C3 |
| R5,R4 |
| C4,GP,G2 |
| S1,S2,C1,C4,G2,R2,R3 |
| R1,R2,R4,S3 |
| S2,S5,C3,C1,C4 |
| S2,S4,C4,C3,C1 |
| S2,S4 |
| S3,S1,S2 |
| S1,S2,S3,C1,R2 |
| S3,S1,S2,C1,R2 |
| S2,C3,S5 |
| S1,S2,C1,C4,C3,G2,R2,R3 |
| S5,C4 |
| S2,S1,C3 |
| C1,C4,C3,C6 |
| S1,S2,C1,C4,C3,C6,G2,R2,R3 |
| R1,R2,R4,S3,C4,C6 |
| R4,R1,R4,R1,R2,R3,R3 |
| S2,R3,R2 |
| S1,S2,S5,CP |
| S1,S3,CP |
| C6,C1 |
| R4,R2,R1,R3 |
| R3,R1,R2 |
| R1,R4,R2,R3 |
| S2,C4,C1,C3 |
| R3,R1,R2,R4 |
| C4,S1 |
| S2,S5,R3,GP, |
| S2,S5,R3,GP |
| S1,S2,S3,S5,C1,C3,C4 |
| S2,S3,S5,C1,C3,C4,C6 |
| S5,S1 |
| 03.06.2011 |
| CT1 CT3, CT4 |
| CT3, |
| CT4 |
| CT3 |
| GP,G2,G1 |
| S5,S1,C1 |
| SP,RP,CP |
| SP,CP,GP,RP |
| R1,R2,R4,R3 |
| R4,R2,R5 |
| R2,R4,R5 |
| R1,R2,R4,S2,S3,C4,C6 |
| C1-IETF |
| S4-IETF |
| C1-IETF, C3-IETF, C4-IETF |
| S3-IETF |
| C4-IETF |
| C1-IETF, C3-IETF |
| S2,S4,C1,R2 |
| S2,S4,C3,C4 |
| S2,S4,C1,C3,R2 |
| S1,S2,C1,IETF |
| S4,IETF |
| C1,C4,IETF |
| S2,S4,C1,C3,R2,IETF |
| S3,C1,C4,C3,IETF |
| S3,C4,IETF |
| C1,IETF |
| S1,S2,S3,S5,C1,C3,C4,C6,IETF |
| S2,S3,C1,C4,IETF |
| S1,S2,C1,C3,C4,IETF |
| C1,C3,C4,IETF |
| S1,S5,C1,C3,C4,IETF |
| C1,C3,IETF |
| S2,C1,C3,C4,IETF |
| S2,S4,C3,C4,IETF |
| S5,C1,C4,IETF |
| S5,C1,C3,C4,IETF |
| S2,S3,S5,C1,C3,C4,IETF |
| S2,IETF |
| S3,C1,C3,C4,IETF |
| S2,S3,C1,C3,C4,IETF |

## Schedule

| ID | WBS | Task | Type | Duration | Start | Finish | Complete | Remaining | Baseline start | Baseline finish | Baseline duration | Total slack | Constraint | Resources | Work | Actual work | Text1 | Text6 | Text8 | Text2 | Text4 | Text5 | Text7 | Text3 |
| --- | --- | --- | --- | --- | --- | --- | --- | --- | --- | --- | --- | --- | --- | --- | --- | --- | --- | --- | --- | --- | --- | --- | --- | --- |
| 1 | 1 | Version 2011 June 21 | milestone | 0d? | 2000-01-03 A | 2000-01-03 A | 100% |  | 2000-01-03 | 2000-01-03 | 0d? |  |  | - |  |  |  |  |  |  |  |  |  |  |
| 2 | 2 | Rel-11 Stage 1 freeze 09/2011 | milestone | 0d? | 2000-01-03 A | 2000-01-03 A | 100% |  | 2000-01-03 | 2000-01-03 | 0d? |  | finish no earlier than 1998-12-07 | - |  |  |  |  |  |  |  |  |  |  |
| 3 | 3 | **5 Rel-10 Stage 3 exceptions to 09/2011** |  | 76d? | 2011-06-03 A | 2011-09-16 | 84% | 11.85d? | 1998-08-21 | 2011-09-16 | 3413d? | 320d |  | - | 3648h | 3078.97h |  |  |  |  |  |  |  |  |
| 4 | 3.1 | GERAN part of Network Improvements for Machine-Type Communications (Stage 3) |  | 76d? | 2011-06-03 A | 2011-09-16 | 75% | 19d? | 2011-06-03 | 2011-09-16 | 76d? | 320d | finish no earlier than 2011-09-16 | G2 | 608h | 456h | NIMTC | Rel-10 |  |  |  |  |  |  |
| 5 | 3.2 | GERAN part: Multi-standard radio Base Station RF requirements for non-contiguous spectrum deployments |  | 76d? | 2011-06-03 A | 2011-09-16 | 80% | 15.2d? | 2011-06-03 | 2011-09-16 | 76d? | 320d | finish no earlier than 2011-09-16 | G1 | 608h | 486.4h | MSR_NC-Core | Rel-10 |  |  |  |  |  |  |
| 6 | 3.3 | UMTS/LTE 3500 MHz |  | 76d? | 2011-06-03 A | 2011-09-16 | 87% | 9.88d? | 2011-06-03 | 2011-09-16 | 76d? | 320d | finish no earlier than 2011-09-16 | R4,R2,R3 | 608h | 528.96h | RInImp8-UMTSLTE3500 | Rel-10 |  |  |  |  |  |  |
| 7 | 3.4 | Core part: Extending 850 MHz Upper Band (814 – 849 MHz) |  | 76d? | 2011-06-03 A | 2011-09-16 | 90% | 7.6d? | 2011-06-03 | 2011-09-16 | 76d? | 320d | finish no earlier than 2011-09-16 | R4,R2,R3 | 608h | 547.2h | e850_UB-Core | Rel-10 |  |  |  |  |  |  |
| 8 | 3.5 | Alarm Correlation and Root Cause Analysis |  | 76d | 2011-06-03 A | 2011-09-16 | 90% | 7.6d | 1998-08-21 | 1998-12-07 | 76d | 320d | finish no earlier than 2011-09-16 | S5 | 608h | 547.2h | OAM-AC-RCA | Rel-10 |  |  |  |  |  |  |
| 9 | 4 | Gantt: dark blue=done; light blue=to be done; grey: previous values; black=summary | milestone | 0d? | 2000-01-03 A | 2000-01-03 A | 100% |  | 2000-01-03 | 2000-01-03 | 0d? |  | finish no earlier than 1998-12-07 | - |  |  |  |  |  |  |  |  |  |  |
| 10 | 5 | Release 11 Features |  | 457d? | 2010-03-25 | 2011-12-23 |  |  | 2010-03-25 | 2011-12-23 | 457d? | 250d | finish no earlier than 2011-12-23 | SP,CP,GP,RP | 3656h |  |  | Rel-11 | All |  |  |  |  |  |
| 11 | 6 | **Advanced IP Interconnection of Services** |  | 517d? | 2010-03-25 A | 2012-03-16 | 71% | 149.9d? | 2010-03-25 | 2012-03-16 | 517d? | 190d |  | S1,S2 | 9872h | 7009.61h | IPXS | Rel-11 | Alain | PCG-24 | Telefónica | chris.friel@O2.com | SP-47 |  |
| 12 | 6.1 | Stage 1 for Advanced IP Interconnection of Services |  | 390d | 2010-03-25 A | 2011-09-21 | 97% | 11.7d | 2010-03-25 | 2011-09-21 | 390d | 317d | finish no earlier than 2011-09-21 | S1 | 3120h | 3026.4h | IPXS | Rel-11 | Alain | PCG-24 | Telefónica | chris.friel@O2.com | SP-47 | 22.101, 22.228 |
| 13 | 6.2 | Stage 2 for Advanced IP Interconnection of Services |  | 327d? | 2010-12-16 A | 2012-03-16 | 40% | 196.2d? | 2010-12-16 | 2012-03-16 | 327d? | 190d | finish no earlier than 2012-03-16 | S2 | 2616h | 1046.4h | IPXS | Rel-11 | Maurice | PCG-26 | Ericsson | fredrik.lindholm@ericsson.com | SP-50 | 23.228 |
| 14 | 7 | **System Improvements to Machine-Type Communications** |  | 530d? | 2010-06-10 A | 2012-06-20 | 22% | 411.5d? | 2010-06-10 | 2012-06-20 | 530d? | 122d |  | S1,S2,S3 | 44168h | 8285.2h | SIMTC | Rel-11 | Alain | PCG-25 | KPN | toon.norp@tno.nl | SP-48 |  |
| 15 | 7.1 | Stage 1 for System Improvements to Machine-Type Communications |  | 335d? | 2010-06-10 A | 2011-09-21 | 30% | 234.5d? | 2010-06-10 | 2011-09-21 | 335d? | 317d | finish no earlier than 2011-09-21 | S1 | 2680h | 804h | SIMTC | Rel-11 | Alain | PCG-25 | KPN | toon.norp@tno.nl | SP-48 | 22.368 |
| 16 | 7.2 | TR on Stage 2 for System Improvements to Machine-Type Communications |  | 461d? | 2010-06-10 A | 2012-03-15 | 15% | 391.85d? | 2010-06-10 | 2012-03-15 | 461d? | 191d | finish no earlier than 2012-03-15 | S2 | 3688h | 553.2h | SIMTC | Rel-11 | Maurice | PCG-25 | Intel | puneet.jain@intel.com | SP-48 | new TR 23.888 |
| 17 | 7.3 | TR on Security aspects of System Improvements to Machine-Type Communications |  | 455d? | 2010-09-23 A | 2012-06-20 | 50% | 227.5d? | 2010-09-23 | 2012-06-20 | 455d? | 122d | finish no earlier than 2012-06-20 | S3 | 3640h | 1820h | SIMTC | Rel-11 | Dionisio | PCG-25 | Samsung | Rajavelsamy R (rajvel@samsung.com) | SP-49 | new TR 33.868 |
| 18 | 7.4 | **Building Block 1: Reachability Aspects** |  | 206d? | 2011-06-08 | 2012-03-21 |  |  | 2011-06-08 | 2012-03-21 | 206d? | 187d |  | S2,S3 | 9888h |  | SIMTC-Reach | Rel-11 | Maurice | PCG-27 | Intel | puneet.jain@intel.com | SP-52 | TBD |
| 19 | 7.4.1 | MTC Feature Control (described in TS 22.368, clause 7.1.1 and 23.888, clause 5.7) |  | 206d? | 2011-06-08 | 2012-03-21 |  |  | 2011-06-08 | 2012-03-21 | 206d? | 187d | finish no earlier than 2012-03-21 | S2 | 1648h |  | SIMTC-Reach | Rel-11 | Maurice | PCG-27 | Intel | puneet.jain@intel.com | SP-52 | TBD |
| 20 | 7.4.2 | Device Triggering (TS 22.368, 7.1.2) |  | 206d? | 2011-06-08 | 2012-03-21 |  |  | 2011-06-08 | 2012-03-21 | 206d? | 187d | finish no earlier than 2012-03-21 | S2 | 1648h |  | SIMTC-Reach | Rel-11 | Maurice | PCG-27 | Intel | puneet.jain@intel.com | SP-52 | TBD |
| 21 | 7.4.3 | Addressing (TS 22.368, 7.1.3) |  | 206d? | 2011-06-08 | 2012-03-21 |  |  | 2011-06-08 | 2012-03-21 | 206d? | 187d | finish no earlier than 2012-03-21 | S2 | 1648h |  | SIMTC-Reach | Rel-11 | Maurice | PCG-27 | Intel | puneet.jain@intel.com | SP-52 | TBD |
| 22 | 7.4.4 | Identifiers – especially removal of MSISDN dependencies in the architecture (TS 22.368, 7.1.4); |  | 206d? | 2011-06-08 | 2012-03-21 |  |  | 2011-06-08 | 2012-03-21 | 206d? | 187d | finish no earlier than 2012-03-21 | S2 | 1648h |  | SIMTC-Reach | Rel-11 | Maurice | PCG-27 | Intel | puneet.jain@intel.com | SP-52 | TBD |
| 23 | 7.4.5 | PS Only support (TS 22.368, 7.2.4) |  | 206d? | 2011-06-08 | 2012-03-21 |  |  | 2011-06-08 | 2012-03-21 | 206d? | 187d | finish no earlier than 2012-03-21 | S2 | 1648h |  | SIMTC-Reach | Rel-11 | Maurice | PCG-27 | Intel | puneet.jain@intel.com | SP-52 | TBD |
| 24 | 7.5 | **Building Block 2: Signalling Optimizations** |  | 206d? | 2011-06-08 | 2012-03-21 |  |  | 2011-06-08 | 2012-03-21 | 206d? | 187d |  | S2,S3 | 4944h |  | SIMTC-Sig | Rel-11 | Maurice | PCG-27 | Intel | puneet.jain@intel.com | SP-52 | TBD |
| 25 | 7.5.1 | Effectively maintain connectivity for a large number of MTC Devices (TS 22.368, 7.1.1) |  | 206d? | 2011-06-08 | 2012-03-21 |  |  | 2011-06-08 | 2012-03-21 | 206d? | 187d | finish no earlier than 2012-03-21 | S2 | 1648h |  | SIMTC-Sig | Rel-11 | Maurice | PCG-27 | Intel | puneet.jain@intel.com | SP-52 | TBD |
| 26 | 7.5.2 | Small Data Transmissions (TS 22.368, 7.2.5) |  | 206d? | 2011-06-08 | 2012-03-21 |  |  | 2011-06-08 | 2012-03-21 | 206d? | 187d | finish no earlier than 2012-03-21 | S2 | 1648h |  | SIMTC-Sig | Rel-11 | Maurice | PCG-27 | Intel | puneet.jain@intel.com | SP-52 | TBD |

Notes:
- 1: -
- 2: -
- 3: -
- 4: GP#50 completion 05/11=>09/11. GP#49 exception in GP-110506
- 5: GP#49 completion 03/11=>09/11. No exception sheet
- 6: RP#52 TDD completed. FDD extension 06/11=>09/11. Exception sheet in RP-110906
- 7: RP#52 completion 06/11=>09/11. Exception sheet in RP-110755
- 8: SP#52 completion 06/11=>09/11. Exception sheet in SP-110278
- 9: -
- 10: -
- 11: SP#50 updated WID SP-100227=>SP-100876 (added Stage 2). Triggered by Rel-10 TR 22.893 UID_380083 Study on advanced requirements for IP interconnect (FS_IPXS)
- 12: SP#50 updated WID SP-100227=>SP-100876. Completion 12/10=>09/11
- 13: SP#50 updated WID SP-100227=>SP-100876 (added Stage 2)
- 14: SP#52 updated WID SP-100877=>SP-110422 (break-down in several BBs). Enhancements to Rel-10 Feature UID_410031 (Network Improvements for Machine Type Communications) based on Rel-11 Study on enhancements to MTC
- 15: -
- 16: SP#52 updated WID SP-100877=>SP-110422 (break-down in several BBs)
- 17: SP#52 updated WID SP-100877=>SP-110422 (break-down in several BBs)
- 18: SP#52 updated WID SP-100877=>SP-110422 (break-down in several BBs)
- 19: -
- 20: -
- 21: -
- 22: -
- 23: -
- 24: SP#52 updated WID SP-100877=>SP-110422 (break-down in several BBs)
- 25: -
- 26: -

| ID | WBS | Task | Type | Duration | Start | Finish | Complete | Remaining | Baseline start | Baseline finish | Baseline duration | Total slack | Constraint | Resources | Work | Actual work | Text1 | Text2 | Text4 | Text6 | Text7 | Text8 | Text9 | Text12 |
| --- | --- | --- | --- | --- | --- | --- | --- | --- | --- | --- | --- | --- | --- | --- | --- | --- | --- | --- | --- | --- | --- | --- | --- | --- |
| 27 | 7.6 | **Building Block 3: CN-based requirements and Power Considerations** |  | 206d? | 2011-06-08 | 2012-03-21 |  |  | 2011-06-08 | 2012-03-21 | 206d? | 187d |  | S2,S3 | 6592h |  | SIMTC-CN_Pow | PCG-27 | Intel | Rel-11 | SP-52 | Maurice |  |  |
| 28 | 7.6.1 | Charging Requirements (TS 22.368, 7.1.5) |  | 206d? | 2011-06-08 | 2012-03-21 |  |  | 2011-06-08 | 2012-03-21 | 206d? | 187d | finish no earlier than 2012-03-21 | S2 | 1648h |  | SIMTC-CN_Pow | PCG-27 | Intel | Rel-11 | SP-52 | Maurice |  |  |
| 29 | 7.6.2 | Lower Power Consumption (TS 22.368, 7.1.1) |  | 206d? | 2011-06-08 | 2012-03-21 |  |  | 2011-06-08 | 2012-03-21 | 206d? | 187d | finish no earlier than 2012-03-21 | S2 | 1648h |  | SIMTC-CN_Pow | PCG-27 | Intel | Rel-11 | SP-52 | Maurice |  |  |
| 30 | 7.6.3 | MTC Monitoring (TS 22.368, 7.2.8) |  | 206d? | 2011-06-08 | 2012-03-21 |  |  | 2011-06-08 | 2012-03-21 | 206d? | 187d | finish no earlier than 2012-03-21 | S2 | 1648h |  | SIMTC-CN_Pow | PCG-27 | Intel | Rel-11 | SP-52 | Maurice |  |  |
| 31 | 7.7 | **Building Block 4: Secure Connection** |  | 271d? | 2011-06-08 | 2012-06-20 |  |  | 2011-06-08 | 2012-06-20 | 271d? | 122d |  | S3 | 4336h |  | SIMTC-Sec | PCG-27 | Samsung | Rel-11 | SP-52 | Dionisio |  |  |
| 32 | 7.7.1 | Secure Connection MTC Feature (TS 22.368, 7.2.10) |  | 271d? | 2011-06-08 | 2012-06-20 |  |  | 2011-06-08 | 2012-06-20 | 271d? | 122d | finish no earlier than 2012-06-20 | S3 | 2168h |  | SIMTC-Sec | PCG-27 | Samsung | Rel-11 | SP-52 | Dionisio |  |  |
| 33 | 7.8 | Deleted - Stage 2 on SA2 part for System Improvements to Machine-Type Communications |  | 260d? | 2010-06-10 A | 2011-06-08 A | 100% |  | 2010-06-10 | 2011-06-08 | 260d? |  | finish no earlier than 2011-06-08 | S2 | 2080h | 2080h | SIMTC | PCG-25 | Intel | Rel-11 | SP-48 | Maurice | PCG-27 | SP-52 |
| 34 | 7.9 | Deleted - Stage 2 on Security part for System Improvements to Machine-Type Communications |  | 260d? | 2010-06-10 A | 2011-06-08 A | 100% |  | 2010-06-10 | 2011-06-08 | 260d? |  | finish no earlier than 2011-06-08 | S3 | 2080h | 2080h | SIMTC | PCG-25 | Samsung | Rel-11 | SP-48 | Dionisio | PCG-27 | SP-52 |
| 35 | 8 | **Unstructured Supplementary Service Data (USSD) simulation service in IMS** |  | 391d? | 2010-06-10 A | 2011-12-08 |  | 391d? | 2010-06-10 | 2011-12-08 | 391d? | 261d |  | S1,C1,C3 | 6368h |  | USSI | PCG-25 | Deutsche Telekom | Rel-11 | SP-48 | Alain |  |  |
| 36 | 8.1 | Stage 1 for USSD simulation service in IMS | milestone | 0d? | 2010-06-10 A | 2010-06-10 A | 100% |  | 2010-06-10 | 2010-06-10 | 0d? |  | finish no earlier than 2010-06-10 | S1 |  |  | USSI | PCG-25 | Deutsche Telekom | Rel-11 | SP-48 | Alain |  |  |
| 37 | 8.2 | **Stage 3 for USSD simulation service in IMS** |  | 135d? | 2011-06-03 | 2011-12-08 |  |  | 2011-06-03 | 2011-12-08 | 135d? | 261d |  | C1,C3 | 3240h |  | USSI | PCG-27 | Deutsche Telekom | Rel-11 | CP-52 | Frederic |  |  |
| 38 | 8.2.1 | CT1 part of Stage 3 for USSD simulation service in IMS |  | 135d? | 2011-06-03 | 2011-12-08 |  |  | 2011-06-03 | 2011-12-08 | 135d? | 261d | start no earlier than 2011-06-03 | C1 | 1080h |  | USSI | PCG-27 | Deutsche Telekom, Huawei TS 24.390 Rapp | Rel-11 | CP-52 | Frederic |  |  |
| 39 | 8.2.2 | CT3 part of Stage 3 for USSD simulation service in IMS |  | 135d? | 2011-06-03 | 2011-12-08 |  |  | 2011-06-03 | 2011-12-08 | 135d? | 261d | start no earlier than 2011-06-03 | C3 | 1080h |  | USSI | PCG-27 | Deutsche Telekom | Rel-11 | CP-52 | Jiwan |  |  |
| 40 | 9 | **SIPTO Service Continuity of IP Data Session** |  | 260d? | 2010-09-23 A | 2011-09-21 | 97% | 7.79d? | 2010-09-23 | 2011-09-21 | 260d? | 317d |  | S1 | 4160h | 4035.26h | SIPTO_SC | PCG-25 | Vodafone | Rel-11 | SP-49 | Alain |  |  |
| 41 | 9.1 | Stage 1 for SIPTO Service Continuity of IP Data Session |  | 260d? | 2010-09-23 A | 2011-09-21 | 97% | 7.8d? | 2010-09-23 | 2011-09-21 | 260d? | 317d | finish no earlier than 2011-09-21 | S1 | 2080h | 2017.6h | SIPTO_SC | PCG-25 | Vodafone | Rel-11 | SP-49 | Alain |  |  |
| 42 | 10 | **QoS Control Based on Subscriber Spending Limits** |  | 390d? | 2010-09-23 A | 2012-03-21 | 47% | 208.38d? | 2010-09-23 | 2012-03-21 | 390d? | 187d |  | S1,S2,S5,C3 | 11024h | 4424.8h | QoS_SSL | PCG-25 | Vodafone | Rel-11 | SP-49 | Alain |  |  |
| 43 | 10.1 | Stage 1 for QoS Control Based on Subscriber Spending Limits |  | 260d? | 2010-09-23 A | 2011-09-21 | 97% | 7.8d? | 2010-09-23 | 2011-09-21 | 260d? | 317d | finish no earlier than 2011-09-21 | S1 | 2080h | 2017.6h | QoS_SSL | PCG-25 | Vodafone | Rel-11 | SP-49 | Alain |  |  |
| 44 | 10.2 | Stage 2 for QoS Control Based on Subscriber Spending Limits |  | 192d? | 2011-03-23 A | 2011-12-15 | 75% | 48d? | 2011-03-23 | 2011-12-15 | 192d? | 256d | finish no earlier than 2011-12-15 | S2 | 1536h | 1152h | QoS_SSL | PCG-26 | Huawei | Rel-11 | SP-51 | Maurice |  |  |
| 45 | 10.3 | Charging for QoS Control Based on Subscriber Spending Limits |  | 330d? | 2010-12-16 A | 2012-03-21 | 10% | 297d? | 2010-12-16 | 2012-03-21 | 330d? | 187d | finish no earlier than 2012-03-21 | S5 | 2640h | 264h | QoS_SSL | PCG-26 | Nokia Siemens Networks, Huawei | Rel-11 | SP-50 | Dionisio |  |  |
| 46 | 10.4 | CT3 aspects of QoS Control Based on Subscriber Spending Limits |  | 206d? | 2011-06-03 A | 2012-03-16 | 15% | 175.1d? | 2011-06-03 | 2012-03-16 | 206d? | 190d | finish no earlier than 2012-03-16 | C3 | 1648h | 247.2h | QoS_SSL-CT3 | PCG-27 | Huawei | Rel-11 | CP-52 | Jiwan |  |  |
| 47 | 11 | **Optimized Service Charging and Allocation of Resources in IMS whilst Roaming** |  | 321d? | 2010-09-23 A | 2011-12-15 | 55% | 145.57d? | 2010-09-23 | 2011-12-15 | 321d? | 256d |  | S1,S2 | 9784h | 5347.03h | OSCAR | PCG-25 | Vodafone | Rel-11 | SP-49 | Alain |  |  |
| 48 | 11.1 | TR on Stage 2 aspects of Optimized Service Charging and Allocation of Resources in IMS whilst Roaming |  | 321d? | 2010-09-23 A | 2011-12-15 | 75% | 80.25d? | 2010-09-23 | 2011-12-15 | 321d? | 256d | finish no earlier than 2011-12-15 | S2 | 2568h | 1926h | OSCAR | PCG-25 | Vodafone | Rel-11 | SP-49 | Maurice |  |  |
| 49 | 11.2 | Stage 1 for Optimized Service Charging and Allocation of Resources in IMS whilst Roaming |  | 260d? | 2010-09-23 A | 2011-09-21 | 97% | 7.8d? | 2010-09-23 | 2011-09-21 | 260d? | 317d | finish no earlier than 2011-09-21 | S1 | 2080h | 2017.6h | OSCAR | PCG-25 | Vodafone | Rel-11 | SP-49 | Alain |  |  |
| 50 | 11.3 | Stage 2 for Optimized Service Charging and Allocation of Resources in IMS whilst Roaming |  | 321d? | 2010-09-23 | 2011-12-15 |  |  | 2010-09-23 | 2011-12-15 | 321d? | 256d | finish no earlier than 2011-12-15 | S2 | 2568h |  | OSCAR | PCG-25 | Vodafone | Rel-11 | SP-49 | Maurice |  |  |

Notes:
- 27: SP#52 updated WID SP-100877=>SP-110422 (break-down in several BBs) / Text3: TBD / Text5: puneet.jain@intel.com
- 28: - / Text3: TBD / Text5: puneet.jain@intel.com
- 29: - / Text3: TBD / Text5: puneet.jain@intel.com
- 30: - / Text3: TBD / Text5: puneet.jain@intel.com
- 31: SP#52 updated WID SP-100877=>SP-110422 (break-down in several BBs) / Text3: TBD / Text5: Rajavelsamy R (rajvel@samsung.com)
- 32: - / Text3: TBD / Text5: Rajavelsamy R (rajvel@samsung.com)
- 33: SP#52 stopped. Updated WID SP-100877=>SP-110422 (break-down in several BBs) / Text3: Depends on the outcome of the Stage 2 TR / Text5: puneet.jain@intel.com
- 34: SP#52 stopped. Updated WID SP-100877=>SP-110422 (break-down in several BBs) / Text3: TBD / Text5: Rajavelsamy R (rajvel@samsung.com)
- 35: SP#48 approved WID & Stage 1 completed. Specify a "CS domain USSD" like service over IMS (see GSM Mobile User Initiated USSD) / Text5: kurt.bischinger@t-mobile.at
- 36: SP#48 completed / Text3: 22.173 / Text5: kurt.bischinger@t-mobile.at
- 37: No stage 2 impact, as reuse existing IMS architecture in TS 23.228 / Text5: reinhard.lauster@t-mobile.at
- 38: No stage 2 impact, as reuse existing IMS architecture in TS 23.228 / Text3: 24.173, 24.229, new TS 24.390 / Text5: reinhard.lauster@t-mobile.at, TS 24.390 Rapp: lili.yang@huawei.com
- 39: No stage 2 impact, as reuse existing IMS architecture in TS 23.228 / Text3: 29.165 / Text5: reinhard.lauster@t-mobile.at
- 40: Linked to Rel-10 Local IP Access and Selected Internet IP Traffic Offload (LIPA_SIPTO) / Text3: Stage 1 / Text5: mona.mustapha@vodafone.com
- 41: SP#50 completion 12/10=>09/11 / Text3: 22.101, 22.220 / Text5: mona.mustapha@vodafone.com
- 42: SP#51 updated WID SP-100773=>SP-110086 (added SA2 part) / Text5: mona.mustapha@vodafone.com
- 43: SP#51 updated WID SP-100773=>SP-110086. Use cases & service requirements to allow: 1) modification of QoS based on subscribers spending limits 2) enforcing of spending limits for roaming subscribers without having dedicated support in the visited network / Text3: 22.115 / Text5: mona.mustapha@vodafone.com
- 44: SP#51 updated WID SP-100773=>SP-110086 (added SA2 part) / Text3: 23.203 / Text5: Xu Xia (xiatony@huawei.com)
- 45: SP#51 updated WID SP-100773=>SP-110086 (added SA2 part). Stage 3: Linked to CT3 TS 29.079 OMR within the IMS; Stage 3 (UID_480110) / Text3: Stage 2 (32.240, 32.296), Stage 3 (new TS 32.294) / Text5: Gerald.Goermer@nsn.com, shan.mingjun@huawei.com
- 46: Stage 3 (coordinate with SA5 which defines the Sy protocol) / Text3: 29.212, 29.213, 29.214, 29.215, new TS 29.219 Policy and Charging Control over Sy reference point / Text5: QiaoWeihua@huawei.com
- 47: SP#52 updated WID SP-100701=>SP-110347. Triggered by S1-102236/GSMA RILTE 10_007r1 (IREG LS_038 to 3GPP on Optimal Media Routing drawbacks) / Text5: mona.mustapha@vodafone.com
- 48: SP#52 updated WID SP-100701=>SP-110347 / Text3: new TR 23.849 / Text5: Susana.Sabater@vodafone.com
- 49: SP#52 updated WID SP-100701=>SP-110347 / Text3: 22.115, 22.173 / Text5: mona.mustapha@vodafone.com
- 50: SP#52 updated WID SP-100701=>SP-110347 / Text3: TBD / Text5: Susana.Sabater@vodafone.com

| ID | WBS | Task | Duration | Start | Finish | Complete | Remaining | Baseline start | Baseline finish | Baseline duration | Total slack | Constraint | Resources | Work | Actual work | Text1 | Text2 | Text4 | Text5 | Text6 | Text7 | Text8 |
| --- | --- | --- | --- | --- | --- | --- | --- | --- | --- | --- | --- | --- | --- | --- | --- | --- | --- | --- | --- | --- | --- | --- |
| 51 | 12 | **Non Voice Emergency Services** | 200d? | 2010-12-16 A | 2011-09-21 | 50% | 100d? | 2010-12-16 | 2011-09-21 | 200d? | 317d |  | S1 | 3200h | 1600h | NOVES | PCG-26 | Qualcomm | dwilliams@qualcomm.com | Rel-11 | SP-50 | Alain |
| 52 | 12.1 | Stage 1 for NOVES | 200d? | 2010-12-16 A | 2011-09-21 | 50% | 100d? | 2010-12-16 | 2011-09-21 | 200d? | 317d | finish no earlier than 2011-09-21 | S1 | 1600h | 800h | NOVES | PCG-26 | Qualcomm | dwilliams@qualcomm.com | Rel-11 | SP-50 | Alain |
| 53 | 13 | **Interworking between Mobile Operators using the Evolved Packet System and Data Application Providers** | 327d? | 2010-12-16 A | 2012-03-16 | 35% | 212.58d? | 2010-12-16 | 2012-03-16 | 327d? | 190d |  | S1,S2 | 6960h | 2435.36h | MOSAP | PCG-26 | Cisco | Vojislav Vucetic (vvucetic@cisco.com) | Rel-11 | SP-50 | Alain |
| 54 | 13.1 | Stage 1 for MOSAP | 200d? | 2010-12-16 A | 2011-09-21 | 95% | 10d? | 2010-12-16 | 2011-09-21 | 200d? | 317d | finish no earlier than 2011-09-21 | S1 | 1600h | 1520h | MOSAP | PCG-26 | Cisco | Vojislav Vucetic (vvucetic@cisco.com) | Rel-11 | SP-50 | Alain |
| 55 | 13.2 | TR on Stage 2 for MOSAP | 138d? | 2011-06-06 | 2011-12-14 |  |  | 2011-06-06 | 2011-12-14 | 138d? | 257d | finish no earlier than 2011-12-14 | S2 | 1104h |  | MOSAP | PCG-27 | Intel | vivek.g.gupta@intel.com | Rel-11 | SP-52 | Maurice |
| 56 | 13.3 | Stage 2 for MOSAP | 205d? | 2011-06-06 | 2012-03-16 |  |  | 2011-06-06 | 2012-03-16 | 205d? | 190d | finish no earlier than 2012-03-16 | S2 | 1640h |  | MOSAP | PCG-27 | Intel | vivek.g.gupta@intel.com | Rel-11 | SP-52 | Maurice |
| 57 | 14 | **Support for 3GPP Voice Interworking with Enterprise IP-PBX** | 131d? | 2011-03-23 A | 2011-09-21 | 60% | 52.4d? | 2011-03-23 | 2011-09-21 | 131d? | 317d |  | S1 | 2096h | 1257.57h | VINE | PCG-26 | Tatara Systems | Phillip Brown (pbrown@tatarasystems.com) | Rel-11 | SP-51 | Alain |
| 58 | 14.1 | Stage 1 for Support for 3GPP Voice Interworking with Enterprise IP-PBX | 131d? | 2011-03-23 A | 2011-09-21 | 60% | 52.4d? | 2011-03-23 | 2011-09-21 | 131d? | 317d | finish no earlier than 2011-09-21 | S1 | 1048h | 628.8h | VINE | PCG-26 | Tatara Systems | Phillip Brown (pbrown@tatarasystems.com) | Rel-11 | SP-51 | Alain |
| 59 | 15 | **IMS Network-Independent Public User Identities** | 76d? | 2011-06-08 A | 2011-09-21 | 80% | 15.19d? | 2011-06-08 | 2011-09-21 | 76d? | 317d |  | S1 | 1216h | 972.87h | INIPUI | PCG-27 | Vodafone | mona.mustapha@vodafone.com | Rel-11 | SP-52 | Alain |
| 60 | 15.1 | Stage 1 for IMS Network-Independent Public User Identities | 76d? | 2011-06-08 A | 2011-09-21 | 80% | 15.2d? | 2011-06-08 | 2011-09-21 | 76d? | 317d | start no earlier than 2011-06-08 | S1 | 608h | 486.4h | INIPUI | PCG-27 | Vodafone | mona.mustapha@vodafone.com | Rel-11 | SP-52 | Alain |
| 61 | 16 | **Anonymous Call Rejection in the CS domain** | 2d? | 2011-06-07 A | 2011-06-08 A | 100% |  | 2011-06-07 | 2011-06-08 | 2d? |  |  | S1 | 32h | 32h | ACR_CS | PCG-27 | Alcatel-Lucent | Betsy.Covell@alcatel-lucent.com | Rel-11 | SP-52 | Alain |
| 62 | 16.1 | Stage 1 for Anonymous Call Rejection in the CS domain | 2d? | 2011-06-07 A | 2011-06-08 A | 100% |  | 2011-06-07 | 2011-06-08 | 2d? |  | finish no earlier than 2011-06-07 | S1 | 16h | 16h | ACR_CS | PCG-27 | Alcatel-Lucent | Betsy.Covell@alcatel-lucent.com | Rel-11 | SP-52 | Alain |
| 63 | 17 | **Support BroadBand forum Accesses Interworking** | 595d? | 2009-12-10 A | 2012-03-21 | 46% | 319.57d? | 2009-12-10 | 2012-03-21 | 595d? | 187d |  | S2,S1 | 22472h | 10402.7h | BBAI | PCG-24 | Ericsson, Huawei | peter.bleckert@ericsson.com | Rel-11 | SP-46 | Alain |
| 64 | 17.1 | TR on Stage 2 for BBAI | 449d? | 2010-03-26 A | 2011-12-14 | 60% | 179.6d? | 2010-03-26 | 2011-12-14 | 449d? | 257d | finish no earlier than 2011-12-14 | S2 | 3592h | 2155.2h | BBAI | PCG-24 | Ericsson | stefan.rommer@ericsson.com | Rel-11 | SP-47 | Maurice |
| 65 | 17.2 | Stage 1 BB I for BBAI | 76d? | 2009-12-10 A | 2010-03-25 A | 100% |  | 2009-12-10 | 2010-03-25 | 76d? |  | start no earlier than 2009-12-10 | S1 | 608h | 608h | BBAI | PCG-24 | Ericsson | peter.bleckert@ericsson.com | Rel-11 | SP-46 | Alain |
| 66 | 17.3 | Stage 2 BB I for BBAI | 389d? | 2010-03-26 A | 2011-09-21 | 40% | 233.4d? | 2010-03-26 | 2011-09-21 | 389d? | 317d | finish no earlier than 2011-09-21 | S2 | 3112h | 1244.8h | BBAI | PCG-24 | Ericsson | stefan.rommer@ericsson.com | Rel-11 | SP-47 | Maurice |
| 67 | 17.4 | Stage 1 BB II for BBAI | 260d? | 2010-09-23 A | 2011-09-21 | 97% | 7.8d? | 2010-09-23 | 2011-09-21 | 260d? | 317d | finish no earlier than 2011-09-21 | S1 | 2080h | 2017.6h | BBAI | PCG-25 | Ericsson | peter.bleckert@ericsson.com | Rel-11 | SP-49 | Alain |
| 68 | 17.5 | Stage 2 BB II for BBAI | 390d? | 2010-09-23 A | 2012-03-21 | 5% | 370.5d? | 2010-09-23 | 2012-03-21 | 390d? | 187d | finish no earlier than 2012-03-21 | S2 | 3120h | 156h | BBAI | PCG-24 | Ericsson | stefan.rommer@ericsson.com | Rel-11 | SP-47 | Maurice |
| 69 | 17.6 | Stage 1 BB III for BBAI | 260d? | 2010-09-23 A | 2011-09-21 | 97% | 7.8d? | 2010-09-23 | 2011-09-21 | 260d? | 317d | finish no earlier than 2011-09-21 | S1 | 2080h | 2017.6h | BBAI | PCG-25 | Huawei | Amar Deol (adeol@huawei.com) | Rel-11 | SP-49 | Alain |
| 70 | 17.7 | Stage 2 BB III for BBAI | 390d? | 2010-09-23 | 2012-03-21 |  |  | 2010-09-23 | 2012-03-21 | 390d? | 187d | finish no earlier than 2012-03-21 | S2 | 3120h |  | BBAI | PCG-24 | Huawei | marco.spini@huawei.com | Rel-11 | SP-47 | Maurice |
| 71 | 18 | **SRVCC aspect of enhancements for Multimedia Priority Service** | 395d? | 2010-06-10 A | 2011-12-14 | 40% | 238.21d? | 2010-06-10 | 2011-12-14 | 395d? | 257d |  | S2 | 8400h | 3334.35h | eMPS_SRVCC | PCG-25 | NTT DoCoMo | Atsushi Minokuchi (minokuchi@nttdocomo.co.jp) | Rel-11 | SP-48 | Maurice |
| 72 | 18.1 | TR on SRVCC for eMPS | 260d? | 2010-06-10 A | 2011-06-08 A | 100% |  | 2010-06-10 | 2011-06-08 | 260d? |  | finish no earlier than 2011-06-08 | S2 | 2080h | 2080h | eMPS_SRVCC | PCG-25 | NTT DoCoMo | Atsushi Minokuchi (minokuchi@nttdocomo.co.jp) | Rel-11 | SP-48 | Maurice |
| 73 | 18.2 | Stage 2 on SRVCC for eMPS | 395d? | 2010-06-10 | 2011-12-14 |  |  | 2010-06-10 | 2011-12-14 | 395d? | 257d | finish no earlier than 2011-12-14 | S2 | 3160h |  | eMPS_SRVCC | PCG-25 | NTT DoCoMo | Atsushi Minokuchi (minokuchi@nttdocomo.co.jp) | Rel-11 | SP-48 | Maurice |
| 74 | 19 | **Single Radio Video Call Continuity for 3G-CS** | 300d? | 2010-10-15 A | 2011-12-08 | 31% | 206.47d? | 2010-10-15 | 2011-12-08 | 300d? | 261d |  | S2,C1,C3,C4 | 8302.8h | 1503.66h | vSRVCC | PCG-26 | Samsung | Haris Zisimopoulos (haris.z@samsung.com) | Rel-11 | SP-50 | Maurice |
| 75 | 19.1 | Stage 2 for Single Radio Video Call Continuity for 3G-CS | 197.85d? | 2010-10-15 A | 2011-09-21 | 95% | 9.89d? | 2010-10-15 | 2011-09-21 | 197.85d? | 317d | finish no earlier than 2011-09-21 | S2 | 1582.8h | 1503.66h | vSRVCC | PCG-26 | Samsung | Haris Zisimopoulos (haris.z@samsung.com) | Rel-11 | SP-50 | Maurice |

Notes:
- 51: Triggered by SA1 Rel-11 TR 22.871 Study on Non Voice Emergency Services (FS_NOVES) / Text3: Stage 1
- 52: - / Text3: 22.101
- 53: SP#52 updated WID SP-100891=>SP-110350 (Added SA2 part). Linked to Rel-10 Feature UID_500006 PEST
- 54: - / Text3: 22.278
- 55: SP#52 updated WID SP-100891=>SP-110350 / Text3: new TR 23.862 (EPC enhancements to support Interworking with data application providers)
- 56: SP#52 updated WID SP-100891=>SP-110350 / Text3: TBD
- 57: Triggered by Rel-11 TR 22.809 Study on Support for 3GPP Voice Interworking with Enterprise IP-PBX (FS_VINE) UID_480033 / Text3: Stage 1
- 58: - / Text3: 22.228
- 59: Triggered by Rel-11 TR 22.894 Study of IMS Network-Independent Public User Identities (FS_INIPUI) UID_490033. Charging aspects to be included / Text3: Stage 1
- 60: SP#52 approved WID and SP-110379 (22.115 CR#0058, 22.228 CR#0126) / Text3: 22.115, 22.228
- 61: SP#52 Stage 1 completed / Text3: Stage 1
- 62: SP#52 completed. Approved WID and CRs in SP-110376 (22.082 CR#0005, 22.085 CR#0004, 22.081 CR#0007, 22.088 CR#0003, 22.004 CR#0013) / Text3: 22.004, 22.081, 22.082, 22.085, 22.088
- 63: SP#52 updated WID SP-100881=>SP-110423. Triggered by BBF WT 203, WT-134 (interworking btw 3GPP EPS and BBF's fixed broadband accesses). Stage 2 will be based on 3GPP Stage 1
- 64: SP#52 TR 23.839 v100 for Information. TR structure to follow the structure of the Building Blocks. Once a BB is completed, TR to be sent for SA Information. When all the BBs are completed, TR to be sent for SA approval. / Text3: new TR 23.839
- 65: SP#47 completed. Provide service requirements for supporting interworking between 3GPP EPS and the fixed broadband accesses defined by BBF / Text3: 22.278 CR#0058
- 66: SP#52 updated WID SP-100881=>SP-110423. Completion 06/11=>09/11 / Text3: 23.203, 23.401, 23.402, new TS 23.139
- 67: SP#51 completion 03/11=>09/11 / Text3: 22.278
- 68: SP#52 updated WID SP-100881=>SP-110423. Completion 12/11=>03/12 / Text3: 23.203, 23.401, 23.402, 23.139
- 69: SP#51 completion 03/11=>09/11 / Text3: 22.278
- 70: SP#52 updated WID SP-100881=>SP-110423. Completion 12/11=>03/12 / Text3: 23.203, 23.401, 23.402, 23.139
- 71: SP#52 updated WID SP-100359=>SP-110346. Analyze and if needed specify mechanisms for the priority handling of SRVCC with regard to LTE/EPC / Text3: Stage 2
- 72: SP#52 completed. TR 23.854 v200 for Approval / Text3: new TR 23.854
- 73: SP#51 completion 03/11=>12/11 / Text3: 23.216, 23.237
- 74: Complete Stage 2 to support Single Radio VIDEO Call Continuity from E-UTRAN to UTRAN-CS based on the agreed architecture alternative in TR 23.886
- 75: SP#52 completion 06/11=>09/11. Triggered by Feasibility Study on video call handover capability in TR 23.886 UID_470048 Study on Single Radio Video Call Continuity for 3G-CS (FS_vSRVCC) / Text3: 23.203, 23.216, 23.237

| ID | WBS | Task | Duration | Start | Finish | Complete | Remaining | Baseline start | Baseline finish | Baseline duration | Total slack | Constraint | Resources | Work | Actual work | Text1 | Text2 | Text4 | Text5 | Text6 | Text7 | Text8 | Text3 |
| --- | --- | --- | --- | --- | --- | --- | --- | --- | --- | --- | --- | --- | --- | --- | --- | --- | --- | --- | --- | --- | --- | --- | --- |
| 76 | 19.2 | **CN aspects of Single Radio Video Call Continuity for 3G-CS** | 135d? | 2011-06-03 | 2011-12-08 |  |  | 2011-06-03 | 2011-12-08 | 135d? | 261d |  | C1,C3,C4 | 4320h |  | vSRVCC-CT | PCG-27 | NEC | gottfried.punz@neclab.eu | Rel-11 | CP-52 | Frederic |  |
| 77 | 19.2.1 | CT1 aspects of Single Radio Video Call Continuity for 3G-CS | 135d? | 2011-06-03 | 2011-12-08 |  |  | 2011-06-03 | 2011-12-08 | 135d? | 261d | start no earlier than 2011-06-03 | C1 | 1080h |  | vSRVCC-CT | PCG-27 | NEC | gottfried.punz@neclab.eu | Rel-11 | CP-52 | Frederic | 24.008, 24.237, 24.301 |
| 78 | 19.2.2 | CT3 aspects of Single Radio Video Call Continuity for 3G-CS | 135d? | 2011-06-03 | 2011-12-08 |  |  | 2011-06-03 | 2011-12-08 | 135d? | 261d | start no earlier than 2011-06-03 | C3 | 1080h |  | vSRVCC-CT | PCG-27 | NEC | gottfried.punz@neclab.eu | Rel-11 | CP-52 | Jiwan | 29.211, 29.212 |
| 79 | 19.2.3 | CT4 aspects of Single Radio Video Call Continuity for 3G-CS | 135d? | 2011-06-03 | 2011-12-08 |  |  | 2011-06-03 | 2011-12-08 | 135d? | 261d | start no earlier than 2011-06-03 | C4 | 1080h |  | vSRVCC-CT | PCG-27 | NEC | gottfried.punz@neclab.eu | Rel-11 | CP-52 | Kimmo | 29.280 |
| 80 | 20 | **Network Provided Location Information for IMS** | 465d? | 2010-06-10 A | 2012-03-21 | 31% | 318.75d? | 2010-06-10 | 2012-03-21 | 465d? | 187d |  | S2,S1,S5 | 14288h | 4493.73h | NWK-PL2IMS | PCG-25 | T-Mobile | michele.zarri@t-mobile.co.uk | Rel-11 | SP-48 | Maurice |  |
| 81 | 20.1 | Stage 1 for Network Provided Location Information for IMS | 201d? | 2010-12-15 A | 2011-09-21 | 97% | 6.03d? | 2010-12-15 | 2011-09-21 | 201d? | 317d | finish no earlier than 2011-09-21 | S1 | 1608h | 1559.76h | NWK-PL2IMS | PCG-26 | n/a | n/a | Rel-11 | SP-50 | Alain | 22.115 |
| 82 | 20.2 | TR on Stage 2 for network provided location information to the IMS | 335d? | 2010-06-10 A | 2011-09-21 | 60% | 134d? | 2010-06-10 | 2011-09-21 | 335d? | 317d | finish no earlier than 2011-09-21 | S2 | 2680h | 1608h | NWK-PL2IMS | PCG-25 | T-Mobile | michele.zarri@t-mobile.co.uk | Rel-11 | SP-48 | Maurice | new TR 23.8bc |
| 83 | 20.3 | Stage 2 for Network Provided Location Information for IMS | 395d? | 2010-06-10 | 2011-12-14 |  |  | 2010-06-10 | 2011-12-14 | 395d? | 257d | finish no earlier than 2011-12-14 | S2 | 3160h |  | NWK-PL2IMS | PCG-25 | T-Mobile | michele.zarri@t-mobile.co.uk | Rel-11 | SP-48 | Maurice | 23.060, 23.203, 23.228, 23.401 |
| 84 | 20.4 | Network Provided Location Information for IMS Charging | 390d? | 2010-09-23 A | 2012-03-21 | 5% | 370.5d? | 2010-09-23 | 2012-03-21 | 390d? | 187d | finish no earlier than 2012-03-21 | S5 | 3120h | 156h | NWK-PL2IMS_CH | PCG-25 | Nokia Siemens Networks | Gerald.Goermer@nsn.com | Rel-11 | SP-49 | Dionisio | Stage 2 (32.240, 32.260), Stage 3 (32.298, 32.299) |
| 85 | 21 | **LIPA Mobility and SIPTO at the Local Network** | 305d? | 2010-10-15 A | 2011-12-15 | 35% | 198.26d? | 2010-10-15 | 2011-12-15 | 305d? | 256d |  | S2 | 4510.8h | 1578.7h | LIMONET | PCG-26 | Huawei | Patrice Hédé (patrice.hede@huawei.com) | Rel-11 | SP-50 | Maurice | Stage 2 |
| 86 | 21.1 | Stage 2 for LIPA Mobility and SIPTO at the Local Network | 258.85d? | 2010-10-15 A | 2011-12-15 | 35% | 168.25d? | 2010-10-15 | 2011-12-15 | 258.85d? | 256d | finish no earlier than 2011-12-15 | S2 | 2070.8h | 724.78h | LIMONET | PCG-26 | Huawei | Patrice Hédé (patrice.hede@huawei.com) | Rel-11 | SP-50 | Maurice | 23.060, 23.401, new TR 23.859 |
| 87 | 22 | **Service Awareness and Privacy Policies** | 303.15d? | 2010-10-12 A | 2011-12-09 | 73% | 82.85d? | 2010-10-12 | 2011-12-09 | 303.15d? | 260d |  | S2,S1,C3 | 5536h | 2528.8h | SAPP | PCG-26 | Allot Communications | Alla Goldner (agoldner@llot.com) | Rel-11 | SP-50 | Maurice |  |
| 88 | 22.1 | Stage 1 for Service Awareness and Privacy Policies | 46.15d? | 2010-10-12 A | 2010-12-15 A | 100% |  | 2010-10-12 | 2010-12-15 | 46.15d? |  | finish no earlier than 2010-12-15 | S1 | 369.2h | 369.2h | SAPP | PCG-26 | Allot Communications | Alla Goldner (agoldner@llot.com) | Rel-11 | SP-50 | Maurice |  |
| 89 | 22.2 | Stage 2 for Service Awareness and Privacy Policies | 197.85d? | 2010-10-15 A | 2011-09-21 | 93% | 13.85d? | 2010-10-15 | 2011-09-21 | 197.85d? | 317d | finish no earlier than 2011-09-21 | S2 | 1582.8h | 1472h | SAPP | PCG-26 | Allot Communications | Alla Goldner (agoldner@llot.com) | Rel-11 | SP-50 | Maurice | 23.203 |
| 90 | 22.3 | CT3 part of Service Awareness and Privacy Policies | 191d? | 2011-03-18 A | 2011-12-09 | 45% | 105.05d? | 2011-03-18 | 2011-12-09 | 191d? | 260d | finish no earlier than 2011-12-09 | C3 | 1528h | 687.6h | SAPP-CT3 | PCG-26 | Allot Communications | Alla Goldner (agoldner@llot.com) | Rel-11 | CP-51 | Jiwan | Stage 3: 29.212, 29.213, 29.214, 29.215 |
| 91 | 23 | **VPLMN Autonomous CSG Roaming** | 305d? | 2010-10-15 A | 2011-12-15 | 30% | 213.5d? | 2010-10-15 | 2011-12-15 | 305d? | 256d |  | S2 | 4510.8h | 1353.2h | VCSG | PCG-26 | Qualcomm | AC Mahendran (ac@qualcomm.com) | Rel-11 | SP-50 | Maurice | Stage 2 |
| 92 | 23.1 | Stage 2 for VPLMN Autonomous CSG Roaming | 258.85d? | 2010-10-15 A | 2011-12-15 | 30% | 181.19d? | 2010-10-15 | 2011-12-15 | 258.85d? | 256d | finish no earlier than 2011-12-15 | S2 | 2070.8h | 621.24h | VCSG | PCG-26 | Qualcomm | AC Mahendran (ac@qualcomm.com) | Rel-11 | SP-50 | Maurice | 23.002, 23.060, 23.401 |
| 93 | 24 | **Data Identification in Access Network Discovery and Selection Function (ANDSF)** | 192d? | 2011-03-23 A | 2011-12-15 | 6% | 180.32d? | 2011-03-23 | 2011-12-15 | 192d? | 256d |  | S2 | 4120h | 250.63h | DIDA | PCG-26 | Qualcomm | Gerardo Giaretta (gerardo@qualcomm.com) | Rel-11 | SP-51 | Maurice | Stage 2 |
| 94 | 24.1 | TR on Stage 2 for Data Identification in ANDSF | 131d? | 2011-03-23 A | 2011-09-21 | 15% | 111.35d? | 2011-03-23 | 2011-09-21 | 131d? | 317d | finish no earlier than 2011-09-21 | S2 | 1048h | 157.2h | DIDA | PCG-26 | Qualcomm | Gerardo Giaretta (gerardo@qualcomm.com) | Rel-11 | SP-51 | Maurice | 23.855 |
| 95 | 24.2 | Stage 2 for Data Identification in ANDSF | 192d? | 2011-03-23 | 2011-12-15 |  |  | 2011-03-23 | 2011-12-15 | 192d? | 256d | finish no earlier than 2011-12-15 | S2 | 1536h |  | DIDA | PCG-26 | Qualcomm | Gerardo Giaretta (gerardo@qualcomm.com) | Rel-11 | SP-51 | Maurice |  |
| 96 | 25 | **Operator Policies for IP Interface Selection** | 192d? | 2011-03-23 A | 2011-12-15 | 12% | 168.64d? | 2011-03-23 | 2011-12-15 | 192d? | 256d |  | S2 | 4120h | 501.26h | OPIIS | PCG-26 | LG Electronics | saso.stojanovski@lge.com | Rel-11 | SP-51 | Maurice | Stage 2 |
| 97 | 25.1 | TR on Stage 2 for Operator Policies for IP Interface Selection | 131d? | 2011-03-23 A | 2011-09-21 | 30% | 91.7d? | 2011-03-23 | 2011-09-21 | 131d? | 317d | finish no earlier than 2011-09-21 | S2 | 1048h | 314.4h | OPIIS | PCG-26 | LG Electronics | saso.stojanovski@lge.com | Rel-11 | SP-51 | Maurice | 23.853 |
| 98 | 25.2 | Stage 2 for Operator Policies for IP Interface Selection | 192d? | 2011-03-23 | 2011-12-15 |  |  | 2011-03-23 | 2011-12-15 | 192d? | 256d | finish no earlier than 2011-12-15 | S2 | 1536h |  | OPIIS | PCG-26 | LG Electronics | saso.stojanovski@lge.com | Rel-11 | SP-51 | Maurice | 23.060, 23.401, 23.402 |
| 99 | 26 | **LOcation-Based Selection of gaTEways foR WLAN** | 192d? | 2011-03-23 A | 2011-12-15 | 35% | 124.81d? | 2011-03-23 | 2011-12-15 | 192d? | 256d |  | S2 | 3072h | 1075.16h | LOBSTER | PCG-26 | ZTE | zhu.chunhui@zte.com.cn | Rel-11 | SP-51 | Maurice | Stage 2 |
| 100 | 26.1 | Stage 2 for LOBSTER | 192d? | 2011-03-23 A | 2011-12-15 | 35% | 124.8d? | 2011-03-23 | 2011-12-15 | 192d? | 256d | finish no earlier than 2011-12-15 | S2 | 1536h | 537.6h | LOBSTER | PCG-26 | ZTE | zhu.chunhui@zte.com.cn | Rel-11 | SP-51 | Maurice | 23.402 |

Notes:
- 76: Stage 3
- 77: -
- 78: -
- 79: -
- 80: SP#51 Stage 2 delayed by 6 months. Architecture solutions making Cell/PLMN ID (the UE is camped on) available to IMS nodes when the mobile operator needs to record this information either to fulfil legal obligations or for charging purposes.
- 81: SP#51 completion 03/11=>06/11
- 82: SP#51 completion 03/11=>09/11
- 83: SP#51 completion 06/11=>12/11
- 84: SP#51 updated WID SP-100638=>SP-110125. Stage 2/3. Stage 1 in SA1 TS 22.115
- 85: Linked to UID_490030 SIPTO Service Continuity of IP Data Session (SIPTO_SC), UID_450035 Local IP Access and Selected IP Traffic Offload (LIPA_SIPTO), UID_460026 Support BBF Accesses Interworking (BBAI)
- 86: -
- 87: SP#50 Stage 1 completed. Triggered by the SA1,SA2 Rel-10 TR 23.813 Study on Policy solutions and enhancements (FS_PP) UID_440047
- 88: For deep packet inspection (i.e. Traffic Detection Functionality) SA1 indicated that no new requirements are needed (see Objective of FS_PP SA1,SA2 Rel-10 Study on Policy solutions and enhancements UID_440047 TR 23.813)
- 89: -
- 90: Stage 3 to support Application Detection and Control Functionality. Update Gx / introduce Sd reference points and procedures. Update S9 reference point in roaming scenarios
- 91: Linked to Rel-10 UID_450053 Enhanced Home NodeB / eNodeB (EHNB). Implements Rel-9 requirements for CSG support in SA1 TS 22.220
- 92: -
- 93: Linked to Rel-10 IFOM (IP Flow Mobility and seamless WLAN offload) UID_450041. Defines IP flow mobility, seamless and non seamless WLAN offload and respective ANDSF extensions
- 94: -
- 95: -
- 96: Linked to Rel-10 IFOM (IP Flow Mobility and seamless WLAN offload) UID_450041 (non-seamless WLAN offload aspects) & Rel-11 LIMONET (LIPA Mobility and SIPTO at the Local Network) UID_500028 (support traffic offload at local network)
- 97: -
- 98: -
- 99: Related to UID_350027 SAE for support for non-3GPP accesses (SAES-SA-FP_n3GPP). Enhancements to ePDG and PDN GW selection functions for S2b and S2c based on UE location
- 100: -

| ID | WBS | Task | Duration | Start | Finish | Complete | Remaining | Baseline start | Baseline finish | Baseline duration | Total slack | Constraint | Resources | Work | Actual work | Text1 | Text2 | Text4 | Text6 | Text7 | Text8 |
| --- | --- | --- | --- | --- | --- | --- | --- | --- | --- | --- | --- | --- | --- | --- | --- | --- | --- | --- | --- | --- | --- |
| 101 | 27 | **Short Message Service (SMS) submit and delivery without MSISDN in IMS** | 206d? | 2011-06-08 | 2012-03-21 |  |  | 2011-06-08 | 2012-03-21 | 206d? | 187d |  | S2 | 4944h |  | SMSMI | PCG-27 | Nokia Siemens Networks | Rel-11 | SP-52 | Maurice |
| 102 | 27.1 | TR on Stage 2 for SMS submit and delivery without MSISDN in IMS | 206d? | 2011-06-08 | 2012-03-21 |  |  | 2011-06-08 | 2012-03-21 | 206d? | 187d | start no earlier than 2011-06-08 | S2 | 1648h |  | SMSMI | PCG-27 | Nokia Siemens Networks | Rel-11 | SP-52 | Maurice |
| 103 | 27.2 | Stage 2 for SMS submit and delivery without MSISDN in IMS | 206d? | 2011-06-08 | 2012-03-21 |  |  | 2011-06-08 | 2012-03-21 | 206d? | 187d | start no earlier than 2011-06-08 | S2 | 1648h |  | SMSMI | PCG-27 | Nokia Siemens Networks | Rel-11 | SP-52 | Maurice |
| 104 | 28 | **Security small Enhancements** | 860d? | 2009-06-04 A | 2012-09-19 | 22% | 669.38d? | 2009-06-04 | 2012-09-19 | 860d? | 57d |  | S3 | 27776h | 5908.55h | Sec11 | PCG-27 |  | Rel-11 | SP-52 | Dionisio |
| 105 | 28.1 | EEA3 and EIA3 (new Encryption & Integrity EPS security Algorithms) | 661d? | 2009-06-04 A | 2011-12-15 | 50% | 330.5d? | 2009-06-04 | 2011-12-15 | 661d? | 256d | finish no earlier than 2011-12-15 | S3 | 5288h | 2644h | EEA3_EIA3 | PCG-23 | CATR | Rel-11 | SP-44 | Dionisio |
| 106 | 28.2 | Specification of Protection against Unsolicited Communication for IMS | 335d? | 2010-06-10 A | 2011-09-21 | 50% | 167.5d? | 2010-06-10 | 2011-09-21 | 335d? | 317d | finish no earlier than 2011-09-21 | S3 | 2680h | 1340h | SPUCI | PCG-25 | NEC | Rel-11 | SP-48 | Dionisio |
| 107 | 28.3 | H(e)NB security features for UE mobility scenarios (Stage 2) | 192d? | 2011-03-23 | 2011-12-15 |  |  | 2011-03-23 | 2011-12-15 | 192d? | 256d | finish no earlier than 2011-12-15 | S3 | 1536h |  | HNB_mob_Sec | PCG-26 | Huawei | Rel-11 | SP-51 | Dionisio |
| 108 | 28.4 | **Security aspects of Public Warning System** | 188d? | 2011-03-23 A | 2011-12-09 | 6% | 177.36d? | 2011-03-23 | 2011-12-09 | 188d? | 260d |  | S3,S1,S2,C1,R2 | 7056h | 399.55h | PWS_Sec | PCG-26 | Ericsson | Rel-11 | SP-51 | Dionisio |
| 109 | 28.4.1 | Stage 1 for Security aspects of Public Warning System | 56d? | 2011-03-23 | 2011-06-08 |  |  | 2011-03-23 | 2011-06-08 | 56d? | 392d | finish no earlier than 2011-06-08 | S1 | 448h |  | PWS_Sec | PCG-26 | Ericsson | Rel-11 | SP-51 | Alain |
| 110 | 28.4.2 | Stage 2 for Security aspects of Public Warning System | 131d? | 2011-03-23 | 2011-09-21 |  |  | 2011-03-23 | 2011-09-21 | 131d? | 317d | finish no earlier than 2011-09-21 | S2 | 1048h |  | PWS_Sec | PCG-26 | Ericsson | Rel-11 | SP-51 | Maurice |
| 111 | 28.4.3 | SA3 part for Security aspects of Public Warning System | 131d? | 2011-03-23 A | 2011-09-21 | 30% | 91.7d? | 2011-03-23 | 2011-09-21 | 131d? | 317d | finish no earlier than 2011-09-21 | S3 | 1048h | 314.4h | PWS_Sec | PCG-26 | Ericsson | Rel-11 | SP-51 | Dionisio |
| 112 | 28.4.4 | CT1 part for Security aspects of Public Warning System | 188d? | 2011-03-23 | 2011-12-09 |  |  | 2011-03-23 | 2011-12-09 | 188d? | 260d | finish no earlier than 2011-12-09 | C1 | 1504h |  | PWS_Sec | PCG-26 | Ericsson | Rel-11 | SP-51 | Frederic |
| 113 | 28.4.5 | RAN2 part for Security aspects of Public Warning System | 188d? | 2011-03-23 | 2011-12-09 |  |  | 2011-03-23 | 2011-12-09 | 188d? | 260d | finish no earlier than 2011-12-09 | R2 | 1504h |  | PWS_Sec | PCG-26 | Ericsson | Rel-11 | SP-51 | Joern |
| 114 | 28.5 | Security enhancements for usage of GBA from the browser | 206d? | 2011-06-08 | 2012-03-21 |  |  | 2011-06-08 | 2012-03-21 | 206d? | 187d | finish no earlier than 2012-03-21 | S3 | 1648h |  | Web_GBA | PCG-27 | Nokia | Rel-11 | SP-52 | Dionisio |
| 115 | 28.6 | Lawful Interception in the 3GPP Rel-11 | 336d? | 2011-06-08 | 2012-09-19 |  |  | 2011-06-08 | 2012-09-19 | 336d? | 57d | finish no earlier than 2012-09-19 | S3 | 2688h |  | LI11 | PCG-27 | PIDS, Alcatel-Lucent | Rel-11 | SP-52 | Dionisio |
| 116 | 29 | **Codec for Enhanced Voice Services** | 645d? | 2010-03-25 A | 2012-09-12 | 35% | 418.6d? | 2010-03-25 | 2012-09-12 | 645d? | 62d |  | S4,S1 | 10328h | 3625.19h | EVS_codec | PCG-24 | Huawei | Rel-11 | SP-47 | Paolo |
| 117 | 29.1 | Stage 1 for EVS_codec | 1d? | 2010-03-25 A | 2010-03-25 A | 100% |  | 2010-03-25 | 2010-03-25 | 1d? |  | start no earlier than 2010-03-25 | S1 | 8h | 8h | EVS_codec | PCG-24 | Huawei | Rel-11 | SP-47 | Paolo |
| 118 | 29.2 | Codec for Enhanced Voice Services | 645d? | 2010-03-25 A | 2012-09-12 | 35% | 419.25d? | 2010-03-25 | 2012-09-12 | 645d? | 62d | finish no earlier than 2012-09-12 | S4 | 5160h | 1806h | EVS_codec | PCG-24 | Huawei | Rel-11 | SP-47 | Paolo |
| 119 | 30 | Extensions of Acoustic Test Specifications in TS 26.131 and TS 26.132 | 331d? | 2011-06-08 | 2012-09-12 |  |  | 2011-06-08 | 2012-09-12 | 331d? | 62d | finish no earlier than 2012-09-12 | S4 | 2648h |  | Ext_ATS | PCG-27 | Orange, Qualcomm | Rel-11 | SP-52 | Paolo |
| 120 | 31 | **Rel-11 Operations, Administration, Maintenance and Provisioning (OAM&P)** | 448d? | 2011-03-23 A | 2012-12-07 | 4% | 430.85d? | 2011-03-23 | 2012-12-07 | 448d? | 0d |  | S5 | 23752h | 869.8h | OAM11 | PCG-26 |  | Rel-11 | SP-51 | Dionisio |
| 121 | 31.1 | **Network Infrastructure Management** | 261d? | 2011-03-23 A | 2012-03-21 | 5% | 247.96d? | 2011-03-23 | 2012-03-21 | 261d? | 187d |  | S5 | 4176h | 208.74h | OAM11-NIM | PCG-26 |  | Rel-11 | SP-51 | Dionisio |
| 122 | 31.1.1 | IRP framework enhancements to support Management of Converged Networks | 261d? | 2011-03-23 A | 2012-03-21 | 5% | 247.95d? | 2011-03-23 | 2012-03-21 | 261d? | 187d | finish no earlier than 2012-03-21 | S5 | 2088h | 104.4h | OAM-FMC-IRP | PCG-26 | Nokia Siemens Networks, Ericsson | Rel-11 | SP-51 | Dionisio |
| 123 | 31.2 | **Performance Management** | 448d? | 2011-03-23 A | 2012-12-07 | 5% | 424.02d? | 2011-03-23 | 2012-12-07 | 448d? | 0d |  | S5 | 9784h | 523.83h | OAM11-PM | PCG-26 |  | Rel-11 | SP-51 | Dionisio |
| 124 | 31.2.1 | IMS Performance Management enhancements | 191d? | 2011-03-23 A | 2011-12-14 | 10% | 171.9d? | 2011-03-23 | 2011-12-14 | 191d? | 257d | finish no earlier than 2011-12-14 | S5 | 1528h | 152.8h | OAM-ePM-IMS | PCG-26 | ZTE | Rel-11 | SP-51 | Dionisio |
| 125 | 31.2.2 | Enhanced Management of UE based network performance measurements | 448d? | 2011-03-23 A | 2012-12-07 | 5% | 425.6d? | 2011-03-23 | 2012-12-07 | 448d? | 0d | finish no earlier than 2012-12-07 | S5 | 3584h | 179.2h | OAM-ePM-UE | PCG-26 | Huawei, Ericsson, Nokia Siemens Networks | Rel-11 | SP-51 | Dionisio |
| 126 | 31.2.3 | CN performance measurements enhancement | 136d? | 2011-06-08 | 2011-12-14 |  |  | 2011-06-08 | 2011-12-14 | 136d? | 257d | finish no earlier than 2011-12-14 | S5 | 1088h |  | OAM-ePM-CN | PCG-27 | China Mobile | Rel-11 | SP-52 | Dionisio |

Notes:
- 101: Linked to Rel-7 SMSIP (Support of SMS over generic 3GPP IP access) UID_32081 & Rel-11 SIMTC (System Improvements to Machine-Type Communications) UID_480030 / Text3: Stage 2 / Text5: Jozsef.Varga@nsn.com
- 102: - / Text3: new TR 23.863 Support of Short Message Service (SMS) in IMS without MSISDN; Stage 2 / Text5: Jozsef.Varga@nsn.com
- 103: - / Text3: 23.204 / Text5: Jozsef.Varga@nsn.com
- 104: -
- 105: SP#52 moved as BB under generic SA3 Feature Sec11. Develop new EPS algorithms acceptable to regions such as China / Text3: 35.xxx (EEA3 & EIA3 Algorithm Specification, Implementers’ test data, Design and evaluation report, Final project report), 33.401 (SAE Security Architecture) / Text5: Yuan Qi (yuanqi@mail.ritt.com.cn)
- 106: SP#52 completion 06/11=>09/11. SP#52 moved as BB under generic SA3 Feature Sec11. Continuation of Rel-9 UID_410027/410029. Builds on TR 33.937 Study of Mechanisms for PUCI / Text3: new TR 33.8xy, TS 33.abc / Text5: Anand R. Prasad (anand@bq.jp.nec.com)
- 107: SP#52 moved as BB under generic SA3 Feature Sec11. Add HeNB Security extensions to Extended H(e)NB Features (EHNBF) UID_450053 / Text3: 33.320 Stage 2 / Text5: Marcus Wong (mwong@huawei.com)
- 108: SA3 review of PWS security requirements in 22.268 (as per LS S1-102385) and current ETWS security solution (C1 23.041, S2 23.401, R2 36.331) concluded need for further joint S1,S2,S3,C1,R2 work adding HeNB Security extensions to EHNBF UID_450053 / Text5: john.mattsson@ericsson.com
- 109: Add HeNB Security extensions to Extended H(e)NB Features (EHNBF) UID_450053 / Text3: 22.268 PWS requirements / Text5: john.mattsson@ericsson.com
- 110: - / Text3: 23.401 GPRS enhancements for E-UTRAN access / Text5: john.mattsson@ericsson.com
- 111: - / Text3: 33.102, 33.401, 43.020, FFS a New TS 33.xxx PWS security architecture) / Text5: john.mattsson@ericsson.com
- 112: - / Text3: 23.041 Technical realization of Cell Broadcast Service (CBS) / Text5: john.mattsson@ericsson.com
- 113: - / Text3: 36.331 E-UTRA Radio Resource Control (RRC) Protocol specification / Text5: john.mattsson@ericsson.com
- 114: - / Text3: 33.220, 33.222, new TR 33.823 / Text5: Silke.Holtmanns@nokia.com
- 115: Stage 1/2/3 / Text3: 33.106, 33.107, 33.108 / Text5: Koen Jaspers (k.b.jaspers@minjus.nl), terry.jacobson@alcatel-lucent.com
- 116: SP#49 SA4 completion =>03/12. Moved to Rel-11. SP#47 Stage 1 completed. Develop EVS codec for EPS based on TR 22.813 recommendations. Triggered by UID_370045 Study on enhanced voice service requirements for EPS (TR 22.813) / Text5: anisse.taleb@huawei.com
- 117: SP#47 completed / Text3: 22.173 / Text5: anisse.taleb@huawei.com
- 118: SP#51 completion 12/11=>09/12 / Text3: 26.xyz, 26.xyz, 26.xyz, 26.xyz, 26.xyz, 26.xyz, 26.xyz, 26.xyz, 26.xyz, 26.xyz, 26.9yz, 26.xyz / Text5: anisse.taleb@huawei.com
- 119: - / Text3: 26.131, 26.132 / Text5: stephane.ragot@orange-ftgroup.com, Andre Schevciw (aschevci@qualcomm.com)
- 120: - / Text3: TR 30.821
- 121: -
- 122: Triggered by SA5 Studies TR 32.833, 32.828, 32.831. Produce a TS set to reduce FMC operators' CAPEX/OPEX and facilitate OSS to integrate the various NM services consumed into the so-called end-to-end view of the FMC network under management / Text3: 32.abc (Various existing NRM IRPs), 32.101, 32.152, 32.622, new TS (32.xy1, 32.xy2, 32.xy3) / Text5: thomas.tovinger@ericsson.com, olaf.pollakowski@nsn.com
- 123: -
- 124: - / Text3: 32.409 / Text5: arsalan.naeem@zte.com.cn
- 125: - / Text3: 32.421, 32.422, 32.423, 32.441, 32.442, 32.446 / Text5: Zou Lan (zlan@huawei.com), ulf.hubinette@ericsson.com, gyula.bodog@nsn.com
- 126: - / Text3: 32.406, 32.407, 32.426 / Text5: Liang Shuangchun (liangshuangchun@cmdi.chinamobile.com), Li Jian (lijian@chinamobile.com)

| ID | WBS | Task | Type | Duration | Start | Finish | Complete | Remaining | Baseline start | Baseline finish | Baseline duration | Total slack | Constraint | Resources | Work | Actual work | Text1 | Text2 | Text6 | Text7 | Text8 | Text4 | Text5 |
| --- | --- | --- | --- | --- | --- | --- | --- | --- | --- | --- | --- | --- | --- | --- | --- | --- | --- | --- | --- | --- | --- | --- | --- |
| 127 | 31.3 | **Self-Organizing Networks (SON) - OAM aspects** |  | 388d? | 2011-03-23 | 2012-09-14 |  |  | 2011-03-23 | 2012-09-14 | 388d? | 60d |  | S5 | 6208h |  | OAM11-SON | PCG-26 | Rel-11 | SP-51 | Dionisio |  |  |
| 128 | 31.3.1 | UTRAN Self-Organizing Networks (SON) management |  | 388d? | 2011-03-23 | 2012-09-14 |  |  | 2011-03-23 | 2012-09-14 | 388d? | 60d | finish no earlier than 2012-09-14 | S5 | 3104h |  | OAM-SON-UTRAN | PCG-26 | Rel-11 | SP-51 | Dionisio | Huawei | kai.zhangkai@huawei.com |
| 129 | 32 | **Rel-11 Charging Management small Enhancements** |  | 585d? | 2010-03-25 A | 2012-06-20 | 66% | 198.96d? | 2010-03-25 | 2012-06-20 | 585d? | 122d |  | S5 | 11464h | 7565.14h | CH11 | PCG-26 | Rel-11 | SP-51 | Dionisio |  |  |
| 130 | 32.1 | Add solutions for Rc - reference point within the Online Charging System (OCS) |  | 520d? | 2010-03-25 A | 2012-03-21 | 95% | 26d? | 2010-03-25 | 2012-03-21 | 520d? | 187d | finish no earlier than 2012-03-21 | S5 | 4160h | 3952h | CH-Rc | PCG-24 | Rel-11 | SP-47 | Dionisio | Huawei | shan.mingjun@huawei.com |
| 131 | 32.2 | Charging for Policy Enhancements for Sponsored Connectivity and Coherent Access to Policy related Data Bases |  | 328d? | 2011-03-21 A | 2012-06-20 | 20% | 262.4d? | 2011-03-21 | 2012-06-20 | 328d? | 122d | finish no earlier than 2012-06-20 | S5 | 2624h | 524.8h | PEST-CH | PCG-26 | Rel-11 | SP-51 | Dionisio | Ericsson | patrik.teppo@@ericsson.com |
| 132 | 33 | **Transit Inter Operator Identifier for IMS Interconnection Charging in multi operator environment** |  | 366d? | 2010-10-27 A | 2012-03-21 | 20% | 293.82d? | 2010-10-27 | 2012-03-21 | 366d? | 187d |  | S5,S1,C1 | 6104h | 1203.86h | IOI_IMS_CH | PCG-26 | Rel-11 | SP-51 | Dionisio | Deutsche Telekom | matthias.seibel@telekom.de |
| 133 | 33.1 | Stage 1 for Transit Inter Operator Identifier for IMS Interconnection Charging in multi operator environment | milestone | 0d? | 2010-10-27 A | 2010-10-27 A | 100% |  | 2010-10-27 | 2010-10-27 | 0d? |  | finish no earlier than 2012-03-21 | S1 |  |  | IOI_IMS_CH | PCG-26 | Rel-11 | SP-51 | Dionisio | Deutsche Telekom | matthias.seibel@telekom.de |
| 134 | 33.2 | Stage 2/3 SA5 part of Transit Inter Operator Identifier for IMS Interconnection Charging in multi operator environment |  | 261d? | 2010-10-27 A | 2012-03-21 | 30% | 182.7d? | 2010-10-27 | 2012-03-21 | 261d? | 187d | finish no earlier than 2012-03-21 | S5 | 2088h | 626.4h | IOI_IMS_CH | PCG-26 | Rel-11 | SP-51 | Dionisio | Deutsche Telekom | matthias.seibel@telekom.de |
| 135 | 33.3 | Stage 3 for Transit Inter Operator Identifier for IMS Interconnection Charging in multi operator environment |  | 136d? | 2011-06-03 | 2011-12-09 |  |  | 2011-06-03 | 2011-12-09 | 136d? | 260d | finish no earlier than 2011-12-09 | C1 | 1088h |  | IOI_IMS_CH | PCG-27 | Rel-11 | CP-52 | Frederic | Deutsche Telekom | martin.huelsemann@telekom.de] |
| 136 | 34 | **User Data Convergence - Data Model** |  | 647d? | 2010-03-25 A | 2012-09-14 | 14% | 556.18d? | 2010-03-25 | 2012-09-14 | 647d? | 60d |  | C4,S1 | 15160h | 1809.6h | UDC_DM | PCG-25 | Rel-11 | CP-48 | Kimmo | Telecom Italia | mauro.ficaccio@telecomitalia.it |
| 137 | 34.1 | Stage 1 for UDC Data Model |  | 56d? | 2010-03-25 A | 2010-06-10 A | 100% |  | 2010-03-25 | 2010-06-10 | 56d? |  | finish no earlier than 2010-06-10 | S1 | 448h | 448h | UDC_DM | PCG-25 | Rel-11 | CP-48 | Alain | Telecom Italia | mauro.ficaccio@telecomitalia.it |
| 138 | 34.2 | TR on User Data Convergence (UDC) Data Model |  | 596d? | 2010-06-04 A | 2012-09-14 | 20% | 476.8d? | 2010-06-04 | 2012-09-14 | 596d? | 60d | finish no earlier than 2012-09-14 | C4 | 4768h | 953.6h | UDC_DM | PCG-25 | Rel-11 | CP-48 | Kimmo | Telecom Italia | mauro.ficaccio@telecomitalia.it |
| 139 | 34.3 | User Data Convergence (UDC) Data Model |  | 596d? | 2010-06-04 | 2012-09-14 |  |  | 2010-06-04 | 2012-09-14 | 596d? | 60d | finish no earlier than 2012-09-14 | C4 | 4768h |  | UDC_DM | PCG-25 | Rel-11 | CP-48 | Kimmo | Telecom Italia | mauro.ficaccio@telecomitalia.it |
| 140 | 35 | Definition of the UICC Application for Hosting Party Module |  | 261d? | 2011-03-18 A | 2012-03-16 | 30% | 182.7d? | 2011-03-18 | 2012-03-16 | 261d? | 190d | finish no earlier than 2012-03-16 | C6 | 2088h | 626.4h | HPM_UICC | PCG-26 | Rel-11 | CP-51 | Xavier | Gemalto | Denis.Lheriteau@gemalto.com |
| 141 | 36 | Usability improvement of II-NNI specification for inter-connection by means of Option Item list |  | 136d? | 2011-06-03 | 2011-12-09 |  |  | 2011-06-03 | 2011-12-09 | 136d? | 260d | finish no earlier than 2011-12-09 | C3 | 1088h |  | NNI_OI | PCG-27 | Rel-11 | CP-52 | Jiwan | NTT | arai.kenjiro@lab.ntt.co.jp |
| 142 | 37 | enhanced Nodes Restoration for EPC |  | 136d? | 2011-06-03 | 2011-12-09 |  |  | 2011-06-03 | 2011-12-09 | 136d? | 260d | start no earlier than 2011-06-03 | C4 | 1088h |  | eNR_EPC | PCG-27 | Rel-11 | CP-52 | Kimmo | ZTE | lu.fei1@zte.com.cn |
| 143 | 38 | **Reference Location Information** |  | 136d? | 2011-06-03 A | 2011-12-09 | 80% | 27.19d? | 2011-06-03 | 2011-12-09 | 136d? | 260d |  | C4,C1 | 2176h | 1740.87h | RLI | PCG-27 | Rel-11 | CP-52 | Kimmo | Huawei | susan.shishufeng@Huawei.com |
| 144 | 38.1 | CT4 part of Reference Location Information | milestone | 0d? | 2011-06-03 A | 2011-06-03 A | 100% |  | 2011-06-03 | 2011-06-03 | 0d? |  | finish no earlier than 2011-06-03 | C4 |  |  | RLI | PCG-27 | Rel-11 | CP-52 | Kimmo | Huawei | susan.shishufeng@Huawei.com |
| 145 | 38.2 | CT1 part of Reference Location Information |  | 136d? | 2011-06-03 A | 2011-12-09 | 80% | 27.2d? | 2011-06-03 | 2011-12-09 | 136d? | 260d | start no earlier than 2011-06-03 | C1 | 1088h | 870.4h | RLI | PCG-27 | Rel-11 | CP-52 | Frederic | Huawei | susan.shishufeng@Huawei.com |
| 146 | 39 | **IMS Stage-3 IETF Protocol Alignment** |  | 336d? | 2011-06-03 | 2012-09-14 |  |  | 2011-06-03 | 2012-09-14 | 336d? | 60d |  | C1,C3 | 8064h |  | IMSProtoc5 | PCG-27 | Rel-11 | CP-52 | Frederic | Alcatel-Lucent | keith.drage@alcatel-lucent.com |
| 147 | 39.1 | CT1 part of IMS Stage-3 IETF Protocol Alignment |  | 336d? | 2011-06-03 | 2012-09-14 |  |  | 2011-06-03 | 2012-09-14 | 336d? | 60d | finish no earlier than 2012-09-14 | C1 | 2688h |  | IMSProtoc5 | PCG-27 | Rel-11 | CP-52 | Frederic | Alcatel-Lucent | keith.drage@alcatel-lucent.com |
| 148 | 39.2 | CT3 part ofIMS Stage-3 IETF Protocol Alignment |  | 336d? | 2011-06-03 | 2012-09-14 |  |  | 2011-06-03 | 2012-09-14 | 336d? | 60d | finish no earlier than 2012-09-14 | C3 | 2688h |  | IMSProtoc5 | PCG-27 | Rel-11 | CP-52 | Jiwan | Alcatel-Lucent | keith.drage@alcatel-lucent.com |
| 149 | 40 | **Full Support of Multi-Operator Core Network by GERAN** |  | 201d? | 2011-03-04 A | 2011-12-09 | 12% | 177.5d? | 2011-03-04 | 2011-12-09 | 201d? | 260d |  | G2,S2,C1 | 4220.8h | 493.63h | Full_MOCN-GERAN | PCG-26 | Rel-11 | GP-49 | Paolo | Alcatel-Lucent | michel.robert@alcatel-lucent.com |
| 150 | 40.1 | GERAN part of Full Support of Multi-Operator Core Network by GERAN |  | 191d? | 2011-03-04 A | 2011-11-25 | 20% | 152.8d? | 2011-03-04 | 2011-11-25 | 191d? | 270d | finish no earlier than 2011-11-25 | G2 | 1528h | 305.6h | Full_MOCN-GERAN | PCG-26 | Rel-11 | GP-49 | Gert | Alcatel-Lucent | michel.robert@alcatel-lucent.com |
| 151 | 40.2 | Stage 2 for Full Support of Multi-Operator Core Network by GERAN |  | 37.8d? | 2011-06-08 | 2011-09-21 |  |  | 2011-06-08 | 2011-09-21 | 37.8d? | 317d | finish no earlier than 2011-09-21 | S2 | 302.4h |  | Full_MOCN-GERAN | PCG-26 | Rel-11 | GP-49 | Maurice | Alcatel-Lucent | nicolas.drevon@alcatel-lucent.com |
| 152 | 40.3 | CN Stage 3 for Full Support of Multi-Operator Core Network by GERAN |  | 97.8d? | 2011-06-03 | 2011-12-09 |  |  | 2011-06-03 | 2011-12-09 | 97.8d? | 260d | start no earlier than 2011-06-03 | C1 | 782.4h |  | Full_MOCN-GERAN | PCG-26 | Rel-11 | GP-49 | Frederic | Alcatel-Lucent | jennifer.liu@alcatel-lucent.com |

Notes:
- 127: -
- 128: - / Text3: UTRA 32.405, 32.500, 32.511, 32.521, 32.522, 32.526, 32.642, 32.646
- 129: - / Text3: TR 30.821
- 130: SP#51 completion 03/11=>09/11. WID updated SP-100078=>SP-110129. Moved to Rel-11. Stage 3 (Stage 1 in 22.115). Triggered by Rel-10 TR 32.825 SA5 Study on Rc Reference Point Functionalities and Message Flows (UID_410044) / Text3: 32.296, 32.299
- 131: Stage 3 / Text3: 32.251, 32.298, 32.299
- 132: Stage 2/3. Coordination needed with CT1 and CT3. Stage 1 in SA1 22.115
- 133: Stage 1 in Rel-10 TS 22.115 and earlier (Service aspects; Charging and billing) to support interconnection charging for IMS transit scenarios. No new requirement for Rel-11; only SA5 and CT1 is done in Rel-11 / Text3: 22.115
- 134: Coordination needed with CT1 and CT3 / Text3: 32.240, 32.260, 32.298, 32.299
- 135: - / Text3: 24.229
- 136: CP#52 updated WID CP-100609=>CP-110384. Completion 12/11=>09/12. SP#48 Stage 1 completed as Rel-10
- 137: SP#48 completed as Rel-10 / Text3: 22.101
- 138: CP#52 updated WID CP-100609=>CP-110384. Completion 12/11=>09/12 / Text3: new TR 29.935
- 139: CP#52 updated WID CP-100609=>CP-110384. Completion 12/11=>09/12 / Text3: 29.335
- 140: Defines Stage 3 for UICC application residing in Hosting Party Module / Text3: 31.102, new TS 31.1xy Characteristics of the Hosting Party Identity Module (HPIM)
- 141: Stage 3 (No architectural change, specify the list of selectable items related to control plane signalling directly for the same architecture) / Text3: 29.165
- 142: Stage 2/3 Triggered by DRAFT TR 23.857 Study on EPC Nodes Restoration UID_490014 / Text3: 23.007, 23.008, 29.274, 29.275
- 143: Stage 3. Stage 2 clause C.1.1 of SA2 TS 23.167 CR#0182 (WI code: TEI11)
- 144: CP#52 completed / Text3: 23.008, 29.228, 29.328, 29.329
- 145: - / Text3: 24.229
- 146: Stage 3
- 147: - / Text3: 23.218, 24.229, 24.930
- 148: - / Text3: 29.163, 29.165
- 149: GP#49 approved WID. Standardization of management of MOCN supporting MSs/UEs in GERAN. Continuation of Rel-10 MOCN-GERAN UID_490001 / Text3: GERAN
- 150: GP#49 approved WID / Text3: 43.022, 44.018, 45.002
- 151: SP#52 approved WID / Text3: 23.251
- 152: CP#52 approved WID / Text3: 24.008

| ID | WBS | Task | Duration | Start | Finish | Complete | Remaining | Baseline start | Baseline finish | Baseline duration | Total slack | Constraint | Resources | Work | Actual work | Text1 | Text2 | Text4 | Text5 | Text6 | Text7 | Text8 | Text11 |
| --- | --- | --- | --- | --- | --- | --- | --- | --- | --- | --- | --- | --- | --- | --- | --- | --- | --- | --- | --- | --- | --- | --- | --- |
| 153 | 41 | **Network-Based Positioning Support in LTE** | 921d? | 2009-03-09 A | 2012-09-14 | 18% | 753.38d? | 2009-03-09 | 2012-09-14 | 921d? | 60d |  | R2,R1,R3,R4 | 16256h | 2958.61h | LCS_LTE-NBPS | PCG-22 | TruePosition | terri.brooks@trueposition.com | Rel-11 | RP-43 | Joern |  |
| 154 | 41.1 | Core part: Network-Based Positioning Support in LTE | 455.5d? | 2009-03-09 A | 2011-12-09 | 55% | 204.97d? | 2009-03-09 | 2011-12-09 | 455.5d? | 260d | start no earlier than 2009-03-09 | R2,R1,R3,R4 | 3644h | 2004.2h | LCS_LTE-NBPS-Core | PCG-22 | TruePosition | terri.brooks@trueposition.com | Rel-11 | RP-43 | Joern | RP-110563 |
| 155 | 41.2 | Perf. part: Network-Based Positioning Support in LTE | 921d? | 2009-03-09 | 2012-09-14 |  |  | 2009-03-09 | 2012-09-14 | 921d? | 60d | finish no earlier than 2012-09-14 | R4 | 7368h |  | LCS_LTE-NBPS-Perf | PCG-22 | TruePosition | terri.brooks@trueposition.com | Rel-11 | RP-43 | Joern | RP-110564 |
| 156 | 42 | **Service continuity, counting improvements and location information for MBMS for LTE** | 456d? | 2010-06-04 A | 2012-03-02 | 5% | 433.21d? | 2010-06-04 | 2012-03-02 | 456d? | 200d |  | R2,R3 | 7296h | 364.74h | MBMS_LTE_SC | PCG-25 | Huawei | derek.richards@huawei.com | Rel-11 | RP-48 | Joern |  |
| 157 | 42.1 | Core part: Service continuity, counting improvements and location information for MBMS for LTE | 456d? | 2010-06-04 A | 2012-03-02 | 5% | 433.2d? | 2010-06-04 | 2012-03-02 | 456d? | 200d | finish no earlier than 2012-03-02 | R2,R3 | 3648h | 182.4h | MBMS_LTE_SC-Core | PCG-25 | Huawei | derek.richards@huawei.com | Rel-11 | RP-48 | Joern | RP-110769 |
| 158 | 43 | **LTE-Advanced Carrier Aggregation of Band 3 and Band 7** | 521d? | 2010-12-10 A | 2012-12-07 | 5% | 496.41d? | 2010-12-10 | 2012-12-07 | 521d? | 0d |  | R4 | 12064h | 569.52h | LTE_CA_B3_B7 | PCG-25 | TeliaSonera | Ralf.Schuh@TeliaSonera.com | Rel-11 | RP-48 | Issam |  |
| 159 | 43.1 | Core part: LTE-Advanced Carrier Aggregation of Band 3 and Band 7 | 466d? | 2010-12-10 A | 2012-09-21 | 10% | 419.4d? | 2010-12-10 | 2012-09-21 | 466d? | 55d | finish no earlier than 2012-09-21 | R4 | 3728h | 372.8h | LTE_CA_B3_B7-Core | PCG-25 | TeliaSonera | Ralf.Schuh@TeliaSonera.com | Rel-11 | RP-48 | Issam | RP-110782 |
| 160 | 43.2 | Perf. part: LTE-Advanced Carrier Aggregation of Band 3 and Band 7 | 521d? | 2010-12-10 | 2012-12-07 |  |  | 2010-12-10 | 2012-12-07 | 521d? | 0d | finish no earlier than 2012-12-07 | R4 | 4168h |  | LTE_CA_B3_B7-Perf | PCG-25 | TeliaSonera | Ralf.Schuh@TeliaSonera.com | Rel-11 | RP-48 | Issam | RP-110783 |
| 161 | 44 | **LTE Advanced Carrier Aggregation of Band 4 and Band 17** | 521d? | 2010-12-10 A | 2012-12-07 | 5% | 496.41d? | 2010-12-10 | 2012-12-07 | 521d? | 0d |  | R4 | 12064h | 569.52h | LTE_CA_B4_B17 | PCG-26 | AT&T | marc.grant@att.com | Rel-11 | RP-50 | Issam |  |
| 162 | 44.1 | Core part: LTE Advanced Carrier Aggregation of Band 4 and Band 17 | 466d? | 2010-12-10 A | 2012-09-21 | 10% | 419.4d? | 2010-12-10 | 2012-09-21 | 466d? | 55d | finish no earlier than 2012-09-21 | R4 | 3728h | 372.8h | LTE_CA_B4_B17-Core | PCG-26 | AT&T | marc.grant@att.com | Rel-11 | RP-50 | Issam | RP-110568 |
| 163 | 44.2 | Perf. part: LTE Advanced Carrier Aggregation of Band 4 and Band 17 | 521d? | 2010-12-10 | 2012-12-07 |  |  | 2010-12-10 | 2012-12-07 | 521d? | 0d | finish no earlier than 2012-12-07 | R4 | 4168h |  | LTE_CA_B4_B17-Perf | PCG-26 | AT&T | marc.grant@att.com | Rel-11 | RP-50 | Issam | RP-110569 |
| 164 | 45 | **LTE Advanced Carrier Aggregation of Band 4 and Band 13** | 521d? | 2010-12-10 A | 2012-12-07 | 5% | 496.41d? | 2010-12-10 | 2012-12-07 | 521d? | 0d |  | R4 | 12064h | 569.52h | LTE_CA_B4_B13 | PCG-26 | Ericsson | christian.bergljung@stericsson.com | Rel-11 | RP-50 | Issam |  |
| 165 | 45.1 | Core part: LTE Advanced Carrier Aggregation of Band 4 and Band 13 | 466d? | 2010-12-10 A | 2012-09-21 | 10% | 419.4d? | 2010-12-10 | 2012-09-21 | 466d? | 55d | finish no earlier than 2012-09-21 | R4 | 3728h | 372.8h | LTE_CA_B4_B13-Core | PCG-26 | Ericsson | christian.bergljung@stericsson.com | Rel-11 | RP-50 | Issam | RP-110570 |
| 166 | 45.2 | Perf. part: LTE Advanced Carrier Aggregation of Band 4 and Band 13 | 521d? | 2010-12-10 | 2012-12-07 |  |  | 2010-12-10 | 2012-12-07 | 521d? | 0d | finish no earlier than 2012-12-07 | R4 | 4168h |  | LTE_CA_B4_B13-Perf | PCG-26 | Ericsson | christian.bergljung@stericsson.com | Rel-11 | RP-50 | Issam | RP-110571 |
| 167 | 46 | **LTE Carrier Aggregation Enhancements** | 451d? | 2011-03-18 | 2012-12-07 |  |  | 2011-03-18 | 2012-12-07 | 451d? | 0d |  | R1,R2,R3,R4 | 10384h |  | LTE_CA_enh | PCG-26 | Nokia | Lars Lindh | Rel-11 | RP-51 | Patrick |  |
| 168 | 46.1 | Core part: LTE Carrier Aggregation Enhancements | 396d? | 2011-03-18 | 2012-09-21 |  |  | 2011-03-18 | 2012-09-21 | 396d? | 55d | finish no earlier than 2012-09-21 | R1,R2,R4,R3 | 3168h |  | LTE_CA_enh-Core | PCG-26 | Nokia | Lars Lindh | Rel-11 | RP-51 | Patrick | RP-110588 |
| 169 | 46.2 | Perf. part: LTE Carrier Aggregation Enhancements | 451d? | 2011-03-18 | 2012-12-07 |  |  | 2011-03-18 | 2012-12-07 | 451d? | 0d | finish no earlier than 2012-12-07 | R4 | 3608h |  | LTE_CA_enh-Perf | PCG-26 | Nokia | Lars Lindh | Rel-11 | RP-51 | Issam | RP-110589 |
| 170 | 47 | **LTE Advanced Carrier Aggregation of Band 4 and Band 12** | 451d? | 2011-03-18 | 2012-12-07 |  |  | 2011-03-18 | 2012-12-07 | 451d? | 0d |  | R4,R2 | 10384h |  | LTE_CA_B4_B12 | PCG-26 | US Cellular | Sebastian THALANANY | Rel-11 | RP-51 | Issam |  |
| 171 | 47.1 | Core part: LTE Advanced Carrier Aggregation of Band 4 and Band 12 | 396d? | 2011-03-18 | 2012-09-21 |  |  | 2011-03-18 | 2012-09-21 | 396d? | 55d | finish no earlier than 2012-09-21 | R4,R2 | 3168h |  | LTE_CA_B4_B12-Core | PCG-26 | US Cellular | Sebastian THALANANY | Rel-11 | RP-51 | Issam | RP-110574 |
| 172 | 47.2 | Perf. part: LTE Advanced Carrier Aggregation of Band 4 and Band 12 | 451d? | 2011-03-18 | 2012-12-07 |  |  | 2011-03-18 | 2012-12-07 | 451d? | 0d | finish no earlier than 2012-12-07 | R4,R2 | 3608h |  | LTE_CA_B4_B12-Perf | PCG-26 | US Cellular | Sebastian THALANANY | Rel-11 | RP-51 | Issam | RP-110575 |
| 173 | 48 | **LTE Advanced Carrier Aggregation of Band 5 and Band 12** | 451d? | 2011-03-18 | 2012-12-07 |  |  | 2011-03-18 | 2012-12-07 | 451d? | 0d |  | R4,R2 | 10384h |  | LTE_CA_B5_B12 | PCG-26 | US Cellular | Sebastian THALANANY | Rel-11 | RP-51 | Issam |  |
| 174 | 48.1 | Core part: LTE Advanced Carrier Aggregation of Band 5 and Band 12 | 396d? | 2011-03-18 | 2012-09-21 |  |  | 2011-03-18 | 2012-09-21 | 396d? | 55d | finish no earlier than 2012-09-21 | R4,R2 | 3168h |  | LTE_CA_B5_B12-Core | PCG-26 | US Cellular | Sebastian THALANANY | Rel-11 | RP-51 | Issam | RP-110576 |
| 175 | 48.2 | Perf. part: LTE Advanced Carrier Aggregation of Band 5 and Band 12 | 451d? | 2011-03-18 | 2012-12-07 |  |  | 2011-03-18 | 2012-12-07 | 451d? | 0d | finish no earlier than 2012-12-07 | R4,R2 | 3608h |  | LTE_CA_B5_B12-Perf | PCG-26 | US Cellular | Sebastian THALANANY | Rel-11 | RP-51 | Issam | RP-110577 |
| 176 | 49 | **LTE Advanced Carrier Aggregation of Band 20 and Band 7** | 451d? | 2011-03-18 | 2012-12-07 |  |  | 2011-03-18 | 2012-12-07 | 451d? | 0d |  | R4 | 10384h |  | LTE_CA_B20_B7 | PCG-26 | Huawei | Steven Chen | Rel-11 | RP-51 | Issam |  |
| 177 | 49.1 | Core part: LTE Advanced Carrier Aggregation of Band 20 and Band 7 | 396d? | 2011-03-18 | 2012-09-21 |  |  | 2011-03-18 | 2012-09-21 | 396d? | 55d | finish no earlier than 2012-09-21 | R4 | 3168h |  | LTE_CA_B20_B7-Core | PCG-26 | Huawei | Steven Chen | Rel-11 | RP-51 | Issam | RP-110578 |
| 178 | 49.2 | Perf. part: LTE Advanced Carrier Aggregation of Band 20 and Band 7 | 451d? | 2011-03-18 | 2012-12-07 |  |  | 2011-03-18 | 2012-12-07 | 451d? | 0d | finish no earlier than 2012-12-07 | R4 | 3608h |  | LTE_CA_B20_B7-Perf | PCG-26 | Huawei | Steven Chen | Rel-11 | RP-51 | Issam | RP-110579 |

Notes:
- 153: - / Text3: LTE
- 154: - / Text3: 36.111, 36.133, 36.214, 36.300, 36.305, 36.331, 36.413, 36.423, 36.455
- 155: - / Text3: 36.104, 36.111, 36.133, 36.141
- 156: RP#51 completion 06/11=>03/12 (Moved to Rel-11). WID updated RP-100690=>RP-110452 / Text3: LTE
- 157: RP#51 completion 06/11=>03/12 (Moved to Rel-11). On hold in RAN3 until RAN2 makes progress). WID updated RP-100690=>RP-110452 / Text3: 25.446, 36.300, 36.304, 36.321, 36.322, 36.323, 36.331, 36.440, 36.441, 36.442, 36.443, 36.444, 36.445
- 158: RP#52 updated WID RP-100668=>RP-110702. RP#51 moved to Rel-11. In Europe Band 3,7,20 are interesting for LTE and LTE-Advanced deployment. Different CA combinations for these bands are of high priority for Region 1. This work covers Band 3,7 combination / Text3: LTE
- 159: RP#52 updated WID RP-100668=>RP-110702 / Text3: 36.101, 36.104, 36.113, 36.124, 36.133, 36.141, 36.307, 36.331, 36.807, 36.808
- 160: RP#52 updated WID RP-100668=>RP-110702 / Text3: 36.101, 36.104, 36.133, 36.307
- 161: Stage 3 / Text3: LTE
- 162: - / Text3: 36.101, 36.104, 36.133, 36.141, 36.307, new TR 36.8xy (LTE-Advanced CA of Band 4 and Band 13 for the DL/UL with 20 MHz/10 MHz), TR 36.8ab (LTE-Advanced CA of Band 4 and Band 13 for the DL/UL with 20 MHz/20 MHz)
- 163: - / Text3: 36.101, 36.104, 36.133, 36.307
- 164: Stage 3 / Text3: LTE
- 165: - / Text3: 36.101, 36.104, 36.133, 36.307, new TR 36.8xy (LTE-Advanced CA of Band 4 and Band 13 for the DL/UL with 20 MHz/10 MHz), TR 36.8ab (LTE-Advanced CA of Band 4 and Band 13 for the DL/UL with 20 MHz/20 MHz)
- 166: - / Text3: 36.101, 36.104, 36.133, 36.141, 36.307
- 167: Stage 3. Triggered by Rel-11 UID_500015 Study on HSDPA Multipoint Transmission (FS_HSDPA_MP_TX) / Text3: LTE
- 168: RP#52 updated WID RP-110451=>RP-110702 / Text3: 36.101, 36.104, 36.133, 36.201, 36.211, 36.212, 36.213, 36.300, 36.302, 36.306, 36.321, 36.331, 36.413, 36.423
- 169: - / Text3: 36.101, 36.104, 36.133, 36.141
- 170: Stage 3 (DL/UL 20/10MHz & DL/UL 20/20MHz) / Text3: LTE
- 171: - / Text3: 36.101, 36.104, 36.133, 36.141, 36.307, new TR 36.8xy (DL/UL 20/10MHz)
- 172: - / Text3: 36.101, 36.104, 36.133, 36.307
- 173: Stage 3 (DL/UL 20/10MHz & (DL/UL 20/20MHz) / Text3: LTE
- 174: - / Text3: 36.101, 36.104, 36.133, 36.141, 36.307, new TR 36.8xy (DL/UL 20/10MHz)
- 175: - / Text3: 36.101, 36.104, 36.133, 36.307
- 176: Stage 3 (DL/UL 30/20MHz; 1 UL active & DL/UL 30/30MHz; 2 UL active) / Text3: LTE
- 177: Text3: 36.101, 36.104, 36.133, 36.141, 36.307, 37.104, 37.141, new TR 36.8xy (DL/UL 30/20MHz; 1 UL active)
- 178: Text3: 36.101, 36.104, 36.133, 36.141, 36.307

| ID | WBS | Task | Duration | Start | Finish | Complete | Remaining | Baseline start | Baseline finish | Baseline duration | Total slack | Constraint | Resources | Work | Actual work | Text1 | Text2 | Text4 | Text5 | Text6 | Text7 | Text8 | Text11 |
| --- | --- | --- | --- | --- | --- | --- | --- | --- | --- | --- | --- | --- | --- | --- | --- | --- | --- | --- | --- | --- | --- | --- | --- |
| 179 | 50 | **LTE Advanced Carrier Aggregation Band 2 and Band 17** | 451d? | 2011-03-18 | 2012-12-07 |  |  | 2011-03-18 | 2012-12-07 | 451d? | 0d |  | R4 | 10384h |  | LTE_CA_B2_B17 | PCG-26 | AT&T | marc.grant@att.com | Rel-11 | RP-51 | Issam |  |
| 180 | 50.1 | Core part: LTE Advanced Carrier Aggregation Band 2 and Band 17 | 396d? | 2011-03-18 | 2012-09-21 |  |  | 2011-03-18 | 2012-09-21 | 396d? | 55d | finish no earlier than 2012-09-21 | R4 | 3168h |  | LTE_CA_B2_B17-Core | PCG-26 | AT&T | marc.grant@att.com | Rel-11 | RP-51 | Issam | RP-110580 |
| 181 | 50.2 | Perf. part: LTE Advanced Carrier Aggregation Band 2 and Band 17 | 451d? | 2011-03-18 | 2012-12-07 |  |  | 2011-03-18 | 2012-12-07 | 451d? | 0d | finish no earlier than 2012-12-07 | R4 | 3608h |  | LTE_CA_B2_B17-Perf | PCG-26 | AT&T | marc.grant@att.com | Rel-11 | RP-51 | Issam | RP-110581 |
| 182 | 51 | **LTE Advanced Carrier Aggregation Band 4 and Band 5** | 451d? | 2011-03-18 | 2012-12-07 |  |  | 2011-03-18 | 2012-12-07 | 451d? | 0d |  | R4 | 10384h |  | LTE_CA_B4_B5 | PCG-26 | AT&T | marc.grant@att.com | Rel-11 | RP-51 | Issam |  |
| 183 | 51.1 | Core part: LTE Advanced Carrier Aggregation Band 4 and Band 5 | 396d? | 2011-03-18 | 2012-09-21 |  |  | 2011-03-18 | 2012-09-21 | 396d? | 55d | finish no earlier than 2012-09-21 | R4 | 3168h |  | LTE_CA_B4_B5-Core | PCG-26 | AT&T | marc.grant@att.com | Rel-11 | RP-51 | Issam | RP-110582 |
| 184 | 51.2 | Perf. part: LTE Advanced Carrier Aggregation Band 4 and Band 5 | 451d? | 2011-03-18 | 2012-12-07 |  |  | 2011-03-18 | 2012-12-07 | 451d? | 0d | finish no earlier than 2012-12-07 | R4 | 3608h |  | LTE_CA_B4_B5-Perf | PCG-26 | AT&T | marc.grant@att.com | Rel-11 | RP-51 | Issam | RP-110583 |
| 185 | 52 | **LTE Advanced Carrier Aggregation Band 5 and Band 17** | 451d? | 2011-03-18 | 2012-12-07 |  |  | 2011-03-18 | 2012-12-07 | 451d? | 0d |  | R4 | 10384h |  | LTE_CA_B5_B17 | PCG-26 | AT&T | marc.grant@att.com | Rel-11 | RP-51 | Issam |  |
| 186 | 52.1 | Core part: LTE Advanced Carrier Aggregation Band 5 and Band 17 | 396d? | 2011-03-18 | 2012-09-21 |  |  | 2011-03-18 | 2012-09-21 | 396d? | 55d | finish no earlier than 2012-09-21 | R4 | 3168h |  | LTE_CA_B5_B17-Core | PCG-26 | AT&T | marc.grant@att.com | Rel-11 | RP-51 | Issam | RP-110584 |
| 187 | 52.2 | Perf. part: LTE Advanced Carrier Aggregation Band 5 and Band 17 | 451d? | 2011-03-18 | 2012-12-07 |  |  | 2011-03-18 | 2012-12-07 | 451d? | 0d | finish no earlier than 2012-12-07 | R4 | 3608h |  | LTE_CA_B5_B17-Perf | PCG-26 | AT&T | marc.grant@att.com | Rel-11 | RP-51 | Issam | RP-110585 |
| 188 | 53 | **Further Enhanced Non CA-based ICIC for LTE** | 326d? | 2011-03-18 | 2012-06-15 |  |  | 2011-03-18 | 2012-06-15 | 326d? | 125d |  | R1,R2,R3,R4 | 7824h |  | eICIC_enh_LTE | PCG-26 | China Mobile | Xiaodong Xu (xuxiaodong@chinamobile.com) | Rel-11 | RP-51 | Patrick |  |
| 189 | 53.1 | Core part: Further Enhanced Non CA-based ICIC for LTE | 326d? | 2011-03-18 | 2012-06-15 |  |  | 2011-03-18 | 2012-06-15 | 326d? | 125d | finish no earlier than 2012-06-15 | R1,R2,R3,R4 | 2608h |  | eICIC_enh_LTE-Core | PCG-26 | China Mobile | Xiaodong Xu (xuxiaodong@chinamobile.com) | Rel-11 | RP-51 | Patrick | RP-110572 |
| 190 | 53.2 | Perf. part: Further Enhanced Non CA-based ICIC for LTE | 326d? | 2011-03-18 | 2012-06-15 |  |  | 2011-03-18 | 2012-06-15 | 326d? | 125d | finish no earlier than 2012-06-15 | R4 | 2608h |  | eICIC_enh_LTE-Perf | PCG-26 | China Mobile | Xiaodong Xu (xuxiaodong@chinamobile.com) | Rel-11 | RP-51 | Issam | RP-110573 |
| 191 | 54 | **New Band LTE Downlink FDD 716-728 MHz** | 451d? | 2011-03-18 | 2012-12-07 |  |  | 2011-03-18 | 2012-12-07 | 451d? | 0d |  | R4 | 10384h |  | LTE_DL_FDD700 | PCG-26 | AT&T | marc.grant@att.com | Rel-11 | RP-51 | Issam |  |
| 192 | 54.1 | Core part: New Band LTE Downlink FDD 716-728 MHz | 396d? | 2011-03-18 | 2012-09-21 |  |  | 2011-03-18 | 2012-09-21 | 396d? | 55d | finish no earlier than 2012-09-21 | R4 | 3168h |  | LTE_DL_FDD700-Core | PCG-26 | AT&T | marc.grant@att.com | Rel-11 | RP-51 | Issam | RP-110586 |
| 193 | 54.2 | Perf. part: New Band LTE Downlink FDD 716-728 MHz | 451d? | 2011-03-18 | 2012-12-07 |  |  | 2011-03-18 | 2012-12-07 | 451d? | 0d | finish no earlier than 2012-12-07 | R4 | 3608h |  | LTE_DL_FDD700-Perf | PCG-26 | AT&T | marc.grant@att.com | Rel-11 | RP-51 | Issam | RP-110587 |
| 194 | 55 | **LTE RAN Enhancements for Diverse Data Applications** | 326d? | 2011-03-18 A | 2012-06-15 | 5% | 309.71d? | 2011-03-18 | 2012-06-15 | 326d? | 125d |  | R2 | 5216h | 260.74h | LTE_eDDA | PCG-26 | Research In Motion | Gordon Young (gyoung@rim.com) | Rel-11 | RP-51 | Joern |  |
| 195 | 55.1 | Core part: LTE RAN Enhancements for Diverse Data Applications | 326d? | 2011-03-18 A | 2012-06-15 | 5% | 309.7d? | 2011-03-18 | 2012-06-15 | 326d? | 125d | finish no earlier than 2012-06-15 | R2 | 2608h | 130.4h | LTE_eDDA-Core | PCG-26 | Research In Motion | Gordon Young (gyoung@rim.com) | Rel-11 | RP-51 | Joern | RP-110590 |
| 196 | 56 | **LTE E850 - Lower Band for Region 2 (non-US)** | 261d? | 2011-03-18 | 2012-03-16 |  |  | 2011-03-18 | 2012-03-16 | 261d? | 190d |  | R1,R2,R4 | 5704h |  | LTE_e850_LB | PCG-26 | NII Holdings | bill.shvodian@nii.com | Rel-11 | RP-51 | Patrick |  |
| 197 | 56.1 | Core part: LTE E850 - Lower Band for Region 2 (non-US) | 191d? | 2011-03-18 | 2011-12-09 |  |  | 2011-03-18 | 2011-12-09 | 191d? | 260d | finish no earlier than 2011-12-09 | R1,R2,R4 | 1528h |  | LTE_e850_LB-Core | PCG-26 | NII Holdings | bill.shvodian@nii.com | Rel-11 | RP-51 | Patrick | RP-110591 |
| 198 | 56.2 | Perf. part: LTE E850 - Lower Band for Region 2 (non-US) | 261d? | 2011-03-18 | 2012-03-16 |  |  | 2011-03-18 | 2012-03-16 | 261d? | 190d | finish no earlier than 2012-03-16 | R4 | 2088h |  | LTE_e850_LB-Perf | PCG-26 | NII Holdings | bill.shvodian@nii.com | Rel-11 | RP-51 | Issam | RP-110779 |
| 199 | 57 | **Carrier based HetNet ICIC for LTE** | 326d? | 2011-03-18 A | 2012-06-15 | 5% | 309.71d? | 2011-03-18 | 2012-06-15 | 326d? | 125d |  | R3,R1,R2 | 5216h | 260.74h | LTE_CA_HetNet_ICIC | PCG-26 | Nokia Siemens Networks | krzysztof.kordybach@nsn.com | Rel-11 | RP-51 | Juha |  |
| 200 | 57.1 | Core part: Carrier based HetNet ICIC for LTE | 326d? | 2011-03-18 A | 2012-06-15 | 5% | 309.7d? | 2011-03-18 | 2012-06-15 | 326d? | 125d | finish no earlier than 2012-06-15 | R3,R1,R2 | 2608h | 130.4h | LTE_CA_HetNet_ICIC-Core | PCG-26 | Nokia Siemens Networks | krzysztof.kordybach@nsn.com | Rel-11 | RP-51 | Juha | RP-110593 |
| 201 | 58 | **UE Over The Air (Antenna) conformance testing methodology - Laptop mounted equipment Free Space test** | 716d? | 2009-09-18 A | 2012-06-15 | 53% | 339.19d? | 2009-09-18 | 2012-06-15 | 716d? | 125d |  | R4,R5 | 12064h | 6348.85h | UEAnt_FSTest | PCG-23 | CATR | Guo Lin (guolin@emcite.com) | Rel-11 | RP-45 | Issam |  |
| 202 | 58.1 | Core part: UE Over The Air (Antenna) conformance testing methodology - Laptop mounted equipment Free Space test | 521d? | 2009-09-18 A | 2011-09-16 | 80% | 104.2d? | 2009-09-18 | 2011-09-16 | 521d? | 320d | finish no earlier than 2011-09-16 | R4 | 4168h | 3334.4h | UEAnt_FSTest | PCG-23 | CATR | Guo Lin (guolin@emcite.com) | Rel-11 | RP-45 | Issam | RP-110549 |
| 203 | 58.2 | Test part: UE Over The Air (Antenna) conformance testing methodology - Laptop mounted equipment Free Space test | 271d? | 2011-06-03 | 2012-06-15 |  |  | 2011-06-03 | 2012-06-15 | 271d? | 125d | finish no earlier than 2012-06-15 | R5 | 2168h |  | UEAnt_FSTest-UEConTest | PCG-27 | ZTE | carolyn.tayl@zte.com.cn | Rel-11 | RP-52 | Ingbert |  |

Notes:
- 179: Stage 3 / Text3: LTE
- 180: Text3: 36.101, 36.104, 36.133, 36.141, 36.307, new TR 36.8xy (DL/UL 10/15/20MHz)
- 181: Text3: 36.101, 36.104, 36.133, 36.307
- 182: Stage 3 / Text3: LTE
- 183: Text3: 36.101, 36.104, 36.133, 36.141, 36.307, new TR 36.8xy (DL/UL 10/15/20MHz)
- 184: Text3: 36.101, 36.104, 36.133, 36.307
- 185: Stage 3 / Text3: LTE
- 186: Text3: 36.101, 36.104, 36.133, 36.141, 36.307, new TR 36.8xy (DL/UL 10/15/20MHz)
- 187: Text3: 36.101, 36.104, 36.133, 36.141, 36.307
- 188: Stage 2/3 / Text3: LTE
- 189: - / Text3: 36.101, 36.133, 36.201, 36.211, 36.212, 36.213, 36.214, 36.300, 36.304, 36.321, 36.331, 36.413, 36.423
- 190: RP#52 updated WID RP-110420=>RP-110824 / Text3: 36.101, 36.104, 36.133, 36.141
- 191: Stage 3 / Text3: LTE
- 192: RP#52 updated WID RP-110435=>RP-110710 / Text3: 36.101, 36.104, 36.141, 36.307
- 193: - / Text3: 36.101, 36.104, 36.133, 36.141, 36.307
- 194: Stage 3 ? / Text3: LTE
- 195: - / Text3: 36.300, 36.321, 36.331
- 196: Stage 3 / Text3: UTRA, LTE
- 197: - / Text3: 25.461, 25.466, 36.101, 36.104, 36.113, 36.124, 36.133, 36.307, 36.331
- 198: - / Text3: 36.101, 36.104, 36.133, 36.141
- 199: Stage 2/3 / Text3: LTE
- 200: - / Text3: 36.300, 36.413, 36.420, 36.423
- 201: RP#51 moved to Rel-11 / Text3: UTRA 25.144, 25.914, 34.114
- 202: RP#51 moved to Rel-11 / Text3: UTRA 25.144, 25.914, 34.114
- 203: - / Text3: 34.114

| ID | WBS | Task | Duration | Start | Finish | Complete | Remaining | Baseline start | Baseline finish | Baseline duration | Total slack | Constraint | Resources | Work | Actual work | Text1 | Text2 | Text4 | Text5 | Text6 | Text7 | Text8 | Text11 |
| --- | --- | --- | --- | --- | --- | --- | --- | --- | --- | --- | --- | --- | --- | --- | --- | --- | --- | --- | --- | --- | --- | --- | --- |
| 204 | 59 | **Eight carrier HSDPA** | 521d? | 2010-12-10 A | 2012-12-07 | 13% | 453.51d? | 2010-12-10 | 2012-12-07 | 521d? | 0d |  | R1,R2,R3,R4 | 10944h | 1417.8h | 8C_HSDPA | PCG-26 | Ericsson | johan.hultell@ericsson.com | Rel-11 | RP-50 | Patrick |  |
| 205 | 59.1 | Core part: Eight carrier HSDPA | 396d? | 2010-12-10 A | 2012-06-15 | 30% | 277.2d? | 2010-12-10 | 2012-06-15 | 396d? | 125d | finish no earlier than 2012-06-15 | R1,R2,R3,R4 | 3168h | 950.4h | 8C_HSDPA-Core | PCG-26 | Ericsson | johan.hultell@ericsson.com | Rel-11 | RP-50 | Patrick | RP-110551 |
| 206 | 59.2 | Perf. part: Eight carrier HSDPA | 521d? | 2010-12-10 | 2012-12-07 |  |  | 2010-12-10 | 2012-12-07 | 521d? | 0d | finish no earlier than 2012-12-07 | R4 | 4168h |  | 8C_HSDPA-Perf | PCG-26 | Ericsson | johan.hultell@ericsson.com | Rel-11 | RP-50 | Issam | RP-110552 |
| 207 | 60 | **UE demodulation performance requirements under multiple-cell scenario for 1.28Mcps TDD** | 201d? | 2010-12-10 A | 2011-09-16 | 70% | 60.3d? | 2010-12-10 | 2011-09-16 | 201d? | 320d |  | R4 | 3216h | 2251.22h | LCR_TDD_UE_demod_mc | PCG-26 | China Mobile | Li Nan (linan@chinamobile.com) | Rel-11 | RP-50 | Issam |  |
| 208 | 60.1 | Perf. part: UE demodulation performance requirements under multiple-cell scenario for 1.28Mcps TDD | 201d? | 2010-12-10 A | 2011-09-16 | 70% | 60.3d? | 2010-12-10 | 2011-09-16 | 201d? | 320d | finish no earlier than 2011-09-16 | R4 | 1608h | 1125.6h | LCR_TDD_UE_demod_mc-Perf | PCG-26 | China Mobile | Li Nan (linan@chinamobile.com) | Rel-11 | RP-50 | Issam | RP-110550 |
| 209 | 61 | **Uplink Transmit Diversity for HSPA** | 461d? | 2010-12-10 A | 2012-09-14 | 9% | 417.65d? | 2010-12-10 | 2012-09-14 | 461d? | 60d |  | R1,R4,R2,R3 | 16360h | 1538.38h | HSPA_UL_TxDiv | PCG-26 | Huawei | Wang Zongjie | Rel-11 | RP-50 | Patrick |  |
| 210 | 61.1 | Core part: Uplink Transmit Diversity for HSPA - Closed Loop | 331d? | 2010-12-10 A | 2012-03-16 | 40% | 198.6d? | 2010-12-10 | 2012-03-16 | 331d? | 190d | finish no earlier than 2012-03-16 | R1,R4,R2,R3 | 2648h | 1059.2h | HSPA_UL_TxDiv-CL-Core | PCG-26 | Huawei | Wang Zongjie | Rel-11 | RP-50 | Patrick | RP-110553 |
| 211 | 61.2 | Perf. part: Uplink Transmit Diversity for HSPA - Closed Loop | 461d? | 2010-12-10 | 2012-09-14 |  |  | 2010-12-10 | 2012-09-14 | 461d? | 60d | finish no earlier than 2012-09-14 | R4 | 3688h |  | HSPA_UL_TxDiv-CL-Perf | PCG-26 | Huawei | Wang Zongjie | Rel-11 | RP-50 | Issam | RP-110554 |
| 212 | 61.3 | Core part: Uplink Transmit Diversity for HSPA - Open Loop | 331d? | 2010-12-10 A | 2012-03-16 | 5% | 314.45d? | 2010-12-10 | 2012-03-16 | 331d? | 190d | finish no earlier than 2012-03-16 | R4,R1,R2,R3 | 2648h | 132.4h | HSPA_UL_TxDiv-OL-Core | PCG-26 | Huawei | Wang Zongjie | Rel-11 | RP-50 | Patrick | RP-110555 |
| 213 | 61.4 | Perf. part: Uplink Transmit Diversity for HSPA - Open Loop | 461d? | 2010-12-10 | 2012-09-14 |  |  | 2010-12-10 | 2012-09-14 | 461d? | 60d | finish no earlier than 2012-09-14 | R4 | 3688h |  | HSPA_UL_TxDiv-OL-Perf | PCG-26 | Huawei | Wang Zongjie | Rel-11 | RP-50 | Issam | RP-110556 |
| 214 | 62 | **Introduction of New Configuration for 4C-HSDPA** | 451d? | 2011-03-18 | 2012-12-07 |  |  | 2011-03-18 | 2012-12-07 | 451d? | 0d |  | R4,R2 | 9824h |  | 4C_HSDPA_Config | PCG-26 | Telus Communications | jorge.delrio@telus.com | Rel-11 | RP-51 | Issam |  |
| 215 | 62.1 | Core part: Introduction of New Configuration for 4C-HSDPA | 326d? | 2011-03-18 | 2012-06-15 |  |  | 2011-03-18 | 2012-06-15 | 326d? | 125d | finish no earlier than 2012-06-15 | R4,R2 | 2608h |  | 4C_HSDPA_Config-Core | PCG-26 | Telus Communications | jorge.delrio@telus.com | Rel-11 | RP-51 | Issam | RP-110557 |
| 216 | 62.2 | Perf. part: Introduction of New Configuration for 4C-HSDPA | 451d? | 2011-03-18 | 2012-12-07 |  |  | 2011-03-18 | 2012-12-07 | 451d? | 0d | finish no earlier than 2012-12-07 | R4,R2 | 3608h |  | 4C_HSDPA_Config-Perf | PCG-26 | Telus Communications | jorge.delrio@telus.com | Rel-11 | RP-51 | Issam | RP-110558 |
| 217 | 63 | **Non-contiguous 4C-HSDPA operation** | 451d? | 2011-03-18 | 2012-12-07 |  |  | 2011-03-18 | 2012-12-07 | 451d? | 0d |  | R4,R2,R3 | 9824h |  | NC_4C_HSDPA | PCG-26 | Ericsson | Muhammad Kazmi | Rel-11 | RP-51 | Issam |  |
| 218 | 63.1 | Core part: Non-contiguous 4C-HSDPA operation | 326d? | 2011-03-18 | 2012-06-15 |  |  | 2011-03-18 | 2012-06-15 | 326d? | 125d | finish no earlier than 2012-06-15 | R4,R2,R3 | 2608h |  | NC_4C_HSDPA-Core | PCG-26 | Ericsson | Muhammad Kazmi | Rel-11 | RP-51 | Issam | RP-110559 |
| 219 | 63.2 | Perf. part: Non-contiguous 4C-HSDPA operation | 451d? | 2011-03-18 | 2012-12-07 |  |  | 2011-03-18 | 2012-12-07 | 451d? | 0d | finish no earlier than 2012-12-07 | R4 | 3608h |  | NC_4C_HSDPA-Perf | PCG-26 | Ericsson | Muhammad Kazmi | Rel-11 | RP-51 | Issam | RP-110560 |
| 220 | 64 | **Further Enhancements to CELL_FACH** | 451d? | 2011-03-18 A | 2012-12-07 | 1% | 447.23d? | 2011-03-18 | 2012-12-07 | 451d? | 0d |  | R1,R2,R3,R4 | 9824h | 82.34h | Cell_FACH_enh | PCG-26 | Qualcomm | Ravi Agarwal | Rel-11 | RP-51 | Patrick |  |
| 221 | 64.1 | Core part: Further Enhancements to CELL_FACH | 326d? | 2011-03-18 A | 2012-06-15 | 2% | 319.48d? | 2011-03-18 | 2012-06-15 | 326d? | 125d | finish no earlier than 2012-06-15 | R2,R1,R3,R4 | 2608h | 52.16h | Cell_FACH_enh-Core | PCG-26 | Qualcomm | Ravi Agarwal | Rel-11 | RP-51 | Joern | RP-110774 |
| 222 | 64.2 | Perf. part: Further Enhancements to CELL_FACH | 451d? | 2011-03-18 | 2012-12-07 |  |  | 2011-03-18 | 2012-12-07 | 451d? | 0d | finish no earlier than 2012-12-07 | R4 | 3608h |  | Cell_FACH_enh-Perf | PCG-26 | Qualcomm | Heechoon Lee | Rel-11 | RP-51 | Issam | RP-110562 |
| 223 | 65 | **LTE Advanced Carrier Aggregation in Band 38** | 396d? | 2011-06-03 | 2012-12-07 |  |  | 2011-06-03 | 2012-12-07 | 396d? | 0d |  | R4 | 9064h |  | LTE_CA_B38 | PCG-27 | Huawei | ronnie.zhang@huawei.com | Rel-11 | RP-52 | Issam |  |
| 224 | 65.1 | Core part: LTE Advanced Carrier Aggregation in Band 38 | 341d? | 2011-06-03 | 2012-09-21 |  |  | 2011-06-03 | 2012-09-21 | 341d? | 55d | finish no earlier than 2012-09-21 | R4 | 2728h |  | LTE_CA_B38-Core | PCG-27 | Huawei | ronnie.zhang@huawei.com | Rel-11 | RP-52 | Issam |  |
| 225 | 65.2 | Perf. part: LTE Advanced Carrier Aggregation in Band 38 | 396d? | 2011-06-03 | 2012-12-07 |  |  | 2011-06-03 | 2012-12-07 | 396d? | 0d | finish no earlier than 2012-12-07 | R4 | 3168h |  | LTE_CA_B38-Perf | PCG-27 | Huawei | ronnie.zhang@huawei.com | Rel-11 | RP-52 | Issam |  |
| 226 | 66 | **LTE Advanced Carrier Aggregation in Band 41** | 396d? | 2011-06-03 | 2012-12-07 |  |  | 2011-06-03 | 2012-12-07 | 396d? | 0d |  | R4 | 9064h |  | LTE_CA_B41 | PCG-27 | Clearwire | michael.hart@clearwire.com | Rel-11 | RP-52 | Issam |  |
| 227 | 66.1 | Core part: LTE Advanced Carrier Aggregation in Band 41 | 341d? | 2011-06-03 | 2012-09-21 |  |  | 2011-06-03 | 2012-09-21 | 341d? | 55d | finish no earlier than 2012-09-21 | R4 | 2728h |  | LTE_CA_B41-Core | PCG-27 | Clearwire | michael.hart@clearwire.com | Rel-11 | RP-52 | Issam |  |
| 228 | 66.2 | Perf. part: LTE Advanced Carrier Aggregation in Band 41 | 396d? | 2011-06-03 | 2012-12-07 |  |  | 2011-06-03 | 2012-12-07 | 396d? | 0d | finish no earlier than 2012-12-07 | R4 | 3168h |  | LTE_CA_B41-Perf | PCG-27 | Clearwire | michael.hart@clearwire.com | Rel-11 | RP-52 | Issam |  |

Notes:
- 204: Stage 3 / Text3: UTRA
- 205: - / Text3: 25.101, 25.104, 25.133, 25.211, 25.212, 25.213, 25.214, 25.215, 25.308, 25.331, 25.423, 25.433, 26.306
- 206: - / Text3: 25.101, 25.104, 25.133, 25.141
- 207: Stage 3 / Text3: UTRA
- 208: - / Text3: 25.102
- 209: Stage 2/3 / Text3: UTRA
- 210: - / Text3: 25.101, 25.104, 25.133, 25.211, 25.212, 25.213, 25.214, 25.215, 25.306, 25.319, 25.321, 25.331, 25.423, 25.433
- 211: - / Text3: 25.101, 25.104, 25.133, 25.141
- 212: RP#51 updated WID RP-101438=>RP-110374 (Changed lead WG) / Text3: 25.101, 25.133, 25.306, 25.319, 25.321, 25.331, 25.423, 25.433
- 213: - / Text3: 25.101, 25.133
- 214: RP#52 delayed by 6 months / Text3: UTRA
- 215: RP#52 completion 12/11=>06/12 / Text3: 25.101, 25.104, 25.141, 25.317
- 216: RP#52 completion 06/12=>12/12 / Text3: 25.101, 25.104, 25.141, 25.317
- 217: UTRA / Text3: UTRA
- 218: - / Text3: 25.101, 25.104, 25.133, 25.331, 25.423, 25.433
- 219: - / Text3: 25.101, 25.104, 25.133, 25.141
- 220: Stage 2/3 / Text3: UTRA
- 221: RP#52 updated WID RP-110436=>RP-110913 / Text3: 25.101, 25.104, 25.133, 25.211, 25.212, 25.213, 25.214, 25.306, 25.308, 25.319, 25.321, 25.331, 25.423, 25.433
- 222: - / Text3: 25.101, 25.104, 25.133, 25.141
- 223: Stage 3 / Text3: LTE
- 224: 36.101, 36.104, 36.133, 36.141, 36.307, 37.104, 37.141, new TR 36.8xy / Text3: LTE
- 225: 36.101, 36.104, 36.133, 36.141, 36.307, 37.104, 37.141 / Text3: LTE
- 226: Stage 3 linked to Rel-10 Carrier Aggregation for LTE UID_460007 / Text3: LTE
- 227: 36.101, 36.104, 36.133, 36.141, 36.307, 37.104, new TR 36.8xy / Text3: LTE
- 228: 36.101, 36.104, 36.133, 36.141, 36.307 / Text3: LTE

| ID | WBS | Task | Duration | Start | Finish | Complete | Remaining | Baseline start | Baseline finish | Baseline duration | Total slack | Constraint | Resources | Work | Actual work | Text1 | Text2 | Text3 | Text4 | Text6 | Text7 | Text8 |
| --- | --- | --- | --- | --- | --- | --- | --- | --- | --- | --- | --- | --- | --- | --- | --- | --- | --- | --- | --- | --- | --- | --- |
| 229 | 67 | **LTE for 700 MHz Digital Dividend** | 396d? | 2011-06-03 | 2012-12-07 |  |  | 2011-06-03 | 2012-12-07 | 396d? | 0d |  | R4,R2,R3 | 9064h |  | LTE_APAC700 | PCG-27 | LTE | Ericsson | Rel-11 | RP-52 | Issam |
| 230 | 67.1 | Core part: LTE for 700 MHz Digital Dividend | 341d? | 2011-06-03 | 2012-09-21 |  |  | 2011-06-03 | 2012-09-21 | 341d? | 55d | finish no earlier than 2012-09-21 | R4,R2,R3 | 2728h |  | LTE_APAC700-Core | PCG-27 | LTE | Ericsson | Rel-11 | RP-52 | Issam |
| 231 | 67.2 | Perf. part: LTE for 700 MHz Digital Dividend | 396d? | 2011-06-03 | 2012-12-07 |  |  | 2011-06-03 | 2012-12-07 | 396d? | 0d | finish no earlier than 2012-12-07 | R4 | 3168h |  | LTE_APAC700-Perf | PCG-27 | LTE | Ericsson | Rel-11 | RP-52 | Issam |
| 232 | 68 | (Small) Technical Enhancements and Improvements for Rel-11 | 402d? | 2010-06-10 A | 2011-12-23 | 20% | 321.6d? | 2010-06-10 | 2011-12-23 | 402d? | 250d | finish no earlier than 2011-12-23 | All | 3216h | 643.2h | TEI11 | PCG-25 |  |  | Rel-11 | SP-48 | All |
| 233 | 69 | Release 11 Studies | 525d? | 2009-12-10 A | 2012-06-20 | 38% | 325.8d? | 2009-12-10 | 2012-06-20 | 525d? | 122d | finish no earlier than 2012-06-20 | SP,GP | 1086.4h |  |  |  |  |  | Rel-11 |  | All |
| 234 | 70 | Study on IMS based Peer-to-Peer Content Distribution Services | 284d? | 2009-05-12 A | 2010-06-10 A | 100% |  | 2009-05-12 | 2010-06-10 | 284d? |  | finish no earlier than 2010-06-10 | S1,S2 | 2272h | 2272h | FS_IMS_P2P | PCG-23 | 22.906 | China Mobile | Rel-11 | SP-45 | Alain |
| 235 | 71 | Study on Non Voice Emergency Services | 462d? | 2009-12-10 A | 2011-09-16 | 95% | 23.1d? | 2009-12-10 | 2011-09-16 | 462d? | 320d | finish no earlier than 2011-09-16 | S1 | 3696h | 3511.2h | FS_NOVES | PCG-24 | 22.871 | Qualcomm | Rel-11 | SP-46 | Alain |
| 236 | 72 | Study on UICC/USIM enhancements | 465d? | 2009-12-10 A | 2011-09-21 | 55% | 210.9d? | 2009-12-10 | 2011-09-21 | 465d? | 317d | finish no earlier than 2011-09-21 | S1 | 3720h | 2032.8h | FS_U2e | PCG-24 | 22.817 | Giesecke & Devrient | Rel-11 | SP-46 | Alain |
| 237 | 73 | Study on Alternatives to E.164 for Machine-Type Communications | 390d? | 2010-03-25 A | 2011-09-21 | 40% | 234d? | 2010-03-25 | 2011-09-21 | 390d? | 317d | finish no earlier than 2011-09-21 | S1 | 3120h | 1248h | FS_AMTC | PCG-24 | 22.988 | T-Mobile USA | Rel-11 | SP-47 | Alain |
| 238 | 74 | Study on enhancements for Machine-Type Communications (MTC) | 335d? | 2010-06-10 A | 2011-09-21 | 40% | 201d? | 2010-06-10 | 2011-09-21 | 335d? | 317d | finish no earlier than 2011-09-21 | S1 | 2680h | 1072h | FS_MTCe | PCG-25 | 22.888 | Huawei | Rel-11 | SP-48 | Alain |
| 239 | 75 | Study on Support for 3GPP Voice Interworking with Enterprise IP-PBX | 130d? | 2010-09-23 A | 2011-03-23 A | 100% |  | 2010-09-23 | 2011-03-23 | 130d? |  | finish no earlier than 2011-02-21 | S1,S2 | 1040h | 1040h | FS_VINE | PCG-25 | 22.809 | Tatara Systems | Rel-11 | SP-48 | Alain |
| 240 | 76 | Study on IMS Network-Independent Public User Identities | 185d? | 2010-09-23 A | 2011-06-08 A | 100% |  | 2010-09-23 | 2011-06-08 | 185d? |  | finish no earlier than 2011-06-08 | S1 | 1480h | 1480h | FS_INIPUI | PCG-25 | 22.894 | Vodafone | Rel-11 | SP-49 | Alain |
| 241 | 77 | Study on Integration of Single Sign-On (SSO) frameworks with 3GPP networks | 260d? | 2010-09-23 A | 2011-09-21 | 60% | 104d? | 2010-09-23 | 2011-09-21 | 260d? | 317d | finish no earlier than 2011-09-21 | S1 | 2080h | 1248h | FS_SSO_Int | PCG-25 | 22.895 | InterDigital | Rel-11 | SP-49 | Alain |
| 242 | 78 | Study on Continuity of Data Sessions to Local Networks | 200d? | 2010-12-16 A | 2011-09-21 | 80% | 40d? | 2010-12-16 | 2011-09-21 | 200d? | 317d | finish no earlier than 2011-09-21 | S1 | 1600h | 1280h | FS_CSN | PCG-26 | 22.896 | NEC | Rel-11 | SP-50 | Alain |
| 243 | 79 | Study on non-MTC Mobile Data Applications Impacts | 200d? | 2010-12-16 A | 2011-09-21 | 60% | 80d? | 2010-12-16 | 2011-09-21 | 200d? | 317d | finish no earlier than 2011-09-21 | S1 | 1600h | 960h | FS_MODAI | PCG-26 | 22.801 | Huawei, China Mobile | Rel-11 | SP-50 | Alain |
| 244 | 80 | Study on IMS Evolution | 786d? | 2008-09-18 A | 2011-09-21 | 85% | 117.9d? | 2008-09-18 | 2011-09-21 | 786d? | 317d | finish no earlier than 2011-09-21 | S2 | 6288h | 5344.8h | FS_eIMS | PCG-21 | 23.812 | China Mobile | Rel-11 | SP-41 | Maurice |
| 245 | 81 | Study on Multi Access PDN connectivity and IP flow Mobility | 786d? | 2008-09-18 A | 2011-09-21 | 75% | 196.5d? | 2008-09-18 | 2011-09-21 | 786d? | 317d | finish no earlier than 2011-09-21 | S2,S1 | 6288h | 4716h | FS_MAPIM | PCG-21 | 23.861 | Qualcomm | Rel-11 | SP-41 | Maurice |
| 246 | 82 | Study on Policy solutions and enhancements | 525d? | 2009-06-04 A | 2011-06-08 A | 100% |  | 2009-06-04 | 2011-06-08 | 525d? |  | finish no earlier than 2011-06-08 | S2,S1 | 4200h | 4200h | FS_PP | PCG-23 | 23.813 | AT&T | Rel-11 | SP-44 | Maurice |
| 247 | 83 | Study on IPv6 Migration | 525d? | 2009-06-04 A | 2011-06-08 A | 100% |  | 2009-06-04 | 2011-06-08 | 525d? |  | finish no earlier than 2011-06-08 | S2 | 4200h | 4200h | FS_IP6M | PCG-23 | 23.975 | China Mobile | Rel-11 | SP-44 | Maurice |
| 248 | 84 | Study on IMS based Peer-to-Peer Content Distribution Services (Stage 2) | 320d? | 2010-09-23 A | 2011-12-14 | 25% | 239.75d? | 2010-09-23 | 2011-12-14 | 320d? | 257d | finish no earlier than 2011-12-14 | S2,S1 | 2560h | 642h | FS_IMS_P2P_CDS | PCG-25 | 23.844 | China Mobile | Rel-11 | SP-49 | Maurice |
| 249 | 85 | Study on Single Radio Voice Call Continuity from UTRAN/GERAN to E-UTRAN/HSPA | 465d? | 2009-12-10 A | 2011-09-21 | 90% | 46.5d? | 2009-12-10 | 2011-09-21 | 465d? | 317d | finish no earlier than 2011-09-21 | S2 | 3720h | 3348h | FS_rSRVCC | PCG-24 | 23.885 | Orange | Rel-11 | SP-46 | Maurice |
| 250 | 86 | Study on Core Network Overload solutions | 320d? | 2010-09-23 A | 2011-12-14 | 60% | 127.4d? | 2010-09-23 | 2011-12-14 | 320d? | 257d | finish no earlier than 2011-12-14 | S2 | 2560h | 1540.8h | FS_CNO | PCG-25 | 23.843 | Huawei | Rel-11 | SP-49 | Maurice |
| 251 | 87 | Study on System Enhancements for Energy Efficiency | 260d? | 2010-12-16 A | 2011-12-14 | 15% | 220.85d? | 2010-12-16 | 2011-12-14 | 260d? | 257d | finish no earlier than 2011-12-14 | S2 | 2080h | 313.2h | FS_SEEE | PCG-26 | 23.866 | Huawei | Rel-11 | SP-50 | Maurice |
| 252 | 88 | Study on S2a Mobility based On GTP and WLAN access to EPC | 192d? | 2011-03-23 A | 2011-12-15 | 35% | 124.8d? | 2011-03-23 | 2011-12-15 | 192d? | 256d | finish no earlier than 2011-12-14 | S2 | 1528h | 537.6h | FS_SaMOG | PCG-26 | 23.852 | ZTE | Rel-11 | SP-51 | Maurice |
| 253 | 89 | Study on Roaming Architecture for Voice over IMS with Local Breakout | 192d? | 2011-03-23 A | 2011-12-15 | 25% | 144d? | 2011-03-23 | 2011-12-15 | 192d? | 256d | finish no earlier than 2011-12-14 | S2 | 1528h | 384h | FS_RAVEL | PCG-26 | 23.850 | Deutsche Telekom | Rel-11 | SP-51 | Maurice |

Notes:
- 229: Stage 3 Asian Pacific American Caucus (APAC) Asia-Pacific Telecommunity (APT) Wireless Forum (APT/AWF/REP-14 "APT Report on Harmonised Frequency Arrangements for the Band 698-806 MHz", Sep 2010) / Text5: olav.queseth@ericsson.com
- 230: 25.461, 25.466, 36.101, 36.104, 36.113, 36.124, 36.133, 36.307, 37.104, 37.113, new TR 36.8xy APAC 700 MHz Work Item Technical report / Text5: olav.queseth@ericsson.com
- 231: 36.133, 36.141, 37.141 / Text5: olav.queseth@ericsson.com
- 232: SP#50 EU-Alert is introduced under Public Warning System in parallel with the already existing ETWS and CMAS. SA1 22.268 CR#9r1 adds EU-ALERT specific requirements & CT1 23.041 CRs#
- 233: -
- 234: SP#48 completed / Text5: Li Gang (ligangyf@chinamobile.com)
- 235: SP#52 completion 06/11=>09/11. Spin-off Feature UID_500030 Non Voice Emergency Services (NOVES) / Text5: dwilliams@qualcomm.com
- 236: SP#51 completion 03/11=>09/11. Triggered by GSMA Smart SIM and 3GNBK projects, and to evolve from traditional USAT to multimedia USIM toolkit support, particularly to Smart Card Web Server / Text5: Ilario ilario.macchi@gi-de.com
- 237: SP#51 completion 06/11=>09/11. Determine an alternative to E.164 for identifying individual devices and route messages between those devices / Text5: gary.jones@T-Mobile.com
- 238: SP#51 completion 06/11=>09/11. Study Network improvements for MTC Device to MTC Device communications via one or more PLMNs (direct-mode communication between devices is out of scope), etc. Align also with ETSI TC M2M work. / Text5: laurence.meriau@huawei.com
- 239: SP#51 TR 22.809 approved. Support Interworking between 3GPP networks and Enterprise environments to provide enterprise voice services via 3GPP mobile devices / Text5: Phillip Brown (pbrown@tatarasystems.com)
- 240: SP#52 completed / Text5: mona.mustapha@vodafone.com
- 241: SP#51 completion 06/11=>09/11. Linked to SA3 Study on Single Sign On (SSO) Application Security for IMS - based on SIP Digest (UID_480048), SA3 TR 33.924 Extended Identity Management (GBA-IdM) and SA3 TR 33.980 (LibSec) / Text5: christopher.wallace@interdigital.com
- 242: SP#52 updated WID SP-100885=> ??. TR 22.896v100 for SA Information. Linked to SA1 Rel-11 Feature UID_490030 SIPTO Service Continuity of IP Data Session (SIPTO_SC) / Text5: joerg.swetina@nw.neclab.eu
- 243: Linked to UID_490036 SA2 Rel-11 TR 23.843 Study on Core Network Overload solutions (FS_CNO) / Text5: Amar Deol (adeol@huawei.com), Gang Li
- 244: SP#51 moved to Rel-11 / Text5: Li Gang (ligangyf@chinamobile.com), Yu Qing (yuqing@chinamobile.com)
- 245: SP#51 moved to Rel-11. Spin-off UID_430035 MAPCON and UID_450041 IFOM / Text5: Gerardo Giaretta (gerardog@qualcomm.com)
- 246: SP#52 completed / Text5: farooq.bari@att.com
- 247: SP#52 completed / Text5: Li Lianyuan (lilianyuan@chinamobile.com), Liu Hong (liuhongyfw@chinamobile.com)
- 248: Triggered by TR 22.906 SA1 Study on IMS based Peer-to-Peer Content Distribution Services UID_450047 / Text5: Yu Qing (yuqing@chinamobile.com)
- 249: SP#51 moved to Rel-11. Study on "reverse direction" from UTRAN/GERAN to E-UTRAN/HSPA (Rel-8 SRVCC was in the other direction E-UTRAN/HSPA to GERAN/UTRAN) / Text5: delphin.barankanira@orange-ftgroup.com
- 250: Linked to CT4 UID_490014 Study on EPC Nodes Restoration. Support from CT4 and RAN WGs is anticipated. / Text5: David Xiang (dxiang@huawei.com)
- 251: Linked to SA5, CT, (GE(RAN) studies on Energy saving & SA5 Rel-10 implementation Work Item on Energy Saving Management architectures and management solutions / Text5: frank.mademann@huawei.com
- 252: Linked to Rel-8 UID_350027 SAE for support for non-3GPP accesses, Rel-10 UID_480037 SMOG (S2b Mobility based on GTP), Rel-11 UID_4600026 BBAI (Support for BBF Accesses Interworking) / Text5: zhu.chunhui@zte.com.cn
- 253: Linked to Rel-11 OSCAR (Optimized Service Charging and Allocation of Resources in IMS whilst Roaming) UID_490032. Related to LBO/home routing decision / Text5: michele.zarri@telekom.com

| ID | WBS | Task | Duration | Start | Finish | Complete | Remaining | Baseline start | Baseline finish | Baseline duration | Total slack | Constraint | Resources | Work | Actual work | Text1 | Text2 | Text4 | Text6 | Text7 | Text8 | Text3 | Text11 |
| --- | --- | --- | --- | --- | --- | --- | --- | --- | --- | --- | --- | --- | --- | --- | --- | --- | --- | --- | --- | --- | --- | --- | --- |
| 254 | 90 | **Study on Usage Monitoring Control Enhancement** | 136d? | 2011-06-08 | 2011-12-14 |  |  | 2011-06-08 | 2011-12-14 | 136d? | 257d |  | S2,S1,S5 | 3264h |  | FS_UMONC | PCG-27 | ZTE, Huawei | Rel-11 | SP-52 | Maurice |  |  |
| 255 | 90.1 | Study on Usage Monitoring Control PCC enhancement | 136d? | 2011-06-08 | 2011-12-14 |  |  | 2011-06-08 | 2011-12-14 | 136d? | 257d | start no earlier than 2011-06-08 | S2,S1 | 1088h |  | FS_UMONC | PCG-27 | ZTE | Rel-11 | SP-52 | Maurice | 23.8xx (Study on Usage Monitoring Control PCC enhancement) |  |
| 256 | 90.2 | Study on Usage Monitoring Control OCS enhancement | 136d? | 2011-06-08 | 2011-12-14 |  |  | 2011-06-08 | 2011-12-14 | 136d? | 257d | finish no earlier than 2011-12-14 | S5 | 1088h |  | FS_UMONC | PCG-27 | Huawei | Rel-11 | SP-52 | Dionisio | 32.8xy (Study on Usage Monitoring Control OCS enhancement) |  |
| 257 | 91 | Study on UTRAN key management enhancements | 981d? | 2007-12-20 A | 2011-09-21 | 90% | 98.1d? | 2007-12-20 | 2011-09-21 | 981d? | 317d | finish no earlier than 2011-09-21 | S3 | 7848h | 7063.2h | FS_UKM | PCG-21 | Ericsson | Rel-11 | SP-38 | Dionisio | 33.859 |  |
| 258 | 92 | Study on Extended IMS Media Plane Security features | 335d? | 2010-06-10 A | 2011-09-21 | 60% | 134d? | 2010-06-10 | 2011-09-21 | 335d? | 317d | finish no earlier than 2011-09-21 | S3 | 2680h | 1608h | FS_eMEDIASEC | PCG-25 | Vodafone | Rel-11 | SP-48 | Dionisio | 33.8xy |  |
| 259 | 93 | Study on Single Sign On (SSO) Application Security for IMS - based on SIP Digest | 335d? | 2010-06-10 A | 2011-09-21 | 80% | 67d? | 2010-06-10 | 2011-09-21 | 335d? | 317d | finish no earlier than 2011-09-21 | S3 | 2680h | 2144h | FS_SSO_APS | PCG-25 | Nokia | Rel-11 | SP-48 | Dionisio | 33.914 |  |
| 260 | 94 | Study on Security aspects of Integration of Single Sign-On (SSO) frameworks with 3GPP networks | 200d? | 2010-12-16 A | 2011-09-21 | 15% | 170d? | 2010-12-16 | 2011-09-21 | 200d? | 317d | finish no earlier than 2011-09-21 | S3 | 1600h | 240h | FS_SSO_Int_Sec | PCG-26 | Ericsson | Rel-11 | SP-50 | Dionisio | 33.8xy |  |
| 261 | 95 | Study on Mobile 3D Video Coding | 206d? | 2011-06-08 | 2012-03-21 |  |  | 2011-06-08 | 2012-03-21 | 206d? | 187d | finish no earlier than 2012-03-21 | S4 | 1648h |  | FS_M3DVC | PCG-27 | Orange | Rel-11 | SP-52 | Paolo | TR 26.9xy (Study on Mobile 3D Video Coding) |  |
| 262 | 96 | Study on version handling | 315d? | 2010-03-25 A | 2011-06-08 | 65% | 110.25d? | 2010-03-25 | 2011-06-08 | 315d? | 392d | finish no earlier than 2011-06-08 | S5 | 2520h | 1638h | FS_OAM_VH | PCG-24 | Ericsson | Rel-11 | SP-47 | Dionisio | 32.830 |  |
| 263 | 97 | Study on Management of Converged Networks | 395d? | 2010-06-10 A | 2011-12-14 | 20% | 316d? | 2010-06-10 | 2011-12-14 | 395d? | 257d | finish no earlier than 2011-12-14 | S5 | 3160h | 632h | FS_ManCon | PCG-25 | Nokia Siemens Networks | Rel-11 | SP-48 | Dionisio | 32.833 |  |
| 264 | 98 | Study on User Data Convergence (UDC) information model handling and provisioning: Example Use Cases | 320d? | 2010-09-23 A | 2011-12-14 | 40% | 192d? | 2010-09-23 | 2011-12-14 | 320d? | 257d | finish no earlier than 2011-12-14 | S5 | 2560h | 1024h | FS_UDC_AppUseCase | PCG-25 | Alcatel-Lucent | Rel-11 | SP-49 | Dionisio | 32.901 |  |
| 265 | 99 | Study on OAM aspects of inter-RAT Energy Saving | 191d? | 2011-03-23 A | 2011-12-14 | 10% | 171.9d? | 2011-03-23 | 2011-12-14 | 191d? | 257d | start no earlier than 2011-03-23 | S5 | 1528h | 152.8h | FS_OAM_ES_iRAT | PCG-26 | Nokia Siemens Networks | Rel-11 | SP-51 | Dionisio | 32.834 |  |
| 266 | 100 | Study on management of Heterogeneous Networks | 191d? | 2011-03-23 | 2011-12-14 |  |  | 2011-03-23 | 2011-12-14 | 191d? | 257d | start no earlier than 2011-03-23 | S5 | 1528h |  | FS_OAM_HetNet | PCG-26 | Ericsson | Rel-11 | SP-51 | Dionisio | 32.8xy |  |
| 267 | 101 | Study on impacts on UE-Core Network signalling from Energy Saving | 261d? | 2010-06-04 A | 2011-06-03 A | 100% |  | 2010-06-04 | 2011-06-03 | 261d? |  | finish no earlier than 2011-06-03 | C1 | 2088h | 2088h | FS_UE-CN_ES | PCG-25 | NEC | Rel-11 | CP-48 | Frederic | 24.826 |  |
| 268 | 102 | Study on EPC Nodes Restoration | 261d? | 2010-09-17 A | 2011-09-16 | 79% | 54.81d? | 2010-09-17 | 2011-09-16 | 261d? | 320d | finish no earlier than 2011-09-16 | C4 | 2088h | 1649.52h | FS_EPC_NR | PCG-25 | ZTE | Rel-11 | CP-49 | Kimmo | 23.857 |  |
| 269 | 103 | Study on GERAN improvements for Machine-Type Communications | 457.5d? | 2010-05-24 A | 2012-03-02 | 20% | 366d? | 2010-05-24 | 2012-03-02 | 457.5d? | 200d | finish no earlier than 2012-03-02 | G1,G2 | 3660h | 732h | FS_NIMTC_GERAN | PCG-24 | Ericsson | Rel-11 | GP-44 | Paolo | GERAN 43.868 |  |
| 270 | 104 | Study on Signal Precoding enhancements for EGPRS2 DL | 321d? | 2010-09-03 A | 2011-11-25 | 70% | 96.3d? | 2010-09-03 | 2011-11-25 | 321d? | 270d | finish no earlier than 2011-11-25 | G1,G2 | 2568h | 1797.6h | FS_SPEED | PCG-25 | Ericsson | Rel-11 | GP-46 | Paolo | GERAN 45.860 |  |
| 271 | 105 | Study on Solutions for GSM/EDGE BTS Energy Saving | 261d? | 2010-09-03 A | 2011-09-02 | 25% | 195.75d? | 2010-09-03 | 2011-09-02 | 261d? | 330d | finish no earlier than 2011-09-02 | G1,G2 | 2088h | 522h | FS_Energy_BTS | PCG-25 | Nokia Siemens Networks, Vodafone | Rel-11 | GP-47 | Paolo | GERAN 45.8xy |  |
| 272 | 106 | Study on Voice services over Adaptive Multi-user channels on One Slot (VAMOS) enhancements | 261d? | 2011-05-20 | 2012-05-18 |  |  | 2011-05-20 | 2012-05-18 | 261d? | 145d | start no earlier than 2011-05-20 | GP,G2,G1 | 2088h |  | FS_eVAMOS | PCG-27 | China Mobile, Huawei | Rel-11 | GP-50 | Paolo | GERAN 45.8xy |  |
| 273 | 107 | Study on GERAN enhancements for Mobile Data Applications | 206d? | 2011-05-20 | 2012-03-02 |  |  | 2011-05-20 | 2012-03-02 | 206d? | 200d | finish no earlier than 2012-03-02 | G2,G1 | 1648h |  | FS_GERAN_eMDA | PCG-27 | Huawei | Rel-11 | GP-50 | Gert | GERAN 45.8xy |  |
| 274 | 108 | Study on Coordinated Multi-Point operation for LTE | 200d? | 2010-12-10 A | 2011-09-15 | 50% | 100d? | 2010-12-10 | 2011-09-15 | 200d? | 321d | finish no earlier than 2011-09-15 | R1,R2,R3 | 1600h | 800h | FS_CoMP_LTE | PCG-24 | Samsung | Rel-11 | RP-47 | Patrick | LTE 36.819 | RP-110887 |
| 275 | 109 | Study on Signalling and procedure for interference avoidance for in-device coexistence | 336d? | 2010-06-04 A | 2011-09-16 | 95% | 16.8d? | 2010-06-04 | 2011-09-16 | 336d? | 320d | finish no earlier than 2011-09-16 | R2,R4 | 2688h | 2553.6h | FS_SPIA_IDC | PCG-25 | China Mobile | Rel-11 | RP-48 | Joern | LTE 36.816 | RP-110598 |
| 276 | 110 | Study on Inclusion of RF Pattern Matching Technologies as a positioning method in the E-UTRAN | 261d? | 2010-12-10 A | 2011-12-09 | 15% | 221.85d? | 2010-12-10 | 2011-12-09 | 261d? | 260d | finish no earlier than 2011-12-09 | R4 | 2088h | 313.2h | FS_LCS_LTE_RFPMT | PCG-26 | Polaris Wireless | Rel-11 | RP-50 | Issam | LTE 36.809 | RP-110603 |
| 277 | 111 | Study on HetNet mobility enhancements for LTE | 191d? | 2011-03-18 A | 2011-12-09 | 10% | 171.9d? | 2011-03-18 | 2011-12-09 | 191d? | 260d | finish no earlier than 2011-12-09 | R2,R1,R3,R4 | 1528h | 152.8h | FS_HetNet_eMOB_LTE | PCG-26 | Alcatel-Lucent | Rel-11 | RP-51 | Joern | LTE 36.8xy | RP-110604 |
| 278 | 112 | Study on Enhanced Uplink Transmission for LTE | 191d? | 2011-03-18 | 2011-12-09 |  |  | 2011-03-18 | 2011-12-09 | 191d? | 260d | finish no earlier than 2011-12-09 | R1 | 1528h |  | FS_eUL_TX_LTE | PCG-26 | Huawei | Rel-11 | RP-51 | Patrick | LTE 36.8xy | RP-110605 |
| 279 | 113 | Study on further Downlink MIMO enhancements for LTE-Advanced | 191d? | 2011-03-18 A | 2011-12-09 | 5% | 181.45d? | 2011-03-18 | 2011-12-09 | 191d? | 260d | start no earlier than 2011-03-18 | R1 | 1528h | 76.4h | FS_LTE_eDL_MIMO_enh | PCG-26 | Alcatel-Lucent | Rel-11 | RP-51 | Patrick | LTE 36.8xy | RP-110607 |
| 280 | 114 | Study on Interference analysis between 800~900 MHz bands | 131d? | 2011-03-18 | 2011-09-16 |  |  | 2011-03-18 | 2011-09-16 | 131d? | 320d | finish no earlier than 2011-09-16 | R4 | 1048h |  | FS_B800_B900_Interf_LTE | PCG-26 | LG Uplus | Rel-11 | RP-51 | Issam | LTE 36.8xy | RP-110608 |
| 281 | 115 | Study on Further Enhancements to LTE TDD for DL-UL Interference Management and Traffic Adaptation | 261d? | 2011-03-18 | 2012-03-16 |  |  | 2011-03-18 | 2012-03-16 | 261d? | 190d | finish no earlier than 2012-03-16 | R1,R4 | 2088h |  | FS_LTE_TDD_eIMTA | PCG-26 | CATT | Rel-11 | RP-51 | Patrick | LTE 36.8xy | RP-110609 |
| 282 | 116 | Study on Measurement of Radiated Performance for MIMO and multi-antenna reception for HSPA and LTE terminals | 651.8d? | 2009-03-06 A | 2011-12-09 | 65% | 228.13d? | 2009-03-06 | 2011-12-09 | 651.8d? | 260d | finish no earlier than 2011-12-09 | R4 | 5214.4h | 3389.37h | FS_HSPA_LTE_measRP_MIMO_multi-antenna | PCG-22 | Vodafone | Rel-11 | RP-43 | Issam | UTRA, LTE 37.976 | RP-110594 |
| 283 | 117 | Study on Extending 850 MHz | 601d? | 2009-05-30 A | 2011-09-16 | 75% | 150.25d? | 2009-05-30 | 2011-09-16 | 601d? | 320d | finish no earlier than 2011-09-16 | R4 | 4808h | 3606h | FS_e850 | PCG-23 | Ericsson | Rel-11 | RP-44 | Issam | UTRA, LTE 37.806 | RP-110595 |
| 284 | 118 | Study on RAN improvements for Machine-Type Communications | 521d? | 2009-09-18 A | 2011-09-16 | 45% | 286.55d? | 2009-09-18 | 2011-09-16 | 521d? | 320d | finish no earlier than 2011-09-16 | R2,R1,R3,R4 | 4168h | 1875.6h | FS_NIMTC_RAN | PCG-23 | Huawei | Rel-11 | RP-45 | Joern | UTRA, LTE 37.868 | RP-110596 |
| 285 | 119 | Study on UE Application Layer Data Throughput Performance | 200d? | 2010-12-10 A | 2011-09-15 | 60% | 80d? | 2010-12-10 | 2011-09-15 | 200d? | 321d | finish no earlier than 2011-09-15 | R5,R4 | 1600h | 960h | FS_UE_App_Data_Perf | PCG-26 | Spirent | Rel-11 | RP-50 | Ingbert | UTRA, LTE 37.901 | RP-110600 |
| 286 | 120 | Study on further enhancements for HNB and HeNB | 191d? | 2011-03-18 A | 2011-12-09 | 10% | 171.9d? | 2011-03-18 | 2011-12-09 | 191d? | 260d | start no earlier than 2011-03-18 | R3,R2 | 1528h | 152.8h | FS_EHNB_enh | PCG-26 | Alcatel-Lucent | Rel-11 | RP-51 | Juha | UTRA, LTE 37.8xy | RP-110606 |
| 287 | 121 | Study on Uplink MIMO | 200d? | 2010-12-10 A | 2011-09-15 | 80% | 40d? | 2010-12-10 | 2011-09-15 | 200d? | 321d | finish no earlier than 2011-09-15 | R1 | 1600h | 1280h | FS_UTRA_UL_MIMO | PCG-26 | Qualcomm | Rel-11 | RP-50 | Patrick | UTRA 25.8xy | RP-110601 |
| 288 | 122 | Study on HSDPA Multipoint Transmission | 201d? | 2010-12-10 A | 2011-09-16 | 80% | 40.2d? | 2010-12-10 | 2011-09-16 | 201d? | 320d | finish no earlier than 2011-09-16 | R1,R2,R3 | 1608h | 1286.4h | FS_HSDPA_MP_TX | PCG-26 | Nokia Siemens Networks | Rel-11 | RP-50 | Patrick | UTRA 25.872 | RP-110602 |
| 289 | 123 | Study on UMTS/LTE in 900 MHz band (Japan, Korea) | 75d? | 2011-06-03 | 2011-09-15 |  |  | 2011-06-03 | 2011-09-15 | 75d? | 321d | finish no earlier than 2011-09-15 | R4 | 600h |  | FS_UTRA_LTE_900MHz | PCG-27 | NTT DoCoMo | Rel-11 | SP-52 | Issam | UTRA, LTE 37.8xy |  |
| 290 | 124 | Release 10 Features | 295.2d? | 2008-12-11 A | 2011-06-08 | 80% | 59.04d? | 2008-12-11 | 2011-06-08 | 295.2d? | 392d | finish no earlier than 2011-06-08 | CP,GP,RP,SP | 2361.6h | 1889.28h |  |  |  | Rel-10 |  |  |  |  |

Notes:
- 254: -
- 255: SA1 is expected to provide inputs on scenarios, use cases and requirements before SA#54 / Text5: SA2 Zaifeng Zong (zong.zaifeng@zte.com.cn), SA1 Mian Li (Li.Mian@zte.com.cn)
- 256: - / Text5: Hui Cai (Sarah.Cai@huawei.com)
- 257: SP#52 completion 06/11=>09/11. SP#50 TR 33.859 v100 for Information / Text5: karl.norrman@ericsson.com
- 258: SP#52 completion 06/11=>09/11. Continuation of Rel-9 Feature UID_430036 IMS Media Plane Security (MEDIASEC). Study solutions and extensions to features and functionality described in TR 33.828 and TS 33.328. / Text5: peter.howard@vodafone.com
- 259: SP#52 TR 33.914 v100 for Information. Completion 06/11=>09/11. Study reuse of non-UICC credentials (in particular SIP Digest) to provide security for the access to applications. Provide reference material for IMS based non-UICC based SSO to applications / Text5: Silke.Holtmanns@nokia.com
- 260: Linked to SA1 FS_SSO_Int (Study Integration of SSO frameworks with 3GPP networks),SA3 FS_SSO_APS (Study SSO Application Security for IMS - based on SIP Digest),GBA-IdM (33.924),LIBSEC (33.980 Interworking of Liberty Alliance IFF, Identity Web SF and GAA) / Text5: vesa.lehtovirta@ericsson.com
- 261: Extends Rel-10 work on 3D video formats UID_480044 Improved Video Coding Support for PSS and MBMS / Text5: gilles.teniou@orange-ftgroup.com
- 262: SP#52 completion 06/11=>12/11 / Text5: thomas.tovinger@ericsson.com
- 263: SP#51 moved to Rel-11. Completion 03/11=>12/11 / Text5: olaf.pollakowski@nsn.com
- 264: SP#51 updated WID SP-100502=>SP-110127. Completion 03/11=>12/11 (moved to Rel-11) / Text5: Nick Mazzarella (njmazzarella@alcatel-lucent.com)
- 265: Triggered by Rel-10 UID_430044 TR 32.826 Study on Telecommunication Management; Energy Savings Management (FS_OAM_ESM) and UID_470037 OAM aspects of Energy Saving in Radio Networks (OAM-ES) / Text5: clemens.suerbaum@nsn.com
- 266: - / Text5: yunxi.li@ericsson.com
- 267: CP#52 completed. Linked to SA5 UID_430044 (FS_OAM-ESM) & UID_470037 (OAM-ES), RAN3 UID_470015 (FS_Energy_LTE), RAN1 UID_460016 (FS_Energy_UMTS) / Text5: gottfried.punz@nw.neclab.eu
- 268: Continue work in Rel-11 especially to cover handling of Idle mode Signalling Reduction (ISR). Linked to SA2 UID_490036 Study on Core Network Overload solutions / Text5: lu.fei1@zte.com.cn
- 269: GP#50 completion 09/11=>03/12. GP#44 approved WID / Text5: paul.schliwa-bertling@ericsson.com
- 270: GP#50 completion 09/11=>11/11. GP#46 approved WID. Precoded EGPRS2 DL provides significant performance gains for EGPRS2 (in interference and sensitivity limited scenarios, allowing significant increase to data capacity and spectral efficiency) / Text5: marten.sundberg@ericsson.com
- 271: GP#47 approved WID / Text5: juergen.hofmann@nsn.com, leo.patanapongpibul@vodafone.com
- 272: GP#50 approved WID. Triggered by Rel-8 TR 45.914 Study Multi-User-Reusing One Timeslot (MUROS) UID_50590 and Rel-9 Voice services over Adaptive Multi-user channels on One Slot (VAMOS) UID_420002 / Text5: dengjuan@chinamobile.com, Chao Luo (chluo@huawei.com)
- 273: GP#50 approved WID. Triggered by RAN#51 (Mar 2011) WID in RP-110454 (LTE RAN Enhancements for Diverse Data Applications) UID_510031 / Text5: ming.fang@huawei.com
- 274: RP#52 TR 36.819 v100 for Information / Text5: bruno.clerckx@samsung.com
- 275: RP#52 moved from Rel-10 to Rel-11. TR 36.816 v200 Approved but incomplete Performance analysis of TDM solutions. Study coexistence scenario of LTE and Industrial, Scientific and Medical (ISM) Radio within the same device working in adjacent frequencies / Text5: Zhenping Hu (huzhenping@chinamobile.com)
- 276: LTE RP#51 updated WID RP-101445=>RP-110385. / Text5: Robert Gross (rgross@polariswireless.com)
- 277: LTE RP#52 updated WID RP-110438=>RP-110709 / Text5: Sudeep Palat
- 278: LTE / Text5: Yunzhe Hou
- 279: LTE / Text5: federico.boccardi@alcatel-lucent.com
- 280: LTE / Text5: Koo Yeon Sang (yskoo@lguplus.co.kr)
- 281: LTE / Text5: Zukang Shen (shenzukang@datangmobile.cn)
- 282: UTRA, LTE RP#52 moved from Rel-10 to Rel-11. RP#47 moved from Rel-9 to Rel-10 / Text5: soonleh.ling@vodafone.com
- 283: UTRA, LTE RP#52 moved from Rel-10 to Rel-11. TR 37.806 v100 for Information. RP#47 moved from Rel-9 to Rel-10 / Text5: christian.bergljung@stericsson.com
- 284: RP#52 moved to Rel-11 (No WID change; continue on RAN overload only until 09/11). Triggered by TR 22.868 Study on Facilitating Machine to Machine Communication in GSM and UMTS (M2M) UID_7027 and Rel-10 NIMTC UID_410030 / Text5: Jeff Gao (gaoyq@huawei.com)
- 285: UTRA, LTE RP#52 TR 37.901 v100 for Information / Text5: ron.borsato@spirent.com
- 286: UTRA, LTE / Text5: Martin,Warner@alcatel-lucent.com
- 287: UTRA / Text5: Sharad Sambhwani
- 288: RP#52 TR 25.872 v100 for Information / Text5: karri.ranta-aho@nsn.com
- 289: UTRA, LTE Possible RAN#53 new WI for 900MHz band in Japan and existing SI on interference analysis between 800~900MHz bands in Korea target similar frequencies. Need to study harmonization of new WI between Japan/Korea. / Text5: Masahiro Fujii (fujiima@nttdocomo.co.jp)
- 290: -

| ID | WBS | Task | Duration | Start | Finish | Complete | Remaining | Baseline start | Baseline finish | Baseline duration | Total slack | Constraint | Resources | Work | Actual work | Text1 | Text2 | Text4 | Text5 | Text6 | Text7 | Text8 | Text9 | Text12 | Text11 |
| --- | --- | --- | --- | --- | --- | --- | --- | --- | --- | --- | --- | --- | --- | --- | --- | --- | --- | --- | --- | --- | --- | --- | --- | --- | --- |
| 291 | 125 | **Enhancements for Multimedia Priority Service** | 1311d? | 2006-03-13 A | 2011-03-18 A | 100% |  | 2006-03-13 | 2011-03-18 | 1311d? |  |  | S1,S2,C4,C3,C1 | 28072h | 28072h | eMPS | PCG-21 | Telcordia | jgarraha@telcordia.com | Rel-10 | SP-39 | Alain |  |  |  |
| 292 | 125.1 | Stage 1 on enhancements for Multimedia Priority Service | 584d? | 2006-03-13 A | 2008-06-05 A | 100% |  | 2006-03-13 | 2008-06-05 | 584d? |  | start no earlier than 2006-03-12 | S1 | 4672h | 4672h | ePRIOR | PCG-21 | Telcordia | jgarraha@telcordia.com | Rel-10 | SP-39 | Alain |  |  |  |
| 293 | 125.2 | **Stage 2 on enhancements for Multimedia Priority Service** | 206d? | 2009-12-10 A | 2010-09-23 A | 100% |  | 2009-12-10 | 2010-09-23 | 206d? |  |  | S2 | 6592h | 6592h | eMPS | PCG-24 | Telcordia, NTT DoCoMo | Vijay Varma, Katsutoshi Nishida | Rel-10 | SP-46 | Maurice |  |  |  |
| 294 | 125.2.1 | Stage 2 on eMPS for CSFB | 206d? | 2009-12-10 A | 2010-09-23 A | 100% |  | 2009-12-10 | 2010-09-23 | 206d? |  | finish no earlier than 2010-09-24 | S2 | 1648h | 1648h | eMPS | PCG-24 | Telcordia, NTT DoCoMo | Vijay Varma, Katsutoshi Nishida | Rel-10 | SP-46 | Maurice |  |  |  |
| 295 | 125.2.2 | Stage 2 on eMPS for EPS Bearer Service | 206d? | 2009-12-10 A | 2010-09-23 A | 100% |  | 2009-12-10 | 2010-09-23 | 206d? |  | finish no earlier than 2010-12-09 | S2 | 1648h | 1648h | eMPS | PCG-24 | Telcordia, NTT DoCoMo | Vijay Varma, Katsutoshi Nishida | Rel-10 | SP-46 | Maurice |  |  |  |
| 296 | 125.2.3 | Stage 2 on eMPS for IMS Aspects | 206d? | 2009-12-10 A | 2010-09-23 A | 100% |  | 2009-12-10 | 2010-09-23 | 206d? |  | finish no earlier than 2010-12-09 | S2 | 1648h | 1648h | eMPS | PCG-24 | Telcordia, NTT DoCoMo | Vijay Varma, Katsutoshi Nishida | Rel-10 | SP-46 | Maurice |  |  |  |
| 297 | 125.3 | Deleted - TR 23.854 on Stage 2 on enhancements for Multimedia Priority Service | 266d? | 2009-12-10 A | 2010-12-16 A | 100% |  | 2009-12-10 | 2010-12-16 | 266d? |  | finish no earlier than 2011-03-17 | S2 | 2128h | 2128h | eMPS | PCG-24 | Telcordia, NTT DoCoMo | Vijay Varma, Katsutoshi Nishida | Rel-10 | SP-46 | Maurice | PCG-27 | SP-50 |  |
| 298 | 125.4 | **Stage 3 on enhancements for Multimedia Priority Service** | 131d? | 2010-09-17 A | 2011-03-18 A | 100% |  | 2010-09-17 | 2011-03-18 | 131d? |  |  | C4,C3,C1 | 4192h | 4192h | eMPS-CN | PCG-25 | Ericsson | Philip.hodges@ericsson.com | Rel-10 | CP-49 | Kimmo |  |  |  |
| 299 | 125.4.1 | CT4 part on Stage 3 on enhancements for Multimedia Priority Service | 131d? | 2010-09-17 A | 2011-03-18 A | 100% |  | 2010-09-17 | 2011-03-18 | 131d? |  | start no earlier than 2010-09-17 | C4 | 1048h | 1048h | eMPS-CN | PCG-25 | Ericsson | Philip.hodges@ericsson.com | Rel-10 | CP-49 | Kimmo |  |  |  |
| 300 | 125.4.2 | CT3 part on Stage 3 on enhancements for Multimedia Priority Service | 131d? | 2010-09-17 A | 2011-03-18 A | 100% |  | 2010-09-17 | 2011-03-18 | 131d? |  | start no earlier than 2010-09-17 | C3 | 1048h | 1048h | eMPS-CN | PCG-25 | Ericsson | Philip.hodges@ericsson.com | Rel-10 | CP-49 | Jiwan |  |  |  |
| 301 | 125.4.3 | CT1 part on Stage 3 on enhancements for Multimedia Priority Service | 131d? | 2010-09-17 A | 2011-03-18 A | 100% |  | 2010-09-17 | 2011-03-18 | 131d? |  | start no earlier than 2010-09-17 | C1 | 1048h | 1048h | eMPS-CN | PCG-25 | Ericsson | Philip.hodges@ericsson.com | Rel-10 | CP-49 | Frederic |  |  |  |
| 302 | 126 | **Network Improvements for Machine-Type Communications** | 773d? | 2008-09-18 A | 2011-09-02 | 97% | 23.31d? | 2008-09-18 | 2011-09-02 | 773d? | 330d |  | S1,S2,C1,C4,C3,C6,G2,R2,R3 | 25585.2h | 22055.2h | NIMTC | PCG-21 | KPN | toon.norp@tno.nl | Rel-10 | SP-41 | Alain |  |  |  |
| 303 | 126.1 | Stage 1 for Network Improvements for Machine-Type Communications | 397d? | 2008-09-18 A | 2010-03-25 A | 100% |  | 2008-09-18 | 2010-03-25 | 397d? |  | finish no earlier than 2009-12-10 | S1 | 3176h | 3176h | NIMTC | PCG-21 | KPN | toon.norp@tno.nl | Rel-10 | SP-41 | Alain |  |  |  |
| 304 | 126.2 | Deleted - TR on Stage 2 for Network Improvements for Machine-Type Communications | 321d? | 2009-09-24 A | 2010-12-16 A | 100% |  | 2009-09-24 | 2010-12-16 | 321d? |  | finish no earlier than 2010-11-30 | S2 | 2568h | 2568h | NIMTC | PCG-23 | Samsung | erik.guttman@partner.samsung.com | Rel-10 | SP-45 | Maurice | PCG-26 | SP-50 |  |
| 305 | 126.3 | Stage 2 for Network Improvements for Machine-Type Communications | 19d? | 2010-08-30 A | 2010-09-23 A | 100% |  | 2010-08-30 | 2010-09-23 | 19d? |  | finish no earlier than 2010-09-17 | S2 | 152h | 152h | NIMTC | PCG-23 | Samsung | erik.guttman@partner.samsung.com | Rel-10 | SP-45 | Maurice |  |  |  |
| 306 | 126.4 | Deleted - Security for Network Improvements for Machine-Type Communications | 193.15d? | 2009-12-10 A | 2010-09-23 A | 100% |  | 2009-12-10 | 2010-09-23 | 193.15d? |  | finish no earlier than 2010-09-23 | S3 | 1545.2h | 1545.2h | NIMTC | PCG-24 | Samsung | Rajavelsamy R (rajvel@samsung.com) | Rel-10 | SP-46 | Dionisio | PCG-25 | SP-49 |  |
| 307 | 126.5 | **CN part of Stage 3 for Network Improvements for Machine-Type Communications** | 261d? | 2010-06-04 A | 2011-06-03 A | 100% |  | 2010-06-04 | 2011-06-03 | 261d? |  |  | C1,C4,C3,C6 | 8800h | 8800h | NIMTC | PCG-25 | Ericsson | mikael.wass@ericsson.com | Rel-10 | CP-48 | Frederic |  |  |  |
| 308 | 126.5.1 | CT1 part of Stage 3 for Network Improvements for Machine-Type Communications | 261d? | 2010-06-04 A | 2011-06-03 A | 100% |  | 2010-06-04 | 2011-06-03 | 261d? |  | finish no earlier than 2011-06-03 | C1 | 2088h | 2088h | NIMTC | PCG-25 | Ericsson | mikael.wass@ericsson.com | Rel-10 | CP-48 | Frederic |  |  |  |
| 309 | 126.5.2 | Deleted - CT3 part of Stage 3 for Network Improvements for Machine-Type Communications | 261d? | 2010-06-04 A | 2011-06-03 A | 100% |  | 2010-06-04 | 2011-06-03 | 261d? |  | finish no earlier than 2010-12-10 | C3 | 2088h | 2088h | NIMTC | PCG-25 | Ericsson | mikael.wass@ericsson.com | Rel-10 | CP-48 | Jiwan | PCG-27 | CP-52 |  |
| 310 | 126.5.3 | CT4 part of Stage 3 for Network Improvements for Machine-Type Communications | 261d? | 2010-06-04 A | 2011-06-03 A | 100% |  | 2010-06-04 | 2011-06-03 | 261d? |  | finish no earlier than 2011-03-18 | C4 | 2088h | 2088h | NIMTC | PCG-25 | Ericsson | mikael.wass@ericsson.com | Rel-10 | CP-48 | Kimmo |  |  |  |
| 311 | 126.5.4 | CT6 part of Stage 3 for Network Improvements for Machine-Type Communications | 56d? | 2011-03-18 A | 2011-06-03 A | 100% |  | 2011-03-18 | 2011-06-03 | 56d? |  | finish no earlier than 2011-06-03 | C6 | 448h | 448h | NIMTC | PCG-26 | Sagem-Orga | heiko.kruse@sagem-orga.com | Rel-10 | CP-51 | Xavier |  |  |  |
| 312 | 126.6 | Charging for Network Improvements for Machine-Type Communication | 3d? | 2011-03-21 A | 2011-03-23 A | 100% |  | 2011-03-21 | 2011-03-23 | 3d? |  | start no earlier than 2011-03-21 | S5 | 24h | 24h | NIMTC-CH | PCG-26 | Ericsson | patrik.teppo@@ericsson.com | Rel-10 | SP-51 | Dionisio |  |  |  |
| 313 | 126.7 | GERAN part of Network Improvements for Machine-Type Communications (Stage 3) | 261d? | 2010-09-03 A | 2011-09-02 | 75% | 65.25d? | 2010-09-03 | 2011-09-02 | 261d? | 330d | finish no earlier than 2011-09-02 | G2 | 2088h | 1566h | NIMTC | PCG-25 | Vodafone, Ericsson | leo.patanapongpibul@vodafone.com, john.diachina@ericsson.com | Rel-10 | GP-47 | Gert |  |  |  |
| 314 | 126.8 | RAN mechanisms to avoid CN overload due to Machine-Type Communications | 131d? | 2010-09-17 A | 2011-03-18 A | 100% |  | 2010-09-17 | 2011-03-18 | 131d? |  | finish no earlier than 2011-03-18 | R2,R3 | 1048h | 1048h | NIMTC-RAN_overload | PCG-25 | Huawei | Jeff Gao (gaoyq@huawei.com) | Rel-10 | RP-49 | Joern |  |  | RP-110063 |

Notes:
- 291: CP#51 completed. SP#49 moved Stage 1 from Rel-9 & Completed Stage 2. SP#40 Stage 1 completed. Continuation of Rel-8 Feature PRIOR (UID_340044)
- 292: ePRIOR started Mar 2006 as a Rel-8 Feature. It was delayed to Rel-9 (completed at SP#40), then moved to Rel-10 at SP#49 and demoted to Building Block level. / Text3: 22.153, 22.278
- 293: SP#49 completed. Updated WID SP-100166=>SP-100647
- 294: SP#49 completed / Text3: 23.002, 23.203, 23.221, 23.228, 23.272, 23.401
- 295: SP#49 completed / Text3: 23.002, 23.203, 23.221, 23.228, 23.272, 23.401
- 296: SP#49 completed / Text3: 23.002, 23.203, 23.221, 23.228, 23.272, 23.401
- 297: SP#49 TR 23.854 v100 for Information. SP#50 moved to Rel-11 SRVCC aspect of enhancements for Multimedia Priority Service UID_480135 (place holder for solution alternatives and agreed functions to be reflected in affected existing TS) / Text3: new TR 23.854
- 298: CP#51 completed / Text3: Stage 3
- 299: CP#51 completed / Text3: 23.008, 29.002, 29.228, 29.229, 29.272, 29.274, 29.277, 29.328, 29.329
- 300: CP#51 completed / Text3: 29.212, 29.213, 29.214
- 301: CP#51 completed / Text3: 24.008, 24.229, 24.301
- 302: SP#50 updated WID SP-090832=>SP-100863 (document the SA2 work). SP#49 Security stopped. SP#47 Stage 1 completed. Triggered by Rel-8 UID_7027 Study on Facilitating Machine to Machine Communication in GSM and UMTS (FS_M2M) TR 22.868
- 303: SA#47 completed / Text3: 22.011, new 22.368
- 304: SP#50 updated WID SP-090832=>SP-100863 (TR 23.888 not submitted for approval to conclude Rel-10 NIMTC as it will continue to serve as basis for Rel-11 SIMTC work item) / Text3: new TR 23.888
- 305: SP#49 completed. SP#50 updated WID SP-090832=>SP-100863 (document the SA2 work) / Text3: 23.060, 23.236, 23.401
- 306: SP#49 stopped (activity moved to Rel-11 under UID_490028 TR on Security aspects of System Improvements to Machine-Type Communications (SIMTC) / Text3: new 33.868
- 307: CP#52 completed. Updated WID CP-110147=>CP-110442 (SA2 decided to move impact from CT3 to CT4) / Text3: Stage 3
- 308: CP#52 completed / Text3: 23.122, 24.008, 24.301, new 24.368
- 309: CP#52 stopped (SA2 decided to move impact from CT3 to CT4). Updated WID CP-110147=>CP-110442 (no CT3 impact) / Text3: 29.212, 29.213, 29.215
- 310: CP#52 completed. SA2 decided to move impact from CT3 to CT4. Change of mind set in SA/SA2 impacts from Gx changed back to S5/S8 PMIP / Text3: 23.003, 23.008, 29.002, 29.060, 29.230, 29.272, 29.274, 29.275, 29.282
- 311: CP#52 completed. Work on (U)SIM OTA support of low priority configuration, Device binding between USIM and MTC device & USIM aspects of EAB / Text3: 31.102
- 312: SP#51 completed / Text3: 32.251, 32.298, 32.299
- 313: GP#50 completion 05/11=>09/11. GP#49 Exception in GP-110506. GP#47 approved WID / Text3: 44.018, 44.060
- 314: Stage 3. RP#51 completed / Text3: UTRA, LTE 25.331, 25.413, 36.331, 36.413

| ID | WBS | Task | Duration | Start | Finish | Complete | Remaining | Baseline start | Baseline finish | Baseline duration | Total slack | Constraint | Resources | Work | Actual work | Text1 | Text2 | Text4 | Text6 | Text7 | Text8 |
| --- | --- | --- | --- | --- | --- | --- | --- | --- | --- | --- | --- | --- | --- | --- | --- | --- | --- | --- | --- | --- | --- |
| 315 | 127 | **Multi Access PDN Connectivity** | 527d? | 2009-03-13 A | 2011-03-18 A | 100% |  | 2009-03-13 | 2011-03-18 | 527d? |  |  | S2,C4,C1,C3 | 9592h | 9592h | MAPCON | PCG-22 | Telecom Italia | Rel-10 | SP-43 | Maurice |
| 316 | 127.1 | Stage 2 for Multi Access PDN Connectivity | 401d? | 2009-03-13 A | 2010-09-23 A | 100% |  | 2009-03-13 | 2010-09-23 | 401d? |  |  | S2 | 3208h | 3208h | MAPCON |  | Telecom Italia | Rel-10 |  | Maurice |
| 317 | 127.2 | **CT aspects of Multi Access PDN Connectivity** | 90d? | 2010-11-15 A | 2011-03-18 A | 100% |  | 2010-11-15 | 2011-03-18 | 90d? |  |  | C4,C1,C3 | 2168h | 2168h | MAPCON-St3 | PCG-26 | ZTE | Rel-10 | CP-50 | Kimmo |
| 318 | 127.2.1 | CT4 aspects of Multi Access PDN Connectivity | 20d? | 2010-11-15 A | 2010-12-10 A | 100% |  | 2010-11-15 | 2010-12-10 | 20d? |  | start no earlier than 2010-12-10 | C4 | 160h | 160h | MAPCON-St3 | PCG-26 | ZTE | Rel-10 | CP-50 | Kimmo |
| 319 | 127.2.2 | CT1 aspects of Multi Access PDN Connectivity | 71d? | 2010-12-10 A | 2011-03-18 A | 100% |  | 2010-12-10 | 2011-03-18 | 71d? |  | start no earlier than 2010-12-10 | C1 | 568h | 568h | MAPCON-St3 | PCG-26 | ZTE | Rel-10 | CP-50 | Frederic |
| 320 | 127.2.3 | CT3 aspects of Multi Access PDN Connectivity | 90d? | 2010-11-15 A | 2011-03-18 A | 100% |  | 2010-11-15 | 2011-03-18 | 90d? |  | finish no earlier than 2011-03-18 | C3 | 720h | 720h | MAPCON-St3 | PCG-26 | ZTE | Rel-10 | CP-50 | Jiwan |
| 321 | 128 | **IMS Service Continuity – Inter Device Transfer enhancements** | 657d? | 2009-06-04 A | 2011-12-09 | 70% | 200.21d? | 2009-06-04 | 2011-12-09 | 657d? | 260d |  | S1,S2,C1,IETF | 13040h | 6585.6h | IMS_SC_eIDT | PCG-23 | Huawei | Rel-10 | SP-44 | Alain |
| 322 | 128.1 | Stage 1 - IMS Service Continuity – Inter Device Transfer enhancements | 211d? | 2009-06-04 A | 2010-03-25 A | 100% |  | 2009-06-04 | 2010-03-25 | 211d? |  | finish no earlier than 2010-03-25 | S1 | 1688h | 1688h | IMS_SC_eIDT | PCG-23 | Huawei | Rel-10 | SP-44 | Alain |
| 323 | 128.2 | Stage 2 - IMS Inter-UE Transfer enhancements | 261d? | 2009-09-24 A | 2010-09-23 A | 100% |  | 2009-09-24 | 2010-09-23 | 261d? |  | finish no earlier than 2010-09-23 | S2 | 2088h | 2088h | IMS_SC_eIDT | PCG-23 | Huawei | Rel-10 | SP-45 | Maurice |
| 324 | 128.3 | Stage 3 - IMS Inter-UE Transfer enhancements | 261d? | 2010-03-19 A | 2011-03-18 A | 100% |  | 2010-03-19 | 2011-03-18 | 261d? |  | start no earlier than 2010-03-19 | C1 | 2088h | 2088h | IMS_SC_eIDT | PCG-24 | Huawei | Rel-10 | CP-47 | Frederic |
| 325 | 128.4 | (IETF) Stage 3 - IMS Inter-UE Transfer enhancements | 451d? | 2010-03-19 A | 2011-12-09 | 20% | 360.8d? | 2010-03-19 | 2011-12-09 | 451d? | 260d | finish no earlier than 2011-12-09 | C1-IETF | 3608h | 721.6h | IMS_SC_eIDT | PCG-27 | Huawei | Rel-10 | CP-52 | Frederic |
| 326 | 129 | **IP-Short-Message-Gateway enhancements for CPM-SMS Interworking** | 257d? | 2009-09-24 A | 2010-09-17 A | 100% |  | 2009-09-24 | 2010-09-17 | 257d? |  |  | S1,S2,C3 | 5792.8h | 5792.8h | CPM-SMS | PCG-23 | China Mobile | Rel-10 | SP-45 | Alain |
| 327 | 129.1 | Stage 1 for CPM-SMS | 131d? | 2009-09-24 A | 2010-03-25 A | 100% |  | 2009-09-24 | 2010-03-25 | 131d? |  | finish no earlier than 2010-03-25 | S1 | 1048h | 1048h | CPM-SMS | PCG-23 | China Mobile | Rel-10 | SP-45 | Alain |
| 328 | 129.2 | Stage 2 for CPM-SMS | 130.1d? | 2009-09-24 A | 2010-03-25 A | 100% |  | 2009-09-24 | 2010-03-25 | 130.1d? |  | finish no earlier than 2010-03-25 | S2 | 1040.8h | 1040.8h | CPM-SMS | PCG-23 | Orange | Rel-10 | SP-45 | Maurice |
| 329 | 129.3 | Stage 3 for IP-Short-Message-Gateway enhancements for CPM-SMS Interworking | 206d? | 2009-12-04 A | 2010-09-17 A | 100% |  | 2009-12-04 | 2010-09-17 | 206d? |  | finish no earlier than 2010-09-17 | C3 | 1648h | 1648h | CPM-SMS | PCG-24 | Ericsson | Rel-10 | CP-46 | Jiwan |
| 330 | 130 | **Completion of Communications on Not Logged-in** | 387d? | 2009-09-24 A | 2011-03-18 A | 100% |  | 2009-09-24 | 2011-03-18 | 387d? |  |  | S1,C1,C3 | 5800h | 5800h | CCNL | PCG-23 | Deutsche Telekom | Rel-10 | SP-45 | Alain |
| 331 | 130.1 | Stage 1 for Completion of Communications on Not Logged-in | 1d? | 2009-09-24 A | 2009-09-24 A | 100% |  | 2009-09-24 | 2009-09-24 | 1d? |  | start no earlier than 2009-09-24 | S1 | 8h | 8h | CCNL | PCG-23 | Deutsche Telekom | Rel-10 | SP-45 | Alain |
| 332 | 130.2 | CT1 part of Stage 3 for Completion of Communications on Not Logged-in | 261d? | 2010-03-19 A | 2011-03-18 A | 100% |  | 2010-03-19 | 2011-03-18 | 261d? |  | finish no earlier than 2011-03-18 | C1 | 2088h | 2088h | CCNL | PCG-24 | Deutsche Telekom | Rel-10 | CP-47 | Frederic |
| 333 | 130.3 | CT3 part of Stage 3 for Completion of Communications on Not Logged-in | 76d? | 2010-06-04 A | 2010-09-17 A | 100% |  | 2010-06-04 | 2010-09-17 | 76d? |  | finish no earlier than 2010-09-17 | C3 | 608h | 608h | CCNL | PCG-25 | Deutsche Telekom | Rel-10 | CP-48 | Jiwan |
| 334 | 131 | **Local IP Access and Selected Internet IP Traffic Offload** | 390d? | 2009-09-24 A | 2011-03-23 A | 100% |  | 2009-09-24 | 2011-03-23 | 390d? |  |  | S2,S1,S3,S5,C4,C1 | 28656h | 28656h | LIPA_SIPTO | PCG-23 | Huawei, China Mobile | Rel-10 | SP-45 | Maurice |
| 335 | 131.1 | Stage 1 for Local IP Access and Selected Internet IP Traffic Offload | 131d? | 2009-09-24 A | 2010-03-25 A | 100% |  | 2009-09-24 | 2010-03-25 | 131d? |  | finish no earlier than 2010-03-25 | S1 | 1048h | 1048h | LIPA_SIPTO | PCG-23 | Huawei, China Mobile | Rel-10 | SP-45 | Alain |
| 336 | 131.2 | TR on Local IP Access and Selected Internet IP Traffic Offload | 387d? | 2009-09-24 A | 2011-03-18 A | 100% |  | 2009-09-24 | 2011-03-18 | 387d? |  | finish no earlier than 2011-03-18 | S2 | 3096h | 3096h | LIPA_SIPTO | PCG-23 | Huawei, China Mobile | Rel-10 | SP-45 | Maurice |
| 337 | 131.3 | Security for Local IP Access and Selected Internet IP Traffic Offload | 261d? | 2009-09-24 A | 2010-09-23 A | 100% |  | 2009-09-24 | 2010-09-23 | 261d? |  | finish no earlier than 2010-09-23 | S3 | 2088h | 2088h | LIPA_SIPTO | PCG-23 | Huawei, Qualcomm | Rel-10 | SP-45 | Dionisio |
| 338 | 131.4 | OAM&P for Local IP Access and Selected Internet IP Traffic Offload | 390d? | 2009-09-24 A | 2011-03-23 A | 100% |  | 2009-09-24 | 2011-03-23 | 390d? |  | finish no earlier than 2011-03-23 | S5 | 3120h | 3120h | LIPA_SIPTO | PCG-23 | Huawei, China Mobile | Rel-10 | SP-45 | Dionisio |
| 339 | 131.5 | Charging for Local IP Access and Selected Internet IP Traffic Offload | 335d? | 2009-12-10 A | 2011-03-23 A | 100% |  | 2009-12-10 | 2011-03-23 | 335d? |  | finish no earlier than 2011-03-23 | S5 | 2680h | 2680h | LIPA_SIPTO | PCG-24 | Huawei, China Mobile | Rel-10 | SP-46 | Dionisio |
| 340 | 131.6 | Stage 2 for Local IP Access | 261d? | 2009-09-24 A | 2010-09-23 A | 100% |  | 2009-09-24 | 2010-09-23 | 261d? |  | finish no earlier than 2010-08-10 | S2 | 2088h | 2088h | LIPA | PCG-23 | Huawei, China Mobile | Rel-10 | SP-45 | Maurice |

Notes:
- 315: CP#51 completed. SP#49 Stage 2 completed. Triggered by TR 23.861 UID_410043 FS_MAPIM. Stage 1 in Rel-9 22.278 (6.2 - IP session control) / Text5: ivano.guardini@telecomitalia.it
- 316: SP#49 completed. Triggered by TR 23.861 UID_410043 FS_MAPIM. Stage 1 in Rel-9 22.278 (6.2 - IP session control) / Text3: 23.237, 23.401, 23.402 / Text5: ivano.guardini@telecomitalia.it
- 317: CP#51 completed / Text5: Xingyue (Joy) Zhou (zhou.xingyue@zte.com.cn)
- 318: CP#50 completed / Text3: 29.273, 29.272, 29.002, 23.008 / Text5: Xingyue (Joy) Zhou (zhou.xingyue@zte.com.cn)
- 319: CP#51 completed / Text3: 24.302, 24.312 / Text5: Xingyue (Joy) Zhou (zhou.xingyue@zte.com.cn)
- 320: CP#51 completed / Text3: 29.215 / Text5: Xingyue (Joy) Zhou (zhou.xingyue@zte.com.cn)
- 321: CP#51 completed. SP#47 Stage 1 completed. Rel-9 set Inter-Device Transfer requirements UID_410033 (IMS_SCC-IDT). Adds IDT scenarios and requirements / Text5: Amar Deol (adeol@huawei.com)
- 322: SA#47 completed / Text3: 22.228 / Text5: Amar Deol (adeol@huawei.com)
- 323: SP#49 completed / Text3: 23.237, 23.292, new 23.831 / Text5: Lee Valerius (lvalerius@huawei.com)
- 324: CP#51 completed. WID updated CP-100334=>CP-110285 / Text3: 24.216, 24.229, 24.237, new (24.837, 24.337) / Text5: georg.mayer@huawei.com
- 325: Not completed internet-draft / Text3: draft-holmberg-sipcore-proxy-feature
- 326: SP#47 Stage 1 completed. IP-SM-GW enhancements for interworking with OMA CPM / Text5: Qing Huang (huangqing@chinamobile.com)
- 327: SA#47 completed. External requirements (Stage 1 in OMA-RD-CPM-V1_0-20090310-C) / Text3: 22.340 / Text5: Qing Huang
- 328: SP#47 completed / Text3: 23.204, new TR 23.824 / Text5: antoine.mouquet@orange-ftgroup.com
- 329: CP#49 completed. Linked to Rel-8 UID_340031 Service-Level Interworking for Messaging Services (MESSIW) 23.204 / Text3: 29.311 / Text5: Jan Holm
- 330: CP#51 completed. SP#45 Stage 1 completed / Text5: Kurt Bischinger
- 331: SP#45 completed / Text3: 22.173 CR#0056r1 / Text5: Kurt Bischinger
- 332: CP#51 completed / Text3: 24.173, 24.642 / Text5: martin.huelsemann@telekom.de
- 333: CP#49 completed / Text3: 29.165 / Text5: martin.huelsemann@telekom.de
- 334: TSG#51 completed. Updated WID SP-100696=>SP-110131. SP#49 Stage 2 & Security completed. UID_400035 Enhanced Home NodeB/eNodeB (EHNB) formerly covered Local IP Access to Internet and Local access to Home Network from the Home NodeB/eNodeB / Text5: patrice.hede@huawei.com, Tao Sun (suntao@chinamobile.com)
- 335: SP#47 completed / Text3: 22.101, 22.220 / Text5: Amar Deol (adeolf@huawei.com), Gang Li (ligangyf@chinamobile.com)
- 336: SP#51 completed. TR 23.829 for Approval / Text3: new TR 23.829 / Text5: patrice.hede@huawei.com, Tao Sun (suntao@chinamobile.com)
- 337: SP#49 completed / Text3: 33.102, 33.107, 33.108, 33.320, 33.401 / Text5: Marcus Wong (mwong@huawei.com), Brian Rosenberg (bmr@qualcomm.com)
- 338: SP#51 completed. Updated WID SP-100696=>SP-110131 / Text3: 32.581, 32.582, 32.584, 32.591, 32.592, 32.642, 32.646, 32.772, 32.782 / Text5: Zou Lan (zlan@huawei.com), Chen Gang (chengang@chinamobile.com)
- 339: SP#51 completed. Updated WID SP-100696=>SP-110131 / Text3: 32.251 / Text5: shan.mingjun@huawei.com, Ai Chen (chenai@chinamobile.com)
- 340: SP#49 completed (has impacts to RAN) / Text3: 23.060, 23.401 / Text5: patrice.hede@huawei.com, Tao Sun (suntao@chinamobile.com)

| ID | WBS | Task | Duration | Start | Finish | Complete | Baseline start | Baseline finish | Baseline duration | Constraint | Resources | Work | Actual work | Text1 | Text2 | Text4 | Text5 | Text6 | Text7 | Text8 |
| --- | --- | --- | --- | --- | --- | --- | --- | --- | --- | --- | --- | --- | --- | --- | --- | --- | --- | --- | --- | --- |
| 341 | 131.7 | **Stage 3 for Local IP Access** | 206d? | 2010-06-04 A | 2011-03-18 A | 100% | 2010-06-04 | 2011-03-18 | 206d? |  | C4,C1 | 4944h | 4944h | LIPA | PCG-25 | China Mobile | Zhang Hao (zhanghao@chinamobile.com) | Rel-10 | CP-48 | Kimmo |
| 342 | 131.7.1 | CT4 part of Stage 3 for Local IP Access | 206d? | 2010-06-04 A | 2011-03-18 A | 100% | 2010-06-04 | 2011-03-18 | 206d? | finish no earlier than 2011-03-18 | C4 | 1648h | 1648h | LIPA | PCG-25 | China Mobile | Zhang Hao (zhanghao@chinamobile.com) | Rel-10 | CP-48 | Kimmo |
| 343 | 131.7.2 | CT1 part of Stage 3 for Local IP Access | 206d? | 2010-06-04 A | 2011-03-18 A | 100% | 2010-06-04 | 2011-03-18 | 206d? | finish no earlier than 2011-03-18 | C1 | 1648h | 1648h | LIPA | PCG-25 | China Mobile | Zhang Hao (zhanghao@chinamobile.com) | Rel-10 | CP-48 | Frederic |
| 344 | 131.8 | Stage 2 for SIPTO for macro networks | 261d? | 2009-09-24 A | 2010-09-23 A | 100% | 2009-09-24 | 2010-09-23 | 261d? | finish no earlier than 2010-09-23 | S2 | 2088h | 2088h | SIPTO | PCG-23 | Huawei, China Mobile | patrice.hede@huawei.com, Tao Sun (suntao@chinamobile.com) | Rel-10 | SP-45 | Maurice |
| 345 | 131.9 | **Stage 3 for SIPTO for macro networks** | 206d? | 2010-06-04 A | 2011-03-18 A | 100% | 2010-06-04 | 2011-03-18 | 206d? |  | C4,C1 | 4384h | 4384h | SIPTO | PCG-25 | Huawei | Caixia Qi (qcxmay@huawei.com) | Rel-10 | CP-48 | Kimmo |
| 346 | 131.9.1 | CT4 part of Stage 3 for SIPTO for macro networks | 206d? | 2010-06-04 A | 2011-03-18 A | 100% | 2010-06-04 | 2011-03-18 | 206d? | finish no earlier than 2011-03-18 | C4 | 1648h | 1648h | SIPTO | PCG-25 | Huawei | Caixia Qi (qcxmay@huawei.com) | Rel-10 | CP-48 | Kimmo |
| 347 | 131.9.2 | CT1 part of Stage 3 for SIPTO for macro networks | 136d? | 2010-06-04 A | 2010-12-10 A | 100% | 2010-06-04 | 2010-12-10 | 136d? | finish no earlier than 2011-03-18 | C1 | 1088h | 1088h | SIPTO | PCG-25 | Huawei | Caixia Qi (qcxmay@huawei.com) | Rel-10 | CP-48 | Frederic |
| 348 | 132 | **IP Flow Mobility and seamless WLAN offload** | 390d? | 2009-09-24 A | 2011-03-23 A | 100% | 2009-09-24 | 2011-03-23 | 390d? |  | S2,S1,S5,C1,C3 | 12680h | 12680h | IFOM | PCG-23 | Qualcomm | Gerardo Giaretta (gerardo@qualcomm.com) | Rel-10 | SP-45 | Maurice |
| 349 | 132.1 | Stage 1 for IP Flow Mobility and seamless WLAN offload | 56d? | 2009-09-24 A | 2009-12-10 A | 100% | 2009-09-24 | 2009-12-10 | 56d? | finish no earlier than 2009-12-10 | S1 | 448h | 448h | IFOM | PCG-23 | Qualcomm | David Williams (dwilliam@qualcomm.com) | Rel-10 | SP-45 | Alain |
| 350 | 132.2 | Stage 2 for IP Flow Mobility and seamless WLAN offload | 261d? | 2009-09-24 A | 2010-09-23 A | 100% | 2009-09-24 | 2010-09-23 | 261d? | finish no earlier than 2010-09-23 | S2 | 2088h | 2088h | IFOM | PCG-23 | Qualcomm | Gerardo Giaretta (gerardo@qualcomm.com) | Rel-10 | SP-45 | Maurice |
| 351 | 132.3 | Charging for IP Flow Mobility and seamless WLAN offload | 260d? | 2010-03-25 A | 2011-03-23 A | 100% | 2010-03-25 | 2011-03-23 | 260d? | finish no earlier than 2011-03-23 | S5 | 2080h | 2080h | IFOM | PCG-24 | Alcatel-Lucent | maryse.gardella@alcatel-lucent.com | Rel-10 | SP-47 | Dionisio |
| 352 | 132.4 | **Stage 3 for IP Flow Mobility and seamless WLAN offload** | 206d? | 2010-06-04 A | 2011-03-18 A | 100% | 2010-06-04 | 2011-03-18 | 206d? |  | C1,C3 | 4944h | 4944h | IFOM-CT | PCG-25 | Qualcomm | Patrick Stupar (pstupar@qualcomm.com) | Rel-10 | CP-48 | Frederic |
| 353 | 132.4.1 | CT1 part of Stage 3 for IP Flow Mobility and seamless WLAN offload | 206d? | 2010-06-04 A | 2011-03-18 A | 100% | 2010-06-04 | 2011-03-18 | 206d? | finish no earlier than 2011-03-18 | C1 | 1648h | 1648h | IFOM-CT | PCG-25 | Qualcomm | Patrick Stupar (pstupar@qualcomm.com) | Rel-10 | CP-48 | Frederic |
| 354 | 132.4.2 | CT3 part of Stage 3 for IP Flow Mobility and seamless WLAN offload | 206d? | 2010-06-04 A | 2011-03-18 A | 100% | 2010-06-04 | 2011-03-18 | 206d? | finish no earlier than 2011-03-18 | C3 | 1648h | 1648h | IFOM-CT | PCG-25 | Qualcomm | Patrick Stupar (pstupar@qualcomm.com) | Rel-10 | CP-48 | Jiwan |
| 355 | 133 | **Enabling Coder Selection and Rate Adaptation for UTRAN and E-UTRAN for Load Adaptive Applications** | 442d? | 2009-09-24 A | 2011-06-03 A | 100% | 2009-09-24 | 2011-06-03 | 442d? |  | S2,S4,C4,C3,C1 | 16664h | 16664h | ECSRA_LAA | PCG-23 | Qualcomm | AC Mahendran (ac@qualcomm.com) | Rel-10 | SP-45 | Maurice |
| 356 | 133.1 | TR on Enabling Coder Selection and Rate Adaptation for UTRAN and E-UTRAN for Load Adaptive Applications | 186d? | 2009-09-24 A | 2010-06-10 A | 100% | 2009-09-24 | 2010-06-10 | 186d? | finish no earlier than 2010-09-23 | S2,S4 | 1488h | 1488h | ECSRA_LAA | PCG-23 | Qualcomm | AC Mahendran (ac@qualcomm.com) | Rel-10 | SP-45 | Maurice |
| 357 | 133.2 | SA4 review of TR on Enabling Coder Selection and Rate Adaptation for UTRAN and E-UTRAN for Load Adaptive Applications | 320d? | 2009-09-24 A | 2010-12-15 A | 100% | 2009-09-24 | 2010-12-15 | 320d? | finish no earlier than 2010-12-15 | S4 | 2560h | 2560h | ECSRA_LAA | PCG-23 | Qualcomm | AC Mahendran (ac@qualcomm.com) | Rel-10 | SP-45 | Paolo |
| 358 | 133.3 | Stage 2 for Enabling Coder Selection and Rate Adaptation for UTRAN and E-UTRAN for Load Adaptive Applications | 261d? | 2009-09-24 A | 2010-09-23 A | 100% | 2009-09-24 | 2010-09-23 | 261d? | finish no earlier than 2010-09-23 | S2 | 2088h | 2088h | ECSRA_LAA | PCG-23 | Qualcomm | AC Mahendran (ac@qualcomm.com) | Rel-10 | SP-45 | Maurice |
| 359 | 133.4 | SA4 aspects of Enabling Coder Selection and Rate Adaptation for UTRAN and E-UTRAN for Load Adaptive Applications | 130d? | 2010-09-23 A | 2011-03-23 A | 100% | 2010-09-23 | 2011-03-23 | 130d? | finish no earlier than 2011-03-23 | S4 | 1040h | 1040h | ECSRA_LAA | PCG-25 | Qualcomm | AC Mahendran (ac@qualcomm.com) | Rel-10 | SP-49 | Paolo |
| 360 | 133.5 | **CN aspects of Enabling Coder Selection and Rate Adaptation for UTRAN and E-UTRAN for Load Adaptive Applications** | 186d? | 2010-09-17 A | 2011-06-03 A | 100% | 2010-09-17 | 2011-06-03 | 186d? |  | C4,C3,C1 | 5952h | 5952h | ECSRA_LAA-CN | PCG-25 | Ericsson | Philip.hodges@ericsson.com | Rel-10 | CP-49 | Kimmo |
| 361 | 133.5.1 | CT4 part of CN aspects of Enabling Coder Selection and Rate Adaptation for UTRAN and E-UTRAN for Load Adaptive Applications | 186d? | 2010-09-17 A | 2011-06-03 A | 100% | 2010-09-17 | 2011-06-03 | 186d? | start no earlier than 2010-09-17 | C4 | 1488h | 1488h | ECSRA_LAA-CN | PCG-25 | Ericsson | Philip.hodges@ericsson.com | Rel-10 | CP-49 | Kimmo |
| 362 | 133.5.2 | CT3 part of CN aspects of Enabling Coder Selection and Rate Adaptation for UTRAN and E-UTRAN for Load Adaptive Applications | 186d? | 2010-09-17 A | 2011-06-03 A | 100% | 2010-09-17 | 2011-06-03 | 186d? | finish no earlier than 2011-06-03 | C3 | 1488h | 1488h | ECSRA_LAA-CN | PCG-25 | Ericsson | Philip.hodges@ericsson.com | Rel-10 | CP-49 | Jiwan |
| 363 | 133.5.3 | CT1 part of CN aspects of Enabling Coder Selection and Rate Adaptation for UTRAN and E-UTRAN for Load Adaptive Applications | 186d? | 2010-09-17 A | 2011-06-03 A | 100% | 2010-09-17 | 2011-06-03 | 186d? | start no earlier than 2010-09-17 | C1 | 1488h | 1488h | ECSRA_LAA-CN | PCG-25 | Ericsson | Philip.hodges@ericsson.com | Rel-10 | CP-49 | Frederic |
| 364 | 134 | **Extended H(e)NB features** | 467d? | 2008-12-11 A | 2010-09-23 A | 100% | 2008-12-11 | 2010-09-23 | 467d? |  | S1,S2,S3 | 4344h | 4344h | EHNBF | PCG-23 | NEC | joerg.swetina@nw.neclab.eu | Rel-10 | SP-45 | Alain |
| 365 | 134.1 | Stage 1 of Extended H(e)NB features | 131d? | 2009-09-24 A | 2010-03-25 A | 100% | 2009-09-24 | 2010-03-25 | 131d? | finish no earlier than 2010-03-25 | S1 | 1048h | 1048h | EHNBF | PCG-23 | NEC | joerg.swetina@nw.neclab.eu | Rel-10 | SP-45 | Alain |
| 366 | 134.2 | IMS aspects of Architecture for Home NodeB | 336d? | 2008-12-11 A | 2010-03-25 A | 100% | 2008-12-11 | 2010-03-25 | 336d? | finish no earlier than 2010-03-25 | S2 | 2688h | 2688h | EHNB-IMS | PCG-22 | Alcatel-Lucent | Nicolas Drevon | Rel-10 | SP-42 | Maurice |
| 367 | 134.3 | Extended H(e)NB Security features (Stage 2) | 76d? | 2010-06-10 A | 2010-09-23 A | 100% | 2010-06-10 | 2010-09-23 | 76d? | finish no earlier than 2010-09-23 | S3 | 608h | 608h | EHNBF-Sec | PCG-25 | Huawei | Marcus Wong (mwong@huawei.com) | Rel-10 | SP-48 | Dionisio |

Notes:
- 341: CP#51 completed
- 342: CP#51 completed / Text3: 23.008, 23.015, 29.002, 29.060, 29.272, 29.274, 29.281, 29.303
- 343: CP#51 completed / Text3: 24.008, 24.301
- 344: SP#49 completed (SIPTO GW selection for wild card APN and for GERAN. Serving-GW selection for SIPTO. Corrections and Clarifications of the SIPTO procedure) / Text3: 23.060, 23.401
- 345: CP#51 completed. Updated WID CP-100419=>CP-110091
- 346: CP#51 completed. Updated WID CP-100419=>CP-110091 / Text3: 23.003, 23.008, 29.002, 29.272, 29.303
- 347: CP#50 completed / Text3: 24.008, 24.301
- 348: Triggered by Rel-10 TR 23.861 (UID_410043 Study on Multi Access PDN connectivity and IP flow mobility - MAPIM)
- 349: SP#46completed / Text3: 22.278
- 350: SP#49 completed / Text3: 23.203, 23.402, new 23.261
- 351: SP#51 completed / Text3: 32.240, 32.251, 32.252, 32.298, 32.299
- 352: CP#51 completed / Text3: Stage 3
- 353: CP#51 completed / Text3: 24.008, 24.301, 24.302, 24.303, 24.312, 24.327
- 354: CP#51 completed / Text3: 29.212, 29.213, 29.214, 29.215
- 355: CP#52 completed. SP#49 SA2 completed. Triggered by Rel-9 UID_440013 Vocoder rate adaptation for LTE / Text3: UTRA, LTE
- 356: SP#48 completed / Text3: new 23.860
- 357: SP#50 completed / Text3: new 23.860
- 358: SP#49 completed / Text3: 23.060, 23.203, 23.228, 23.401
- 359: SP#51 completed / Text3: 26.114
- 360: CP#51 completion 03/11=>06/11 (exception in CP-110272) / Text3: Stage 2/3
- 361: CP#52 completed / Text3: 23.334, 29.334, 29.238, 23.333, 29.333, 29.232, 29.332
- 362: CP#52 completed / Text3: 29.162, 29.163, 29.213, 29.235, 29.292
- 363: CP#52 completed / Text3: 24.229
- 364: SP#49 completed. Adds extensions to Rel-9 functionality in UID_400035 Enhanced Home NodeB / eNodeB (EHNB) / Text3: UTRA, LTE
- 365: SP#47 completed / Text3: 22.220
- 366: SP#47 completed. Chosen solution has no normative impacts / Text3: new 23.832
- 367: SP#49 completed / Text3: 33.320

| ID | WBS | Task | Type | Duration | Start | Finish | Complete | Baseline start | Baseline finish | Baseline duration | Constraint | Resources | Work | Actual work | Text1 | Text2 | Text4 | Text5 | Text6 | Text7 | Text8 | Text9 | Text12 |
| --- | --- | --- | --- | --- | --- | --- | --- | --- | --- | --- | --- | --- | --- | --- | --- | --- | --- | --- | --- | --- | --- | --- | --- |
| 368 | 135 | **Optimal Media Routing** |  | 314d? | 2010-03-25 A | 2011-06-08 A | 100% | 2010-03-25 | 2011-06-08 | 314d? |  | S2,S5,C3,C1,C4 | 10984h | 10984h | OMR | PCG-24 | Alcatel-Lucent | andy.bennett@alcatel-lucent.com | Rel-10 | SP-46 | Maurice |  |  |
| 369 | 135.1 | Stage 2 for Optimal Media Routing | milestone | 0d? | 2010-03-25 A | 2010-03-25 A | 100% | 2010-03-25 | 2010-03-25 | 0d? |  | S2 |  |  | OMR | PCG-24 | Alcatel-Lucent | andy.bennett@alcatel-lucent.com | Rel-10 | SP-46 | Maurice |  |  |
| 370 | 135.2 | **Stage 3 for Optimal Media Routing** |  | 261d? | 2010-06-04 A | 2011-06-03 A | 100% | 2010-06-04 | 2011-06-03 | 261d? |  | C3,C1,C4 | 7472h | 7472h | OMR | PCG-25 | Alcatel-Lucent | jim.calme@alcatel-lucent.com | Rel-10 | CP-48 | Jiwan |  |  |
| 371 | 135.2.1 | CT3 part of Stage 3 for Optimal Media Routeing |  | 261d? | 2010-06-04 A | 2011-06-03 A | 100% | 2010-06-04 | 2011-06-03 | 261d? | finish no earlier than 2011-06-03 | C3 | 2088h | 2088h | OMR | PCG-25 | Alcatel-Lucent | jim.calme@alcatel-lucent.com | Rel-10 | CP-48 | Jiwan |  |  |
| 372 | 135.2.2 | CT1 part of Stage 3 for Optimal Media Routeing |  | 206d? | 2010-06-04 A | 2011-03-18 A | 100% | 2010-06-04 | 2011-03-18 | 206d? | finish no earlier than 2011-03-18 | C1 | 1648h | 1648h | OMR | PCG-25 | Alcatel-Lucent | jim.calme@alcatel-lucent.com | Rel-10 | CP-48 | Frederic |  |  |
| 373 | 135.2.3 | Deleted - CT4 part of Stage 3 for Optimal Media Routeing |  | 206d? | 2010-06-04 A | 2011-03-18 A | 100% | 2010-06-04 | 2011-03-18 | 206d? | finish no earlier than 2011-03-18 | C4 | 1648h | 1648h | OMR | PCG-25 | Alcatel-Lucent | jim.calme@alcatel-lucent.com | Rel-10 | CP-48 | Kimmo | PCG-26 | CP-51 |
| 374 | 135.3 | Charging for Optimal Media Routing |  | 125d? | 2010-12-16 A | 2011-06-08 A | 100% | 2010-12-16 | 2011-06-08 | 125d? | finish no earlier than 2011-06-08 | S5 | 1000h | 1000h | OMR | PCG-26 | Alcatel-Lucent | maryse.gardella@alcatel-lucent.com | Rel-10 | SP-50 | Dionisio |  |  |
| 375 | 136 | **IMS Emergency Session Enhancements** |  | 312d? | 2010-03-25 A | 2011-06-03 A | 100% | 2010-03-25 | 2011-06-03 | 312d? |  | S1,S2,C1 | 4560h | 4560h | IESE | PCG-24 | Deutsche Telekom, T-Mobile | michele.zarri@t-mobile.co.uk | Rel-10 | SP-47 | Maurice |  |  |
| 376 | 136.1 | Stage 1 for IMS Emergency Session Enhancements |  | 1d? | 2010-03-25 A | 2010-03-25 A | 100% | 2010-03-25 | 2010-03-25 | 1d? | start no earlier than 2010-03-25 | S1 | 8h | 8h | IESE | PCG-24 | Deutsche Telekom, T-Mobile | Kurt Bischinger | Rel-10 | SP-47 | Alain |  |  |
| 377 | 136.2 | Stage 2 for IMS Emergency Session Enhancements |  | 131d? | 2010-03-25 A | 2010-09-23 A | 100% | 2010-03-25 | 2010-09-23 | 131d? | finish no earlier than 2010-09-23 | S2 | 1048h | 1048h | IESE | PCG-24 | Deutsche Telekom, T-Mobile | michele.zarri@t-mobile.co.uk | Rel-10 | SP-47 | Maurice |  |  |
| 378 | 136.3 | Stage 3 for IMS Emergency Session Enhancements |  | 126d? | 2010-12-10 A | 2011-06-03 A | 100% | 2010-12-10 | 2011-06-03 | 126d? | finish no earlier than 2011-06-03 | C1 | 1008h | 1008h | IESE | PCG-26 | Deutsche Telekom | reinhard.lauster@t-mobile.at | Rel-10 | CP-50 | Frederic |  |  |
| 379 | 137 | **S2b Mobility based on GTP** |  | 202d? | 2010-06-10 A | 2011-03-18 A | 100% | 2010-06-10 | 2011-03-18 | 202d? |  | S2,C4,C3,C1 | 5856h | 5856h | SMOG | PCG-25 | Alcatel-Lucent | bruno.landais@alcatel-lucent.com | Rel-10 | SP-48 | Maurice |  |  |
| 380 | 137.1 | Stage 2 for S2b Mobility based on GTP |  | 76d? | 2010-06-10 A | 2010-09-23 A | 100% | 2010-06-10 | 2010-09-23 | 76d? | finish no earlier than 2010-09-23 | S2 | 608h | 608h | SMOG | PCG-25 | Alcatel-Lucent | bruno.landais@alcatel-lucent.com | Rel-10 | SP-48 | Maurice |  |  |
| 381 | 137.2 | **Stage 3 for S2b Mobility based on GTP** |  | 131d? | 2010-09-17 A | 2011-03-18 A | 100% | 2010-09-17 | 2011-03-18 | 131d? |  | C4,C3,C1 | 3632h | 3632h | SMOG-St3 | PCG-25 | Alcatel-Lucent | bruno.landais@alcatel-lucent.com | Rel-10 | CP-49 | Kimmo |  |  |
| 382 | 137.2.1 | CT4 part of Stage 3 for S2b Mobility based on GTP |  | 131d? | 2010-09-17 A | 2011-03-18 A | 100% | 2010-09-17 | 2011-03-18 | 131d? | finish no earlier than 2011-03-18 | C4 | 1048h | 1048h | SMOG-St3 | PCG-25 | Alcatel-Lucent | bruno.landais@alcatel-lucent.com | Rel-10 | CP-49 | Kimmo |  |  |
| 383 | 137.2.2 | CT3 part of Stage 3 for S2b Mobility based on GTP |  | 131d? | 2010-09-17 A | 2011-03-18 A | 100% | 2010-09-17 | 2011-03-18 | 131d? | finish no earlier than 2011-03-18 | C3 | 1048h | 1048h | SMOG-St3 | PCG-25 | Alcatel-Lucent | bruno.landais@alcatel-lucent.com | Rel-10 | CP-49 | Jiwan |  |  |
| 384 | 137.2.3 | CT1 part of Stage 3 for S2b Mobility based on GTP |  | 61d? | 2010-09-17 A | 2010-12-10 A | 100% | 2010-09-17 | 2010-12-10 | 61d? | finish no earlier than 2010-12-10 | C1 | 488h | 488h | SMOG-St3 | PCG-25 | Alcatel-Lucent | bruno.landais@alcatel-lucent.com | Rel-10 | CP-49 | Frederic |  |  |
| 385 | 138 | **Policy Enhancements for Sponsored Connectivity and Coherent Access to Policy related Databases** |  | 113.15d? | 2010-10-12 A | 2011-03-18 A | 100% | 2010-10-12 | 2011-03-18 | 113.15d? |  | S2,C3 | 1473.2h | 1473.2h | PEST | PCG-26 | Qualcomm | AC Mahendran (ac@qualcomm.com) | Rel-10 | SP-50 | Maurice |  |  |
| 386 | 138.1 | Stage 2 for Policy Enhancements for Sponsored Connectivity and Coherent Access to Policy related Databases | milestone | 0d? | 2010-10-12 A | 2010-12-15 A | 100% | 2010-10-12 | 2010-12-15 | 0d? | finish no earlier than 2010-12-15 | S2 |  |  | PEST | PCG-26 | Qualcomm | AC Mahendran (ac@qualcomm.com) | Rel-10 | SP-50 | Maurice |  |  |
| 387 | 138.2 | CT3 aspects of Policy Enhancements for Sponsored Connectivity and Coherent Access to Policy related Databases |  | 71d? | 2010-12-10 A | 2011-03-18 A | 100% | 2010-12-10 | 2011-03-18 | 71d? | finish no earlier than 2011-03-18 | C3 | 568h | 568h | PEST-CT3 | PCG-26 | ZTE | zhou.xiaoyun@zte.com.cn | Rel-10 | CP-50 | Jiwan |  |  |
| 388 | 139 | **Lawful Interception in the 3GPP Rel-10** |  | 315d? | 2010-03-25 A | 2011-06-08 A | 100% | 2010-03-25 | 2011-06-08 | 315d? |  | S3 | 20480h | 20480h | LI10 | PCG-24 | PIDS, BT | Koen Jaspers (k.b.jaspers@minjus.nl), alex.leadbeater@bt.com | Rel-10 | SP-47 | Dionisio |  |  |
| 389 | 139.1 | LI for CAT (Customer Alerting Tones) |  | 315d? | 2010-03-25 A | 2011-06-08 A | 100% | 2010-03-25 | 2011-06-08 | 315d? | finish no earlier than 2011-03-23 | S3 | 2520h | 2520h | LI10 | PCG-24 | PIDS, BT | Koen Jaspers (k.b.jaspers@minjus.nl), alex.leadbeater@bt.com | Rel-10 | SP-47 | Dionisio |  |  |
| 390 | 139.2 | LI for CRS (Customized Ringing Signal) |  | 315d? | 2010-03-25 A | 2011-06-08 A | 100% | 2010-03-25 | 2011-06-08 | 315d? | finish no earlier than 2011-03-23 | S3 | 2520h | 2520h | LI10 | PCG-24 | PIDS, BT | Koen Jaspers (k.b.jaspers@minjus.nl), alex.leadbeater@bt.com | Rel-10 | SP-47 | Dionisio |  |  |
| 391 | 139.3 | LI for EPS enhancements |  | 315d? | 2010-03-25 A | 2011-06-08 A | 100% | 2010-03-25 | 2011-06-08 | 315d? | finish no earlier than 2011-03-23 | S3 | 2520h | 2520h | LI10 | PCG-24 | PIDS, BT | Koen Jaspers (k.b.jaspers@minjus.nl), alex.leadbeater@bt.com | Rel-10 | SP-47 | Dionisio |  |  |
| 392 | 139.4 | LI for VCC (Voice Call Continuity) |  | 260d? | 2010-03-25 A | 2011-03-23 A | 100% | 2010-03-25 | 2011-03-23 | 260d? | finish no earlier than 2011-03-23 | S3 | 2080h | 2080h | LI10 | PCG-24 | PIDS, BT | Koen Jaspers (k.b.jaspers@minjus.nl), alex.leadbeater@bt.com | Rel-10 | SP-47 | Dionisio |  |  |
| 393 | 139.5 | LI for MEDIASEC (IMS Media security) |  | 260d? | 2010-03-25 A | 2011-03-23 A | 100% | 2010-03-25 | 2011-03-23 | 260d? | finish no earlier than 2011-03-23 | S3 | 2080h | 2080h | LI10 | PCG-24 | PIDS, BT | Koen Jaspers (k.b.jaspers@minjus.nl), alex.leadbeater@bt.com | Rel-10 | SP-47 | Dionisio |  |  |
| 394 | 139.6 | LI for H(e)NB also with Local IP Access and Selected IP Traffic Offload (LIPA, SIPTO) |  | 260d? | 2010-03-25 A | 2011-03-23 A | 100% | 2010-03-25 | 2011-03-23 | 260d? | finish no earlier than 2011-03-23 | S3 | 2080h | 2080h | LI10 | PCG-24 | PIDS, BT | Koen Jaspers (k.b.jaspers@minjus.nl), alex.leadbeater@bt.com | Rel-10 | SP-47 | Dionisio |  |  |
| 395 | 139.7 | LI for MBMS_LTE_enh (Multimedia Broadcast and Multicast Service enhancements) |  | 260d? | 2010-03-25 A | 2011-03-23 A | 100% | 2010-03-25 | 2011-03-23 | 260d? | finish no earlier than 2011-03-23 | S3 | 2080h | 2080h | LI10 | PCG-24 | PIDS, BT | Koen Jaspers (k.b.jaspers@minjus.nl), alex.leadbeater@bt.com | Rel-10 | SP-47 | Dionisio |  |  |
| 396 | 139.8 | LI for LCLS (Local Call Local Switch) |  | 260d? | 2010-03-25 A | 2011-03-23 A | 100% | 2010-03-25 | 2011-03-23 | 260d? | finish no earlier than 2011-03-23 | S3 | 2080h | 2080h | LI10 | PCG-24 | PIDS, BT | Koen Jaspers (k.b.jaspers@minjus.nl), alex.leadbeater@bt.com | Rel-10 | SP-47 | Dionisio |  |  |
| 397 | 140 | Optimization of IMS based PSS and MBMS User Service |  | 260d? | 2010-03-25 A | 2011-03-23 A | 100% | 2010-03-25 | 2011-03-23 | 260d? | finish no earlier than 2011-03-23 | S4 | 2080h | 2080h | OPT_IMS_PSS_MBMS_US | PCG-24 | Ericsson | markus.kampmann@ericsson.com | Rel-10 | SP-47 | Paolo |  |  |

Notes:
- 368: CP#52 completed. SP#47 Stage 2 completed. Triggered by TR 23.894 (UID_370050 Study on System enhancements for the use of IMS services in local breakout)
- 369: SP#47 completed / Text3: 23.228
- 370: CP#51 completion 03/11=>06/11. WID updated CP-100327=>CP-110134
- 371: CP#52 completed / Text3: 29.162, 29.163, 29.165, 29.235, new TS 29.079
- 372: CP#51 completed. WID updated CP-100327=>CP-110134 / Text3: 24.229
- 373: CP#51 stopped (CT4 specs not impacted). WID updated CP-100327=>CP-110134
- 374: SP#52 completed. Stage 3: Linked to CT3 TS 29.079 OMR within the IMS; Stage 3 (UID_480110) / Text3: 32.260, 32.298, 32.299
- 375: CP#52 completed. SP#49 completed. Source of external requirements: ETSI TISPAN TS 181.019 (Business Communication Requirements)
- 376: SP#47 completed / Text3: 22.101 CR#0343
- 377: SP#49 completed / Text3: 23.167
- 378: CP#52 completed / Text3: 24.229
- 379: CP#51 completed. SP#49 Stage 2 completed. Related to Rel-10 UID_470049 Study on S2b mobility based on GTP (TR23.834), UID_350027 SAE for support for non-3GPP accesses. Stage1 in Rel-8 UID_320022 Reqs for evolution of 3GPP system architecture (AIPN-SAE)
- 380: SP#49 completed / Text3: 23.002, 23.203, 23.402
- 381: CP#51 Stage 3 completed
- 382: CP#51 completed / Text3: 23.003, 23.007, 23.008, 29.273, 29.274, 29.281, 29.303
- 383: CP#51 completed / Text3: 29.212, 29.213, 29.215
- 384: CP#50 completed / Text3: 24.302
- 385: CP#51 completed. SP#50 Stage 2 completed. Triggered by the SA1,SA2 Rel-10 TR 23.813 Study on Policy solutions and enhancements (FS_PP) UID_440047. Provides Video Call seamless service continuity for 3G/LTE terminal user
- 386: SP#51 updated WID SP-100702=>SP-110196. SA#49 work completed as SA2 CRs approved under TEI10 (SP-10557) / Text3: 23.002, 23.203
- 387: CP#51 completed / Text3: 29.212, 29.213, 29.214, 29.215
- 388: SP#52 completed / Text3: 33.106 (LI requirements), 33.107 (LI architecture and functions), 33.108 (Handover interface for LI)
- 389: SP#52 completed / Text3: 33.106, 33.107, 33.108
- 390: SP#52 completed / Text3: 33.106, 33.107, 33.108
- 391: SP#52 completed / Text3: 33.106, 33.107, 33.108
- 392: SP#51 completed / Text3: 33.106, 33.107, 33.108
- 393: SP#51 completed / Text3: 33.106, 33.107, 33.108
- 394: SP#51 completed / Text3: 33.106, 33.107, 33.108
- 395: SP#51 completed / Text3: 33.106, 33.107, 33.108
- 396: SP#51 completed / Text3: 33.106, 33.107, 33.108
- 397: SP#51 completed. Work to enhance UID_430046 Rel-9 IMS_PSS_MBMS_US_EXT / Text3: 26.237

| ID | WBS | Task | Duration | Start | Finish | Complete | Remaining | Baseline start | Baseline finish | Baseline duration | Total slack | Constraint | Resources | Work | Actual work | Text1 | Text2 | Text4 | Text6 | Text7 | Text8 | Text9 | Text12 | Text11 |
| --- | --- | --- | --- | --- | --- | --- | --- | --- | --- | --- | --- | --- | --- | --- | --- | --- | --- | --- | --- | --- | --- | --- | --- | --- |
| 398 | 141 | **HTTP-based Streaming and Download Services** | 447d? | 2010-03-25 A | 2011-12-09 | 66% | 153.67d? | 2010-03-25 | 2011-12-09 | 447d? | 260d |  | S4,IETF | 6252.4h | 3053.2h | HTTP_SDS | PCG-24 | Qualcomm | Rel-10 | SP-47 | Paolo |  |  |  |
| 399 | 141.1 | HTTP-based Streaming and Download Services | 315d? | 2010-03-25 A | 2011-06-08 A | 100% |  | 2010-03-25 | 2011-06-08 | 315d? |  | finish no earlier than 2011-05-26 | S4 | 2520h | 2520h | HTTP_SDS | PCG-24 | Qualcomm | Rel-10 | SP-47 | Paolo |  |  |  |
| 400 | 141.2 | (IETF) HTTP-based Streaming and Download Services | 266.6d? | 2010-03-25 A | 2011-12-09 | 25% | 199.95d? | 2010-03-25 | 2011-12-09 | 266.6d? | 260d | start no earlier than 2010-03-25 | S4-IETF | 2132.8h | 533.2h | HTTP_SDS | PCG-27 | Qualcomm | Rel-10 | CP-52 | Paolo |  |  |  |
| 401 | 142 | PSS and MBMS enhancements | 205d? | 2010-06-10 A | 2011-03-23 A | 100% |  | 2010-06-10 | 2011-03-23 | 205d? |  | finish no earlier than 2011-03-23 | S4 | 1640h | 1640h | MBS_Enh | PCG-25 | Ericsson | Rel-10 | SP-48 | Paolo |  |  |  |
| 402 | 143 | Enhancements and Addition of Audio Tests to 26.131 and 26.132 | 260d? | 2010-06-10 A | 2011-06-08 A | 100% |  | 2010-06-10 | 2011-06-08 | 260d? |  | finish no earlier than 2011-06-08 | S4 | 2080h | 2080h | EAAT | PCG-25 | Vodafone | Rel-10 | SP-48 | Paolo |  |  |  |
| 403 | 144 | Video Coding Enhancements in MTSI | 3d? | 2011-03-21 A | 2011-03-23 A | 100% |  | 2011-03-21 | 2011-03-23 | 3d? |  | start no earlier than 2011-03-21 | S4 | 24h | 24h | VCEM | PCG-26 | Ericsson | Rel-10 | SP-51 | Paolo |  |  |  |
| 404 | 145 | **Rel-10 Operations, Administration, Maintenance and Provisioning (OAM&P)** | 390d? | 2009-12-10 A | 2011-06-08 | 99% | 1.2d? | 2009-12-10 | 2011-06-08 | 390d? | 392d |  | S5,C4 | 43536h | 41003.2h | OAM10 | PCG-24 |  | Rel-10 | SP-46 | Dionisio |  |  |  |
| 405 | 145.1 | **Network Infrastructure Management** | 390d? | 2009-12-10 A | 2011-06-08 | 99% | 3.4d? | 2009-12-10 | 2011-06-08 | 390d? | 392d |  | S5 | 13376h | 13259.2h | OAM10-NIM | PCG-24 |  | Rel-10 | SP-46 | Dionisio |  |  |  |
| 406 | 145.1.1 | Common RAT Network Resource Model (NRM) | 390d? | 2009-12-10 A | 2011-06-08 A | 100% |  | 2009-12-10 | 2011-06-08 | 390d? |  | finish no earlier than 2011-06-08 | S5 | 3120h | 3120h | RAT_NRM_common | PCG-24 | Ericsson | Rel-10 | SP-46 | Dionisio |  |  |  |
| 407 | 145.1.2 | IRP Solution Set specification organisation improvements | 260d? | 2010-03-25 A | 2011-03-23 A | 100% |  | 2010-03-25 | 2011-03-23 | 260d? |  | finish no earlier than 2011-03-23 | S5 | 2080h | 2080h | OAM-IRP-SS | PCG-24 | Nokia Siemens Networks, Huawei | Rel-10 | SP-47 | Dionisio |  |  |  |
| 408 | 145.1.3 | Deleted - Service Oriented Architecture (SOA) for IRP continuation from Rel-9 | 260d? | 2010-03-25 A | 2011-03-23 A | 100% |  | 2010-03-25 | 2011-03-23 | 260d? |  | finish no earlier than 2011-06-08 | S5 | 2080h | 2080h | OAM-SOA-IRP | PCG-24 | Nokia Siemens Networks, Ericsson | Rel-10 | SP-47 | Dionisio | PCG-26 | SP-51 |  |
| 409 | 145.1.4 | IRP Overview, Profiles & Usage Guide | 260d? | 2010-06-10 A | 2011-06-08 A | 100% |  | 2010-06-10 | 2011-06-08 | 260d? |  | finish no earlier than 2011-06-08 | S5 | 2080h | 2080h | OAM-NIM-IRP_OPU | PCG-25 | Nokia Siemens Networks | Rel-10 | SP-48 | Dionisio |  |  |  |
| 410 | 145.1.5 | Alarm Correlation and Root Cause Analysis | 56d? | 2011-03-23 A | 2011-06-08 | 80% | 11.2d? | 2011-03-23 | 2011-06-08 | 56d? | 392d | start no earlier than 2011-03-23 | S5 | 448h | 358.4h | OAM-AC-RCA | PCG-26 | Ericsson | Rel-10 | SP-51 | Dionisio |  |  | Exception sheet in SP-110278 |
| 411 | 145.1.6 | Inventory Management Network Resource Model enhancements | 56d? | 2011-03-23 A | 2011-06-08 A | 100% |  | 2011-03-23 | 2011-06-08 | 56d? |  | start no earlier than 2011-03-23 | S5 | 448h | 448h | OAM-IM-NMR | PCG-26 | Nokia Siemens Networks | Rel-10 | SP-51 | Dionisio |  |  |  |
| 412 | 145.2 | **Self-Organizing Networks (SON) - OAM aspects** | 390d? | 2009-12-10 A | 2011-06-08 A | 100% |  | 2009-12-10 | 2011-06-08 | 390d? |  |  | S5 | 11000h | 11000h | OAM10-SON | PCG-24 |  | Rel-10 | SP-46 | Dionisio |  |  |  |
| 413 | 145.2.1 | SON Self-optimization management continuation | 390d? | 2009-12-10 A | 2011-06-08 A | 100% |  | 2009-12-10 | 2011-06-08 | 390d? |  | finish no earlier than 2011-03-23 | S5 | 3120h | 3120h | LTE-SON-OAM_SO | PCG-24 | Huawei | Rel-10 | SP-46 | Dionisio |  |  |  |
| 414 | 145.2.2 | SON Self-healing management | 335d? | 2009-12-10 A | 2011-03-23 A | 100% |  | 2009-12-10 | 2011-03-23 | 335d? |  | finish no earlier than 2011-03-23 | S5 | 2680h | 2680h | LTE-SON-OAM_SH | PCG-24 | ZTE | Rel-10 | SP-46 | Dionisio |  |  |  |
| 415 | 145.2.3 | OAM aspects of Energy Saving in Radio Networks | 260d? | 2010-03-25 A | 2011-03-23 A | 100% |  | 2010-03-25 | 2011-03-23 | 260d? |  | finish no earlier than 2011-03-23 | S5 | 2080h | 2080h | OAM-ES | PCG-24 | Nokia Siemens Networks | Rel-10 | SP-47 | Dionisio |  |  |  |
| 416 | 145.3 | Subscription Management (SuM) evolution | 260d? | 2010-03-25 A | 2011-03-23 A | 100% |  | 2010-03-25 | 2011-03-23 | 260d? |  | finish no earlier than 2011-03-23 | S5 | 2080h | 2080h | OAM10-SuM | PCG-24 | Ericsson | Rel-10 | SP-47 | Dionisio |  |  |  |
| 417 | 145.4 | **Performance Management** | 315d? | 2010-03-25 A | 2011-06-08 A | 100% |  | 2010-03-25 | 2011-06-08 | 315d? |  |  | S5,C4 | 13960h | 13960h | OAM10-PM | PCG-24 |  | Rel-10 | SP-47 | Dionisio |  |  |  |
| 418 | 145.4.1 | Key Performance Indicators (KPIs) for IMS | 260d? | 2010-03-25 A | 2011-03-23 A | 100% |  | 2010-03-25 | 2011-03-23 | 260d? |  | finish no earlier than 2011-03-23 | S5 | 2080h | 2080h | OAM-PM-KPI_IMS | PCG-24 | China Mobile | Rel-10 | SP-47 | Dionisio |  |  |  |
| 419 | 145.4.2 | Key Performance Indicators (KPIs) for EPC | 260d? | 2010-03-25 A | 2011-03-23 A | 100% |  | 2010-03-25 | 2011-03-23 | 260d? |  | finish no earlier than 2011-03-23 | S5 | 2080h | 2080h | OAM-PM-KPI_EPC | PCG-24 | China Mobile | Rel-10 | SP-47 | Dionisio |  |  |  |
| 420 | 145.4.3 | **Management of UE based network performance measurements** | 315d? | 2010-03-25 A | 2011-06-08 A | 100% |  | 2010-03-25 | 2011-06-08 | 315d? |  |  | S5,C4 | 5200h | 5200h | OAM-PM-UE | PCG-24 | Huawei, Nokia Siemens Networks, Ericsson | Rel-10 | SP-47 | Dionisio |  |  |  |
| 421 | 145.4.3.1 | Management of UE based network performance measurements | 315d? | 2010-03-25 A | 2011-06-08 A | 100% |  | 2010-03-25 | 2011-06-08 | 315d? |  | finish no earlier than 2011-06-08 | S5 | 2520h | 2520h | OAM-PM-UE | PCG-24 | Huawei, Nokia Siemens Networks, Ericsson | Rel-10 | SP-47 | Dionisio |  |  |  |
| 422 | 145.4.3.2 | CN aspects of Management of UE based network performance measurements | 20d? | 2011-02-21 A | 2011-03-18 A | 100% |  | 2011-02-21 | 2011-03-18 | 20d? |  | start no earlier than 2011-02-21 | C4 | 160h | 160h | OAM-PM-UE | PCG-26 | Nokia Siemens Networks | Rel-10 | CP-51 | Kimmo |  |  |  |
| 423 | 145.4.4 | 3G HNB and LTE HeNB Subsystem performance measurements | 260d? | 2010-03-25 A | 2011-03-23 A | 100% |  | 2010-03-25 | 2011-03-23 | 260d? |  | finish no earlier than 2011-03-23 | S5 | 2080h | 2080h | OAM-PM-HeNS | PCG-24 | China Mobile | Rel-10 | SP-47 | Dionisio |  |  |  |

Notes:
- 398: SP#52 completed. Work to enhance UID_430038 Rel-9 PSS and MBMS extensions / Text3: 26.234, 26.244, 26.346, new TS 26.247 (Progressive Download and Dynamic Adaptive Streaming over HTTP (3GP-DASH)) / Text5: Thomas Stockhammer (c_tstock@qualcomm.com)
- 399: SP#52 completed. Work to enhance UID_430038 Rel-9 PSS and MBMS extensions / Text3: 26.234, 26.244, 26.346, new TS 26.247 (Progressive Download and Dynamic Adaptive Streaming over HTTP (3GP-DASH)) / Text5: Thomas Stockhammer (c_tstock@qualcomm.com)
- 400: Not completed internet-draft / Text3: draft-gellens-mime-bucket-bis
- 401: SP#51 completed. Linked to Rel-9 Feature UID_430038 PSS and MBMS extensions (PMA-MBS_Ext). / Text3: 26.234, 26.346 / Text5: Markus.Kampmann@ericsson.com
- 402: SP#52 completed. Reduce fragmentation in acoustic testing (3GPP SA4, ETSI STQ, GCF CAG, CTIA) & Review existing acoustic tests to determine need for new spec / Text3: 26.131, 26.132 / Text5: ramin.afchar@vodafone.com
- 403: SP#51 completed. Linked to Rel-7 UID_7040 Multimedia Telephony Service for IMS - Media handling and interaction in MTSI (MTSI-MHI) / Text3: 26.114 / Text5: frederic.gabin@ericsson.com
- 404: umbrella Feature / Text3: TR 30.820
- 405: umbrella BB
- 406: SP#52 completed. Share equipment btw several RATs (RET,TMA,repeaters) to reduce costs. With existing modelling is difficult to see that several cells are affected when an antenna tilt is changed etc / Text3: 32.616, 32.642, 32.646, 32.652, 32.656, 32.762, 32.766 new (32.791, 32.792, 32.796) / Text5: robert.petersen@ericsson.com
- 407: SP#51 completed / Text3: 32.153, new (32.111-6,32.126,32.176,32.306,32.316,32.326,32.336,32.346,32.356,32.366,32.376,32.386,32.396,32.416,32.446,32.506/26/36,32.606,32.616,32.626,32.636,32.646,32.656,32.666,32.676,32.696,32.716,32.726,32.736,32.746,32.756,32.766,32.776,32.786) / Text5: Jörg Schmidt (joerg@cox.net), Lan Zou (zlan@huawei.com)
- 408: SP#51 work stopped (Reason: lack of progress). Continuation of Rel-9 UID_440065 SOA for IRP (covering SOA Architecture & SOA-supporting Solution Set) to address SOA conforming Registration & Discovery capabilities / Text3: 32.101, 32.150 / Text5: Jörg Schmidt (joerg@cox.net), edwin.tse@ericsson.com
- 409: SP#52 completed. Updated WID SP-100777=>SP-110277 / Text3: new TS 32.103 / Text5: Jörg Schmidt (joerg@cox.net)
- 410: SP#52 completion 06/11=>09/11 (except. SP-110278). Triggered by Rel-10 TR 32.832 Study on Alarm Correlation and Alarm Root Cause Analysis UID_480045 & TR 32.829 Study on Harmonization of 3GPP Alarm IRP and TMF Interface Program Fault Management UID_460038 / Text3: 32.111-1, 32.111-2, 32.111-6 / Text5: brendan.hassett@ericsson.com
- 411: SP#52 completed. Inventory NRM specified in Rel-6 is mainly hardware related. Rel-10 TR 32.828 recommends extending the scope of inventory NRM. Additionally, NGMN Top OPE Recs, v1.0 sets inventory enhancements as one of top 10 priority items / Text3: 32.690, 32.691, 32.692, 32.696 / Text5: olaf.pollakowski@nsn.com
- 412: umbrella BB
- 413: SP#52 completed. Cont'd Rel-9 SON self-optimization management UID_390007 / Text3: 32.425, 32.521, 32.522, 32.526, 32.762, 32.766 / Text5: Lan Zou (zlan@huawei.com)
- 414: SP#51 completed. WID updated SP-100776=>SP-110150. Work moved to Rel-10 after split of the Rel-9 UID_390007 SON self-optimization (removed Self-Healing handling) / Text3: 32.522, 32.526, 32.762, 32.766, new TS 32.541 / Text5: zhu.weihong@zte.com.cn
- 415: SP#51 completed. WID updated SP-100226=>SP-110128. Triggered by Rel-10 TR 32.826 Study on Telecommunication Management; Energy Savings Management (FS_OAM_ESM) UID_430044 / Text3: 32.425, 32.522, 32.526, 32.626, 32.762, 32.766, new 32.551 / Text5: clemens.suerbaum@nsn.com
- 416: SP#51 completed / Text3: 32.172, 32.175, 32.176 / Text5: leo.yang@ericsson.com
- 417: umbrella BB
- 418: SP#51 completed / Text3: new 32.454 / Text5: Li Jian (lijian@chinamobile.com), Liang Shuangchun (liangshuangchun@cmdi.chinamobile.com)
- 419: SP#51 completed / Text3: new 32.455 / Text5: Li Jian (lijian@chinamobile.com), Liang Shuangchun (liangshuangchun@cmdi.chinamobile.com)
- 420: SP#52 completed. Stage 2/3. Linked to UID_460003 Minimization of drive tests for E-UTRAN and UTRAN (MDT_UMTSLTE) / Text5: Zou Lan (zlan@huawei.com), gyula.bodog@nsn.com, ulf.hubinette@ericsson.com
- 421: SP#52 completed / Text3: 32.421, 32.422, 32.423, 32.441, 32.442, 32.446 / Text5: Zou Lan (zlan@huawei.com), gyula.bodog@nsn.com, ulf.hubinette@ericsson.com
- 422: CP#51 completed under the SA5 WI code / Text3: 23.008 (CR#0330), 29.002 (CR#1007), 29.230 (CR#0207), 29.272 (CR#0329) / Text5: ulrich.wiehe@nsn.com
- 423: SP#51 completed / Text3: 32.582, 32.592, new (32.452, 32.453) / Text5: Chen Gang (chengang@chinamobile.com)

| ID | WBS | Task | Type | Duration | Start | Finish | Complete | Remaining | Baseline start | Baseline finish | Baseline duration | Total slack | Constraint | Resources | Work | Actual work | Text1 | Text2 | Text6 | Text7 | Text8 | Text4 | Text5 |
| --- | --- | --- | --- | --- | --- | --- | --- | --- | --- | --- | --- | --- | --- | --- | --- | --- | --- | --- | --- | --- | --- | --- | --- |
| 424 | 146 | **Rel-10 Charging Management small Enhancements** |  | 470d? | 2009-06-04 A | 2011-03-23 A | 100% |  | 2009-06-04 | 2011-03-23 | 470d? |  |  | S5 | 7520h | 7520h | CH10 | PCG-24 | Rel-10 | SP-47 | Dionisio |  |  |
| 425 | 146.1 | IWLAN mobility charging |  | 470d? | 2009-06-04 A | 2011-03-23 A | 100% |  | 2009-06-04 | 2011-03-23 | 470d? |  | finish no earlier than 2011-03-23 | S5 | 3760h | 3760h | eIWLAN_Mob | PCG-23 | Rel-10 | SP-44 | Dionisio | Orange | Jean-Luc Garcia (jl.garcia@orange-ftgroup.com) |
| 426 | 147 | **Advice of Charge (AoC) service support enhancements** |  | 312d? | 2010-03-25 A | 2011-06-03 A | 100% |  | 2010-03-25 | 2011-06-03 | 312d? |  |  | S5,C1 | 6064h | 6064h | eAoC | PCG-24 | Rel-10 | SP-47 | Dionisio | Deutsche Telekom | matthias.seibel@telekom.de |
| 427 | 147.1 | SA5 part - AoC enhancements |  | 260d? | 2010-03-25 A | 2011-03-23 A | 100% |  | 2010-03-25 | 2011-03-23 | 260d? |  | finish no earlier than 2011-03-23 | S5 | 2080h | 2080h | eAoC | PCG-24 | Rel-10 | SP-47 | Dionisio | Deutsche Telekom | matthias.seibel@telekom.de |
| 428 | 147.2 | CT1 part - AoC enhancements (Stage 3) |  | 186d? | 2010-09-17 A | 2011-06-03 A | 100% |  | 2010-09-17 | 2011-06-03 | 186d? |  | finish no earlier than 2011-06-03 | C1 | 1488h | 1488h | eAoC | PCG-25 | Rel-10 | CP-49 | Frederic | Deutsche Telekom | reinhard.lauster@t-mobile.at |
| 429 | 148 | IMS Stage 3 - IETF Protocol Alignment |  | 261d? | 2010-03-19 A | 2011-03-18 A | 100% |  | 2010-03-19 | 2011-03-18 | 261d? |  | finish no earlier than 2011-03-18 | C1 | 2088h | 2088h | IMSProtoc4 | PCG-24 | Rel-10 | CP-47 | Frederic | Alcatel-Lucent | keith.drage@alcatel-lucent.com |
| 430 | 149 | Enhanced User Data Convergence (UDC) Model |  | 206d? | 2010-06-04 A | 2011-03-18 A | 100% |  | 2010-06-04 | 2011-03-18 | 206d? |  | finish no earlier than 2011-03-18 | C4 | 1648h | 1648h | eUDC | PCG-25 | Rel-10 | CP-48 | Kimmo | China Mobile | Lan Sizhong (lansizhong@chinamobile.com) |
| 431 | 150 | Further improvements of II-NNI Stage 3 based on operational feedback and evolution of other specifications |  | 206d? | 2010-06-04 A | 2011-03-18 A | 100% |  | 2010-06-04 | 2011-03-18 | 206d? |  | start no earlier than 2010-06-04 | C3 | 1648h | 1648h | II-NNI2 | PCG-25 | Rel-10 | CP-48 | Jiwan | Orange | beata.dobrowolska@orange-ftgroup.com |
| 432 | 151 | AT Commands for IMS-configuration |  | 206d? | 2010-06-04 A | 2011-03-18 A | 100% |  | 2010-06-04 | 2011-03-18 | 206d? |  |  | C1 | 1648h | 1648h | AT_IMS | PCG-25 | Rel-10 | CP-48 | Frederic | Ericsson | atle.monrad@ericsson.com |
| 433 | 152 | AT Commands for USIM Application Toolkit (USAT) |  | 131d? | 2010-09-17 A | 2011-03-18 A | 100% |  | 2010-09-17 | 2011-03-18 | 131d? |  |  | C1 | 52.4h | 52.4h | AT_UICC | PCG-25 | Rel-10 | CP-49 | Frederic | ST-Ericsson | magnus.mk.karlsson@stericsson.com |
| 434 | 153 | Communication Control for IMS by USIM (Stage 3) |  | 131d? | 2010-09-17 A | 2011-03-18 A | 100% |  | 2010-09-17 | 2011-03-18 | 131d? |  | start no earlier than 2010-09-17 | C6 | 1048h | 1048h | CC_IMS_USIM | PCG-25 | Rel-10 | CP-49 | Xavier | Gemalto | Denis.Lheriteau@gemalto.com |
| 435 | 154 | Dynamic view of SIP message for II-NNI (Stage 3) |  | 126d? | 2010-12-10 A | 2011-06-03 A | 100% |  | 2010-12-10 | 2011-06-03 | 126d? |  | finish no earlier than 2011-06-03 | C3 | 1008h | 1008h | NNI_DV | PCG-26 | Rel-10 | CP-50 | Jiwan | NTT | arai.kenjiro@lab.ntt.co.jp |
| 436 | 155 | Introduction of Smart Card Web Server launch functionality |  | 71d? | 2010-12-10 A | 2011-03-18 A | 100% |  | 2010-12-10 | 2011-03-18 | 71d? |  | finish no earlier than 2011-03-18 | C6 | 568h | 568h | SCWS_L | PCG-26 | Rel-10 | CP-50 | Xavier | Telecom Italia | davide.pratone@telecomitalia.it |
| 437 | 156 | USAT using AT Commands |  | 71d? | 2010-12-10 A | 2011-03-18 A | 100% |  | 2010-12-10 | 2011-03-18 | 71d? |  | finish no earlier than 2011-03-18 | C6 | 568h | 568h | USAT_AT | PCG-26 | Rel-10 | CP-50 | Xavier | Giesecke & Devrient | enric.fort@gi-de.com |
| 438 | 157 | **SRVCC enhancements (Stage 3)** |  | 261d? | 2010-12-10 A | 2011-12-09 | 56% | 114.01d? | 2010-12-10 | 2011-12-09 | 261d? | 260d |  | C1,C4,IETF | 4022.4h | 1409.28h | eSRVCC | PCG-26 | Rel-10 | CP-50 | Frederic | China Mobile | Jiang Y (jiangyi@chinamobile.com) |
| 439 | 157.1 | CT1 part of Stage 3 for SRVCC enhancements - Stage 3 |  | 71d? | 2010-12-10 A | 2011-03-18 A | 100% |  | 2010-12-10 | 2011-03-18 | 71d? |  | finish no earlier than 2011-03-18 | C1 | 568h | 568h | eSRVCC | PCG-26 | Rel-10 | CP-50 | Frederic | China Mobile | Jiang Y (jiangyi@chinamobile.com) |
| 440 | 157.2 | CT4 part of Stage 3 for SRVCC enhancements - Stage 3 |  | 71d? | 2010-12-10 A | 2011-03-18 A | 100% |  | 2010-12-10 | 2011-03-18 | 71d? |  | finish no earlier than 2011-03-18 | C4 | 568h | 568h | eSRVCC | PCG-26 | Rel-10 | CP-50 | Kimmo | China Mobile | Jiang Y (jiangyi@chinamobile.com) |
| 441 | 157.3 | (IETF) CT1 part of Stage 3 for SRVCC enhancements - Stage 3 |  | 170.8d? | 2010-12-10 A | 2011-12-09 | 20% | 136.64d? | 2010-12-10 | 2011-12-09 | 170.8d? | 260d | finish no earlier than 2011-12-09 | C1-IETF | 1366.4h | 273.28h | eSRVCC | PCG-27 | Rel-10 | CP-52 | Frederic | China Mobile |  |
| 442 | 158 | SRVCC in alerting phase (Stage 3) |  | 126d? | 2010-12-10 A | 2011-06-03 A | 100% |  | 2010-12-10 | 2011-06-03 | 126d? |  | finish no earlier than 2011-06-03 | C1 | 1008h | 1008h | aSRVCC | PCG-26 | Rel-10 | CP-50 | Frederic | ZTE | li.shitao@zte.com.cn |
| 443 | 159 | **PCRF failure and restoration** |  | 71d? | 2010-12-10 A | 2011-03-18 A | 100% |  | 2010-12-10 | 2011-03-18 | 71d? |  |  | C4,C3 | 1562h | 1562h | PCRF_FR | PCG-26 | Rel-10 | CP-50 | Kimmo | NEC | Toshiyuki Tamura (tamurato@aj.jp.nec.com) |
| 444 | 159.1 | CT4 part of PCRF failure and restoration |  | 71d? | 2010-12-10 A | 2011-03-18 A | 100% |  | 2010-12-10 | 2011-03-18 | 71d? |  | finish no earlier than 2011-03-18 | C4 | 568h | 568h | PCRF_FR | PCG-26 | Rel-10 | CP-50 | Kimmo | NEC | Toshiyuki Tamura (tamurato@aj.jp.nec.com) |
| 445 | 159.2 | CT3 part of PCRF failure and restoration |  | 53.25d? | 2010-12-10 A | 2011-03-18 A | 100% |  | 2010-12-10 | 2011-03-18 | 53.25d? |  | start no earlier than 2010-12-10 | C3 | 426h | 426h | PCRF_FR | PCG-26 | Rel-10 | CP-50 | Jiwan | NEC | Toshiyuki Tamura (tamurato@aj.jp.nec.com) |
| 446 | 160 | Formalization of WLAN Files | milestone | 0d? | 2011-02-23 A | 2011-03-18 A | 100% |  | 2011-02-23 | 2011-03-18 | 0d? |  | start no earlier than 2011-03-16 | C1 |  |  | FoWF | PCG-26 | Rel-10 | CP-51 | Frederic | Deutsche Telekom | dieter.jacobsohn@telekom.de |
| 447 | 161 | CS and IMS Interworking for CAT service - Early Session model |  | 58d? | 2011-03-16 A | 2011-06-03 A | 100% |  | 2011-03-16 | 2011-06-03 | 58d? |  |  | C3 | 464h | 464h | CIIC_ES | PCG-26 | Rel-10 | CP-51 | Jiwan | ZTE | li.shitao@zte.com.cn |
| 448 | 162 | EPC Node Restoration (without Idle mode Signalling Reduction ISR activated) |  | 3d? | 2011-03-16 A | 2011-03-18 A | 100% |  | 2011-03-16 | 2011-03-18 | 3d? |  | finish no earlier than 2011-03-18 | C4 | 24h | 24h | EPC_NR | PCG-26 | Rel-10 | CP-51 | Kimmo | Alcatel-Lucent | bruno.landais@alcatel-lucent.com |
| 449 | 163 | EPC Node Restoration with Idle mode Signalling Reduction (ISR) activated |  | 58d? | 2011-03-16 A | 2011-06-03 A | 100% |  | 2011-03-16 | 2011-06-03 | 58d? |  | finish no earlier than 2011-03-18 | C4 | 464h | 464h | EPC_NR_ISR | PCG-26 | Rel-10 | CP-51 | Kimmo | NEC | Toshiyuki Tamura (tamurato@aj.jp.nec.com) |
| 450 | 164 | Mobile Terminating Roaming Forwarding with pre-paging |  | 58d? | 2011-03-16 A | 2011-06-03 A | 100% |  | 2011-03-16 | 2011-06-03 | 58d? |  | finish no earlier than 2011-03-18 | C4 | 464h | 464h | MTRF | PCG-26 | Rel-10 | CP-51 | Kimmo | Ericsson | philip.hodges@ericsson.com |

Notes:
- 424: umbrella Feature / Text3: TR 30.820
- 425: SP#51 completed. RAT differentiation for charging. Completes Rel-8 Feature IWLAN_Mob UID_370049 Mobility between 3GPP-WLAN Interworking and 3GPP Systems. Cooperation with CT1,CT3 on affected protocols / Text3: 32.240, 32.252, 32.298, 32.299
- 426: CP#52 completed. SP#51 completed SA5. Continuation of Rel-8 BB UID_80042: Advice of Charge (AoC) support in IMS Charging (IMSTSS). Stage 2/3 work
- 427: SP#51 completed. SA1 Stage 1 in 22.115 / Text3: 32.275, 32.280, 32.298, 32.299
- 428: CP#52 completed. SA1 Stage 1 in 22.115, 22.173, 22.024. Add mobile-specific CAI format and volume charging elements. Extensions to existing AoC XML / Text3: 24.647
- 429: CP#51 completed. Ensure protocol alignment between 3GPP Stage 3 IMS work and IETF. Review capabilities provided in SIP by IETF and document whether these capabilities are supported in the IM CN Subsystem or not / Text3: 23.218, 24.229, 24.930
- 430: CP#51 completed. Specify CRUD (Create/Read/Update/Delete) operations based on SOAP protocol, which may be used by the applications having no high real-time requirement to the data access operations / Text3: 29.335
- 431: CP#51 completed. Improvements of Rel-9 Feature UID_440027 Operational description of the Inter-IMS Network to Network Interface (II-NNI) / Text3: 29.165
- 432: CP#51 completed. Specify 1) IMS-related AT-commands to configure MT and 2) IMS-related unsolicited response codes from MT to present to end-user / Text3: 27.007
- 433: CP#51 completed / Text3: 27.007
- 434: CT#51 completed. Stage 1 in TS 22.038 USAT service description. Linked to CT6's UID_1273 Rel-5 BB Provisioning of IP-based multimedia services (24.229, 31.103) and UID_390021 Rel-8 BB CT6 aspects of SAE (31.102, 31.111) / Text3: 31.102, 31.103, 31.111
- 435: CP#52 completed. Linked to CT3 Rel-10 Feature UID_480014 Further improvements of II-NNI Stage 3 based on operational feedback and evolution of other specifications (II-NNI2) / Text3: 29.165
- 436: CP#51 completed. Define a solution which allows enabling to launch Smart Card Web Server services in an easy and simple manner / Text3: 31.102
- 437: CP#51 completed. Stage 3 based on SA1 22.038CR#37r1 (Make USAT proactive capability reqs applicable to ME as a whole without regard to any particular configuration; e.g. a modem connected to an external display). Linked to CT1 Feature UID_ / Text3: Stage 3 31.102, 31.111
- 438: Triggered by SA2 TR 23.856 Study on Single Radio Voice Call Continuity enhancements (FS_eSRVCC) UID_440049 / Text3: Stage 3
- 439: CP#51 completed / Text3: 24.229, 24.237
- 440: CP#51 completed / Text3: 23.003, 23.008, 29.002, 29.230, 29.272, 29.305, 29.328, 29.329
- 441: Not completed internet-draft / Text3: draft-holmberg-sipcore-proxy-feature
- 442: CP#52 completed. Builds on Rel-8 UID_390057 (IMS-Cont) TS 23.216 Stage 2. Provide Stage 3 for SRVCC PS-CS transfer of a call in alerting phase. Stage 2 TEI10 in TS 23.237 (6.3.2.1.4c/d, 6.3.2.1.7a/b) / Text3: 24.008, 24.237
- 443: CP#51 completed. Triggered by CT3 TR 29.816 Study on Policy and Charging Rules Function (PCRF) failure and restoration (FS_PCRF-FR) UID_450013 / Text3: Stage 2/3 work
- 444: CP#51 completed / Text3: Stage 2 23.007, Stage 3 29.230
- 445: CP#51 completed / Text3: Stage 3 29.212, 29.213, 29.214, 29.215
- 446: CP#51 completed. TS 24.235 for Info+Approval. Define the ME files as specified in 24.234 in OMA Device Management structure / Text3: Stage 3: 24.234, new 24.235
- 447: CP#52 completed. Stage 1 in Rel-8 TS 22.182 Customized Alerting Tones (CAT) service. Stage 3 TS 24.182 defines 3 impl models: Gateway, Forking, Early Session. Specify missing CAT service interworking procedures btw CS & IMS networks / Text3: Stage 3 29.163, 29.235, 29.292
- 448: CP#51 completed. Triggered by DRAFT TR 23.857 Study on EPC Nodes Restoration (FS_EPC_NR) UID_490014 / Text3: Stage 2/3: 23.007, 29.274
- 449: CP#52 completed. Triggered by DRAFT TR 23.857 Study on EPC Nodes Restoration (FS_EPC_NR) UID_490014 / Text3: Stage 2/3: 23.007, 29.274
- 450: CP#52 completed. Provides Stage 2/3 alternative solution to Mobile Terminating Roaming Retry to solve roaming events during paging, in particular to support CSFB. Hence, no new Stage 1 requirements exist / Text3: Stage 2/3: 23.012, 23.018, 23.116, 29.002

| ID | WBS | Task | Duration | Start | Finish | Complete | Remaining | Baseline start | Baseline finish | Baseline duration | Total slack | Constraint | Resources | Work | Actual work | Text1 | Text2 | Text4 | Text6 | Text7 | Text8 | Text9 | Text12 | Text11 |
| --- | --- | --- | --- | --- | --- | --- | --- | --- | --- | --- | --- | --- | --- | --- | --- | --- | --- | --- | --- | --- | --- | --- | --- | --- |
| 451 | 165 | **UICC access to IMS Specification** | 58d? | 2011-03-16 A | 2011-06-03 A | 100% |  | 2011-03-16 | 2011-06-03 | 58d? |  |  | C6,C1 | 952h | 952h | IMS-UICC-S | PCG-26 | Gemalto | Rel-10 | CP-51 | Xavier |  |  |  |
| 452 | 165.1 | CT6 part of UICC access to IMS Specification | 3d? | 2011-03-16 A | 2011-03-18 A | 100% |  | 2011-03-16 | 2011-03-18 | 3d? |  | start no earlier than 2011-03-16 | C6 | 24h | 24h | IMS-UICC-S | PCG-26 | Gemalto | Rel-10 | CP-51 | Xavier |  |  |  |
| 453 | 165.2 | CT1 part of UICC access to IMS Specification | 58d? | 2011-03-16 A | 2011-06-03 A | 100% |  | 2011-03-16 | 2011-06-03 | 58d? |  | start no earlier than 2011-03-16 | C1 | 464h | 464h | IMS-UICC-S | PCG-26 | Gemalto | Rel-10 | CP-51 | Frederic |  |  |  |
| 454 | 166 | **CN aspects of Local Call Local Switch** | 472d? | 2009-05-29 A | 2011-03-18 A | 100% |  | 2009-05-29 | 2011-03-18 | 472d? |  |  | C4 | 13008h | 13008h | LCLS-CN | PCG-23 | Vodafone | Rel-10 | CP-44 | Kimmo |  |  |  |
| 455 | 166.1 | TR on CN aspects of Local Call Local Switch | 341d? | 2009-05-29 A | 2010-09-16 A | 100% |  | 2009-05-29 | 2010-09-16 | 341d? |  | finish no earlier than 2010-09-17 | C4 | 2728h | 2728h | LCLS-CN | PCG-23 | Vodafone | Rel-10 | CP-44 | Kimmo |  |  |  |
| 456 | 166.2 | CN aspects of Local Call Local Switch | 131d? | 2010-09-17 A | 2011-03-18 A | 100% |  | 2010-09-17 | 2011-03-18 | 131d? |  | finish no earlier than 2011-03-18 | C4 | 1048h | 1048h | LCLS-CN | PCG-25 | Vodafone | Rel-10 | CP-49 | Kimmo |  |  |  |
| 457 | 166.3 | Deleted - CT3 aspects of Local Call Local Switch | 341d? | 2009-05-29 A | 2010-09-16 A | 100% |  | 2009-05-29 | 2010-09-16 | 341d? |  | finish no earlier than 2010-09-17 | C3 | 2728h | 2728h | LCLS-CN | PCG-23 | Vodafone | Rel-10 | CP-44 | Jiwan | PCG-25 | CP-49 |  |
| 458 | 166.4 | Deleted - CT1 aspects of Local Call Local Switch | 341d? | 2009-05-29 A | 2010-09-16 A | 100% |  | 2009-05-29 | 2010-09-16 | 341d? |  | finish no earlier than 2010-09-17 | C1 | 2728h | 2728h | LCLS-CN | PCG-23 | Vodafone | Rel-10 | CP-44 | Frederic | PCG-25 | CP-49 |  |
| 459 | 167 | Local Call Local Switch | 1055.8d? | 2007-05-07 A | 2011-05-20 A | 100% |  | 2007-05-07 | 2011-05-20 | 1055.8d? |  |  | GP,G2 | 8446.4h | 8446.4h | LCLS | PCG-22 | Huawei | Rel-10 | GP-41 | Paolo |  |  |  |
| 460 | 168 | **Tightened Link Level Performance Requirements for Single Antenna MS** | 261d? | 2010-09-03 A | 2011-09-02 | 59% | 105.94d? | 2010-09-03 | 2011-09-02 | 261d? | 330d |  | G1,G2,C1,G3new | 7232h | 4296.46h | TIGHTER | PCG-25 | Renesas | Rel-10 | GP-46 | Paolo |  |  |  |
| 461 | 168.1 | CT1 part for TIGHTER | 196d? | 2010-09-03 A | 2011-06-03 A | 100% |  | 2010-09-03 | 2011-06-03 | 196d? |  | finish no earlier than 2011-06-03 | C1 | 1568h | 1568h | TIGHTER | PCG-25 | Renesas | Rel-10 | GP-46 | Frederic |  |  |  |
| 462 | 168.2 | TIGHTER Performance Requirements | 186d? | 2010-09-03 A | 2011-05-20 A | 100% |  | 2010-09-03 | 2011-05-20 | 186d? |  | finish no earlier than 2011-05-20 | G1,G2 | 1488h | 1488h | TIGHTER | PCG-25 | Renesas | Rel-10 | GP-46 | Paolo |  |  |  |
| 463 | 168.3 | TIGHTER Testing | 261d? | 2010-09-03 | 2011-09-02 |  |  | 2010-09-03 | 2011-09-02 | 261d? | 330d | finish no earlier than 2011-09-02 | G3new,G1,G2 | 2088h |  | TIGHTER | PCG-25 | Renesas | Rel-10 | GP-46 | Ingbert |  |  |  |
| 464 | 169 | **Support of Multi-Operator Core Network by GERAN** | 206d? | 2010-05-21 A | 2011-03-04 A | 100% |  | 2010-05-21 | 2011-03-04 | 206d? |  |  | G2,S2,C1 | 5096h | 5096h | MOCN-GERAN | PCG-25 | Alcatel-Lucent | Rel-10 | GP-47 | Gert |  |  |  |
| 465 | 169.1 | Stage 2 for Support of Multi-Operator Core Network by GERAN | 150d? | 2010-05-21 A | 2010-12-16 A | 100% |  | 2010-05-21 | 2010-12-16 | 150d? |  | finish no earlier than 2010-12-15 | S2 | 1200h | 1200h | MOCN-GERAN | PCG-25 | Alcatel-Lucent | Rel-10 | GP-47 | Maurice |  |  |  |
| 466 | 169.2 | CT1 part of Stage 3 for Support of Multi-Operator Core Network by GERAN | 146d? | 2010-05-21 A | 2010-12-10 A | 100% |  | 2010-05-21 | 2010-12-10 | 146d? |  | finish no earlier than 2010-12-10 | C1 | 1168h | 1168h | MOCN-GERAN | PCG-25 | Alcatel-Lucent | Rel-10 | GP-47 | Frederic |  |  |  |
| 467 | 169.3 | GERAN2 part of Stage 3 for Support of Multi-Operator Core Network by GERAN | 135d? | 2010-08-30 A | 2011-03-04 A | 100% |  | 2010-08-30 | 2011-03-04 | 135d? |  | finish no earlier than 2011-03-04 | G2 | 1080h | 1080h | MOCN-GERAN | PCG-25 | Alcatel-Lucent | Rel-10 | GP-47 | Gert |  |  |  |
| 468 | 170 | **Enhancements of Iur-g interface** | 196d? | 2010-09-03 A | 2011-06-03 A | 100% |  | 2010-09-03 | 2011-06-03 | 196d? |  |  | G2,R3 | 4184h | 4184h | eIurg | PCG-25 | China Mobile, ZTE | Rel-10 | GP-47 | Gert |  |  |  |
| 469 | 170.1 | GERAN part for Enhancements of Iur-g interface (Stage 2/3) | 131d? | 2010-09-03 A | 2011-03-04 A | 100% |  | 2010-09-03 | 2011-03-04 | 131d? |  | finish no earlier than 2011-03-04 | G2 | 1048h | 1048h | eIurg-GERAN | PCG-25 | China Mobile, ZTE | Rel-10 | GP-47 | Gert |  |  |  |
| 470 | 170.2 | Core part: Enhancements of Iur-g interface (Stage 2/3) | 196d? | 2010-09-03 A | 2011-06-03 A | 100% |  | 2010-09-03 | 2011-06-03 | 196d? |  | finish no earlier than 2011-06-03 | R3 | 1568h | 1568h | eIurg-RAN | PCG-25 | ZTE | Rel-10 | RP-49 | Juha |  |  | RP-110526 |
| 471 | 171 | 1.28 Mcps TDD Repeater | 599d? | 2007-12-04 A | 2010-03-19 A | 100% |  | 2007-12-04 | 2010-03-19 | 599d? |  | finish no earlier than 2010-03-19 | R4 | 4792h | 4792h | RANimp-Repeaters1.28TDD | PCG-21 | RITT | Rel-10 | RP-38 | Issam |  |  | RP-100039 |
| 472 | 172 | 1.28 Mcps TDD Multi-carrier HSUPA | 321d? | 2009-09-18 A | 2010-12-10 A | 100% |  | 2009-09-18 | 2010-12-10 | 321d? |  | finish no earlier than 2010-12-10 | R1,R2,R3,R4 | 2568h | 2568h | TDD_MC_HSUPA | PCG-23 | CATR | Rel-10 | RP-45 | Patrick |  |  | RP-101079 |
| 473 | 173 | **1.28 Mcps TDD Home NodeB RF requirements** | 266d? | 2009-12-04 A | 2010-12-10 A | 100% |  | 2009-12-04 | 2010-12-10 | 266d? |  |  | R4 | 5304h | 5304h | HNB_LCRTDD_RF | PCG-24 | TD Tech | Rel-10 | RP-46 | Issam |  |  |  |
| 474 | 173.1 | Core part: 1.28Mcps TDD Home NodeB RF requirements | 131d? | 2009-12-04 A | 2010-06-04 A | 100% |  | 2009-12-04 | 2010-06-04 | 131d? |  | finish no earlier than 2010-12-10 | R4 | 1048h | 1048h | HNB_LCRTDD_RF-Core | PCG-24 | TD Tech | Rel-10 | RP-46 | Issam |  |  | RP-100446 |
| 475 | 173.2 | Perf. part: 1.28Mcps TDD Home NodeB RF requirements | 266d? | 2009-12-04 A | 2010-12-10 A | 100% |  | 2009-12-04 | 2010-12-10 | 266d? |  | finish no earlier than 2010-12-10 | R4 | 2128h | 2128h | HNB_LCRTDD_RF-Perf | PCG-24 | TD Tech | Rel-10 | RP-46 | Issam |  |  | RP-101081 |

Notes:
- 451: CP#52 completed. Triggered by Rel-10 TR 31.828 Study on UICC access to IMS (FS_IMS-UICC) UID_480017. Specify mechanism in UICC and ME to make use of IMS functionality implemented in ME for case a) an ISIM is present b) no ISIM is present in UICC / Text5: Denis.Lheriteau@gemalto.com
- 452: CP#51 completed / Text3: 31.102, 31.103, 31.111 / Text5: Denis.Lheriteau@gemalto.com
- 453: CP#52 completed / Text3: 24.229 / Text5: Denis.Lheriteau@gemalto.com
- 454: CP#51 completed / Text3: GERAN Stage 2/3 / Text5: David.Hutton@vodafone.com
- 455: CT#49 completed / Text3: new TR 23.889 / Text5: David.Hutton@vodafone.com
- 456: CP#51 completed / Text3: 23.003, 23.009, 23.205, 23.231, 29.002, 29.205, 29.232, new TS 23.284 / Text5: David.Hutton@vodafone.com
- 457: CP#49 stopped. Result of study TR 23.889: no CT3 specification impact / Text5: David.Hutton@vodafone.com
- 458: CP#49 stopped. Result of study TR 23.889: no CT1 specification impact / Text5: David.Hutton@vodafone.com
- 459: GP#50 completed. GP#41 WID approved / Text3: GERAN Stage 3: 48.008, 48.103 / Text5: wang_zhixi@huawei.com
- 460: CP#52 completed. GP#50 completed (exceptTesting). GP#46 approved WID / Text3: GERAN / Text5: carsten.juncker@renesasmobile.com
- 461: CP#52 completed / Text3: 24.008 / Text5: marko.niemi@renesasmobile.com
- 462: GP#50 completed / Text3: 45.005, 45.015 / Text5: carsten.juncker@renesasmobile.com
- 463: - / Text3: 51.010 / Text5: carsten.juncker@renesasmobile.com
- 464: GP#49 completed. SP/CP#50 completed. GP#47 approved WID. 900 MHz spectrum re-farming to other RATs lead operators to reduce GSM capacity and therefore share their GSM networks. Hence the need for the most suitable (GE)RAN sharing method / Text3: GERAN / Text5: michel.robert@alcatel-lucent.com
- 465: SP#50 completed / Text3: 23.251 / Text5: michel.robert@alcatel-lucent.com
- 466: CP#50 completed / Text3: 24.008 CR#1644 / Text5: michel.robert@alcatel-lucent.com
- 467: GP#49 completed / Text3: 48.008 CR#0325, 48.018 CR#0303 / Text5: michel.robert@alcatel-lucent.com
- 468: RP#52 completed. GP#49 completed. GP#47 approved WID / Text3: GERAN,UTRA / Text5: Ms Juan Deng (dengjuan@chinamobile.com), Xinhui Wang (wangxinhui@zte.com.cn)
- 469: GP#49 completed. GP#48 updated WID GP-101659=>GP-101758 (restricting the scope to GERAN BSC and TD-SCDMA RNC only). GP#47 approved WID / Text3: 43.130, 48.008 / Text5: Ms Juan Deng (dengjuan@chinamobile.com), Xinhui Wang (wangxinhui@zte.com.cn)
- 470: RP#52 completed / Text3: UTRA Stage 2 (25.401, 25.420), Stage 3 (25.423) / Text5: Liu Junqiang (liu.junqiang@zte.com.cn)
- 471: RP#47 completed / Text3: UTRA 25.113, new 25.116, 25.153 (testing) / Text5: qinyan@chinattl.com
- 472: RP#50 completed / Text3: UTRA 25.102, 25.105, 25.123, 25.221, 25.222, 25.223, 25.224, 25.225, 25.306, 25.319, 25.321, 25.331, 25.423, 25.427, 25.433 / Text5: Aihui Song (songaihui@mail.ritt.com.cn)
- 473: RP#50 completed. Triggered by FS_RAN-HNBLCRTDD UID_410016 Study on 1.28 Mcps TDD Home NodeB (TR 25.866) / Text3: UTRA / Text5: Li Rong (lirong@td-tech.com)
- 474: RP#48 completed / Text3: 25.105 / Text5: Li Rong (lirong@td-tech.com)
- 475: RP#50 completed. TR 25.968 v100 for Approval / Text3: 25.142, new TR 25.968 / Text5: Li Rong (lirong@td-tech.com)

| ID | WBS | Task | Duration | Start | Finish | Complete | Remaining | Baseline start | Baseline finish | Baseline duration | Total slack | Constraint | Resources | Work | Actual work | Text1 | Text2 | Text4 | Text5 | Text6 | Text7 | Text8 | Text11 | Text9 | Text12 |
| --- | --- | --- | --- | --- | --- | --- | --- | --- | --- | --- | --- | --- | --- | --- | --- | --- | --- | --- | --- | --- | --- | --- | --- | --- | --- |
| 476 | 174 | **Multi-User Multiple-Input and Multiple-Output (MU-MIMO) for 1.28Mcps TDD** | 316d? | 2010-03-19 A | 2011-06-03 A | 100% |  | 2010-03-19 | 2011-06-03 | 316d? |  |  | R1,R2,R3,R4 | 6584h | 6584h | MUMIMO_LCR_TDD | PCG-24 | CATT | Yanping Xing (xingyanping@datangmobile.cn) | Rel-10 | RP-47 | Patrick |  |  |  |
| 477 | 174.1 | Core part: MU-MIMO for 1.28Mcps TDD | 191d? | 2010-03-19 A | 2010-12-10 A | 100% |  | 2010-03-19 | 2010-12-10 | 191d? |  | finish no earlier than 2010-12-10 | R1,R2,R3 | 1528h | 1528h | MUMIMO_LCR_TDD-Core | PCG-24 | CATT | Yanping Xing (xingyanping@datangmobile.cn) | Rel-10 | RP-47 | Patrick | RP-101085 |  |  |
| 478 | 174.2 | Perf. part: MU-MIMO for 1.28Mcps TDD | 316d? | 2010-03-19 A | 2011-06-03 A | 100% |  | 2010-03-19 | 2011-06-03 | 316d? |  | finish no earlier than 2011-06-03 | R4 | 2528h | 2528h | MUMIMO_LCR_TDD-Perf | PCG-24 | CATT | Sanjun Feng (fengsanjun@datangmobile.cn) | Rel-10 | RP-47 | Issam | RP-110520 |  |  |
| 479 | 175 | **AGNSS Minimum Performance for UTRAN** | 521d? | 2009-09-18 A | 2011-09-16 | 97% | 13.32d? | 2009-09-18 | 2011-09-16 | 521d? | 320d |  | R4,R5 | 9424h | 9183.02h | AGNSSPerf_UTRAN | PCG-23 | Thales | Michel.monnerat@thalesaleniaspace.com | Rel-10 | RP-45 | Issam |  |  |  |
| 480 | 175.1 | AGNSS Minimum Performance Specification Development | 321d? | 2009-09-18 A | 2010-12-10 A | 100% |  | 2009-09-18 | 2010-12-10 | 321d? |  | finish no earlier than 2010-12-10 | R4 | 2568h | 2568h | AGNSSPerf_UTRAN | PCG-23 | Thales | Michel.monnerat@thalesaleniaspace.com | Rel-10 | RP-45 | Issam | RP-101078 |  |  |
| 481 | 175.2 | AGNSS test case development for UMTS | 336d? | 2010-06-04 A | 2011-09-16 | 95% | 16.8d? | 2010-06-04 | 2011-09-16 | 336d? | 320d | finish no earlier than 2011-09-16 | R5 | 2688h | 2553.6h | AGNSSTest_UTRAN | PCG-25 | Thales | Michel.monnerat@thalesaleniaspace.com | Rel-10 | RP-48 | Ingbert | RP-110506 |  |  |
| 482 | 176 | **Inclusion of RF Pattern Matching Technologies as positioning method in the UTRAN** | 336d? | 2009-12-04 A | 2011-03-18 A | 100% |  | 2009-12-04 | 2011-03-18 | 336d? |  |  | R2,R3 | 5376h | 5376h | LCS_UMTS_RFPMT | PCG-24 | Polaris Wireless | Norman Shaw (nshaw@polariswireless.com) | Rel-10 | RP-46 | Joern | RP-110048 |  |  |
| 483 | 176.1 | Core part: Inclusion of RF Pattern Matching Technologies as positioning method in the UTRAN | 336d? | 2009-12-04 A | 2011-03-18 A | 100% |  | 2009-12-04 | 2011-03-18 | 336d? |  | finish no earlier than 2011-03-18 | R2,R3 | 2688h | 2688h | LCS_UMTS_RFPMT-Core | PCG-24 | Polaris Wireless | Norman Shaw (nshaw@polariswireless.com) | Rel-10 | RP-46 | Joern | RP-110048 |  |  |
| 484 | 177 | **Four carrier HSDPA** | 466d? | 2009-12-04 A | 2011-09-16 | 91% | 40.62d? | 2009-12-04 | 2011-09-16 | 466d? | 320d |  | R1,R2,R3,R4 | 10144h | 9259.88h | 4C_HSDPA | PCG-24 | Qualcomm | Arjun Bharadwaj (arjunb@qualcomm.com) | Rel-10 | RP-46 | Patrick |  |  |  |
| 485 | 177.1 | Core part: Four carrier HSDPA | 336d? | 2009-12-04 A | 2011-03-18 A | 100% |  | 2009-12-04 | 2011-03-18 | 336d? |  | finish no earlier than 2011-03-18 | R1,R2,R3,R4 | 2688h | 2688h | 4C_HSDPA-Core | PCG-24 | Qualcomm | Arjun Bharadwaj (arjunb@qualcomm.com) | Rel-10 | RP-46 | Patrick | RP-110046 |  |  |
| 486 | 177.2 | Perf. part: Four carrier HSDPA | 466d? | 2009-12-04 A | 2011-09-16 | 85% | 69.9d? | 2009-12-04 | 2011-09-16 | 466d? | 320d | finish no earlier than 2011-09-16 | R4 | 3728h | 3168.8h | 4C_HSDPA-Perf | PCG-24 | Qualcomm | Arjun Bharadwaj (arjunb@qualcomm.com) | Rel-10 | RP-46 | Issam | RP-110519 |  |  |
| 487 | 178 | **Performance Requirements for two-antenna 1.28Mcps TDD Type 1 and Type 2 UE receiver** | 316d? | 2010-03-19 A | 2011-06-03 A | 100% |  | 2010-03-19 | 2011-06-03 | 316d? |  |  | R4 | 5504h | 5504h | 2ant_UE_LCR_TDD | PCG-24 | TD Tech | dafei.wang@td-tech.com | Rel-10 | RP-47 | Issam |  |  |  |
| 488 | 178.1 | Core part: Performance Requirements for two-antenna 1.28Mcps TDD Type 1 and Type 2 UE receiver | 56d? | 2010-03-19 A | 2010-06-04 A | 100% |  | 2010-03-19 | 2010-06-04 | 56d? |  | finish no earlier than 2010-06-04 | R4 | 448h | 448h | 2ant_UE_LCR_TDD-Core | PCG-24 | TD Tech | dafei.wang@td-tech.com | Rel-10 | RP-47 | Issam | RP-100454 |  |  |
| 489 | 178.2 | Perf. part: Performance Requirements for two-antenna 1.28Mcps TDD Type 1 and Type 2 UE receiver | 316d? | 2010-03-19 A | 2011-06-03 A | 100% |  | 2010-03-19 | 2011-06-03 | 316d? |  | finish no earlier than 2011-06-03 | R4 | 2528h | 2528h | 2ant_UE_LCR_TDD-Perf | PCG-24 | TD Tech | dafei.wang@td-tech.com | Rel-10 | RP-47 | Issam | RP-110521 |  |  |
| 490 | 179 | **Automatic Neighbour Relation (ANR) for UTRAN** | 261d? | 2010-06-04 A | 2011-06-03 A | 100% |  | 2010-06-04 | 2011-06-03 | 261d? |  |  | R3,R2 | 4176h | 4176h | ANR_UTRAN | PCG-25 | ZTE | Zhai.hengxing@zte.com.cn | Rel-10 | RP-48 | Juha |  |  |  |
| 491 | 179.1 | Core part: Automatic Neighbour Relation (ANR) for UTRAN | 261d? | 2010-06-04 A | 2011-06-03 A | 100% |  | 2010-06-04 | 2011-06-03 | 261d? |  | finish no earlier than 2011-06-03 | R3,R2 | 2088h | 2088h | ANR_UTRAN-Core | PCG-25 | ZTE | Zhai.hengxing@zte.com.cn | Rel-10 | RP-48 | Juha | RP-110522 |  |  |
| 492 | 180 | **Support of New Band Combinations for Dual-Band Dual Cell HSDPA** | 261d? | 2010-06-04 A | 2011-06-03 A | 100% |  | 2010-06-04 | 2011-06-03 | 261d? |  |  | R4,R2 | 4784h | 4784h | DB_DC_HSDPA | PCG-25 | AT&T | Vince Spatafora (vs5785@att.com) | Rel-10 | RP-48 | Issam |  |  |  |
| 493 | 180.1 | Core part: Support of New Band Combinations for Dual-Band Dual Cell HSDPA | 261d? | 2010-06-04 A | 2011-06-03 A | 100% |  | 2010-06-04 | 2011-06-03 | 261d? |  | finish no earlier than 2011-06-03 | R4,R2 | 2088h | 2088h | DB_DC_HSDPA-Core | PCG-25 | AT&T | Vince Spatafora (vs5785@att.com) | Rel-10 | RP-48 | Issam | RP-110523 |  |  |
| 494 | 180.2 | Deleted - Perf. part: Support of New Band Combinations for Dual-Band Dual Cell HSDPA | 76d? | 2010-06-04 A | 2010-09-17 A | 100% |  | 2010-06-04 | 2010-09-17 | 76d? |  | finish no earlier than 2010-09-17 | R4,R2 | 608h | 608h | DB_DC_HSDPA-Perf | PCG-25 | AT&T | Vince Spatafora (vs5785@att.com) | Rel-10 | RP-48 | Issam | RP-100759 | PCG-25 | RP-49 |
| 495 | 181 | **MIMO operation with non-MIMO coexistence in HSDPA** | 466d? | 2010-06-04 A | 2012-03-16 | 65% | 163.2d? | 2010-06-04 | 2012-03-16 | 466d? | 190d |  | R4 | 9392h | 6102.81h | MIMO_HSDPA | PCG-25 | Qualcomm | Heechoon Lee | Rel-10 | RP-48 | Issam |  |  |  |
| 496 | 181.1 | Core part: MIMO operation with non-MIMO coexistence in HSDPA | 186d? | 2010-09-17 A | 2011-06-03 A | 100% |  | 2010-09-17 | 2011-06-03 | 186d? |  | finish no earlier than 2011-06-03 | R4 | 1488h | 1488h | MIMO_HSDPA-Core | PCG-25 | Qualcomm | Heechoon Lee | Rel-10 | RP-49 | Issam | RP-110524 |  |  |
| 497 | 181.2 | Perf. part: MIMO operation with non-MIMO coexistence in HSDPA | 261d? | 2010-06-04 A | 2011-06-03 A | 100% |  | 2010-06-04 | 2011-06-03 | 261d? |  | finish no earlier than 2011-06-03 | R4 | 2088h | 2088h | MIMO_HSDPA-Perf | PCG-25 | Qualcomm | Heechoon Lee | Rel-10 | RP-48 | Issam | RP-110525 |  |  |
| 498 | 181.3 | Test part: MIMO operation with non-MIMO coexistence in HSDPA | 261d? | 2011-03-18 A | 2012-03-16 | 5% | 247.95d? | 2011-03-18 | 2012-03-16 | 261d? | 190d | finish no earlier than 2012-03-16 | R5 | 2088h | 104.4h | MIMO_HSDPA-UEConTest | PCG-26 | Qualcomm | Shubhang Vora (svora@qualcomm.com) | Rel-10 | RP-51 | Ingbert | RP-110518 |  |  |
| 499 | 182 | Interfrequency detected set measurements for UMTS | 61d? | 2010-09-17 A | 2010-12-10 A | 100% |  | 2010-09-17 | 2010-12-10 | 61d? |  | finish no earlier than 2010-12-10 | R2,R4 | 488h | 488h | Interf_dset_meas_UMTS | PCG-25 | Nokia | Chris.callender@nokia.com | Rel-10 | RP-49 | Joern | RP-101093 |  |  |

Notes:
- 476: RP#52 completed / Text3: UTRA
- 477: RP#50 completed / Text3: 25.221, 25.222, 25.224, 25.306, 25.308, 25.319, 25.331, 25.423, 25.425, 25.433, 25.435
- 478: RP#52 completed / Text3: 25.102, 25.105, 25.142
- 479: Triggered by Rel-7 UID_20050 (GNSS in UTRAN) and Rel-8 UID_400051 (Support for Additional NSS). Linked to GERAN Rel-9 UID_38002 (A-GNSS Performances and Testing Procedures) / Text3: UTRA
- 480: RP#50 completed / Text3: new 25.172
- 481: RP#52 completion 06/11=>09/11 / Text3: 34.108, 34.109, 34.123-1, 34.123-2, 34.123-3, 36.37.571-5, new 34.172
- 482: RP#51 completed. Triggered by Study UID_380079 Evaluation of the inclusion of Path Loss Based Technology in the UTRAN (25.907) / Text3: UTRA
- 483: RP#51 completed / Text3: 25.305, 25.453
- 484: - / Text3: UTRA
- 485: RP#51 completed. RP#52 TR 25.864 v200 for Approval / Text3: 25.101, 25.104, 25.133, 25.211, 25.212, 25.213, 25.214, 25.215, 25.308, 25.331, 25.423, 25.433, 26.306, new TR 25.864
- 486: RP#52 completion 06/11=>09/11 / Text3: 25.101, 25.104, 25.133, 25.141
- 487: Stage 3. RP#52 completed / Text3: UTRA
- 488: RP#48 completed / Text3: 25.102
- 489: RP#52 completed / Text3: 25.102
- 490: RP#52 Core completed. Automatic Neighbour Relation (ANR) function for UTRAN relieves operators from the burden of manually managing the Neighbour cell Relations (NRs) / Text3: UTRA
- 491: RP#52 completed / Text3: 25.331, 25.413, 25.423, new TS 25.484 (Stage 2)
- 492: RP#52 completed. Rel-9 Dual-Band Dual-Cell HSDPA (UID_430015 Support for different bands for Dual-Cell HSDPA) has one combination per region in principle. This work adds additional combinations: Band I and XI (Region 3) and Band II and V (Region 2) / Text3: UTRA
- 493: RP#52 completed / Text3: 25.101, 25.104, 25.141, 25.317
- 494: RP#49 stopped (Reason: no need for Performance work) / Text3: 25.101, 25.104, 25.141, 25.317
- 495: RP#52 completed. RP#49 updated WID RP-100687=>RP-100993 (changed Title: MIMO Testing in HSDPA => MIMO operation with non-MIMO coexistence in HSDPA) / Text3: UTRA
- 496: RP#52 completed / Text3: 25.104
- 497: RP#52 completed / Text3: 25.101, 25.141
- 498: - / Text3: 34.108, 34.121-1, 34.121-2, 34.123-1, 34.123-2, 34.123-3
- 499: RP#50 completed / Text3: UTRA 25.133, 25.331

| ID | WBS | Task | Duration | Start | Finish | Complete | Remaining | Baseline start | Baseline finish | Baseline duration | Total slack | Constraint | Resources | Work | Actual work | Text1 | Text2 | Text4 | Text5 | Text6 | Text7 | Text8 | Text11 | Text9 | Text12 |
| --- | --- | --- | --- | --- | --- | --- | --- | --- | --- | --- | --- | --- | --- | --- | --- | --- | --- | --- | --- | --- | --- | --- | --- | --- | --- |
| 500 | 183 | **Extending 850 MHz Upper Band (814 – 849 MHz)** | 261d? | 2010-12-10 A | 2011-12-09 | 63% | 97.56d? | 2010-12-10 | 2011-12-09 | 261d? | 260d |  | R4,R2,R3,R5 | 6832h | 3530.8h | e850_UB | PCG-26 | Sprint | John.J.Humbert@Sprint.com | Rel-10 | RP-50 | Issam | Exception sheet in RP-110755 |  |  |
| 501 | 183.1 | Core part: Extending 850 MHz Upper Band (814 – 849 MHz) | 201d? | 2010-12-10 A | 2011-09-16 | 90% | 20.1d? | 2010-12-10 | 2011-09-16 | 201d? | 320d | finish no earlier than 2011-09-16 | R4,R2,R3 | 1608h | 1447.2h | e850_UB-Core | PCG-26 | Sprint | John.J.Humbert@Sprint.com | Rel-10 | RP-50 | Issam | RP-110780 |  |  |
| 502 | 183.2 | Perf. part: Extending 850 MHz Upper Band (814 – 849 MHz) | 201d? | 2010-12-10 A | 2011-09-16 | 90% | 20.1d? | 2010-12-10 | 2011-09-16 | 201d? | 320d | finish no earlier than 2011-09-16 | R4,R2,R3 | 1608h | 1447.2h | e850_UB-Perf | PCG-26 | Sprint | John.J.Humbert@Sprint.com | Rel-10 | RP-50 | Issam | RP-110534 |  |  |
| 503 | 183.3 | Test part: Extending 850 MHz Upper Band (814 – 849 MHz) | 191d? | 2011-03-18 A | 2011-12-09 | 5% | 181.45d? | 2011-03-18 | 2011-12-09 | 191d? | 260d | finish no earlier than 2011-12-09 | R5 | 1528h | 76.4h | e850_UB-UEConTest | PCG-26 | Sprint | John.J.Humbert@Sprint.com | Rel-10 | RP-51 | Ingbert | RP-110517 |  |  |
| 504 | 184 | **Carrier Aggregation for LTE** | 466d? | 2009-12-04 A | 2011-09-16 | 78% | 101.36d? | 2009-12-04 | 2011-09-16 | 466d? | 320d |  | R1,R2,R3,R4 | 10584h | 8281.95h | LTE_CA | PCG-24 | Nokia | Asbjorn.grovlen@nokia.com | Rel-10 | RP-46 | Patrick |  |  |  |
| 505 | 184.1 | Core part: Carrier Aggregation for LTE | 391d? | 2009-12-04 A | 2011-06-03 A | 100% |  | 2009-12-04 | 2011-06-03 | 391d? |  | finish no earlier than 2011-06-03 | R1,R2,R3,R4 | 3128h | 3128h | LTE_CA-Core | PCG-24 | Nokia | lars.e.lindh@nokia.com | Rel-10 | RP-46 | Patrick | RP-110535 |  |  |
| 506 | 184.2 | Perf. part: Carrier Aggregation for LTE | 466d? | 2009-12-04 A | 2011-09-16 | 60% | 186.4d? | 2009-12-04 | 2011-09-16 | 466d? | 320d | finish no earlier than 2011-09-16 | R4 | 3728h | 2236.8h | LTE_CA-Perf | PCG-24 | Nokia | lars.e.lindh@nokia.com | Rel-10 | RP-46 | Issam | RP-110536 |  |  |
| 507 | 185 | **Enhanced Downlink Multiple Antenna Transmission for LTE** | 391d? | 2009-12-04 A | 2011-06-03 | 78% | 84.12d? | 2009-12-04 | 2011-06-03 | 391d? | 395d |  | R1,R2,R4 | 8944h | 7019.87h | LTE_eDL_MIMO | PCG-24 | NTT DoCoMo | Hidekazu Taoka (taoka@nttdocomo.com) | Rel-10 | RP-46 | Patrick |  |  |  |
| 508 | 185.1 | Core part: Enhanced Downlink Multiple Antenna Transmission for LTE | 336d? | 2009-12-04 A | 2011-03-18 A | 100% |  | 2009-12-04 | 2011-03-18 | 336d? |  | finish no earlier than 2011-03-18 | R1,R2,R4 | 2688h | 2688h | LTE_eDL_MIMO-Core | PCG-24 | NTT DoCoMo | Hidekazu Taoka (taoka@nttdocomo.com) | Rel-10 | RP-46 | Patrick | RP-110067 |  |  |
| 509 | 185.2 | Perf. part: Enhanced Downlink Multiple Antenna Transmission for LTE | 391d? | 2009-12-04 A | 2011-06-03 | 60% | 156.4d? | 2009-12-04 | 2011-06-03 | 391d? | 395d | finish no earlier than 2011-06-03 | R4 | 3128h | 1876.8h | LTE_eDL_MIMO-Perf | PCG-24 | NTT DoCoMo | Hidekazu Taoka (taoka@nttdocomo.com) | Rel-10 | RP-46 | Issam | RP-110542 |  |  |
| 510 | 186 | **Uplink Multiple Antenna Transmission for LTE** | 466d? | 2009-12-04 A | 2011-09-16 | 89% | 50.68d? | 2009-12-04 | 2011-09-16 | 466d? | 320d |  | R1,R2,R4 | 10584h | 9432.97h | LTE_UL_MIMO | PCG-24 | Huawei | Mattias.wennstrom@huawei.com | Rel-10 | RP-46 | Patrick |  |  |  |
| 511 | 186.1 | Core part: UL multiple antenna transmission for LTE | 391d? | 2009-12-04 A | 2011-06-03 A | 100% |  | 2009-12-04 | 2011-06-03 | 391d? |  | finish no earlier than 2011-06-03 | R1,R2,R4 | 3128h | 3128h | LTE_UL_MIMO-Core | PCG-24 | Huawei | Mattias.wennstrom@huawei.com | Rel-10 | RP-46 | Patrick | RP-110537 |  |  |
| 512 | 186.2 | Perf. part: UL multiple antenna transmission for LTE | 466d? | 2009-12-04 A | 2011-09-16 | 80% | 93.2d? | 2009-12-04 | 2011-09-16 | 466d? | 320d | finish no earlier than 2011-09-16 | R4 | 3728h | 2982.4h | LTE_UL_MIMO-Perf | PCG-24 | Huawei | Mattias.wennstrom@huawei.com | Rel-10 | RP-46 | Issam | RP-110538 |  |  |
| 513 | 187 | **Deleted - Fixed Wireless Customer-Premises Equipment (CPE) RF Requirements** | 391d? | 2009-12-04 A | 2011-06-03 A | 100% |  | 2009-12-04 | 2011-06-03 | 391d? |  |  | R4,R5 | 9384h | 9384h | FW_CPE_RF | PCG-24 | Verizon Wireless | zheng.zhao@verizonwireless.com | Rel-10 | RP-46 | Issam |  | PCG-27 | RP-52 |
| 514 | 187.1 | Deleted - Core part: Fixed Wireless Customer-Premises Equipment (CPE) RF Requirements | 391d? | 2009-12-04 A | 2011-06-03 A | 100% |  | 2009-12-04 | 2011-06-03 | 391d? |  | finish no earlier than 2011-06-03 | R4 | 3128h | 3128h | FW_CPE_RF-Core | PCG-24 | Verizon Wireless | zheng.zhao@verizonwireless.com | Rel-10 | RP-46 | Issam | RP-110539 | PCG-27 | RP-52 |
| 515 | 187.2 | Deleted - Test part: Fixed Wireless Customer-Premises Equipment (CPE) RF Requirements | 391d? | 2009-12-04 A | 2011-06-03 A | 100% |  | 2009-12-04 | 2011-06-03 | 391d? |  | finish no earlier than 2011-06-03 | R5 | 3128h | 3128h | FW_CPE_RF-UEConTest | PCG-24 | Verizon Wireless | zheng.zhao@verizonwireless.com | Rel-10 | RP-46 | Ingbert | RP-110504 | PCG-27 | RP-52 |
| 516 | 188 | **Relays for LTE** | 394d? | 2009-12-04 A | 2011-06-08 A | 100% |  | 2009-12-04 | 2011-06-08 | 394d? |  |  | R1,R2,R4,S2,S3,C4,C6 | 10584h | 10584h | LTE_Relay | PCG-24 | Ericsson | christian.hoymann@ericsson.com | Rel-10 | RP-46 | Patrick |  |  |  |
| 517 | 188.1 | Core part: Relays for LTE | 391d? | 2009-12-04 A | 2011-06-03 A | 100% |  | 2009-12-04 | 2011-06-03 | 391d? |  | finish no earlier than 2011-06-03 | R1,R2,R4 | 3128h | 3128h | LTE_Relay-Core | PCG-24 | Ericsson | christian.hoymann@ericsson.com | Rel-10 | RP-46 | Patrick | RP-110540 |  |  |
| 518 | 188.2 | Deleted - Perf. part: Relays for LTE | 391d? | 2009-12-04 A | 2011-06-03 A | 100% |  | 2009-12-04 | 2011-06-03 | 391d? |  | finish no earlier than 2011-09-16 | R4 | 3128h | 3128h | LTE_Relay-Perf | PCG-24 | Ericsson | christian.hoymann@ericsson.com | Rel-10 | RP-46 | Issam | RP-110541 | PCG-27 | RP-52 |
| 519 | 188.3 | Stage 2 for Relays for LTE | 3d? | 2011-06-06 A | 2011-06-08 A | 100% |  | 2011-06-06 | 2011-06-08 | 3d? |  | start no earlier than 2011-06-06 | S2 | 24h | 24h | LTE_Relay | PCG-27 | Vodafone | Chris Pudney | Rel-10 | SP-52 | Maurice |  |  |  |
| 520 | 188.4 | TR on LTE Relay Nodes Security | 69d? | 2010-12-16 A | 2011-03-22 A | 100% |  | 2010-12-16 | 2011-03-22 | 69d? |  | finish no earlier than 2011-03-23 | S3 | 552h | 552h | LTE_Relay-Sec | PCG-26 | Qualcomm | Adrian Escott (aescott@qualcomm.com) | Rel-10 | SP-50 | Dionisio |  |  |  |
| 521 | 188.5 | Security for LTE Relay Nodes (Stage 2) | 69d? | 2010-12-16 A | 2011-03-22 A | 100% |  | 2010-12-16 | 2011-03-22 | 69d? |  | finish no earlier than 2011-03-23 | S3 | 552h | 552h | LTE_Relay-Sec | PCG-26 | Qualcomm | Adrian Escott (aescott@qualcomm.com) | Rel-10 | SP-50 | Dionisio |  |  |  |
| 522 | 188.6 | CT6 aspects of LTE Relay Node Security | 3d? | 2011-03-16 A | 2011-03-18 A | 100% |  | 2011-03-16 | 2011-03-18 | 3d? |  | start no earlier than 2011-03-16 | C6 | 24h | 24h | LTE_Relay-Sec | PCG-26 | n/a | n/a | Rel-10 | CP-51 | Xavier |  |  |  |
| 523 | 188.7 | Core Network Impacts for Relay Nodes | 3d? | 2011-03-16 A | 2011-03-18 A | 100% |  | 2011-03-16 | 2011-03-18 | 3d? |  | finish no earlier than 2011-03-18 | C4 | 24h | 24h | LTE_Relay-CN | PCG-26 | Vodafone | David.Hutton@vodafone.com | Rel-10 | CP-51 | Kimmo |  |  |  |

Notes:
- 500: Stage 3 Triggered by R4 Rel-10 LTE TR 37.806 Study on Extending 850 MHz (UID_440016) / Text3: UTRA
- 501: RP#52 completion 06/11=>09/11 (exception in RP-110755) / Text3: 25.101, 25.104, 25.113, 25.133, 25.141, 25.461, 25.466, 36.101, 36.104, 36.113, 36.124, 36.133, 36.141, 36.307, 36.331, 37.104, 37.113, 37.141
- 502: RP#52 completion 06/11=>09/11 / Text3: 25.101, 25.104, 25.113, 25.133, 25.141, 25.461, 25.466, 36.101, 36.104, 36.124, 36.133, 36.141, 36.307, 36.331, 37.104, 37.113, 37.141
- 503: RP#52 completion 06/11=>12/11. E850 UB band in the E-UTRA and UTRA conformance test specifications / Text3: 34.108, 34.121-1, 34.121-2, 34.123-1, 34.123-2, 34.123-3, 36.508, 36.521-1, 36.521-2, 36.521-3, 36.523-1, 36.523-2, 36.523-3
- 504: Triggered by FS_RAN_LTEA (Study on LTE-Advanced) 36.912, 36. 814 / Text3: LTE
- 505: RP#52 completed / Text3: 36.101, 36.104, 36.133, 36.211, 36.212, 36.213, 36.300, 36.302, 36.306, 36.321, 36.331, 36.413, 36.423, 37.104
- 506: RP#50 TR 36.808 v100 for Information / Text3: 36.101, 36.104, 36.133, 36.141, 37.141, new TR (36.807, 36.808)
- 507: Triggered by FS_RAN_LTEA (Study on LTE-Advanced) 36.912, 36. 814 / Text3: LTE
- 508: RP#51 completed / Text3: 36.101, 36.104, 36.133, 36.201, 36.211, 36.212, 36.213, 36.300, 36.306, 36.321, 36.331
- 509: RP#52 completion 06/11=>09/11 / Text3: 36.101, 36.104, 36.133, 36.141
- 510: RP#52 Core completed. Triggered by FS_RAN_LTEA (Study on LTE-Advanced) 36.912, 36. 814 / Text3: LTE
- 511: RP#52 completed. TR 36.817 v110 for Approval / Text3: 36.101, 36.104, 36.133, 36.201, 36.211, 36.212, 36.213, 36.300, 36.306, 36.321, 36.331, new RAN4 TR 36.817
- 512: RP#52 completion 06/11=>09/11 / Text3: 36.101, 36.104, 36.133, 36.141, 36.817
- 513: RP#52 work stopped (lack of contributions). Add new power classes in E-UTRAN UL to allow CPE type applications to be operated at higher max output power / Text3: LTE
- 514: RP#52 work stopped at 55% (lack of contributions) / Text3: 36.101
- 515: RP#52 work stopped (lack of contributions) / Text3: 36.521-1
- 516: RP#52 completed (open RAN4 Core & Perf parts moved to new Rel-11). Triggered by FS_RAN_LTEA (Study on LTE-Advanced) 36.912, 36. 814 / Text3: LTE
- 517: RP#52 completed. Updated WID RP-101417=>RP-101911 (contains only Core part completed in Rel-10). Open RAN4 Core & Perf parts moved to new Rel-11 / Text3: 36.133, 36.201, 36.211, 36.212, 36.213, 36.300, 36.321, 36.323, 36.331, new RAN1 TS 36.216, new RAN4 (36.116, 36.826)
- 518: RP#52 stopped at 30% (no CRs so far) . Transferred completely to Rel-11 together with remaining core part / Text3: 36.133, new TS 36.117 (E-UTRA Relay conformance testing)
- 519: SP#52 SP-110338 (S2-85/S2-112851) 23.401 Cat F CR#2128 Completion of Relay procedure overview / Text3: 23.401
- 520: SP#51 completed / Text3: 33.816
- 521: SP#51 completed (impacting Stage 3 in CT and RAN) / Text3: 33.401 (CR#0437,0438), CT1 24.301, CT4 (29.272, 29.274), CT6 31.102, RAN2 (36.331, 36.323), RAN3 36.413
- 522: CP#51 completed / Text3: 31.101, 31.102
- 523: CP#51 completed / Text3: 23.003, 23.008, 29.303, 29.230, 29.272

| ID | WBS | Task | Duration | Start | Finish | Complete | Remaining | Baseline start | Baseline finish | Baseline duration | Total slack | Constraint | Resources | Work | Actual work | Text1 | Text2 | Text4 | Text5 | Text6 | Text7 | Text8 | Text11 |
| --- | --- | --- | --- | --- | --- | --- | --- | --- | --- | --- | --- | --- | --- | --- | --- | --- | --- | --- | --- | --- | --- | --- | --- |
| 524 | 189 | **Relays for LTE (part 2)** | 661d? | 2009-12-04 A | 2012-06-15 | 23% | 509.82d? | 2009-12-04 | 2012-06-15 | 661d? | 125d |  | R4 | 12224h | 2795.87h | LTE_Relay2 | PCG-24 | Ericsson | christian.hoymann@ericsson.com | Rel-11 | RP-46 | Patrick |  |
| 525 | 189.1 | Core part: Relays for LTE (part 2) | 206d? | 2011-06-03 | 2012-03-16 |  |  | 2011-06-03 | 2012-03-16 | 206d? | 190d | finish no earlier than 2012-03-16 | R4 | 1648h |  | LTE_Relay2-Core | PCG-27 | Ericsson | christian.hoymann@ericsson.com | Rel-11 | RP-52 | Issam |  |
| 526 | 189.2 | Perf. part: Relays for LTE (part 2) | 661d? | 2009-12-04 A | 2012-06-15 | 30% | 462.7d? | 2009-12-04 | 2012-06-15 | 661d? | 125d | finish no earlier than 2012-06-15 | R4 | 5288h | 1586.4h | LTE_Relay2-Perf | PCG-24 | Ericsson | christian.hoymann@ericsson.com | Rel-11 | RP-46 | Issam | RP-110541 |
| 527 | 190 | **Enhanced Inter-Cell Interference Control (ICIC) for non-Carrier Aggregation (CA) based deployments of heterogeneous networks for LTE** | 391d? | 2010-03-19 A | 2011-09-16 | 72% | 108.12d? | 2010-03-19 | 2011-09-16 | 391d? | 320d |  | R1,R2,R3,R4 | 8784h | 6355.04h | eICIC_LTE | PCG-24 | China Mobile | Xiaodong XU (xuxiaodong@chinamobile.com) | Rel-10 | RP-47 | Patrick |  |
| 528 | 190.1 | Core part: Enhanced ICIC for non-CA based deployments of heterogeneous networks for LTE | 316d? | 2010-03-19 A | 2011-06-03 A | 100% |  | 2010-03-19 | 2011-06-03 | 316d? |  | finish no earlier than 2011-06-03 | R1,R2,R3,R4 | 2528h | 2528h | eICIC_LTE-Core | PCG-24 | China Mobile | Xiaodong XU (xuxiaodong@chinamobile.com) | Rel-10 | RP-47 | Patrick | RP-110543 |
| 529 | 190.2 | Perf. part: Enhanced ICIC for non-CA based deployments of heterogeneous networks for LTE | 391d? | 2010-03-19 A | 2011-09-16 | 50% | 195.5d? | 2010-03-19 | 2011-09-16 | 391d? | 320d | finish no earlier than 2011-09-16 | R4 | 3128h | 1564h | eICIC_LTE-Perf | PCG-24 | China Mobile | Xiaodong XU (xuxiaodong@chinamobile.com) | Rel-10 | RP-47 | Issam | RP-110544 |
| 530 | 191 | **LTE TDD in 2600MHz for US** | 191d? | 2010-03-19 A | 2010-12-10 A | 100% |  | 2010-03-19 | 2010-12-10 | 191d? |  |  | R4,R2,R3,R5 | 4712h | 4712h | LTE_TDD_2600_US | PCG-24 | Clearwire | michael.hart@clearwire.com | Rel-10 | RP-47 | Issam |  |
| 531 | 191.1 | Core part: LTE TDD in 2600MHz for US | 131d? | 2010-03-19 A | 2010-09-17 A | 100% |  | 2010-03-19 | 2010-09-17 | 131d? |  | finish no earlier than 2010-09-17 | R4,R2,R3 | 1048h | 1048h | LTE_TDD_2600_US-Core | PCG-24 | Clearwire | michael.hart@clearwire.com | Rel-10 | RP-47 | Issam | RP-100782 |
| 532 | 191.2 | Perf. part: LTE TDD in 2600MHz for US | 131d? | 2010-03-19 A | 2010-09-17 A | 100% |  | 2010-03-19 | 2010-09-17 | 131d? |  | finish no earlier than 2010-09-17 | R4 | 1048h | 1048h | LTE_TDD_2600_US-Perf | PCG-24 | Clearwire | michael.hart@clearwire.com | Rel-10 | RP-47 | Issam | RP-100783 |
| 533 | 191.3 | UE conformance test part: LTE TDD in 2600MHz for US | 136d? | 2010-06-04 A | 2010-12-10 A | 100% |  | 2010-06-04 | 2010-12-10 | 136d? |  | finish no earlier than 2010-12-10 | R5 | 1088h | 1088h | LTE_TDD_2600_US-UEConTest | PCG-25 | Clearwire | michael.hart@clearwire.com | Rel-10 | RP-48 | Ingbert | RP-101071 |
| 534 | 192 | **Adding 2 GHz band LTE FDD (Band 23) for Ancillary Terrestrial Component (ATC) of Mobile Satellite Service (MSS) in North America** | 391d? | 2010-03-19 A | 2011-09-16 | 89% | 41.97d? | 2010-03-19 | 2011-09-16 | 391d? | 320d |  | R2,R4,R5 | 8792h | 7576h | S_Band_LTE_ATC_MSS | PCG-24 | DBSD (formerly ICO) | Mariam.Sorond@ico.com | Rel-10 | RP-47 | Joern |  |
| 535 | 192.1 | Core part: Adding 2 GHz band LTE FDD (Band 23) for ATC of MSS in North America | 316d? | 2010-03-19 A | 2011-06-03 A | 100% |  | 2010-03-19 | 2011-06-03 | 316d? |  | finish no earlier than 2011-06-03 | R4,R2 | 2528h | 2528h | S_Band_LTE_ATC_MSS-Core | PCG-24 | DBSD (formerly ICO) | Mariam.Sorond@ico.com | Rel-10 | RP-47 | Issam | RP-110545 |
| 536 | 192.2 | Perf. part: Adding 2 GHz band LTE FDD (Band 23) for ATC of MSS in North America | 316d? | 2010-03-19 A | 2011-06-03 A | 100% |  | 2010-03-19 | 2011-06-03 | 316d? |  | finish no earlier than 2011-06-03 | R4 | 2528h | 2528h | S_Band_LTE_ATC_MSS-Perf | PCG-24 | DBSD (formerly ICO) | Mariam.Sorond@ico.com | Rel-10 | RP-47 | Issam | RP-110546 |
| 537 | 192.3 | Test part: Adding 2 GHz band LTE FDD (Band 23) for ATC of MSS in North America | 76d? | 2011-06-03 | 2011-09-16 |  |  | 2011-06-03 | 2011-09-16 | 76d? | 320d | finish no earlier than 2011-09-16 | R5 | 608h |  | S_Band_LTE_ATC_MSS-UEConTest | PCG-27 | DBSD (formerly ICO) | Mariam.Sorond@ico.com | Rel-10 | RP-52 | Ingbert |  |
| 538 | 193 | **Adding L-Band (Band 24) LTE for Ancillary Terrestrial Component (ATC) of Mobile Satellite Service (MSS) in North America** | 391d? | 2010-03-19 A | 2011-09-16 | 96% | 14.47d? | 2010-03-19 | 2011-09-16 | 391d? | 320d |  | R4,R2 | 8792h | 8466.65h | L_Band_LTE_ATC_MSS | PCG-24 | LightSquared | Eric.Jacks@lightsquared.com, Maqbool.Aliani@lightsquared.com | Rel-10 | RP-47 | Issam |  |
| 539 | 193.1 | Core part: Adding L-Band (Band 24) LTE for ATC of MSS in North America | 261d? | 2010-03-19 A | 2011-03-18 A | 100% |  | 2010-03-19 | 2011-03-18 | 261d? |  | finish no earlier than 2010-12-10 | R4,R2 | 2088h | 2088h | L_Band_LTE_ATC_MSS-Core | PCG-24 | LightSquared | Eric.Jacks@lightsquared.com, Maqbool.Aliani@lightsquared.com | Rel-10 | RP-47 | Issam | RP-101117 |
| 540 | 193.2 | Perf. part: Adding L-Band (Band 24) LTE for ATC of MSS in North America | 316d? | 2010-03-19 A | 2011-06-03 A | 100% |  | 2010-03-19 | 2011-06-03 | 316d? |  | finish no earlier than 2011-06-03 | R4 | 2528h | 2528h | L_Band_LTE_ATC_MSS-Perf | PCG-24 | LightSquared | Eric.Jacks@lightsquared.com, Maqbool.Aliani@lightsquared.com | Rel-10 | RP-47 | Issam | RP-110548 |
| 541 | 193.3 | Test part: Adding L-Band (Band 24) LTE for ATC of MSS in North America | 131d? | 2011-03-18 A | 2011-09-16 | 80% | 26.2d? | 2011-03-18 | 2011-09-16 | 131d? | 320d | finish no earlier than 2011-09-16 | R5 | 1048h | 838.4h | L_Band_LTE_ATC_MSS-UEConTest | PCG-26 | LightSquared | Masoud.olfat@LightSquared.com | Rel-10 | RP-51 | Ingbert | RP-110516 |
| 542 | 194 | **LTE Self Optimizing Networks (SON) enhancements** | 316d? | 2010-03-19 A | 2011-06-03 A | 100% |  | 2010-03-19 | 2011-06-03 | 316d? |  |  | R3,R2,R4 | 5056h | 5056h | SONenh_LTE | PCG-24 | Nokia Siemens Networks | krzysztof.kordybach@nsn.com | Rel-10 | RP-47 | Juha |  |
| 543 | 194.1 | Core part: LTE Self Optimizing Networks (SON) enhancements | 316d? | 2010-03-19 A | 2011-06-03 A | 100% |  | 2010-03-19 | 2011-06-03 | 316d? |  | finish no earlier than 2011-06-03 | R3,R2,R4 | 2528h | 2528h | SONenh_LTE-Core | PCG-24 | Nokia Siemens Networks | krzysztof.kordybach@nsn.com | Rel-10 | RP-47 | Juha | RP-110547 |
| 544 | 195 | **Further enhancements to MBMS for LTE** | 206d? | 2010-06-04 A | 2011-03-18 A | 100% |  | 2010-06-04 | 2011-03-18 | 206d? |  |  | R2,R3 | 3296h | 3296h | MBMS_LTE_enh | PCG-25 | Huawei | Ms Zhao Junhui (zhaojh@huawei.com) | Rel-10 | RP-48 | Joern |  |
| 545 | 195.1 | Core part: Further enhancements to MBMS for LTE | 206d? | 2010-06-04 A | 2011-03-18 A | 100% |  | 2010-06-04 | 2011-03-18 | 206d? |  | finish no earlier than 2011-03-18 | R2,R3 | 1648h | 1648h | MBMS_LTE_enh-Core | PCG-25 | Huawei | Ms Zhao Junhui (zhaojh@huawei.com) | Rel-10 | RP-48 | Joern | RP-110083 |
| 546 | 196 | **UMTS/LTE 3500 MHz** | 1052d? | 2007-11-30 A | 2011-12-09 | 49% | 539.96d? | 2007-11-30 | 2011-12-09 | 1052d? | 260d |  | R4,R2,R3,R5 | 25914h | 12613h | RInImp8-UMTSLTE3500 | PCG-21 | Ericsson | johan.skold@ericsson.com | Rel-10 | RP-38 | Issam | Exception sheet in RP-110906 |
| 547 | 196.1 | UMTS/LTE 3500 MHz | 980d? | 2007-11-30 A | 2011-09-16 | 87% | 127.4d? | 2007-11-30 | 2011-09-16 | 980d? | 320d | finish no earlier than 2011-09-16 | R4,R2,R3 | 7840h | 6820.8h | RInImp8-UMTSLTE3500 | PCG-21 | Ericsson | johan.skold@ericsson.com | Rel-10 | RP-38 | Issam | RP-110527 |
| 548 | 196.2 | Conformance Test Aspects – LTE 3500 | 787d? | 2008-12-05 A | 2011-12-09 | 45% | 432.85d? | 2008-12-05 | 2011-12-09 | 787d? | 260d | finish no earlier than 2011-12-09 | R5 | 6296h | 2833.2h | LTE-UEConTest_LTE3500 | PCG-22 | Ericsson | fredrik.sundstrom@ericsson.com | Rel-10 | RP-42 | Ingbert | RP-110502 |
| 549 | 196.3 | Conformance Test Aspects – UMTS 3500 | 787d? | 2008-12-05 A | 2011-12-09 | 5% | 750.65d? | 2008-12-05 | 2011-12-09 | 787d? | 260d | finish no earlier than 2011-12-09 | R5 | 6296h | 290.8h | RInImp-UEConTest_UMTS3500 | PCG-22 | Ericsson | fredrik.sundstrom@ericsson.com | Rel-10 | RP-42 | Ingbert | RP-110503 |

Notes:
- 524: Continuation of Rel-10 (open RAN4 Core & Perf parts) / Text3: LTE
- 525: RP#52 Core part not completed in Rel-10 / Text3: 36.116, 36.133, 36.826
- 526: RP#52 transferred completely from Rel-10 UID_460213 / Text3: 36.133, new TS 36.117 (E-UTRA Relay conformance testing)
- 527: Stage 3 Triggered by FS_RAN_LTEA (Study on LTE-Advanced) 36.912, 36.814 / Text3: LTE
- 528: RP#52 completed / Text3: 36.101, 36.133, 36.201, 36.211, 36.212, 36.213, 36.214, 36.300, 36.321, 36.331, 36.413, 36.423
- 529: - / Text3: 36.101, 36.133
- 530: RP#50 Testing completed. RP#49 Core+Perf completed / Text3: LTE
- 531: RP#49 completed / Text3: 25.461, 25.466, 36.101, 36.104, 36.113, 36.124, 36.133, 36.141, 36.307, 36.331, 37.104, 37.113, 37.141, new TR 36.812
- 532: RP#49 completed / Text3: 36.101, 36.104, 36.133, 36.141, 36.307, 37.104, 37.141, new TR 36.812
- 533: RP#50 completed / Text3: 36.508, 36.521-1, 36.521-2, 36.521-3, 36.523-1, 36.523-2, 36.523-3
- 534: RP#52 completed. Updated WID RP-101401=>RP-110775 (changed in Title "LTE" to "LTE FDD (Band 23)" / Text3: LTE
- 535: RP#52 completed. Updated WID RP-101401=>RP-110775. TR 36.811 v200 for Approval / Text3: 25.101, 25.104, 25.141, 25.461, 25.466, 36.101, 36.104, 36.113, 36.124, 36.133, 36.307, 37.104, 37.141, new TR 36.811
- 536: RP#52 completed. Updated WID RP-101401=>RP-110775 / Text3: 36.101, 36.104, 36.113, 36.124, 36.133, 36.141, 36.307, 36.811
- 537: Adding 2 GHz S-band LTE (Band 23) in North America UE Conformance Testing / Text3: 36.508, 36.521-1, 36.521-2, 36.521-3, 36.523-1, 36.523-2, 36.523-3
- 538: RP#52 Perf completed / Text3: LTE
- 539: RP#51 completed / Text3: 25.101, 25.104, 25.141, 25.461, 25.466, 34.124, 36.101, 36.104, 36.113, 36.124, 36.133, 36.307, 37.104, 37.141, new RAN4 TR 36.813
- 540: RP#52 completed / Text3: 34.121-1, 36.101, 36.104, 36.113, 36.124, 36.133, 36.141, 36.307, 36.521-1, 36.813
- 541: RP#52 updated WID RP-110378=>RP-110777 (align Title with Core WI) / Text3: 36.508, 36.521-1, 36.521-2, 36.521-3, 36.523-2
- 542: RP#52 completed / Text3: LTE
- 543: RP#52 completed (Stage 1,2,3) / Text3: 36.300, 36.331, 36.413, 36.423
- 544: RP#51 completed. SA2 decided not to support MBR>GBR in Rel-10 MBMS. For SA2, MBR=GBR in Rel-10 MBMS. Hence RAN removed enabling statistical multiplexing gains for variable bit rate services in Objectives / Text3: LTE
- 545: RP#51 completed / Text3: 25.446, 36.300, 36.321, 36.322, 36.323, 36.331, 36.440, 36.441, 36.442, 36.443, 36.444, 36.445
- 546: RP#52 Core part TDD (completed) and FDD extension until 09/11 in RP-110906 / Text3: UTRA, LTE
- 547: RP#52 TDD completed. FDD extension 06/11=>09/11 (exception sheet in RP-110906. TR 37.801 v100 for Information / Text3: 25.101, 25.104, 25.113, 25.133, 25.141, 25.307, 25.307, 25.331, 25.461, 25.463, 34.124, 36.101, 36.104, 36.113, 36.141, 36.331, new 37.801
- 548: RP#52 completion 09/11=>12/11 / Text3: 36.508, 36.521-1, 36.521-2, 36.521-3
- 549: RP#52 completion 09/11=>12/11 / Text3: 34.108, 34.121-1, 34.121-2

| ID | WBS | Task | Duration | Start | Finish | Complete | Remaining | Baseline start | Baseline finish | Baseline duration | Total slack | Constraint | Resources | Work | Actual work | Text1 | Text2 | Text4 | Text5 | Text6 | Text7 | Text8 | Text11 | Text9 | Text12 |
| --- | --- | --- | --- | --- | --- | --- | --- | --- | --- | --- | --- | --- | --- | --- | --- | --- | --- | --- | --- | --- | --- | --- | --- | --- | --- |
| 550 | 197 | **Minimization of Drive Tests for E-UTRAN and UTRAN** | 391d? | 2009-12-04 A | 2011-06-03 A | 100% |  | 2009-12-04 | 2011-06-03 | 391d? |  |  | R2,R4,R3 | 6256h | 6256h | MDT_UMTSLTE | PCG-24 | Nokia Siemens Networks | malgorzata.tomala@nsn.com | Rel-10 | RP-46 | Joern |  |  |  |
| 551 | 197.1 | Core part: Minimization of Drive Tests for E-UTRAN and UTRAN | 391d? | 2009-12-04 A | 2011-06-03 A | 100% |  | 2009-12-04 | 2011-06-03 | 391d? |  | finish no earlier than 2011-06-03 | R2,R4,R3 | 3128h | 3128h | MDT_UMTSLTE-Core | PCG-24 | Nokia Siemens Networks | malgorzata.tomala@nsn.com | Rel-10 | RP-46 | Joern | RP-110528 |  |  |
| 552 | 198 | **HNB and HeNB Mobility Enhancements** | 261d? | 2010-03-19 A | 2011-03-18 A | 100% |  | 2010-03-19 | 2011-03-18 | 261d? |  |  | R3,R2 | 4176h | 4176h | HNB_HENB_mob_enh | PCG-24 | Alcatel-Lucent | Martin,Warner@alcatel-lucent.com | Rel-10 | RP-47 | Juha |  |  |  |
| 553 | 198.1 | Core part: HNB and HeNB Mobility Enhancements | 261d? | 2010-03-19 A | 2011-03-18 A | 100% |  | 2010-03-19 | 2011-03-18 | 261d? |  | start no earlier than 2010-03-19 | R3,R2 | 2088h | 2088h | HNB_HENB_mob_enh-Core | PCG-24 | Alcatel-Lucent | Martin.Warner@alcatel-lucent.com | Rel-10 | RP-47 | Juha | RP-110058 |  |  |
| 554 | 199 | **Expanded 1900 MHz Band for UTRA and LTE** | 336d? | 2010-06-04 A | 2011-09-16 | 87% | 42.7d? | 2010-06-04 | 2011-09-16 | 336d? | 320d |  | R4,R2,R5 | 7472h | 6256h | E1900 | PCG-25 | Sprint | nick.j.baustert@sprint.com | Rel-10 | RP-48 | Issam |  |  |  |
| 555 | 199.1 | Core part: Expanded 1900 MHz Band for UTRA and LTE | 261d? | 2010-06-04 A | 2011-06-03 A | 100% |  | 2010-06-04 | 2011-06-03 | 261d? |  | finish no earlier than 2011-06-03 | R4,R2 | 2088h | 2088h | E1900-Core | PCG-25 | Sprint | nick.j.baustert@sprint.com | Rel-10 | RP-48 | Issam | RP-110529 |  |  |
| 556 | 199.2 | Perf. part: Expanded 1900 MHz Band for UTRA and LTE | 261d? | 2010-06-04 A | 2011-06-03 A | 100% |  | 2010-06-04 | 2011-06-03 | 261d? |  | finish no earlier than 2011-06-03 | R4,R2 | 2088h | 2088h | E1900-Perf | PCG-25 | Sprint | nick.j.baustert@sprint.com | Rel-10 | RP-48 | Issam | RP-110530 |  |  |
| 557 | 199.3 | Test part: Expanded 1900 MHz Band for UTRA and LTE | 76d? | 2011-06-03 | 2011-09-16 |  |  | 2011-06-03 | 2011-09-16 | 76d? | 320d | finish no earlier than 2011-09-16 | R5 | 608h |  | E1900-UEConTest | PCG-27 | Sprint | nick.j.baustert@sprint.com | Rel-10 | RP-52 | Ingbert |  |  |  |
| 558 | 200 | **Multi-standard radio Base Station RF requirements for non-contiguous spectrum deployments** | 336d? | 2010-06-04 A | 2011-09-16 | 72% | 92.81d? | 2010-06-04 | 2011-09-16 | 336d? | 320d |  | R4,G1 | 9552h | 6913.51h | MSR_NC | PCG-25 | Ericsson | johan.skold@ericsson.com | Rel-10 | RP-48 | Issam |  |  |  |
| 559 | 200.1 | Core part: Multi-standard radio Base Station RF requirements for non-contiguous spectrum deployments | 261d? | 2010-06-04 A | 2011-06-03 A | 100% |  | 2010-06-04 | 2011-06-03 | 261d? |  | finish no earlier than 2011-06-03 | R4 | 2088h | 2088h | MSR_NC-Core | PCG-25 | Ericsson | johan.skold@ericsson.com | Rel-10 | RP-48 | Issam | RP-110531 |  |  |
| 560 | 200.2 | Perf. part: Multi-standard radio Base Station RF requirements for non-contiguous spectrum deployments | 336d? | 2010-06-04 A | 2011-09-16 | 45% | 184.8d? | 2010-06-04 | 2011-09-16 | 336d? | 320d | finish no earlier than 2011-09-16 | R4 | 2688h | 1209.6h | MSR_NC-Perf | PCG-25 | Ericsson | johan.skold@ericsson.com | Rel-10 | RP-48 | Issam | RP-110532 |  |  |
| 561 | 200.3 | GERAN part: Multi-standard radio Base Station RF requirements for non-contiguous spectrum deployments | 261d? | 2010-09-03 A | 2011-09-02 | 80% | 52.2d? | 2010-09-03 | 2011-09-02 | 261d? | 330d | finish no earlier than 2011-09-02 | G1 | 2088h | 1670.4h | MSR_NC-GERAN | PCG-25 | Ericsson | mats.y.samuelsson@ericsson.com | Rel-10 | GP-47 | Paolo | No exception sheet |  |  |
| 562 | 201 | (Small) Technical Enhancements and Improvements for Rel-10 | 470d? | 2009-06-04 A | 2011-03-23 A | 100% |  | 2009-06-04 | 2011-03-23 | 470d? |  | finish no earlier than 2011-03-23 | All | 3760h | 3760h | TEI10 | PCG-23 |  |  | Rel-10 | SP-44 |  |  |  |  |
| 563 | 202 | (IETF) (Small) Technical Enhancements and Improvements for Rel-10 | 451d? | 2009-06-04 A | 2011-12-09 | 20% | 360.8d? | 2009-06-04 | 2011-12-09 | 451d? | 260d | finish no earlier than 2011-12-09 | C1-IETF | 3608h | 721.6h | TEI10 | PCG-27 |  |  | Rel-10 | CP-52 | Frederic |  |  |  |
| 564 | 203 | **Deleted - Registration in Densely-populated area (RED)** | 665d? | 2007-03-12 A | 2009-09-24 A | 100% |  | 2007-03-12 | 2009-09-24 | 665d? |  |  | S1 | 9544h | 9544h | RED |  | NTT DoCoMo | tanakai@nttdocomo.co.jp | Rel-10 | SP-35 | Alain |  | PCG-24 | SP-46 |
| 565 | 203.1 | Deleted - Stage 1 for RED | 4d? | 2007-03-12 A | 2007-03-15 A | 100% |  | 2007-03-12 | 2007-03-15 | 4d? |  | start no earlier than 2007-03-12 | S1 | 32h | 32h | RED |  | NTT DoCoMo | takakurat@s1.nttdocomo.co.jp | Rel-10 | SP-35 | Alain |  | PCG-24 | SP-46 |
| 566 | 203.2 | Deleted - Stage 2 for RED | 524d? | 2007-09-25 A | 2009-09-24 A | 100% |  | 2007-09-25 | 2009-09-24 | 524d? |  | finish no earlier than 2009-09-24 | S2 | 4192h | 4192h | RED |  | NTT DoCoMo | tanakai@nttdocomo.co.jp | Rel-10 | SP-37 | Maurice |  | PCG-23 | SP-45 |
| 567 | 204 | **Deleted - Network Selection for non-3GPP Access** | 471d? | 2007-12-07 A | 2009-09-24 A | 100% |  | 2007-12-07 | 2009-09-24 | 471d? |  |  | S1,C6 | 10452.8h | 10452.8h | N3GtoNSP | PCG-21 | Telefónica O2 | chris.friel@O2.com | Rel-10 | SP-38 | Alain |  | PCG-23 | SP-45 |
| 568 | 204.1 | Deleted - Stage 1 for N3GtoNSP | 471d? | 2007-12-07 A | 2009-09-24 A | 100% |  | 2007-12-07 | 2009-09-24 | 471d? |  | finish no earlier than 2009-12-10 | S1 | 3768h | 3768h | N3GtoNSP | PCG-21 | Telefónica O2 | chris.friel@O2.com | Rel-10 | SP-38 | Alain |  | PCG-23 | SP-45 |
| 569 | 204.2 | Deleted - CT6 issues for N3GtoNSP | 471d? | 2007-12-07 A | 2009-09-24 A | 100% |  | 2007-12-07 | 2009-09-24 | 471d? |  | finish no earlier than 2009-12-04 | C6 | 3768h | 3768h | N3GtoNSP | PCG-21 | Telefónica O2 | chris.friel@O2.com | Rel-10 | CP-38 | Xavier |  | PCG-23 | CP-45 |
| 570 | 205 | **Deleted - GTP-based S8 chaining** | 337d? | 2008-12-11 A | 2010-03-25 A | 100% |  | 2008-12-11 | 2010-03-25 | 337d? |  |  | S2 | 5392h | 5392h | GTPchaining | PCG-22 | Huawei | Haining Wang (wanghaining@huawei.com) | Rel-10 | SP-42 | Maurice |  | PCG-24 | SP-47 |
| 571 | 205.1 | Deleted - Stage 2 for GTPchaining | 337d? | 2008-12-11 A | 2010-03-25 A | 100% |  | 2008-12-11 | 2010-03-25 | 337d? |  | finish no earlier than 2010-03-25 | S2 | 2696h | 2696h | GTPchaining | PCG-22 | Huawei | Haining Wang (wanghaining@huawei.com) | Rel-10 | SP-42 | Maurice |  | PCG-24 | SP-47 |
| 572 | 206 | Deleted - UTRAN 2 ms TTI uplink range improvement | 272d? | 2009-03-06 A | 2010-03-19 A | 100% |  | 2009-03-06 | 2010-03-19 | 272d? |  | finish no earlier than 2010-03-19 | R1,R2,R3,R4 | 2176h | 2176h | RANimp-2mTTI_ULimp | PCG-22 | Nokia Siemens Networks | Karri Ranta-aho (karri.ranta-aho@nsn.com) | Rel-10 | RP-43 | Patrick | RP-100040 | PCG-24 | RP-47 |
| 573 | 207 | Deleted - Enhanced Home NodeB / eNodeB continuation of Rel-9 | 337d? | 2008-12-11 A | 2010-03-25 A | 100% |  | 2008-12-11 | 2010-03-25 | 337d? |  |  | S2 | 2696h | 2696h | eEHNB | PCG-23 | Alcatel-Lucent | Nicolas Drevon | Rel-10 | SP-44 | Maurice |  | PCG-24 | SP-47 |

Notes:
- 550: RP#52 completed. Triggered by UID_430021 TR 36.805 (Study on Minimization of drive-tests in NGN) / Text3: UTRA, LTE
- 551: RP#52 completed / Text3: 25.133, 25.215, 25.304, 25.331, 25.423, 36.133, 36.214, 36.300, 36.304, 36.331, 36.413, 36.423, new 37.320 (Stage 2)
- 552: RP#51 completed. Common UTRA and E-UTRA Work Item to ensure that divergence between the systems is minimized / Text3: UTRA, LTE
- 553: RP#51 completed. WID updated RP-101426=>RP-110183 / Text3: 25.413, 25.467, 25.469, 36.300, 36.413, 36.423, new 25.471
- 554: RP#52 Core & Perf completed. Create a new band that expands UTRA and E-UTRA band 2 to include frequencies between 1910 1915 MHz and 1990-1995 MHz (US FCC allocation) / Text3: UTRA, LTE
- 555: RP#52 completed / Text3: 25.101, 25.104, 25.113, 25.133, 25.141, 25.461, 25.466, 36.101, 36.104, 36.113, 36.124, 36.133, 36.141, 36.307, 36.331, new TR 36.818
- 556: RP#52 completed / Text3: 25.101, 25.104, 25.113, 25.133, 25.141, 25.461, 25.466, 36.101, 36.104, 36.113, 36.124, 36.133, 36.141, 36.307, 36.331, new TR 36.818
- 557: - / Text3: 34.108, 34.121-1, 34.121-2, 34.123-1, 34.123-2, 34.123-3, 36.508, 36.521-1, 36.521-2, 36.521-3, 36.523-1, 36.523-2, 36.523-3
- 558: RP#52 Core completed / Text3: UTRA, LTE, GERAN
- 559: RP#52 completed. TR 37.802 v100 for Approval / Text3: 25.104, 36.104, 37.104, new TR 37.802
- 560: - / Text3: 25.141, 36.141, 37.141, 37.802
- 561: GP#49 completion 03/11=>09/11. GP#47 approved WID / Text3: 45.005, 51.021
- 562: -
- 563: Not completed internet-draft / Text3: draft-atarius-dispatch-meid-urn
- 564: SP#35 Stage 1 completed. SP#45 Stage 2 work stopped. SP#46 work stopped/abandoned / Text3: WID identifies also impacted CT1 24.008, RAN2 25.331
- 565: SP#35 completed. SP#46 work stopped/abandoned / Text3: 22.101 CR#0207
- 566: SP#45 Stage 2 work stopped / Text3: draft TR 23.880 withdrawn, 23.002, 23.060, 23.221, 23.236
- 567: SP#45 work stopped/abandoned
- 568: SP#45 work stopped/abandoned / Text3: 22.011
- 569: SP#45 work stopped/abandoned / Text3: 36.300
- 570: SP#47 work stopped (depending on ongoing related CT4 work). Stage 1 in UID_320022 Rel-8 Requirements for evolution of the 3GPP system architecture (AIPN-SAE): 22.278, 22.011, 22.246
- 571: SP#47 work stopped / Text3: 23.402
- 572: RP#47 work stopped/abandoned (no CR approved). Cell sets the TTI (Transmission Time Interval) to 2 ms / Text3: 25.133, 25.212, 25.214, 25.321, 25.331
- 573: SP#47 deleted (SA2 work moved under SA1 UID_450053). SP#44 Umbrella Feature created to host WIs moved out of Rel-9 (SA2 UID_420034 on IMS aspects of Architecture for Home NodeB)

| ID | WBS | Task | Type | Duration | Start | Finish | Complete | Baseline start | Baseline finish | Baseline duration | Constraint | Resources | Work | Actual work | Text1 | Text2 | Text3 | Text4 | Text6 | Text7 | Text8 | Text9 | Text11 | Text12 |
| --- | --- | --- | --- | --- | --- | --- | --- | --- | --- | --- | --- | --- | --- | --- | --- | --- | --- | --- | --- | --- | --- | --- | --- | --- |
| 574 | 208 | **Deleted - Enhanced Interference Management for Home NodeBs** |  | 131d? | 2010-03-19 A | 2010-09-17 A | 100% | 2010-03-19 | 2010-09-17 | 131d? |  | R3 | 2096h | 2096h | HNB_IM | PCG-24 | UTRA | Qualcomm | Rel-10 | RP-47 | Juha | PCG-25 | RP-100754 | RP-49 |
| 575 | 208.1 | Deleted - Core part: Enhanced Interference Management for Home NodeBs |  | 131d? | 2010-03-19 A | 2010-09-17 A | 100% | 2010-03-19 | 2010-09-17 | 131d? | finish no earlier than 2010-09-17 | R3 | 1048h | 1048h | HNB_IM-Core | PCG-24 | 25.413, 25.467, 25.469 | Qualcomm | Rel-10 | RP-47 | Juha | PCG-25 | RP-100754 | RP-49 |
| 576 | 209 | **Deleted - Latency reductions for LTE** |  | 266d? | 2009-12-04 A | 2010-12-10 A | 100% | 2009-12-04 | 2010-12-10 | 266d? |  | R2,R1 | 4256h | 4256h | LTE_LATRED | PCG-24 | LTE | Ericsson | Rel-10 | RP-46 | Joern | PCG-26 |  | RP-50 |
| 577 | 209.1 | Deleted - Core part: Latency reductions for LTE |  | 266d? | 2009-12-04 A | 2010-12-10 A | 100% | 2009-12-04 | 2010-12-10 | 266d? | finish no earlier than 2010-12-10 | R2,R1 | 2128h | 2128h | LTE_LATRED-Core | PCG-24 | 36.213, 36.300, 36.306, 36.321, 36.331 | Ericsson | Rel-10 | RP-46 | Joern | PCG-26 | RP-101112 | RP-50 |
| 578 | 210 | Release 10 Studies |  | 531d? | 2009-03-12 A | 2011-03-23 A | 100% | 2009-03-12 | 2011-03-23 | 531d? | finish no earlier than 2011-03-23 | CP,GP,RP,SP | 4248h | 4248h |  |  |  |  | Rel-10 |  |  |  |  |  |
| 579 | 211 | **Study on enhanced voice service requirements for the Evolved Packet System (EPS)** |  | 670d? | 2007-09-03 A | 2010-03-25 A | 100% | 2007-09-03 | 2010-03-25 | 670d? |  | S1,S4 | 13384h | 13384h | FS_EV_EPS |  | 22.813 | France Telecom | Rel-10 | SP-37 | Alain |  |  |  |
| 580 | 211.1 | Use cases definition and service and system requirements |  | 334d? | 2007-09-03 A | 2008-12-11 A | 100% | 2007-09-03 | 2008-12-11 | 334d? | finish no earlier than 2008-12-11 | S1 | 2672h | 2672h | FS_EV_EPS-S1 |  | 22.813 | France Telecom | Rel-10 | SP-37 | Alain |  |  |  |
| 581 | 211.2 | Codec specific part of FS_EV_EPS |  | 669d? | 2007-09-03 A | 2010-03-25 A | 100% | 2007-09-03 | 2010-03-25 | 669d? | finish no earlier than 2010-03-25 | S4 | 5352h | 5352h | FS_EV_EPS-S4 |  | 22.813 | Ericsson | Rel-10 | SP-37 | Paolo |  |  |  |
| 582 | 212 | Study on advanced requirements for IP interconnect |  | 528d? | 2007-12-04 A | 2009-12-10 A | 100% | 2007-12-04 | 2009-12-10 | 528d? | finish no earlier than 2009-12-10 | S1 | 4224h | 4224h | FS_IPXS | PCG-21 | 22.893 | Telefónica O2 | Rel-10 | SP-38 | Alain |  |  |  |
| 583 | 213 | Study on Personal Broadcast Service |  | 397d? | 2008-09-18 A | 2010-03-25 A | 100% | 2008-09-18 | 2010-03-25 | 397d? | finish no earlier than 2010-03-25 | S1 | 3168h | 3168h | FS_PBS | PCG-21 | 22.947 | ETRI | Rel-10 | SP-41 | Alain |  |  |  |
| 584 | 214 | Study on LCS support in SAE for non-3GPP accesses |  | 397d? | 2008-09-18 A | 2010-03-25 A | 100% | 2008-09-18 | 2010-03-25 | 397d? | finish no earlier than 2010-03-25 | S1 | 3168h | 3168h | FS_LCS_n3GPP | PCG-21 | 22.814 | SK Telecom | Rel-10 | SP-41 | Alain |  |  |  |
| 585 | 215 | Study on Haptic Services |  | 272d? | 2009-03-12 A | 2010-03-25 A | 100% | 2009-03-12 | 2010-03-25 | 272d? | finish no earlier than 2010-03-25 | S1 | 2168h | 2168h | FS_Haptics | PCG-22 | 22.987 | SK Telecom | Rel-10 | SP-43 | Alain |  |  |  |
| 586 | 216 | Study on System enhancements for the use of IMS services in Local BreakOut and Optimal Routing of Media |  | 575d? | 2007-10-01 A | 2009-12-10 A | 100% | 2007-10-01 | 2009-12-10 | 575d? | finish no earlier than 2009-12-10 | S2 | 4600h | 4600h | FS_IMS_LBO_ORM |  | 23.894 | Telecom Italia, BT | Rel-10 | SP-37 | Maurice |  |  |  |
| 587 | 217 | Study on Intra Domain Connection of RAN Nodes to Multiple CN Nodes |  | 533d? | 2008-03-12 A | 2010-03-25 A | 100% | 2008-03-12 | 2010-03-25 | 533d? | finish no earlier than 2010-03-25 | S2 | 4264h | 4264h | FS_IDC | PCG-21 | 23.924 (was 23.823) | China Mobile | Rel-10 | SP-39 | Maurice |  |  |  |
| 588 | 218 | Study on Single Radio Voice Call Continuity enhancements |  | 341d? | 2009-06-04 A | 2010-09-23 A | 100% | 2009-06-04 | 2010-09-23 | 341d? | finish no earlier than 2010-09-23 | S2 | 2728h | 2728h | FS_eSRVCC | PCG-23 | 23.856 | China Mobile | Rel-10 | SP-44 | Maurice |  |  |  |
| 589 | 219 | Study on Single Radio Video Call Continuity for 3G-CS |  | 131d? | 2010-03-25 A | 2010-09-23 A | 100% | 2010-03-25 | 2010-09-23 | 131d? | finish no earlier than 2010-09-23 | S2 | 1048h | 1048h | FS_vSRVCC | PCG-24 | 23.886 | Samsung | Rel-10 | SP-47 | Maurice |  |  |  |
| 590 | 220 | Study on S2b Mobility based on GTP |  | 56d? | 2010-03-25 A | 2010-06-10 A | 100% | 2010-03-25 | 2010-06-10 | 56d? | finish no earlier than 2010-06-07 | S2 | 448h | 448h | FS_SMOG | PCG-24 | 23.834 | Alcatel-Lucent | Rel-10 | SP-47 | Maurice |  |  |  |
| 591 | 221 | Study on Surround Sound codec extension for PSS and MBMS |  | 530d? | 2009-03-12 A | 2011-03-23 A | 100% | 2009-03-12 | 2011-03-23 | 530d? | finish no earlier than 2011-03-23 | S4 | 4240h | 4240h | FS_SS_PSS_MBMS | PCG-22 | 26.950 | Fraunhofer Gesellschaft | Rel-10 | SP-43 | Paolo |  |  |  |
| 592 | 222 | Study on Improved Video Coding Support |  | 205d? | 2010-06-10 A | 2011-03-23 A | 100% | 2010-06-10 | 2011-03-23 | 205d? | finish no earlier than 2011-03-23 | S4 | 1640h | 1640h | FS_IVCS | PCG-25 | 26.904 | Nokia, ETRI | Rel-10 | SP-48 | Paolo |  |  |  |
| 593 | 223 | Study on Rc Reference Point Functionalities and Message Flows |  | 397d? | 2008-09-18 A | 2010-03-25 A | 100% | 2008-09-18 | 2010-03-25 | 397d? | finish no earlier than 2010-03-23 | S5 | 3170.08h | 3170.08h | FS_OAM_Rc | PCG-21 | 32.825 | Huawei | Rel-10 | SP-41 | Dionisio |  |  |  |
| 594 | 224 | Study on Telecommunication Management; Energy Savings Management |  | 271d? | 2009-03-12 A | 2010-03-25 A | 100% | 2009-03-12 | 2010-03-25 | 271d? | finish no earlier than 2010-03-25 | S5 | 2168h | 2168h | FS_OAM_ESM | PCG-22 | 32.826 | Orange, Vodafone | Rel-10 | SP-43 | Dionisio |  |  |  |
| 595 | 225 | Study on Integration of Device Management Information with Itf-N |  | 211d? | 2009-06-04 A | 2010-03-25 A | 100% | 2009-06-04 | 2010-03-25 | 211d? | finish no earlier than 2010-03-25 | S5 | 1688h | 1688h | FS_IDMI_Itf-N | PCG-23 | 32.827 | Motorola | Rel-10 | SP-44 | Dionisio |  |  |  |
| 596 | 226 | Study on Alignment of 3GPP Generic NRM IRP and TMF Shared Information Data (SID) model |  | 335d? | 2009-12-10 A | 2011-03-23 A | 100% | 2009-12-10 | 2011-03-23 | 335d? | finish no earlier than 2011-03-23 | S5 | 2680h | 2680h | FS_3GNRM_TMFSID | PCG-24 | 32.828 | Nokia Siemens Networks | Rel-10 | SP-46 | Dionisio |  |  |  |
| 597 | 227 | Study on Harmonization of 3GPP Alarm IRP and TMF Interface Program (TIP) Fault Management |  | 335d? | 2009-12-10 A | 2011-03-23 A | 100% | 2009-12-10 | 2011-03-23 | 335d? | finish no earlier than 2011-03-23 | S5 | 2680h | 2680h | FS_3G_TMF_FM | PCG-24 | 32.829 | Nokia Siemens Networks, Alcatel-Lucent | Rel-10 | SP-46 | Dionisio |  |  |  |
| 598 | 228 | Study on Alarm Correlation and Alarm Root Cause Analysis |  | 205d? | 2010-06-10 A | 2011-03-23 A | 100% | 2010-06-10 | 2011-03-23 | 205d? | finish no earlier than 2011-03-23 | S5 | 1640h | 1640h | FS_AC_ARCA | PCG-25 | 32.832 | Ericsson | Rel-10 | SP-48 | Dionisio |  |  |  |
| 599 | 229 | Study on Alignment of 3GPP PM IRP and TMF Interface Program (TIP) PM |  | 205d? | 2010-06-10 A | 2011-03-23 A | 100% | 2010-06-10 | 2011-03-23 | 205d? | finish no earlier than 2011-03-23 | S5 | 1640h | 1640h | FS_3G_TMF_PM | PCG-25 | 32.831 | Alcatel-Lucent | Rel-10 | SP-48 | Dionisio |  |  |  |
| 600 | 230 | Study on Policy and Charging Rules Function (PCRF) failure and restoration |  | 261d? | 2009-08-18 A | 2010-09-17 A | 100% | 2009-08-18 | 2010-09-17 | 261d? | finish no earlier than 2010-09-17 | C3 | 2088h | 2088h | FS_PCRF-FR | PCG-23 | 29.816 | NEC | Rel-10 | CP-45 | Jiwan |  |  |  |
| 601 | 231 | Study on User Data Convergence (UDC) evolution |  | 206d? | 2010-06-04 A | 2011-03-18 A | 100% | 2010-06-04 | 2011-03-18 | 206d? | finish no earlier than 2011-03-18 | C4 | 1648h | 1648h | FS_UDCe | PCG-25 | 23.845 | Alcatel-Lucent | Rel-10 | CP-48 | Kimmo |  |  |  |
| 602 | 232 | Study on UICC access to IMS |  | 206d? | 2010-06-04 A | 2011-03-18 A | 100% | 2010-06-04 | 2011-03-18 | 206d? | finish no earlier than 2011-03-18 | C6 | 1648h | 1648h | FS_IMS-UICC | PCG-25 | 31.828 | Gemalto | Rel-10 | CP-48 | Xavier |  |  |  |
| 603 | 233 | Study on Uplink Tx Diversity for HSPA |  | 208.4d? | 2009-08-18 A | 2010-06-04 A | 100% | 2009-08-18 | 2010-06-04 | 208.4d? | finish no earlier than 2010-06-04 | R4 | 1667.2h | 1667.2h | FS_UL-TxDiv-HSPA | PCG-23 | UTRA 25.863 | Qualcomm | Rel-10 | RP-45 | Issam |  | RP-100499 |  |
| 604 | 234 | Study on Solutions for Energy Saving within UTRA Node B |  | 206d? | 2009-12-04 A | 2010-09-17 A | 100% | 2009-12-04 | 2010-09-17 | 206d? | finish no earlier than 2010-09-17 | R1,R3 | 1648h | 1648h | FS_Energy_UMTS | PCG-24 | UTRA 25.927 | Vodafone | Rel-10 | RP-46 | Patrick |  | RP-100796 |  |
| 605 | 235 | Study on Potential solutions for energy saving for E-UTRAN |  | 316d? | 2010-02-02 A | 2011-06-03 A | 100% | 2010-02-02 | 2011-06-03 | 316d? | finish no earlier than 2011-06-03 | R3,R2 | 2528h | 2528h | FS_Energy_LTE | PCG-24 | LTE 36.927 | China Mobile | Rel-10 | RP-47 | Juha |  | RP-110597 |  |
| 606 | 236 | Study on Improvements of distributed antenna for 1.28Mcps TDD |  | 191d? | 2010-03-05 A | 2010-12-10 A | 100% | 2010-03-05 | 2010-12-10 | 191d? | finish no earlier than 2010-12-10 | R1,R2,R3 | 1528h | 1528h | FS_distr_ant_LCR_TDD | PCG-24 | UTRA 25.865 | ZTE | Rel-10 | RP-47 | Patrick |  | RP-101287 |  |
| 607 | 237 | Deleted - Study on Unauthenticated PS Emergency Calls |  | 471d? | 2008-06-05 A | 2010-03-25 A | 100% | 2008-06-05 | 2010-03-25 | 471d? | finish no earlier than 2010-03-25 | S1 | 3768h | 3768h | FS_UAPSEC | PCG-21 | 22.984 | Nokia Siemens Networks | Rel-10 | SP-40 | Alain | PCG-24 |  | SP-47 |
| 608 | 238 | Deleted - Study on enhancements to IMS border functions for IMS Interconnection of services |  | 586d? | 2008-09-18 A | 2010-12-15 A | 100% | 2008-09-18 | 2010-12-15 | 586d? | finish no earlier than 2010-12-15 | S2 | 4688h | 4688h | FS_eIMS_IBCF | PCG-21 | 23.848 | Starent Networks | Rel-10 | SP-41 | Maurice | PCG-26 |  | SP-50 |
| 609 | 239 | Deleted - Study on EPC Charging enhancement |  | 211d? | 2009-06-04 A | 2010-03-25 A | 100% | 2009-06-04 | 2010-03-25 | 211d? | finish no earlier than 2010-03-25 | S5 | 1688h | 1688h | FS_EPCcharg | PCG-23 |  | Nokia Siemens Networks | Rel-10 | SP-44 | Dionisio | PCG-24 |  | SP-47 |
| 610 | 240 | Deleted - Study on Interworking Proxy between GTP based and PMIP based interfaces |  | 186d? | 2009-09-18 A | 2010-06-04 A | 100% | 2009-09-18 | 2010-06-04 | 186d? | finish no earlier than 2010-06-04 | C4 | 1488h | 1488h | FS_GTP-MIP-IW | PCG-23 | 29.875 | NTT DoCoMo | Rel-10 | CP-45 | Kimmo | PCG-25 |  | CP-48 |
| 611 | 241 | Release 9 Features | milestone | 0d? | 2008-06-05 A | 2008-06-05 A | 100% | 2008-06-05 | 2008-06-05 | 0d? |  | CP,GP,RP,SP |  |  |  |  |  |  | Rel-9 |  |  |  |  |  |

Notes:
- 574: RP#49 stopped (no further standardization needed). Ensure that Enhanced Interference Management methods identified in Rel-9 for HNBs do not fail in deployments with a large penetration of CSG-aware UEs / Text5: Andrei Radulescu (aradules@qualcomm.com)
- 575: RP#49 stopped (no further standardization needed) / Text5: Andrei Radulescu (aradules@qualcomm.com)
- 576: RP#50 work stopped (RP-101266) / Text5: henrik.enbuske@ericsson.com
- 577: RP#50 work stopped (RP-101266) / Text5: henrik.enbuske@ericsson.com
- 578: -
- 579: SP#47 completed. TR 22.813-100 for Approval. Spin-off Feature UID_470030 Codec for Enhanced Voice Services / Text5: LOTTIN, Philippe
- 580: SP#47 completed. TR 22.813-100 for Approval / Text5: LOTTIN, Philippe
- 581: SP#47 completed. TR 22.813-100 for Approval / Text5: stefan.bruhn@ericson.com
- 582: SP#46 completed. Linked to Rel-8 Feature UID_380060 IP Interconnection of Services (IPinterc). Spin-off Feature Rel-11 UID_470051 Advanced IP Interconnection of Services / Text5: chris.friel@O2.com
- 583: SP#47 completed / Text5: Jaihyung Cho
- 584: SP#47 completed / Text5: jinhan.song@sktelecom.com
- 585: SP#47 completed. Covers Mobile/Fixed/Cordless/etc terminals. Haptic (human-machine tactile communication) extend service offering & richness of user experience beyond current visual & auditory senses / Text5: jinhan.song@sktelecom.com
- 586: SP#46 completed. Spin-off Feature UID_460028 Optimal Media Routeing (OMR). Linked to Study on Multimedia Session Continuity UID_350051, Study on Centralized IMS Service Control UID_330012, IMS inter-operator service interconnection interface UID_360011 / Text5: mario.madella@telecomitalia.it, victor.kueh@bt.com
- 587: SP#47 completed. Concluded no further normative work expected. Linked to 23.236 / Text5: LIU HONG (liuhongyfw@chinamobile.com)
- 588: SP#49 completed (Conclusion: select the SIP anchoring based solution for normative work CR (TEI10) introducing and completing stage-2). Analyzed performance of Rel-8 SRVCC solution from E-UTRAN/HSPA to UTRAN/GERAN / Text5: Hou zhiqiang (houzhiqiang@chinamobile.com), Jiang Yi (jiangyi@chinamobile.com)
- 589: SP#49 completed. TR 23.886v100 for Approval. Related to Rel-8 UID_350030 Single Radio Voice Call Continuity for 3GPP (SAES-SRVCC). Study how to provide Video Call seamless service continuity for 3G/LTE terminal user / Text5: Haris Zisimopoulos (haris.z@samsung.com)
- 590: SP#48 completed. Triggered by Rel-8 UID_350027 SAE for support for non-3GPP accesses. Nature of relationship: S2b one of the interfaces defined for non-3GPP accesses support in EPS. Stage 1 in Rel-8 UID_320022 (AIPN-SAE) 22.278,22.101 / Text5: bruno.landais@alcatel-lucent.com
- 591: SP#51 completed. Extend Rel-8 UID_34043 (Extending PSS and MBMS User Services for optimized Mobile TV) / Text5: jan.plogsties@iis.franhofer.de
- 592: SP#51 completed. Extends Rel-9 Improved Video Support for PSS and MBMS (UID_430039) / Text5: imed.bouazizi@nokia.com, jaihyung@etri.re.kr
- 593: SP#47 completed / Text5: shan.mingjun@huawei.com
- 594: SP#47 completed. Study result might impact Feature UID_420011 Self Organising Networks (SON) / Text5: Jean-Michel Cornilly (Orange)
- 595: SP#47 completed. TR 32.827 v100 for Information + Approval. WID updated SP-090462=>SP-100088. Study the missing Itf-N part in the Framework. Study changes to Itf-N to utilize UE based measurements / Text5: Yizhi Yao (yzyao@motorola.com)
- 596: SP#51 completed / Text5: olaf.pollakowski@nsn.com
- 597: SP#51 completed / Text5: olaf.pollakowski@nsn.com, Padma.Sudarsan@alcatel-lucent.com
- 598: SP#51 completed / Text5: edwin.tse@ericsson.com
- 599: SP#51 completed / Text5: Padma.Sudarsan@alcatel-lucent.com
- 600: CP#49 completed (the solution will be chosen during a separate implementation work) / Text5: gottfried.punz@nw.neclab.eu
- 601: CP#51 completed. Study UDC evolution from Features in Rel-9 UID_400034 and Rel-10 UID_480011 UDC Data Model / Text5: jean-jacques.trottin@alcatel-lucent.com
- 602: CP#51 completed / Text5: Denis.Lheriteau@gemalto.com
- 603: RP#48 completed / Text5: Heechoon Lee (heechoon@qualcomm.com)
- 604: RP#49 completed. Based on ETSI EE TS 102 706. / Text5: Prakash.bhat@vodafone.com
- 605: RP#52 completed / Text5: Yang Ning (yangning@chinamobile.com)
- 606: RP#50 completed. TR 25.865 v101 for Approval / Text5: huang.he4@zte.com.cn
- 607: SP#47 work stopped/abandoned / Text5: Juergen Merkel
- 608: SP#50 work stopped. Additional work may be addressed as part of the Rel-11 Feature UID_470051 Advanced IP Interconnection of Services (IPXS) / Text5: Rajat Ghai (rghai@starentnetworks.com)
- 609: SP#47 work stopped. Issue covered by Rel-10 UID_460039 Charging for LIPA_SIPTO and UID_4700xy Charging for IFOM / Text5: Gerald.Goermer@nsn.com
- 610: CP#48 work stopped/abandoned / Text5: takaaki.matsuura.sp@s1.nttdocomo.com
- 611: -

| ID | WBS | Task | Duration | Start | Finish | Complete | Remaining | Baseline start | Baseline finish | Baseline duration | Total slack | Constraint | Resources | Work | Actual work | Text1 | Text2 | Text4 | Text5 | Text6 | Text7 | Text8 | Text11 |
| --- | --- | --- | --- | --- | --- | --- | --- | --- | --- | --- | --- | --- | --- | --- | --- | --- | --- | --- | --- | --- | --- | --- | --- |
| 612 | 242 | **Enhanced Home NodeB / eNodeB** | 923d? | 2008-06-05 A | 2011-12-16 | 96% | 36.33d? | 2008-06-05 | 2011-12-16 | 923d? | 255d |  | S1,S2,S3,S5,C1,C6,R2,R3,R4,GP | 37416h | 30863.2h | EHNB | PCG-21 | T-Mobile | michael.kurz@t-mobile.at | Rel-9 | SP-40 | Alain |  |
| 613 | 242.1 | Stage 1 for EHNB | 261d? | 2008-06-05 A | 2009-06-04 A | 100% |  | 2008-06-05 | 2009-06-04 | 261d? |  | finish no earlier than 2009-06-04 | S1 | 2088h | 2088h | EHNB | PCG-21 | T-Mobile | michael.kurz@t-mobile.at | Rel-9 | SP-40 | Alain |  |
| 614 | 242.2 | Architecture aspects of EHNB | 266d? | 2008-09-18 A | 2009-09-24 A | 100% |  | 2008-09-18 | 2009-09-24 | 266d? |  | finish no earlier than 2009-09-22 | S2 | 2128h | 2128h | EHNB | PCG-21 | T-Mobile | sebastian.speicher@telekom.de | Rel-9 | SP-41 | Maurice |  |
| 615 | 242.3 | Security aspects of Enhanced Home NodeB / eNodeB | 262d? | 2008-12-11 A | 2009-12-10 A | 100% |  | 2008-12-11 | 2009-12-10 | 262d? |  | finish no earlier than 2009-12-10 | S3 | 2096h | 2096h | EHNB-Sec | PCG-22 | Huawei | Marcus Wong (mwong@huawei.com) | Rel-9 | SP-42 | Dionisio |  |
| 616 | 242.4 | CT1 aspects - Support of Home NB and Home eNB enhancements | 321d? | 2009-09-18 A | 2010-12-10 A | 100% |  | 2009-09-18 | 2010-12-10 | 321d? |  | finish no earlier than 2010-12-10 | C1 | 2568h | 2568h | EHNB-CT1 | PCG-23 | Qualcomm | Ramachandran Subramanian (rsubrama@qualcomm.com) | Rel-9 | CP-45 | Frederic |  |
| 617 | 242.5 | CT6 aspects - Support of Home NB and Home eNB enhancements | 131d? | 2009-09-18 A | 2010-03-19 A | 100% |  | 2009-09-18 | 2010-03-19 | 131d? |  | finish no earlier than 2010-03-19 | C6 | 1048h | 1048h | EHNB-CT6 | PCG-23 | Qualcomm | Ramachandran Subramanian (rsubrama@qualcomm.com) | Rel-9 | CP-45 | Xavier |  |
| 618 | 242.6 | 3G HNB Gateway and LTE HeNB Gateway OAM&P | 336d? | 2008-12-11 A | 2010-03-25 A | 100% |  | 2008-12-11 | 2010-03-25 | 336d? |  | finish no earlier than 2010-03-25 | S5 | 2688h | 2688h | HNB-OAM_GW | PCG-22 | China Mobile | GangChen (chengang@chinamobile.com) | Rel-9 | SP-42 | Dionisio |  |
| 619 | 242.7 | 3G HNB and LTE HeNB OAM&P Type 1 Interface | 272d? | 2009-03-12 A | 2010-03-25 A | 100% |  | 2009-03-12 | 2010-03-25 | 272d? |  | finish no earlier than 2010-03-25 | S5 | 2168h | 2168h | HNB_eHNB-OAM_Type1 | PCG-22 | Huawei | Zou Lan (zlan@huawei.com) | Rel-9 | SP-43 | Dionisio |  |
| 620 | 242.8 | 3G HNB and LTE HeNB OAM&P Type 2 Interface | 225d? | 2009-05-15 A | 2010-03-25 A | 100% |  | 2009-05-15 | 2010-03-25 | 225d? |  | finish no earlier than 2010-03-25 | S5 | 1800h | 1800h | HNB_eHNB-OAM_Type2 | PCG-23 | Ericsson | edwin.tse@ericsson.com | Rel-9 | SP-44 | Dionisio |  |
| 621 | 242.9 | LTE FDD Home eNodeB RF Requirements | 336d? | 2008-12-05 A | 2010-03-19 A | 100% |  | 2008-12-05 | 2010-03-19 | 336d? |  | finish no earlier than 2010-03-19 | R4 | 2688h | 2688h | HeNB-RF_FDD | PCG-22 | Motorola | Ying Cai (yingcai@motorola.com) | Rel-9 | RP-42 | Issam | RP-100035 |
| 622 | 242.10 | LTE TDD Home eNodeB RF Requirements | 271d? | 2009-03-06 A | 2010-03-19 A | 100% |  | 2009-03-06 | 2010-03-19 | 271d? |  | finish no earlier than 2010-03-19 | R4 | 2168h | 2168h | HeNB-RF_TDD | PCG-22 | China Mobile | Nan Li (linan@chinamobile.com) | Rel-9 | RP-43 | Issam | RP-100036 |
| 623 | 242.11 | Home NB and Home eNB enhancements - RAN3 aspects | 197d? | 2009-03-06 A | 2009-12-04 A | 100% |  | 2009-03-06 | 2009-12-04 | 197d? |  | finish no earlier than 2009-12-04 | R3 | 1576h | 1576h | EHNB-RAN3 | PCG-22 | Alcatel-Lucent | Martin Warner (mw15@alcatel-lucent.com) | Rel-9 | RP-43 | Juha | RP-091050 |
| 624 | 242.12 | Home NB and Home eNB enhancements - RAN2 aspects | 271d? | 2009-03-06 A | 2010-03-19 A | 100% |  | 2009-03-06 | 2010-03-19 | 271d? |  | finish no earlier than 2010-03-19 | R2 | 2168h | 2168h | EHNB-RAN2 | PCG-22 | Huawei | Yang Xudong (yangxudong@huawei.com) | Rel-9 | RP-43 | Joern | RP-100037 |
| 625 | 242.13 | Conformance Test Aspects – Home NB enhancements for FDD | 326d? | 2010-09-17 A | 2011-12-16 | 70% | 97.8d? | 2010-09-17 | 2011-12-16 | 326d? | 255d | finish no earlier than 2011-12-16 | R5 | 2608h | 1825.6h | EHNB-UTRA_FDD_UEConTest | PCG-25 | Huawei | trica_li@huawei.com | Rel-9 | RP-49 | Ingbert | RP-110511 |
| 626 | 242.14 | Conformance Test Aspects – Home eNB enhancements | 201d? | 2010-12-10 A | 2011-09-16 | 70% | 60.3d? | 2010-12-10 | 2011-09-16 | 201d? | 320d | finish no earlier than 2011-09-16 | R5 | 1608h | 1125.6h | EHNB-LTE_UEConTest | PCG-26 | Qualcomm | Mrs Lena Chaponniere (lchaponn@qualcomm.com) | Rel-9 | RP-50 | Ingbert | RP-110512 |
| 627 | 242.15 | Home NB and Home eNB enhancements - GERAN aspects | 341d? | 2009-05-18 A | 2010-09-03 A | 100% |  | 2009-05-18 | 2010-09-03 | 341d? |  | finish no earlier than 2010-09-03 | GP | 2728h | 2728h | EHNB-GERAN | PCG-23 | Nokia Siemens Networks | leonardo.provvedi@roke.co.uk | Rel-9 | GP-42 | Paolo |  |
| 628 | 243 | **Value-Added Services for Short Message Service** | 586d? | 2007-09-10 A | 2009-12-04 A | 100% |  | 2007-09-10 | 2009-12-04 | 586d? |  |  | S1,C4,C1 | 10888h | 10888h | VAS4SMS |  | China Mobile | Wu Bin (wubin@chinamobile.com) | Rel-9 | SP-37 | Alain |  |
| 629 | 243.1 | Stage 1 for VAS4SMS | 133d? | 2007-09-10 A | 2008-03-12 A | 100% |  | 2007-09-10 | 2008-03-12 | 133d? |  | finish no earlier than 2008-03-21 | S1 | 1064h | 1064h | VAS4SMS |  | China Mobile | Wu Bin (wubin@chinamobile.com) | Rel-9 | SP-37 | Alain |  |
| 630 | 243.2 | CT4 aspects of VAS4SMS Interface and Signalling Flow | 322d? | 2008-09-12 A | 2009-12-04 A | 100% |  | 2008-09-12 | 2009-12-04 | 322d? |  | finish no earlier than 2009-12-04 | C4 | 2568h | 2568h | VAS4SMS | PCG-21 | China Mobile | Wu Bin (wubin@chinamobile.com) | Rel-9 | CP-41 | Kimmo |  |
| 631 | 243.3 | CT1 aspects of VAS4SMS Interface and Signalling Flow | 321d? | 2008-09-09 A | 2009-12-04 A | 100% |  | 2008-09-09 | 2009-12-04 | 321d? |  | finish no earlier than 2009-12-04 | C1 | 2568h | 2568h | VAS4SMS | PCG-21 | China Mobile | Wu Bin (wubin@chinamobile.com) | Rel-9 | CP-41 | Frederic |  |
| 632 | 244 | **Definition of End-User Identity** | 334d? | 2007-09-03 A | 2008-12-11 A | 100% |  | 2007-09-03 | 2008-12-11 | 334d? |  |  | S1 | 5344h | 5344h | EUI |  | Nokia Siemens Networks | Juergen.Merkel@nsn.com | Rel-9 | SP-38 | Alain |  |
| 633 | 244.1 | Definition of End-User Identity | 334d? | 2007-09-03 A | 2008-12-11 A | 100% |  | 2007-09-03 | 2008-12-11 | 334d? |  | finish no earlier than 2008-12-11 | S1 | 2672h | 2672h | EUI | PCG-21 | Nokia Siemens Networks | Juergen.Merkel@NSN.com | Rel-9 | SP-38 | Alain |  |
| 634 | 245 | **Customized Ringing Signal** | 522d? | 2007-12-06 A | 2009-12-03 A | 100% |  | 2007-12-06 | 2009-12-03 | 522d? |  |  | S1,C1 | 7120h | 7120h | CRS | PCG-21 | SK Telecom, China Mobile | Donghee Shim (SK Telecom), Jianping Zheng (China Mobile) | Rel-9 | SP-38 | Alain |  |
| 635 | 245.1 | Stage 1 for Customized Ringing Signal | 266d? | 2007-12-06 A | 2008-12-11 A | 100% |  | 2007-12-06 | 2008-12-11 | 266d? |  | finish no earlier than 2008-12-11 | S1 | 2128h | 2128h | CRS | PCG-21 | SK Telecom, China Mobile | Donghee Shim (SK Telecom), Jianping Zheng (China Mobile) | Rel-9 | SP-38 | Alain |  |
| 636 | 245.2 | Stage 3 for IMS Customized Ringing Signal (CRS) Service | 136d? | 2009-05-29 A | 2009-12-03 A | 100% |  | 2009-05-29 | 2009-12-03 | 136d? |  | finish no earlier than 2010-06-04 | C1 | 816h | 816h | CRS | PCG-23 | China Mobile | wangzhao | Rel-9 | CP-44 | Frederic |  |

Notes:
- 612: CP#50 Core specification completed. Testing ongoing / Text3: UTRA, LTE
- 613: CP#49 the SA1-reqs are moving. CT1 will align when the work in SA1 is clear. (was SP#44 completed.) / Text3: 22.220, 22.011
- 614: SP#45 completed / Text3: 23.401, 23.402, 23.060, new 23.830
- 615: SP#46 completed / Text3: new 33.320
- 616: CP#50 completed (Roaming aspects for manual CSG selection, Support of temporary users and CSG membership changes, Support of user controlled and operator controlled lists) / Text3: 23.122, 24.008, 24.285, 24.301
- 617: CP#47 completed. Storing of CSG related data items on the USIM / Text3: 31.102
- 618: SP#47 completed / Text3: 32.632, 32.633, 32.635, new (32.771, 32.772, 32.773, 32.775, 32.781, 32.782, 32.783, 32.785)
- 619: SP#47 completed / Text3: 32.581, 32.582, 32.583, 32.584, new (32.591, 32.592, 32.593, 32.594)
- 620: SP#47 completed / Text3: new (32.571, 32.572)
- 621: RP#47 completed / Text3: 36.104, 36.141, new TR 36.921
- 622: RP#47 completed / Text3: 36.104, 36.141, 36.300, 36.331, 36.413, new TR 36.922
- 623: RP#46 completed (based on high priority items specified in RP-090995) / Text3: 25.413, 25.467, 25.467, 25.468, 25.469, 25.469, 36.401, 36.413, new 25.444
- 624: RP#47 completed / Text3: 25.304, 25.331, 25.367, 36.300, 36.304, 36.331
- 625: UTRA. Testing for UID_430026 Support of Home NB and Home eNB enhancements RAN2 aspects (25.304, 25.331, 25.367) / Text3: 34.108, 34.123-1, 34.123-2, 34.123-3
- 626: - / Text3: 36.508, 36.523-1, 36.523-2, 36.523-3
- 627: GP#47 completed. GP#42 WID approved / Text3: 43.055, 43.129, 44.018, 44.060, 45.008, 48.008, 48.018
- 628: CP#46 completed
- 629: SP#39 completed. SP#43 Feature moved to Rel-9 / Text3: 22.142
- 630: CP#46 completed / Text3: new 23.142
- 631: CP#46 completed / Text3: 23.040
- 632: SP#42 closed. Stage 1 work closed at 5% completion due to lack of input (added only the EUI definition in 21.905)
- 633: SP#42 closed. Stage 1 work closed at 5% completion due to lack of input (added only the EUI definition in 21.905) / Text3: 21.905
- 634: CP#48 completed
- 635: SP#42 completed. / Text3: 22.173, new 22.183
- 636: CP#48 completed / Text3: 24.173, new 24.183

| ID | WBS | Task | Type | Duration | Start | Finish | Complete | Baseline start | Baseline finish | Baseline duration | Constraint | Resources | Work | Actual work | Text1 | Text2 | Text3 | Text4 | Text6 | Text7 | Text8 | Text11 |
| --- | --- | --- | --- | --- | --- | --- | --- | --- | --- | --- | --- | --- | --- | --- | --- | --- | --- | --- | --- | --- | --- | --- |
| 637 | 246 | **Public Warning System** |  | 523d? | 2007-12-06 A | 2009-12-04 A | 100% | 2007-12-06 | 2009-12-04 | 523d? |  | S1,C1,C4,R2 | 10232h | 10232h | PWS | PCG-21 | GERAN, UTRA, LTE | T-Mobile | Rel-9 | SP-38 | Alain |  |
| 638 | 246.1 | Stage 1 for Public Warning System |  | 266d? | 2007-12-06 A | 2008-12-11 A | 100% | 2007-12-06 | 2008-12-11 | 266d? | finish no earlier than 2008-12-11 | S1 | 2128h | 2128h | PWS | PCG-21 | 22.268 | T-Mobile | Rel-9 | SP-38 | Alain |  |
| 639 | 246.2 | **Stage 3 for Public Warning System** |  | 137d? | 2009-05-29 A | 2009-12-04 A | 100% | 2009-05-29 | 2009-12-04 | 137d? |  | C1,C4 | 3272h | 3272h | PWS-St3 | PCG-23 |  | Qualcomm | Rel-9 | CP-44 | Frederic |  |
| 640 | 246.2.1 | CT1 aspects of Stage 3 for Public Warning System |  | 137d? | 2009-05-29 A | 2009-12-04 A | 100% | 2009-05-29 | 2009-12-04 | 137d? | finish no earlier than 2009-12-04 | C1 | 1088h | 1088h | PWS-St3 | PCG-23 | 23.041 | Qualcomm | Rel-9 | CP-44 | Frederic |  |
| 641 | 246.2.2 | CT4 aspects of Stage 3 for Public Warning System |  | 136d? | 2009-05-30 A | 2009-12-04 A | 100% | 2009-05-30 | 2009-12-04 | 136d? | finish no earlier than 2009-12-04 | C4 | 1088h | 1088h | PWS-St3 | PCG-23 | 29.168 | Qualcomm | Rel-9 | CP-44 | Kimmo |  |
| 642 | 246.3 | Public Warning System (PWS) – RAN aspects |  | 81d? | 2009-05-30 A | 2009-12-04 A | 100% | 2009-05-30 | 2009-12-04 | 81d? | finish no earlier than 2009-12-04 | R2,R3 | 648h | 648h | PWS-RAN | PCG-23 | LTE 36.300, 36.302, 36.331, 36.413 | AT&T | Rel-9 | RP-44 | Joern | RP-091052 |
| 643 | 247 | **Support of Personal Area Networks and Enhancements to Personal Network Management** |  | 523d? | 2008-06-05 A | 2010-06-04 A | 100% | 2008-06-05 | 2010-06-04 | 523d? |  | S1,C1 | 8360h | 8360h | PAN_EPNM | PCG-21 |  | Vodafone | Rel-9 | SP-40 | Alain |  |
| 644 | 247.1 | Stage 1 for PAN_EPNM | milestone | 0d? | 2008-06-05 A | 2008-06-05 A | 100% | 2008-06-05 | 2008-06-05 | 0d? | finish no earlier than 2008-06-05 | S1 |  |  | PAN_EPNM | PCG-21 | 22.259 | Vodafone | Rel-9 | SP-40 | Alain |  |
| 645 | 247.2 | Stage 2 for Support of Personal Area Networks and Enhancements to Personal Network Managemen |  | 196d? | 2009-03-06 A | 2009-12-04 A | 100% | 2009-03-06 | 2009-12-04 | 196d? | finish no earlier than 2009-12-04 | C1 | 1568h | 1568h | PAN_EPNM | PCG-22 | 23.259 | Huawei | Rel-9 | CP-43 | Frederic |  |
| 646 | 247.3 | Stage 3 for Support of Personal Area Networks and Enhancements to Personal Network Managemen |  | 326d? | 2009-03-09 A | 2010-06-04 A | 100% | 2009-03-09 | 2010-06-04 | 326d? | finish no earlier than 2010-06-04 | C1 | 2608h | 2608h | PAN_EPNM | PCG-22 | 24.259 | Huawei | Rel-9 | CP-43 | Frederic |  |
| 647 | 248 | **Multi-Media Telephony Service enhancements** |  | 472d? | 2008-06-05 A | 2010-03-25 A | 100% | 2008-06-05 | 2010-03-25 | 472d? |  | S1,S5,C1 | 10288h | 10288h | eMMTel | PCG-21 |  | France Telecom | Rel-9 | SP-40 | Alain |  |
| 648 | 248.1 | Stage 1 for eMMTel |  | 136d? | 2008-06-05 A | 2008-12-11 A | 100% | 2008-06-05 | 2008-12-11 | 136d? | start no earlier than 2008-06-05 | S1 | 1088h | 1088h | eMMTel | PCG-21 | 22.173 | France Telecom | Rel-9 | SP-40 | Alain |  |
| 649 | 248.2 | Multimedia Telephony (MMTel) Service and Supplementary Services - Online Charging and completion for Offline Charging (all supplementary services) |  | 272d? | 2009-03-12 A | 2010-03-25 A | 100% | 2009-03-12 | 2010-03-25 | 272d? | finish no earlier than 2010-03-25 | S5 | 2168h | 2168h | eMMTel-SS-CH | PCG-22 | 32.275, 32.298, 32.299 | Alcatel-Lucent | Rel-9 | SP-43 | Dionisio |  |
| 650 | 248.3 | Support of Real-time Transfer of Tariff Information (RTTI) in IMS charging |  | 271d? | 2009-03-12 A | 2010-03-25 A | 100% | 2009-03-12 | 2010-03-25 | 271d? | finish no earlier than 2010-03-25 | S5 | 2168h | 2168h | IMSTSS-RTTI-CH | PCG-22 | 32.240, 32.280, 32.298, 32.299 | Orange | Rel-9 | SP-43 | Dionisio |  |
| 651 | 248.4 | Stage 3 - Enhancements for Completion of Communications Supplementary service |  | 136d? | 2009-05-30 A | 2009-12-04 A | 100% | 2009-05-30 | 2009-12-04 | 136d? | finish no earlier than 2009-12-04 | C1 | 1088h | 1088h | eMMTel-CC | PCG-23 | 24.642 | France Telecom | Rel-9 | CP-44 | Frederic |  |
| 652 | 249 | **User Data Convergence (UDC)** |  | 527d? | 2008-06-05 A | 2010-06-10 A | 100% | 2008-06-05 | 2010-06-10 | 527d? |  | S1,S5,C4 | 14456h | 14456h | UDC | PCG-21 |  | Nokia Siemens Networks | Rel-9 | SP-40 | Alain |  |
| 653 | 249.1 | Stage 1 for User Data Convergence (UDC) |  | 136d? | 2008-06-05 A | 2008-12-11 A | 100% | 2008-06-05 | 2008-12-11 | 136d? | start no earlier than 2008-06-05 | S1 | 1088h | 1088h | UDC | PCG-21 | 22.985, 22.101 | Nokia Siemens Networks | Rel-9 | SP-40 | Alain |  |
| 654 | 249.2 | User Data Convergence (UDC) Technical Realization (Stage 2) |  | 271d? | 2009-03-06 A | 2010-03-19 A | 100% | 2009-03-06 | 2010-03-19 | 271d? | finish no earlier than 2010-03-19 | C4 | 2168h | 2168h | UDC-CN | PCG-22 | new 23.335 | Ericsson | Rel-9 | CP-43 | Kimmo |  |
| 655 | 249.3 | User Data Convergence (UDC) Protocol Description |  | 130d? | 2009-09-18 A | 2010-03-19 A | 100% | 2009-09-18 | 2010-03-19 | 130d? | finish no earlier than 2010-03-19 | C4 | 1040h | 1040h | UDC-CN | PCG-23 | new 29.335 | China Mobile, Ericsson | Rel-9 | CP-45 | Kimmo |  |
| 656 | 249.4 | **User Data Convergence (UDC) Modelling and Management** |  | 266d? | 2009-06-04 A | 2010-06-10 A | 100% | 2009-06-04 | 2010-06-10 | 266d? |  | S5 | 5944h | 5944h | UDC-MMAN | PCG-23 |  | T-Mobile, China Mobile, Ericsson | Rel-9 | SP-44 | Dionisio |  |
| 657 | 249.4.1 | UDC – Framework for Model Handling and Management |  | 266d? | 2009-06-04 A | 2010-06-10 A | 100% | 2009-06-04 | 2010-06-10 | 266d? | finish no earlier than 2010-06-10 | S5 | 2128h | 2128h | UDC-MMAN-MFRM | PCG-23 | 32.172, new 32.181 | T-Mobile | Rel-9 | SP-44 | Dionisio |  |
| 658 | 249.4.2 | UDC – Common Baseline Information Model |  | 211d? | 2009-06-04 A | 2010-03-25 A | 100% | 2009-06-04 | 2010-03-25 | 211d? | finish no earlier than 2010-03-25 | S5 | 1688h | 1688h | UDC-MMAN-CBIM | PCG-23 | 32.172, new 32.182 | China Mobile, Ericsson | Rel-9 | SP-44 | Dionisio |  |
| 659 | 250 | **IMS Services Centralization and Continuity** |  | 393d? | 2008-09-18 A | 2010-03-19 A | 100% | 2008-09-18 | 2010-03-19 | 393d? |  | S1,S2,C1 | 12160h | 12160h | IMS_SCC | PCG-21 |  | NEC | Rel-9 | SP-41 | Alain |  |
| 660 | 250.1 | Stage 1 - Inter-Device Transfer – Requirements |  | 61d? | 2008-09-18 A | 2008-12-11 A | 100% | 2008-09-18 | 2008-12-11 | 61d? | finish no earlier than 2009-06-18 | S1 | 488h | 488h | IMS_SCC-IDT | PCG-21 | 22.101, 22.228 | NEC | Rel-9 | SP-41 | Alain |  |
| 661 | 250.2 | Stage 2 - IMS Service Continuity Enhancements: Service, Policy and Interactions |  | 186d? | 2008-09-18 A | 2009-06-04 A | 100% | 2008-09-18 | 2009-06-04 | 186d? | finish no earlier than 2009-06-04 | S2 | 1488h | 1488h | IMS_SCC-SPI | PCG-21 | 23.838, 23.237, 23.292, 23.216 | Huawei | Rel-9 | SP-41 | Maurice |  |
| 662 | 250.3 | Stage 3 - IMS Service Continuity Enhancements: Service, Policy, Interactions and Inter UE Transfer |  | 212d? | 2009-05-29 A | 2010-03-19 A | 100% | 2009-05-29 | 2010-03-19 | 212d? | finish no earlier than 2010-03-19 | C1 | 1696h | 1696h | IMS_SCC-SPI | PCG-23 | 24.216, 24.229, 24.237 | Qualcomm | Rel-9 | CP-44 | Frederic |  |
| 663 | 250.4 | Stage 2 - IMS Centralized Services |  | 186d? | 2008-09-18 A | 2009-06-04 A | 100% | 2008-09-18 | 2009-06-04 | 186d? | finish no earlier than 2009-06-04 | S2 | 1488h | 1488h | IMS_SCC-ICS | PCG-21 | 23.292, new 23.883 | Alcatel-Lucent | Rel-9 | SP-41 | Maurice |  |
| 664 | 250.5 | Stage 3 - Enhancements to IMS Centralized Services |  | 212d? | 2009-05-29 A | 2010-03-19 A | 100% | 2009-05-29 | 2010-03-19 | 212d? | finish no earlier than 2010-03-19 | C1 | 1688h | 1688h | IMS_SCC-ICS | PCG-23 | 24.292, 24.604, 24.607, 24.608, 24.611, 24.623 | Nokia Siemens Networks | Rel-9 | CP-44 | Frederic |  |
| 665 | 250.6 | Stage 3 - IMS Centralized Services support via I1 interface |  | 271d? | 2009-03-06 A | 2010-03-19 A | 100% | 2009-03-06 | 2010-03-19 | 271d? | finish no earlier than 2010-03-19 | C1 | 2168h | 2168h | IMS_SCC-ICS_I1 | PCG-22 | 24.237, 24.292, new 24.294 | Huawei | Rel-9 | CP-43 | Frederic |  |

Notes:
- 637: TSG#46 completed. Larger scope than Rel-8 Feature UID_370051 (ETWS). Triggered by TR 22.968 Study UID_320025 (FS_PWS) / Text5: Mark.Younge@t-mobile.com
- 638: SP#42 completed / Text5: Mark.Younge@t-mobile.com
- 639: RP#46 completed / Text5: Ramachandran Subramanian (rsubrama@qualcomm.com)
- 640: CP#46 completed / Text5: Ramachandran Subramanian (rsubrama@qualcomm.com)
- 641: CP#46 completed / Text5: Ramachandran Subramanian (rsubrama@qualcomm.com)
- 642: RP#46 completed / Text5: don.zelmer@att.com
- 643: CP#48 completed / Text5: armin.toepfer@vodafone.com
- 644: SP#40 completed / Text5: armin.toepfer@vodafone.com
- 645: CP#46 completed / Text5: Lili Yang (kadyyang@huawei.com)
- 646: CP#48 completed / Text5: Lili Yang (kadyyang@huawei.com)
- 647: SP#47 completed / Text5: Philippe Lottin
- 648: SP#42 completed / Text5: Philippe Lottin
- 649: SA#47 completed / Text5: maryse.gardella@alcatel-lucent.com
- 650: SA#47 completed. Linked to SA5 Rel-8 UID_380042 AoC support in IMS Charging (IMSTSS) / Text5: Jean-Luc Garcia (jl.garcia@orange-ftgroup.com)
- 651: CP#46 completed / Text5: Youssef.chadli@orange-ftgroup.com
- 652: SP#48 completed. Triggered by Rel-8 SA5 Study of Common Profile Storage Framework of User Data for network services and management (UID_320006) TR 32.808 / Text5: juergen.merkel@nsn.com
- 653: SP#42 completed / Text5: juergen.merkel@nsn.com
- 654: CP#47 completed / Text5: emiliano.merino@ericsson.com
- 655: CP#47 completed / Text5: Lan Si Zhong (lansizhong@chinamobile.com), emiliano.merino@ericsson.com
- 656: SP#48 completed / Text5: istvan.aba@t-mobile.at, lansizhong@chinamobile.com, miguel.a.garcia@ericsson.com
- 657: SP#48 completed / Text5: istvan.aba@t-mobile.at
- 658: SP#47 completed / Text5: Lan Si Zhong, Miguel Garcia
- 659: CP#47 completed / Text5: Joerg Swetina (joerg.swetina@nw.neclab.eu)
- 660: SP#42 completed / Text5: Joerg Swetina (joerg.swetina@nw.neclab.eu)
- 661: SP#44 completed. TR 23.838 for Approval / Text5: HengLiang Zhang (hl_zhang@huawei.com)
- 662: CP#47 completed / Text5: Roozbeh Atarius (ratarius@qualcomm.com)
- 663: SP#44 completed. TR 23.883 for Information + Approval / Text5: andy.bennett@alcatel-lucent.com
- 664: CP#47 completed / Text5: Peter.Leis@nsn.com
- 665: CP#47 completed / Text5: Lili Yang(kadyyang@huawei.com)

| ID | WBS | Task | Duration | Start | Finish | Complete | Remaining | Baseline start | Baseline finish | Baseline duration | Total slack | Constraint | Resources | Work | Actual work | Text1 | Text2 | Text4 | Text5 | Text6 | Text7 | Text8 | Text11 |
| --- | --- | --- | --- | --- | --- | --- | --- | --- | --- | --- | --- | --- | --- | --- | --- | --- | --- | --- | --- | --- | --- | --- | --- |
| 666 | 251 | **Service Specific Access Control in EPS** | 783d? | 2008-12-11 A | 2011-12-09 | 61% | 305.12d? | 2008-12-11 | 2011-12-09 | 783d? | 260d |  | S1,C1,R5 | 9048h | 1704h | SSAC | PCG-22 | NTT DoCoMo | Frederic Thepot (thepot@docomolab-euro.com) | Rel-9 | SP-42 | Alain |  |
| 667 | 251.1 | Stage 1 for Service Specific Access Control in EPS | 1d? | 2008-12-11 A | 2008-12-11 A | 100% |  | 2008-12-11 | 2008-12-11 | 1d? |  | start no earlier than 2008-12-11 | S1 | 8h | 8h | SSAC | PCG-22 | NTT DoCoMo | Frederic Thepot (thepot@docomolab-euro.com) | Rel-9 | SP-42 | Alain |  |
| 668 | 251.2 | Stage 3 for Service Specific Access Control in EPS | 212d? | 2009-05-29 A | 2010-03-19 A | 100% |  | 2009-05-29 | 2010-03-19 | 212d? |  | finish no earlier than 2010-03-19 | C1 | 1696h | 1696h | SSAC | PCG-23 | NTT DoCoMo | Hideyuki Yamashita (yamashitahi@s1.nttdocomo.co.jp) | Rel-9 | CP-44 | Frederic |  |
| 669 | 251.3 | Conformance Test Aspects - Service Specific Access Control | 136d? | 2011-06-03 | 2011-12-09 |  |  | 2011-06-03 | 2011-12-09 | 136d? | 260d | finish no earlier than 2011-12-09 | R5 | 1088h |  | SSAC_UEConTest | PCG-27 | NTT DoCoMo | Takao.Shimizu.rp@nttdocomo.com | Rel-9 | RP-52 | Ingbert |  |
| 670 | 252 | **Support for IMS Emergency Calls over GPRS and EPS** | 1021d? | 2008-01-14 A | 2011-12-09 | 95% | 50.34d? | 2008-01-14 | 2011-12-09 | 1021d? | 260d |  | S1,S2,S3,C1,C3,C4,R2,R3,R5 | 37043.7h | 25038.9h | IMS_EMER_GPRS_EPS | PCG-21 | Alcatel-Lucent | Deborah Barclay | Rel-9 | SP-38 | Maurice |  |
| 671 | 252.1 | Stage 1 for IMS Emergency Calls over GPRS and EPS | 239d? | 2008-01-14 A | 2008-12-11 A | 100% |  | 2008-01-14 | 2008-12-11 | 239d? |  | finish no earlier than 2008-12-11 | S1 | 1912h | 1912h | IMS_EMER_GPRS_EPS | PCG-21 | Alcatel-Lucent | Deborah Barclay | Rel-9 | SP-38 | Alain |  |
| 672 | 252.2 | Stage 2 for IMS Emergency Calls over GPRS and EPS | 364d? | 2008-01-14 A | 2009-06-04 A | 100% |  | 2008-01-14 | 2009-06-04 | 364d? |  | finish no earlier than 2009-06-04 | S2 | 2912h | 2912h | IMS_EMER_GPRS_EPS | PCG-21 | Alcatel-Lucent | Deborah Barclay | Rel-9 | SP-38 | Maurice |  |
| 673 | 252.3 | Security aspects for IMS Emergency Calls over GPRS and EPS | 391d? | 2008-12-12 A | 2010-06-10 A | 100% |  | 2008-12-12 | 2010-06-10 | 391d? |  | finish no earlier than 2010-03-25 | S3 | 3128h | 3128h | IMS_EMER_GPRS_EPS-Sec | PCG-22 | Alcatel-Lucent | Deborah Barclay | Rel-9 | SP-42 | Dionisio |  |
| 674 | 252.4 | **Stage 3 for IMS Emergency Calls over GPRS and EPS** | 662d? | 2009-05-29 A | 2011-12-09 | 83% | 110.95d? | 2009-05-29 | 2011-12-09 | 662d? | 260d |  | C1,C3,C4,R5 | 11907.7h | 6158.88h | IMS_EMER_GPRS_EPS | PCG-23 | Alcatel-Lucent | Frank Alfano (falfano@alcatel-lucent.com) | Rel-9 | CP-44 | Frederic |  |
| 675 | 252.4.1 | CT1 aspects - Stage 3 for IMS Emergency Calls over GPRS and EPS | 212d? | 2009-05-29 A | 2010-03-19 A | 100% |  | 2009-05-29 | 2010-03-19 | 212d? |  | finish no earlier than 2010-03-19 | C1 | 1696h | 1696h | IMS_EMER_GPRS_EPS | PCG-23 | Alcatel-Lucent | Frank Alfano (falfano@alcatel-lucent.com) | Rel-9 | CP-44 | Frederic |  |
| 676 | 252.4.2 | Conformance Test Aspects - CT1 aspects for IMS Emergency Calls over GPRS and EPS | 396d? | 2010-06-04 A | 2011-12-09 | 65% | 138.6d? | 2010-06-04 | 2011-12-09 | 396d? | 260d | finish no earlier than 2011-12-09 | R5 | 3168h | 2059.2h | IMS_EMER_GPRS_EPS_UEConTest | PCG-25 | Samsung | stoyan.baev@partner.samsung.com | Rel-9 | RP-48 | Ingbert | RP-110507 |
| 677 | 252.4.3 | CT3 aspects - Stage 3 for IMS Emergency Calls over GPRS and EPS | 82d? | 2009-05-29 A | 2009-09-18 A | 100% |  | 2009-05-29 | 2009-09-18 | 82d? |  | start no earlier than 2009-05-29 | C3 | 651.68h | 651.68h | IMS_EMER_GPRS_EPS | PCG-23 | Alcatel-Lucent | Frank Alfano (falfano@alcatel-lucent.com) | Rel-9 | CP-44 | Jiwan |  |
| 678 | 252.4.4 | CT4 aspects - Stage 3 for IMS Emergency Calls over GPRS and EPS | 137d? | 2009-05-29 A | 2009-12-04 A | 100% |  | 2009-05-29 | 2009-12-04 | 137d? |  | finish no earlier than 2009-12-04 | C4 | 1096h | 1096h | IMS_EMER_GPRS_EPS | PCG-23 | Alcatel-Lucent | Frank Alfano (falfano@alcatel-lucent.com) | Rel-9 | CP-44 | Kimmo |  |
| 679 | 252.5 | Support for IMS Emergency Calls over LTE | 206d? | 2008-12-05 A | 2009-09-18 A | 100% |  | 2008-12-05 | 2009-09-18 | 206d? |  |  | R2,R3 | 1648h | 1648h | IMS_EMER_LTE | PCG-22 | Alcatel-Lucent | Sudeep Palat (spalat@alcatel-lucent.com) | Rel-9 | RP-42 | Joern |  |
| 680 | 252.6 | Conformance Test Aspects – Support for IMS Emergency Calls over LTE | 187d? | 2010-03-25 A | 2010-12-10 A | 100% |  | 2010-03-25 | 2010-12-10 | 187d? |  | finish no earlier than 2010-12-10 | R5 | 1496h | 1496h | IMS_EMER_LTE_UEConTest | PCG-24 | Ericsson | leif.mattisson@ericsson.com | Rel-9 | RP-47 | Ingbert | RP-101068 |
| 681 | 252.7 | **SRVCC support for IMS Emergency Calls** | 322d? | 2008-09-18 A | 2009-12-10 A | 100% |  | 2008-09-18 | 2009-12-10 | 322d? |  |  | S2,C1,C4,C3 | 5872h | 5872h | IMS_EMER_GPRS_EPS-SRVCC | PCG-21 | China Mobile | Yu Qing (Yuqing@chinamobile.com) | Rel-9 | SP-41 | Maurice |  |
| 682 | 252.7.1 | SRVCC support for IMS Emergency Calls | 322d? | 2008-09-18 A | 2009-12-10 A | 100% |  | 2008-09-18 | 2009-12-10 | 322d? |  | finish no earlier than 2009-12-10 | S2 | 2576h | 2576h | IMS_EMER_GPRS_EPS-SRVCC | PCG-21 | China Mobile | Yu Qing (Yuqing@chinamobile.com) | Rel-9 | SP-41 | Maurice |  |
| 683 | 252.7.2 | **CT aspects of SRVCC support for IMS Emergency Calls** | 137d? | 2009-05-29 A | 2009-12-04 A | 100% |  | 2009-05-29 | 2009-12-04 | 137d? |  |  | C1,C4,C3 | 3296h | 3296h | IMS_EMER_GPRS_EPS-SRVCC | PCG-24 | China Mobile | jiangyi@chinamobile.com | Rel-9 | CP-46 | Frederic |  |
| 684 | 252.7.2.1 | CT1 aspects of SRVCC support for IMS Emergency Calls | 137d? | 2009-05-29 A | 2009-12-04 A | 100% |  | 2009-05-29 | 2009-12-04 | 137d? |  | finish no earlier than 2009-12-04 | C1 | 1096h | 1096h | IMS_EMER_GPRS_EPS-SRVCC | PCG-23 | China Mobile | jiangyi@chinamobile.com | Rel-9 | CP-44 | Frederic |  |
| 685 | 252.7.2.2 | CT4 aspects of SRVCC support for IMS Emergency Calls | 137d? | 2009-05-29 A | 2009-12-04 A | 100% |  | 2009-05-29 | 2009-12-04 | 137d? |  | finish no earlier than 2009-12-04 | C4 | 1096h | 1096h | IMS_EMER_GPRS_EPS-SRVCC | PCG-23 | China Mobile | jiangyi@chinamobile.com | Rel-9 | CP-44 | Kimmo |  |
| 686 | 252.7.2.3 | CT3 aspects of SRVCC support for IMS Emergency Calls | 1d? | 2009-12-04 A | 2009-12-04 A | 100% |  | 2009-12-04 | 2009-12-04 | 1d? |  | finish no earlier than 2009-12-04 | C3 | 8h | 8h | IMS_EMER_GPRS_EPS-SRVCC | PCG-24 | China Mobile | jiangyi@chinamobile.com | Rel-9 | CP-46 | Kimmo |  |
| 687 | 253 | **LCS for LTE and EPS** | 918d? | 2008-06-05 A | 2011-12-09 | 88% | 108.38d? | 2008-06-05 | 2011-12-09 | 918d? | 260d |  | S2,C1,C4,R2,R1,R3,R4,R5 | 23312h | 16620.8h | LCS_LTE_EPS | PCG-22 |  |  | Rel-9 | SP-43 | Maurice |  |
| 688 | 253.1 | **LCS Control Plane Solution for EPS** | 468d? | 2008-06-05 A | 2010-03-19 A | 100% |  | 2008-06-05 | 2010-03-19 | 468d? |  |  | S2,C4,C1 | 9224h | 9224h | LCS_EPS-CPS | PCG-21 | Polaris Wireless | Robert Gross (rgross@polariswireless.com) | Rel-9 | SP-40 | Maurice |  |
| 689 | 253.1.1 | Stage 2 for LCS Control Plane Solution for EPS | 261d? | 2008-06-05 A | 2009-06-04 A | 100% |  | 2008-06-05 | 2009-06-04 | 261d? |  | finish no earlier than 2009-06-04 | S2 | 2088h | 2088h | LCS_EPS-CPS | PCG-21 | Polaris Wireless | Robert Gross (rgross@polariswireless.com) | Rel-9 | SP-40 | Maurice |  |
| 690 | 253.1.2 | CT4 aspects of Control Plane LCS in the EPC | 212d? | 2009-05-29 A | 2010-03-19 A | 100% |  | 2009-05-29 | 2010-03-19 | 212d? |  | finish no earlier than 2010-03-19 | C4 | 1696h | 1696h | LCS_EPS-CPS | PCG-23 | Polaris Wireless | Robert Gross (rgross@polariswireless.com) | Rel-9 | CP-44 | Kimmo |  |
| 691 | 253.1.3 | CT1 aspects of Control Plane LCS in the EPC | 212d? | 2009-05-29 A | 2010-03-19 A | 100% |  | 2009-05-29 | 2010-03-19 | 212d? |  | finish no earlier than 2010-03-19 | C1 | 1696h | 1696h | LCS_EPS-CPS | PCG-23 | Polaris Wireless | Robert Gross (rgross@polariswireless.com) | Rel-9 | CP-44 | Frederic |  |
| 692 | 253.2 | Positioning Support for LTE | 392d? | 2008-12-05 A | 2010-06-04 A | 100% |  | 2008-12-05 | 2010-06-04 | 392d? |  | finish no earlier than 2010-06-04 | R2,R1,R3,R4 | 3136h | 3136h | LCS_LTE | PCG-22 | Qualcomm | Nathan Tenny (ntenny@qualcomm.com) | Rel-9 | RP-42 | Joern | RP-100442 |
| 693 | 253.3 | Conformance Test Aspects – Positioning Support for LTE | 451d? | 2010-03-19 A | 2011-12-09 | 60% | 180.4d? | 2010-03-19 | 2011-12-09 | 451d? | 260d | finish no earlier than 2011-12-09 | R5 | 3608h | 2164.8h | LCS_LTE_UEConTest | PCG-24 | Qualcomm | Lena Chaponniere (lchaponn@qualcomm.com) | Rel-9 | RP-47 | Ingbert | RP-110505 |

Notes:
- 666: CP#47 completed. Triggered by TR 22.986 Study on Service Specific Access Control in EPS. As EPS is a PS-Domain only system, Domain Specific Access Control (DSAC) doesn't apply, hence SSAC allows restriction of voice and non-voice calls separately
- 667: SP#42 completed. If UE supports E-UTRA and IMS, SSAC is a mandatory Rel-9 function (during congestion in emergency case earthquake/tsunami improves mobile communications). / Text3: 22.011 CR0136
- 668: CP#47 completed / Text3: 24.173, 27.007
- 669: Testing for Stage 3 for Service Specific Access Control in EPS (24.173, 27.007) UID_440040 / Text3: 34.229-1, 34.229-2, 34.229-3
- 670: SP#48 completed / Text3: GERAN, LTE
- 671: SP#42 completed / Text3: 22.101
- 672: SP#44 completed / Text3: 23.869, 23.060, 23.167, 23.203, 23.221, 23.228, 23.271, 23.401, 23.402
- 673: SP#48 completed / Text3: 33.401, 33.402
- 674: CP#47 completed / Text3: GERAN, LTE
- 675: CP#47 completed / Text3: 23.122, 24.008, 24.229, 24.301, 24.302
- 676: Testing for UID_440036 CT1 aspects - Stage 3 of Support for IMS Emergency Calls over GPRS and EPS / Text3: 34.108, 34.123-1, 34.123-2, 34.123-3, 34.229-1, 34.229-2, 34.229-3, 36.508, 36.523-1, 36.523-2, 36.523-3
- 677: CP#45 completed / Text3: 29.212, 29.213, 29.214, 29.215
- 678: CP#46 completed / Text3: 23.003, 23.008, 29.060, 29.272, 29.273, 29.274, 29.275, 29.276
- 679: RP#45 completed / Text3: 36.331, 36.413
- 680: RP#50 completed. Testing for UID_420041 Support for IMS Emergency Calls over LTE / Text3: 36.508, 36.523-1, 36.523-2, 36.523-3
- 681: CP/SP#46 completed
- 682: SP#46 completed. SP#43 WID updated SP-080562=>SP-090099 (added location continuity aspects) / Text3: 23.870, 23.216, 23.237
- 683: CP#46 completed. WID updated CP-090436=>CP-090882 (added CT3 part)
- 684: CP#46 completed / Text3: 24.229, 24.237
- 685: CP#46 completed / Text3: 29.205, 29.280
- 686: CP#46 completed / Text3: 29.163
- 687: RP#48 Core completed/Test ongoing / Text3: LTE
- 688: Triggered by abandoned Study UID_380068 (FS_LCS_EPS). Linked to Feature UID_380064 Support for IMS Emergency Calls over GPRS and EPS
- 689: SP#44 completed / Text3: 23.891, 23.271, 23.401, 23.402
- 690: CP#47 completed (IANA registrations outstanding). Stage 3 SLs and SLg interfaces & transport of positioning messages between E-SMLC and MME in the scope of UID_420006 (Positioning Support for LTE) / Text3: 24.080, 29.002, 29.272, 29.230, new 24.171, 29.171, 29.172, 29.173
- 691: CP#47 completed / Text3: 24.301
- 692: RP#48 completed. UID_400038 (LCS Control Plane Solution for EPS) depends on this WI / Text3: 34.213, 36.133, 36.211, 36.214, 36.300, 36.305, 36.331, 36.355, 36.410, 36.413, 36.455, new 36.171
- 693: RP#52 updated WID RP-100617=>RP-110669. Completion 09/11=>12/11 / Text3: 36.508, 36.509, new (36.571-1/2/3, 37.571-4/5)

| ID | WBS | Task | Duration | Start | Finish | Complete | Remaining | Baseline start | Baseline finish | Baseline duration | Total slack | Constraint | Resources | Work | Actual work | Text1 | Text2 | Text4 | Text5 | Text6 | Text7 | Text8 | Text11 |
| --- | --- | --- | --- | --- | --- | --- | --- | --- | --- | --- | --- | --- | --- | --- | --- | --- | --- | --- | --- | --- | --- | --- | --- |
| 694 | 254 | **MBMS support in EPS** | 918d? | 2008-06-05 A | 2011-12-09 | 91% | 78.35d? | 2008-06-05 | 2011-12-09 | 918d? | 260d |  | S2,S3,S5,C3,C4,R2,R3,R4 | 19568h | 17897.2h | MBMS_EPS | PCG-21 | China Mobile | Liu Hong (liuhongyfw@chinamobile.com) | Rel-9 | SP-40 | Maurice |  |
| 695 | 254.1 | Stage 2 for MBMS support in EPS | 261d? | 2008-06-05 A | 2009-06-04 A | 100% |  | 2008-06-05 | 2009-06-04 | 261d? |  | finish no earlier than 2009-06-04 | S2 | 2088h | 2088h | MBMS_EPS | PCG-21 | China Mobile | Liu Hong (liuhongyfw@chinamobile.com) | Rel-9 | SP-40 | Maurice |  |
| 696 | 254.2 | Security for MBMS support in EPS | 261d? | 2008-12-11 A | 2009-12-10 A | 100% |  | 2008-12-11 | 2009-12-10 | 261d? |  | finish no earlier than 2009-12-10 | S3 | 2088h | 2088h | MBMS_EPS | PCG-22 | China Mobile | Liu Hong (liuhongyfw@chinamobile.com) | Rel-9 | SP-42 | Dionisio |  |
| 697 | 254.3 | MBMS Charging in EPS | 201d? | 2009-03-06 A | 2009-12-10 A | 100% |  | 2009-03-06 | 2009-12-10 | 201d? |  | finish no earlier than 2009-12-10 | S5 | 1600h | 1600h | MBMS_EPS | PCG-22 | ZTE | guo.wenjie1@zte.com.cn | Rel-9 | SP-43 | Dionisio |  |
| 698 | 254.4 | CT4 aspects of MBMS support in EPS (Stage 3) | 137d? | 2009-05-29 A | 2009-12-04 A | 100% |  | 2009-05-29 | 2009-12-04 | 137d? |  | finish no earlier than 2009-12-04 | C4 | 1096h | 1096h | MBMS_EPS | PCG-23 | China Mobile, ZTE | wangjingyf@chinamobile.com, lu.fei1@zte.com.cn | Rel-9 | CP-44 | Kimmo |  |
| 699 | 254.5 | CT3 aspects of MBMS support in EPS (Stage 3) | 137d? | 2009-05-29 A | 2009-12-04 A | 100% |  | 2009-05-29 | 2009-12-04 | 137d? |  | start no earlier than 2009-05-29 | C3 | 1096h | 1096h | MBMS_EPS | PCG-23 | ZTE, China Mobile | zhou.xiaoyun@zte.com.cn, wangjingyf@chinamobile.com | Rel-9 | CP-44 | Jiwan |  |
| 700 | 254.6 | MBMS support in LTE | 271d? | 2009-03-06 A | 2010-03-19 A | 100% |  | 2009-03-06 | 2010-03-19 | 271d? |  | finish no earlier than 2010-03-19 | R2,R3,R4 | 2168h | 2168h | MBMS_LTE | PCG-22 | Huawei | arnaud.meylan@huawei.com | Rel-9 | RP-43 | Joern | RP-100033 |
| 701 | 254.7 | Conformance Test Aspects – MBMS support in LTE | 261d? | 2010-12-10 A | 2011-12-09 | 50% | 130.5d? | 2010-12-10 | 2011-12-09 | 261d? | 260d | finish no earlier than 2011-12-09 | R5 | 2088h | 1044h | MBMS_LTE-UEConTest | PCG-26 | Huawei | Zhang Xin (zhangxin0208@huawei.com) | Rel-9 | RP-50 | Ingbert | RP-110513 |
| 702 | 255 | **Access Network Discovery and Selection Function enhancements** | 333d? | 2008-12-11 A | 2010-03-19 A | 100% |  | 2008-12-11 | 2010-03-19 | 333d? |  |  | S2,C1 | 4720h | 4720h | eANDSF | PCG-22 | Motorola | Apostolis Salkintzis (salki@motorola.com) | Rel-9 | SP-42 | Maurice |  |
| 703 | 255.1 | Stage 2 for Access Network Discovery and Selection Function enhancements | 126d? | 2008-12-11 A | 2009-06-04 A | 100% |  | 2008-12-11 | 2009-06-04 | 126d? |  | finish no earlier than 2009-06-04 | S2 | 1008h | 1008h | eANDSF | PCG-22 | Motorola | Apostolis Salkintzis (salki@motorola.com) | Rel-9 | SP-42 | Maurice |  |
| 704 | 255.2 | CT1 aspects of Access Network Discovery and Selection Function enhancements | 131d? | 2009-09-18 A | 2010-03-19 A | 100% |  | 2009-09-18 | 2010-03-19 | 131d? |  | finish no earlier than 2010-03-19 | C1 | 1048h | 1048h | eANDSF | PCG-23 | Panasonic | benjamin.limck@sg.panasonic.com | Rel-9 | CP-45 | Frederic |  |
| 705 | 256 | **Multiple PDN Connection to the Same APN for PMIP-based Interfaces** | 267d? | 2009-03-13 A | 2010-03-19 A | 100% |  | 2009-03-13 | 2010-03-19 | 267d? |  |  | S2,C4,C1 | 4120h | 4120h | MUPSAP | PCG-22 | Samsung | erik.guttman@partner.samsung.com | Rel-9 | SP-43 | Maurice |  |
| 706 | 256.1 | Stage 2 for Multiple PDN Connection to the Same APN for PMIP-based Interfaces | 61d? | 2009-03-13 A | 2009-06-04 A | 100% |  | 2009-03-13 | 2009-06-04 | 61d? |  | finish no earlier than 2009-06-04 | S2 | 488h | 488h | MUPSAP | PCG-22 | Samsung | erik.guttman@partner.samsung.com | Rel-9 | SP-43 | Maurice |  |
| 707 | 256.2 | CT4 aspects of Multiple PDN Connection to the Same APN for PMIP-based Interfaces | 56d? | 2009-09-18 A | 2009-12-04 A | 100% |  | 2009-09-18 | 2009-12-04 | 56d? |  | finish no earlier than 2009-12-04 | C4 | 448h | 448h | MUPSAP | PCG-23 | Samsung | Surjyakanta Mohapatra (surjya.kanta@samsung.com) | Rel-9 | CP-45 | Kimmo |  |
| 708 | 256.3 | CT1 aspects of Multiple PDN Connection to the Same APN for PMIP-based Interfaces | 131d? | 2009-09-18 A | 2010-03-19 A | 100% |  | 2009-09-18 | 2010-03-19 | 131d? |  | finish no earlier than 2010-03-19 | C1 | 1048h | 1048h | MUPSAP | PCG-23 | Samsung | Surjyakanta Mohapatra (surjya.kanta@samsung.com) | Rel-9 | CP-45 | Frederic |  |
| 709 | 257 | **System aspects of vocoder rate adaptation for LTE** | 661d? | 2009-05-30 A | 2011-12-09 | 85% | 100.71d? | 2009-05-30 | 2011-12-09 | 661d? | 260d |  | S2,S4,C1,C3,R2,IETF | 14649.6h | 8484.47h | LTEimp-Vocoder | PCG-23 | Qualcomm | AC Mahendran (ac@qualcomm.com) | Rel-9 | SP-45 | Maurice |  |
| 710 | 257.1 | SA2 system aspects of vocoder rate adaptation for LTE | 81d? | 2009-06-04 A | 2009-09-24 A | 100% |  | 2009-06-04 | 2009-09-24 | 81d? |  | start no earlier than 2009-06-04 | S2 | 648h | 648h | LTEimp-Vocoder | PCG-23 | Qualcomm | AC Mahendran (ac@qualcomm.com) | Rel-9 | SP-45 | Maurice |  |
| 711 | 257.2 | SA4 system aspects of vocoder rate adaptation for LTE | 136d? | 2009-06-04 A | 2009-12-10 A | 100% |  | 2009-06-04 | 2009-12-10 | 136d? |  | finish no earlier than 2009-12-07 | S4 | 1088h | 1088h | LTEimp-Vocoder | PCG-23 | Qualcomm | Nikolai Leung | Rel-9 | SP-45 | Paolo |  |
| 712 | 257.3 | Vocoder rate adaptation for LTE | 81d? | 2009-05-30 A | 2009-09-18 A | 100% |  | 2009-05-30 | 2009-09-18 | 81d? |  | finish no earlier than 2009-09-18 | R2 | 648h | 648h | LTEimp-Vocoder | PCG-23 | Alcatel-Lucent | Sudeep Palat (spalat@alcatel-lucent.com) | Rel-9 | RP-44 | Joern | RP-090704 |
| 713 | 257.4 | (IETF) SA4 system aspects of vocoder rate adaptation for LTE | 476.6d? | 2009-06-04 A | 2011-12-09 | 80% | 95.32d? | 2009-06-04 | 2011-12-09 | 476.6d? | 260d | start no earlier than 2009-06-04 | S4-IETF | 3812.8h | 3050.23h | LTEimp-Vocoder | PCG-27 | Qualcomm |  | Rel-9 | SP-52 | Paolo |  |
| 714 | 257.5 | (IETF) CT aspects of vocoder rate adaptation for LTE | 476.6d? | 2009-06-04 A | 2011-12-09 | 80% | 95.32d? | 2009-06-04 | 2011-12-09 | 476.6d? | 260d | start no earlier than 2009-06-04 | C1-IETF, C3-IETF, C4-IETF | 3812.8h | 3050.23h | LTEimp-Vocoder | PCG-27 | Qualcomm |  | Rel-9 | CP-52 | Frederic |  |
| 715 | 258 | Access Security Enhancements | 505d? | 2007-07-02 A | 2009-06-04 A | 100% |  | 2007-07-02 | 2009-06-04 | 505d? |  | finish no earlier than 2009-06-03 | S3 | 4040h | 4040h | ACCSEC2 |  | Ericsson | Bengt.Sahlin@ericsson.com | Rel-9 | SP-26 | Dionisio |  |
| 716 | 259 | **Protection against Unsolicited Communication for IMS (PUCI)** | 322d? | 2008-09-18 A | 2009-12-10 A | 100% |  | 2008-09-18 | 2009-12-10 | 322d? |  |  | S3,S1 | 5640h | 5640h | PUCI | PCG-21 | NEC | Anand R. Prasad (anand@bq.jp.nec.com) | Rel-9 | SP-41 | Alain |  |
| 717 | 259.1 | Stage 1 for PUCI | 61d? | 2008-09-18 A | 2008-12-11 A | 100% |  | 2008-09-18 | 2008-12-11 | 61d? |  | finish no earlier than 2009-06-18 | S1 | 488h | 488h | PUCI | PCG-21 | NEC | Anand R. Prasad (anand@bq.jp.nec.com) | Rel-9 | SP-41 | Alain |  |
| 718 | 259.2 | SA3 work on PUCI | 322d? | 2008-09-18 A | 2009-12-10 A | 100% |  | 2008-09-18 | 2009-12-10 | 322d? |  | finish no earlier than 2009-12-10 | S3 | 2576h | 2576h | PUCI | PCG-21 | NEC | Anand R. Prasad (anand@bq.jp.nec.com) | Rel-9 | SP-41 | Dionisio |  |

Notes:
- 694: RP#47 completed. SP#46, CP#46 completed / Text3: LTE
- 695: SP#44 completed / Text3: 23.246
- 696: SP#46 completed / Text3: 33.246
- 697: SP#46 completed / Text3: 32.273, 32.251, 32.298, 32.299
- 698: CP#46 completed / Text3: 29.274, 29.281, 23.007, 23.008
- 699: CP#46 completed / Text3: 29.061
- 700: RP#47 completed / Text3: 25.446, 36.101, 36.104, 36.141, 36.300, 36.304, 36.321, 36.322, 36.323, 36.331, 36.440, 36.441, 36.442, 36.444, 36.445
- 701: - / Text3: 36.508, 36.521-1, 36.521-2, 36.523-1, 36.523-2, 36.523-3
- 702: CP#47 completed. No new Rel-9 use cases defined. Implement service requirements not covered in Rel-8 / Text3: 22.278, SA3 33.402 CR#0055
- 703: SP#44 completed / Text3: 23.402, 23.002
- 704: CP#47 completed / Text3: 24.302, 24.312
- 705: CP#47 completed. Continues Rel-8 SAES Stage 2 UID_320005. Stage 1 in 22.278 (EPS Service requirements)
- 706: SP#44 completed / Text3: 23.060, 23.203, 23.401, 23.402
- 707: CP#46 completed / Text3: 29.275, 23.008, 29.282
- 708: CP#47 completed / Text3: 24.302
- 709: SP#46 completed. Triggered by RAN2 UID_440013 Vocoder rate adaptation for LTE / Text3: LTE
- 710: SP#45 completed (CR adding support for Explicit Congestion Notification) / Text3: 23.401 CR#1103r3
- 711: SP#46 completed / Text3: 26.114
- 712: RP#45 completed / Text3: 36.300 CR#0114
- 713: Not completed internet-draft / Text3: draft-ietf-avtcore-ecn-for-rtp
- 714: Not completed internet-draft / Text3: draft-ietf-avtcore-ecn-for-rtp
- 715: SP#44 completed. Stopped TR 33.801. CRs 33.102,43.020 on A5/2 removal done long time ago. A5/4 introduction CRs will be done under UID_440057 128 bit encryption for GSM and GPRS. SP#26 approved WID (improved GERAN security) / Text3: 33.102, 43.020
- 716: SP#46 TR 33.937 completed but no specification work done in Rel-9. Related work in OMA Categorization Based Content Screening
- 717: SP#42 completed / Text3: 22.228
- 718: SP#46 completed. No normative work done in Rel-9 / Text3: new 33.937

| ID | WBS | Task | Duration | Start | Finish | Complete | Remaining | Baseline start | Baseline finish | Baseline duration | Total slack | Constraint | Resources | Work | Actual work | Text1 | Text2 | Text4 | Text5 | Text6 | Text7 | Text8 | Text3 | Text9 | Text12 |
| --- | --- | --- | --- | --- | --- | --- | --- | --- | --- | --- | --- | --- | --- | --- | --- | --- | --- | --- | --- | --- | --- | --- | --- | --- | --- |
| 719 | 260 | **IMS Media Plane Security** | 717d? | 2009-03-13 A | 2011-12-09 | 61% | 279.15d? | 2009-03-13 | 2011-12-09 | 717d? | 260d |  | S3,C1,C4,C3,IETF | 13072h | 6037.77h | MEDIASEC | PCG-22 | Vodafone | Peter.Howard@vodafone.com | Rel-9 | SP-43 | Dionisio |  |  |  |
| 720 | 260.1 | SA3 aspects of IMS Media Plane Security | 271d? | 2009-03-13 A | 2010-03-25 A | 100% |  | 2009-03-13 | 2010-03-25 | 271d? |  | finish no earlier than 2010-03-25 | S3 | 2168h | 2168h | MEDIASEC | PCG-22 | Vodafone | Peter.Howard@vodafone.com | Rel-9 | SP-43 | Dionisio | new 33.828, 33.328 |  |  |
| 721 | 260.2 | (IETF) SA3 aspects of IMS Media Plane Security | 536.6d? | 2009-03-13 A | 2011-12-09 | 20% | 429.28d? | 2009-03-13 | 2011-12-09 | 536.6d? | 260d | start no earlier than 2009-03-13 | S3-IETF | 4292.8h | 858.57h | MEDIASEC | PCG-27 | Vodafone |  | Rel-9 | SP-52 | Dionisio | draft-dawes-dispatch-mediasec-parameter |  |  |
| 722 | 260.3 | **CN aspects of IMS Media Plane Security** | 186d? | 2009-09-18 A | 2010-06-04 A | 100% |  | 2009-09-18 | 2010-06-04 | 186d? |  |  | C1,C4,C3 | 3011.2h | 3011.2h | MEDIASEC_CORE | PCG-23 | Vodafone | peter.dawes@vodafone.com | Rel-9 | CP-45 | Frederic |  |  |  |
| 723 | 260.3.1 | CT1 aspects of IMS Media Plane Security | 33d? | 2009-09-18 A | 2010-03-19 A | 100% |  | 2009-09-18 | 2010-03-19 | 33d? |  | finish no earlier than 2010-03-19 | C1 | 264h | 264h | MEDIASEC_CORE | PCG-23 | Vodafone | peter.dawes@vodafone.com | Rel-9 | CP-45 | Frederic | 23.218, 24.229 |  |  |
| 724 | 260.3.2 | CT4 aspects of IMS Media Plane Security | 131d? | 2009-09-18 A | 2010-03-19 A | 100% |  | 2009-09-18 | 2010-03-19 | 131d? |  | finish no earlier than 2010-03-19 | C4 | 1048h | 1048h | MEDIASEC_CORE | PCG-23 | Vodafone | peter.dawes@vodafone.com | Rel-9 | CP-45 | Kimmo | 29.238, 23.334, 29.334 |  |  |
| 725 | 260.3.3 | CT3 aspects of IMS Media Plane Security | 131d? | 2009-12-04 A | 2010-06-04 A | 100% |  | 2009-12-04 | 2010-06-04 | 131d? |  | finish no earlier than 2010-06-04 | C3 | 1048h | 1048h | MEDIASEC_CORE | PCG-24 | Vodafone | peter.dawes@vodafone.com | Rel-9 | CP-46 | Jiwan | 29.162 |  |  |
| 726 | 261 | **GBAPush enhancements (Generic push layer)** | 533d? | 2008-03-12 A | 2010-03-25 A | 100% |  | 2008-03-12 | 2010-03-25 | 533d? |  |  | S3 | 8528h | 8528h | eGBAPush | PCG-23 | Ericsson | Rolf Blom | Rel-9 | SP-44 | Dionisio | new 33.224 |  |  |
| 727 | 261.1 | SA3 part of eGBAPush (Generic push layer) | 533d? | 2008-03-12 A | 2010-03-25 A | 100% |  | 2008-03-12 | 2010-03-25 | 533d? |  | finish no earlier than 2010-03-25 | S3 | 4264h | 4264h | eGBAPush | PCG-21 | Ericsson | Rolf Blom | Rel-9 | SP-39 | Dionisio | new 33.224 |  |  |
| 728 | 262 | Extended Identity Management | 136d? | 2009-06-04 A | 2009-12-10 A | 100% |  | 2009-06-04 | 2009-12-10 | 136d? |  | finish no earlier than 2009-12-10 | S3 | 1088h | 1088h | GBA-IdM | PCG-23 | Nokia | Silke.Holtmanns@nokia.com | Rel-9 | SP-44 | Dionisio | new 33.924, CT4 29.109 (added service code) |  |  |
| 729 | 263 | **Network Domain Security (NDS) enhancements to support backhaul security** | 657d? | 2009-06-04 A | 2011-12-09 | 56% | 286.54d? | 2009-06-04 | 2011-12-09 | 657d? | 260d |  | S3,C4,IETF | 10756.8h | 3697.2h | NDS_Backhaul | PCG-23 | Vodafone | Peter.Howard@vodafone.com | Rel-9 | SP-44 | Dionisio |  |  |  |
| 730 | 263.1 | SA3 part of Network Domain Security (NDS) enhancements to support backhaul security | 211d? | 2009-06-04 A | 2010-03-25 A | 100% |  | 2009-06-04 | 2010-03-25 | 211d? |  | finish no earlier than 2010-03-25 | S3 | 1688h | 1688h | NDS_Backhaul | PCG-23 | Vodafone | Peter.Howard@vodafone.com | Rel-9 | SP-44 | Dionisio | 33.102, 33.210, 33.310, 33.401, 33.402 |  |  |
| 731 | 263.2 | (IETF) SA3 part of Network Domain Security (NDS) enhancements to support backhaul security | 476.6d? | 2009-06-04 A | 2011-12-09 | 25% | 357.45d? | 2009-06-04 | 2011-12-09 | 476.6d? | 260d | start no earlier than 2009-06-04 | S3-IETF | 3812.8h | 953.2h | NDS_Backhaul | PCG-27 | Vodafone |  | Rel-9 | SP-52 | Dionisio | draft-ietf-pkix-cmp-transport-protocols |  |  |
| 732 | 263.3 | CT4 part of Network Domain Security (NDS) enhancements to support backhaul security | 132d? | 2009-06-04 A | 2009-12-04 A | 100% |  | 2009-06-04 | 2009-12-04 | 132d? |  | finish no earlier than 2009-12-04 | C4 | 1056h | 1056h | NDS_Backhaul | PCG-23 | Vodafone | Peter.Howard@vodafone.com | Rel-9 | SP-44 | Kimmo |  |  |  |
| 733 | 264 | **128 bit encryption for GSM and GPRS** | 136d? | 2009-06-04 A | 2009-12-10 A | 100% |  | 2009-06-04 | 2009-12-10 | 136d? |  |  | S3,C1,C4,G2,G3new | 6040h | 6040h | A5/4-GEA4 | PCG-23 | Ericsson | Karl Norrman | Rel-9 | SP-44 | Dionisio |  |  |  |
| 734 | 264.1 | SA3 part of 128 bit encryption for GSM and GPRS | 136d? | 2009-06-04 A | 2009-12-10 A | 100% |  | 2009-06-04 | 2009-12-10 | 136d? |  | finish no earlier than 2010-01-06 | S3 | 1088h | 1088h | A5/4-GEA4 | PCG-23 | Ericsson | Karl Norrman | Rel-9 | SP-44 | Dionisio | 33.102,43.020, new 55.226 |  |  |
| 735 | 264.2 | CT1 part of 128 bit encryption for GSM and GPRS | 77d? | 2009-06-04 A | 2009-09-18 A | 100% |  | 2009-06-04 | 2009-09-18 | 77d? |  | start no earlier than 2009-06-04 | C1 | 616h | 616h | A5/4-GEA4 | PCG-23 | Ericsson | Karl Norrman | Rel-9 | SP-44 | Frederic | 24.008,44.064 |  |  |
| 736 | 264.3 | CT4 part of 128 bit encryption for GSM and GPRS | 136d? | 2009-06-04 A | 2009-12-10 A | 100% |  | 2009-06-04 | 2009-12-10 | 136d? |  | start no earlier than 2009-06-04 | C4 | 1088h | 1088h | A5/4-GEA4 | PCG-23 | Ericsson | Karl Norrman | Rel-9 | SP-44 | Kimmo |  |  |  |
| 737 | 264.4 | GERAN2 part of 128 bit encryption for GSM and GPRS | 67d? | 2009-06-04 A | 2009-09-04 A | 100% |  | 2009-06-04 | 2009-09-04 | 67d? |  | finish no earlier than 2009-09-04 | G2 | 536h | 536h | A5/4-GEA4 | PCG-23 | Ericsson | Karl Norrman | Rel-9 | SP-44 | Gert | 44.018,48.008,48.018,48.058 |  |  |
| 738 | 264.5 | GERAN3new (testing) part of 128 bit encryption for GSM and GPRS | 122d? | 2009-06-04 A | 2009-11-20 A | 100% |  | 2009-06-04 | 2009-11-20 | 122d? |  | finish no earlier than 2009-11-20 | G3new | 976h | 976h | A5/4-GEA4 | PCG-23 | Ericsson | Karl Norrman | Rel-9 | SP-44 | Ingbert | 51.010 |  |  |
| 739 | 264.6 | Deleted - SA2 part of 128 bit encryption for GSM and GPRS | 81d? | 2009-06-04 A | 2009-09-24 A | 100% |  | 2009-06-04 | 2009-09-24 | 81d? |  | finish no earlier than 2009-09-24 | S2 | 648h | 648h | A5/4-GEA4 | PCG-23 | Ericsson | Karl Norrman | Rel-9 | SP-44 | Maurice | 23.060 | PCG-23 | SP-45 |
| 740 | 265 | Timed Graphics | 337d? | 2008-12-11 A | 2010-03-25 A | 100% |  | 2008-12-11 | 2010-03-25 | 337d? |  | finish no earlier than 2010-03-25 | S4 | 2696h | 2696h | TG | PCG-22 | Ericsson | clinton.priddle@ericsson.com | Rel-9 | SP-42 | Paolo | 26.114, 26.140, 26.234, 26.244, 26.245, 26.346, new 26.430 |  |  |
| 741 | 266 | Managing MTSI Media Adaptation | 197d? | 2009-03-12 A | 2009-12-10 A | 100% |  | 2009-03-12 | 2009-12-10 | 197d? |  | finish no earlier than 2009-12-10 | S4 | 1568h | 1568h | M3A | PCG-22 | Samsung | kyunghun.jung@samsung.com | Rel-9 | SP-43 | Paolo | 26.114 |  |  |
| 742 | 267 | **PSS and MBMS Aspects** | 272d? | 2009-03-12 A | 2010-03-25 A | 100% |  | 2009-03-12 | 2010-03-25 | 272d? |  |  | S4 | 6512h | 6512h | PMA | PCG-23 | Ericsson, Nokia | Clinton.Priddle@ericsson.com, imed.bouazizi@nokia.com | Rel-9 | SP-44 | Paolo |  |  |  |
| 743 | 267.1 | PSS and MBMS extensions | 271d? | 2009-03-12 A | 2010-03-25 A | 100% |  | 2009-03-12 | 2010-03-25 | 271d? |  | finish no earlier than 2010-03-25 | S4 | 2168h | 2168h | PMA-MBS_Ext | PCG-22 | Ericsson | Clinton.Priddle@ericsson.com | Rel-9 | SP-43 | Paolo | 26.234, 26.346 |  |  |
| 744 | 267.2 | Improved Video Support for PSS and MBMS | 271d? | 2009-03-12 A | 2010-03-25 A | 100% |  | 2009-03-12 | 2010-03-25 | 271d? |  | finish no earlier than 2010-03-25 | S4 | 2168h | 2168h | PMA-IVS | PCG-22 | Nokia | imed.bouazizi@nokia.com | Rel-9 | SP-43 | Paolo | 26.234, 26.244, 26.346, new 26.903 |  |  |
| 745 | 268 | IMS based PSS and MBMS User Service extensions | 197d? | 2009-03-12 A | 2009-12-10 A | 100% |  | 2009-03-12 | 2009-12-10 | 197d? |  | finish no earlier than 2009-12-10 | S4 | 1576h | 1576h | IMS_PSS_MBMS_US_EXT | PCG-22 | Ericsson | Markus Kampmann | Rel-9 | SP-43 | Paolo | 26.237 |  |  |
| 746 | 269 | Syndicated Feed Reception within 3GPP environments | 136d? | 2009-06-04 A | 2009-12-10 A | 100% |  | 2009-06-04 | 2009-12-10 | 136d? |  | start no earlier than 2009-06-04 | S4 | 1088h | 1088h | SFR | PCG-23 | Ericsson | Thorsten.Lohmar@ericsson.com | Rel-9 | SP-44 | Paolo | 26.150 |  |  |
| 747 | 270 | Distortion Measurement Test Methods and Requirements | 131d? | 2009-09-24 A | 2010-03-25 A | 100% |  | 2009-09-24 | 2010-03-25 | 131d? |  | finish no earlier than 2010-03-25 | S4 | 1048h | 1048h | DTMR | PCG-23 | Motorola | Stephen Kendall (wcsk01@motorola.com) | Rel-9 | SP-45 | Paolo | 26.131, 26.132 |  |  |

Notes:
- 719: CP#48 completed
- 720: SP#47 completed
- 721: Not completed internet-draft
- 722: CP#48 completed
- 723: CP#47 completed
- 724: CP#47 completed
- 725: CP#48 completed
- 726: SP#43 umbrella to host 33.224, moved from Rel-8 to Rel-9. SP#47 completed
- 727: SP#47 completed
- 728: SP#46 completed. Stage 1 not identified (GBA Liberty Interworking has been outlined and GBAOpenID interworking is analogous)
- 729: SP#47 completed. Continuation of Rel-8 UID_390044 SAE security architecture. Covers gaps in backhaul security in SAE (also applicable to UTRAN and GERAN backhaul)
- 730: SP#47 completed
- 731: Not completed internet-draft
- 732: CP#46 completed. No impact on CT4 specs
- 733: Allow 128 as an alternative to 64 bit keys (Stage 2/3 + Test spec)
- 734: SP#46 completed
- 735: CP#45 completed
- 736: CP#46 completed. Kc128 enhancements are carried as UMTS keys => no impact on CT4 29.002, 29.060
- 737: GP#43 WID approved + completed
- 738: GP#44 completed. GP#43 WID approved
- 739: SP#45 work stopped/abandoned
- 740: SP#47 completed. Provide graphics in parallel to a video stream (without requiring an umbrella scene descriptor such as 3GPP DIMS in TS 26.142)
- 741: SP#46 completed. Work extending Rel-8 UID_34041 MTSI Video - Dynamic Rate Adaptation/Signalling of Image Size. Update speech/video adaptation algorithms used by network to control MTSI client terminal in congestion or poor transmission conditions.
- 742: Umbrella WI
- 743: SP#47 completed. Extends Rel-8 UID_34043 (PSS_MBMS_OMTV) & ensures compatibility with UID_34046 (IMS_PSS_MBMS_US)
- 744: SP#47 completed
- 745: SP#46 completed. Work extending Rel-8 UID_34046 (IMS_PSS_MBMS_US), SA2 UID_410034 IMSSCC-SPI (IMS Service Continuity Enhancements: Service, Policy and Interactions)
- 746: SP#46 completed. TS 26.150v100 for Approval. RSS optimized for mobile use. Reuse/reference OMA's enabler DCD.
- 747: SP#47 completed

| ID | WBS | Task | Duration | Start | Finish | Complete | Baseline start | Baseline finish | Baseline duration | Constraint | Resources | Work | Actual work | Text1 | Text2 | Text6 | Text7 | Text8 | Text4 | Text9 | Text12 |
| --- | --- | --- | --- | --- | --- | --- | --- | --- | --- | --- | --- | --- | --- | --- | --- | --- | --- | --- | --- | --- | --- |
| 748 | 271 | **Rel-9 Operations, Administration, Maintenance and Provisioning (OAM&P)** | 601d? | 2008-02-22 A | 2010-06-10 A | 100% | 2008-02-22 | 2010-06-10 | 601d? |  | S5 | 36890.4h | 36890.4h | OAM9 | PCG-22 | Rel-9 | SP-42 | Dionisio |  |  |  |
| 749 | 271.1 | **Network Infrastructure Management** | 337d? | 2008-12-11 A | 2010-03-25 A | 100% | 2008-12-11 | 2010-03-25 | 337d? |  | S5 | 8760h | 8760h | OAM9-NIM | PCG-22 | Rel-9 | SP-42 | Dionisio |  |  |  |
| 750 | 271.1.1 | Software Management for Network Elements | 336d? | 2008-12-11 A | 2010-03-25 A | 100% | 2008-12-11 | 2010-03-25 | 336d? | finish no earlier than 2010-03-25 | S5 | 2688h | 2688h | OAM9-NE_SWM | PCG-22 | Rel-9 | SP-42 | Dionisio | Huawei, Nokia Siemens Networks |  |  |
| 751 | 271.1.2 | Service Oriented Architecture (SOA) for IRP | 211d? | 2009-06-04 A | 2010-03-25 A | 100% | 2009-06-04 | 2010-03-25 | 211d? | finish no earlier than 2010-03-25 | S5 | 1688h | 1688h | OAM9 | PCG-23 | Rel-9 | SP-44 | Dionisio | Ericsson, Nokia Siemens Networks |  |  |
| 752 | 271.1.3 | IRP SOAP Solution Sets continuation from Rel-8 | 211d? | 2009-06-04 A | 2010-03-25 A | 100% | 2009-06-04 | 2010-03-25 | 211d? | finish no earlier than 2010-03-25 | S5 | 1688h | 1688h | OAM9 | PCG-23 | Rel-9 | SP-44 | Dionisio | Ericsson |  |  |
| 753 | 271.2 | **Performance Management** | 327d? | 2009-03-12 A | 2010-06-10 A | 100% | 2009-03-12 | 2010-06-10 | 327d? |  | S5 | 7890.41h | 7890.41h | OAM9-PM | PCG-22 | Rel-9 | SP-42 | Dionisio |  |  |  |
| 754 | 271.2.1 | Enhancement of UTRAN Performance Measurements | 136d? | 2009-06-04 A | 2009-12-10 A | 100% | 2009-06-04 | 2009-12-10 | 136d? | start no earlier than 2009-06-04 | S5 | 1088h | 1088h | OAM9 | PCG-23 | Rel-9 | SP-44 | Dionisio | China Mobile |  |  |
| 755 | 271.2.2 | Enhancement of E-UTRAN Performance Measurements | 327d? | 2009-03-12 A | 2010-06-10 A | 100% | 2009-03-12 | 2010-06-10 | 327d? | finish no earlier than 2010-06-10 | S5 | 2616h | 2616h | OAM9 | PCG-22 | Rel-9 | SP-43 | Dionisio | Motorola, Huawei |  |  |
| 756 | 271.2.3 | Enhancement of EPC Performance Measurements | 197d? | 2009-03-12 A | 2009-12-10 A | 100% | 2009-03-12 | 2009-12-10 | 197d? | finish no earlier than 2010-03-25 | S5 | 1570.41h | 1570.41h | OAM9 | PCG-22 | Rel-9 | SP-43 | Dionisio | China Mobile |  |  |
| 757 | 271.3 | **Self-Organizing Networks (SON) - OAM aspects** | 601d? | 2008-02-22 A | 2010-06-10 A | 100% | 2008-02-22 | 2010-06-10 | 601d? |  | S5 | 11736h | 11736h | OAM9-SON | PCG-22 | Rel-9 | SP-43 | Dionisio |  |  |  |
| 758 | 271.3.1 | SON self-optimization management | 600d? | 2008-02-22 A | 2010-06-10 A | 100% | 2008-02-22 | 2010-06-10 | 600d? | finish no earlier than 2010-06-10 | S5 | 4800h | 4800h | LTE_SON-OAM | PCG-21 | Rel-9 | SP-39 | Dionisio | Huawei |  |  |
| 759 | 271.3.2 | Automatic Radio Network Configuration Data Preparation | 266d? | 2009-06-04 A | 2010-06-10 A | 100% | 2009-06-04 | 2010-06-10 | 266d? | finish no earlier than 2010-06-10 | S5 | 2128h | 2128h | OAM9 | PCG-23 | Rel-9 | SP-44 | Dionisio | Nokia Siemens Networks |  |  |
| 760 | 271.4 | Subscription Management (SuM) evolution | 266d? | 2009-06-04 A | 2010-06-10 A | 100% | 2009-06-04 | 2010-06-10 | 266d? | finish no earlier than 2010-06-10 | S5 | 2128h | 2128h | OAM9-SuM | PCG-23 | Rel-9 | SP-44 | Dionisio | Ericsson |  |  |
| 761 | 271.5 | Deleted - Trace | 196d? | 2009-03-13 A | 2009-12-10 A | 100% | 2009-03-13 | 2009-12-10 | 196d? | finish no earlier than 2009-12-10 | S5 | 1568h | 1568h | OAM9-Trace | PCG-22 | Rel-9 | SP-42 | Dionisio |  | PCG-24 | SP-46 |
| 762 | 272 | Rel-9 Charging Management small Enhancements | 211d? | 2009-06-04 A | 2010-03-25 A | 100% | 2009-06-04 | 2010-03-25 | 211d? |  | S5 | 1688h | 1688h | CH9 | PCG-23 | Rel-9 | SP-44 | Dionisio |  |  |  |
| 763 | 273 | **CS-IBCF and CS-TrGW definition in 3GPP specifications** | 472d? | 2008-05-30 A | 2010-03-19 A | 100% | 2008-05-30 | 2010-03-19 | 472d? |  | C3,C4 | 10714.3h | 10714.3h | CS-IBCF | PCG-21 | Rel-9 | CP-40 | Jiwan | Telecom Italia |  |  |
| 764 | 273.1 | CT3 aspects of CS-IBCF and CS-TrGW definition in 3GPP specifications | 472d? | 2008-05-30 A | 2010-03-19 A | 100% | 2008-05-30 | 2010-03-19 | 472d? | finish no earlier than 2009-12-04 | C3 | 3770.34h | 3770.34h | CS-IBCF | PCG-21 | Rel-9 | CP-40 | Jiwan | Telecom Italia |  |  |
| 765 | 273.2 | CT4 aspects of CS-IBCF and CS-TrGW definition in 3GPP specifications | 396d? | 2008-05-30 A | 2009-12-04 A | 100% | 2008-05-30 | 2009-12-04 | 396d? | finish no earlier than 2009-12-04 | C4 | 3168h | 3168h | CS-IBCF | PCG-21 | Rel-9 | CP-40 | Kimmo | Telecom Italia |  |  |
| 766 | 274 | **IMS – Interconnection Border Control Function (IBCF) – Transition Gateway (TrGW); Ix Interface; Stage 3** | 322d? | 2008-09-12 A | 2009-12-04 A | 100% | 2008-09-12 | 2009-12-04 | 322d? |  | C4,C3 | 6858.4h | 6858.4h | IMS_IBCF | PCG-21 | Rel-9 | CP-41 | Kimmo | Alcatel-Lucent |  |  |
| 767 | 274.1 | CT4 part of IMS – Interconnection Border Control Function (IBCF) – Transition Gateway (TrGW); Ix Interface; Stage 3 | 321d? | 2008-09-12 A | 2009-12-04 A | 100% | 2008-09-12 | 2009-12-04 | 321d? | finish no earlier than 2009-12-04 | C4 | 2568h | 2568h | IMS_IBCF | PCG-21 | Rel-9 | CP-41 | Kimmo | Alcatel-Lucent |  |  |
| 768 | 274.2 | CT3 part of IMS – Interconnection Border Control Function (IBCF) – Transition Gateway (TrGW); Ix Interface; Stage 3 | 295.8d? | 2008-09-12 A | 2009-12-04 A | 100% | 2008-09-12 | 2009-12-04 | 295.8d? | finish no earlier than 2010-03-19 | C3 | 2366.4h | 2366.4h | IMS_IBCF | PCG-21 | Rel-9 | CP-41 | Jiwan | Alcatel-Lucent |  |  |
| 769 | 275 | IMS Application Level Gateway Control Function (ALGCF) – IMS Access Media Gateway (IMA-MGW); Iq Interface; Stage 2 and Stage 3 | 321d? | 2008-09-12 A | 2009-12-04 A | 100% | 2008-09-12 | 2009-12-04 | 321d? | finish no earlier than 2009-12-04 | C4 | 2568h | 2568h | IMS_AGCF | PCG-21 | Rel-9 | CP-41 | Kimmo | Alcatel-Lucent |  |  |
| 770 | 276 | **Enhancements of IMS Customized Alerting Tone (CAT) Service** | 392d? | 2008-12-05 A | 2010-06-04 A | 100% | 2008-12-05 | 2010-06-04 | 392d? |  | C1 | 5846.4h | 5846.4h | eCAT | PCG-22 | Rel-9 | CP-42 | Frederic | China Mobile |  |  |
| 771 | 276.1 | Stage 3 for Enhancements of IMS Customized Alerting Tone (CAT) Service | 391d? | 2008-12-05 A | 2010-06-04 A | 100% | 2008-12-05 | 2010-06-04 | 391d? | finish no earlier than 2010-06-04 | C1 | 3128h | 3128h | eCAT-SS | PCG-22 | Rel-9 | CP-42 | Frederic | China Mobile |  |  |

Notes:
- 748: SP#42 umbrella Feature created to host OAM WIs / Text3: TR 30.819
- 749: SP#42 umbrella BB created to host OAM WIs
- 750: SP#47 completed / Text3: 32.531, 32.532, 32.533, new 32.537 / Text5: Bidipta Das (bidipta@huawei.com), Clemens Suerbaum (clemens.suerbaum@nsn.com)
- 751: SP#47 completed (covering SOA Architecture & SOA-supporting Solution Set). Triggered by UID_400029 Study on Service Oriented Architecture (SOA) for IRP (TR 32.824) / Text3: 32.101, 32.102, 32.150 / Text5: edwin.tse@ericsson.com, Jörg Schmidt (joerg@cox.net)
- 752: SP#47 completed. Continuation of Rel-8 UID_400030 IRP SOAP Solution Sets / Text3: New (32.127/ 327/ 337/ 357/ 387/ 397/ 447/ 397/ 447/ 507/ 537), 32.121,32.122,32.123,32,32.321,32.322,32.323,32.325,32.331,32.332,32.333,32.335,32.351,32.352,32.353,32.381,32.382,32.383,32.385,32.391,32.392,32.393,32.395,32.441,32.442,32.443 / Text5: John Power
- 753: SP#42 umbrella BB created to host OAM WIs
- 754: SP#46 completed / Text3: 32.405 / Text5: Liang Shuangchun (liangshuangchun@cmdi.chinamobile.com), Li Jian (lijian@chinamobile.com), Bao Haitao
- 755: SP#48 completed / Text3: 32.425 / Text5: Yizhi Yao (yzyao@motorola.com),Lan Zou (zlan@huawei.com)
- 756: SP#46 completed / Text3: 32.426 / Text5: Li Jian (lijian@chinamobile.com), Liang Shuangchun (liangshuangchun@cmdi.chinamobile.com)
- 757: SP#43 umbrella BB created to host OAM WIs
- 758: SP#48 completed / Text3: 32.425, new (32.521, 32.522, 32.523, 32.525) / Text5: Lan Zou (zlan@huawei.com)
- 759: SP#48 completed / Text3: 32.501, 32.502, 32.503, 32.505, new 32.507 / Text5: clemens.suerbaum@nsn.com
- 760: SP#48 completed / Text3: 32.140, 32.141, 32.152, 32.172, 32.175 / Text5: frode.nergard@ericsson.com
- 761: SP#46 stopped (no work in Rel-9)
- 762: SP#47 completed / Text3: TR 30.819
- 763: CP#47 completed. Rel-8 UID_380061 (Ipinterc) covers Stage 1 in SA1 22.101, 22.228 / Text5: mauro.ficaccio@telecomitalia.it
- 764: CP#47 completed / Text3: 29.235 / Text5: mauro.ficaccio@telecomitalia.it
- 765: CP#46 completed / Text3: 23.231, 29.232, new 29.238 / Text5: mauro.ficaccio@telecomitalia.it
- 766: CP#46 completed / Text5: bruno.landais@alcatel-lucent.fr
- 767: CP#46 completed / Text3: new 29.238 / Text5: bruno.landais@alcatel-lucent.fr
- 768: CP#46 completed / Text3: 29.162, 29.235 / Text5: bruno.landais@alcatel-lucent.fr
- 769: CP#46 completed / Text3: new 23.334, 29.334 / Text5: bruno.landais@alcatel-lucent.fr
- 770: CP#48 completed. Stage 1 in 22.182 / Text5: Jiang Yi
- 771: CP#48 completed / Text3: 24.182 / Text5: Jiang Yi

| ID | WBS | Task | Duration | Start | Finish | Complete | Remaining | Baseline start | Baseline finish | Baseline duration | Total slack | Constraint | Resources | Work | Actual work | Text1 | Text2 | Text4 | Text5 | Text6 | Text7 | Text8 | Text11 |
| --- | --- | --- | --- | --- | --- | --- | --- | --- | --- | --- | --- | --- | --- | --- | --- | --- | --- | --- | --- | --- | --- | --- | --- |
| 772 | 277 | **Completion of IMS Restoration Procedures** | 212d? | 2009-05-29 A | 2010-03-19 A | 100% |  | 2009-05-29 | 2010-03-19 | 212d? |  |  | C3, C4,C1 | 6784h | 6784h | eIMS_RP | PCG-23 | Ericsson | Emiliano Merino (emiliano.merino@ericsson.com) | Rel-9 | CP-44 | Kimmo |  |
| 773 | 277.1 | CT4 aspects of Completion of IMS Restoration Procedures | 212d? | 2009-05-29 A | 2010-03-19 A | 100% |  | 2009-05-29 | 2010-03-19 | 212d? |  | finish no earlier than 2010-03-19 | C4 | 1696h | 1696h | eIMS_RP | PCG-23 | Ericsson | Emiliano Merino (emiliano.merino@ericsson.com) | Rel-9 | CP-44 | Kimmo |  |
| 774 | 277.2 | CT1 aspects of Completion of IMS Restoration Procedures | 212d? | 2009-05-29 A | 2010-03-19 A | 100% |  | 2009-05-29 | 2010-03-19 | 212d? |  | finish no earlier than 2010-03-19 | C1 | 1696h | 1696h | eIMS_RP | PCG-23 | Ericsson | Emiliano Merino (emiliano.merino@ericsson.com) | Rel-9 | CP-44 | Kimmo |  |
| 775 | 277.3 | CT3 aspects of Completion of IMS Restoration Procedures | 212d? | 2009-05-29 A | 2010-03-19 A | 100% |  | 2009-05-29 | 2010-03-19 | 212d? |  | finish no earlier than 2010-03-19 | C3 | 1696h | 1696h | eIMS_RP | PCG-24 | Ericsson | Emiliano Merino (emiliano.merino@ericsson.com) | Rel-9 | CP-46 | Kimmo |  |
| 776 | 278 | **IMS Stage 3 - IETF Protocol Alignment** | 662d? | 2009-05-29 A | 2011-12-09 | 42% | 382.77d? | 2009-05-29 | 2011-12-09 | 662d? | 260d |  | C1,IETF | 8904h | 2237.2h | IMSProtoc3 | PCG-23 | Alcatel-Lucent | Keith Drage (drage@alcatel-lucent.com) | Rel-9 | CP-44 | Frederic |  |
| 777 | 278.1 | IMS Stage 3 - IETF Protocol Alignment | 212d? | 2009-05-29 A | 2010-03-19 A | 100% |  | 2009-05-29 | 2010-03-19 | 212d? |  | finish no earlier than 2010-03-19 | C1 | 1696h | 1696h | IMSProtoc3 | PCG-23 | Alcatel-Lucent | Keith Drage (drage@alcatel-lucent.com) | Rel-9 | CP-44 | Frederic |  |
| 778 | 278.2 | (IETF) IMS Stage 3 - IETF Protocol Alignment | 451d? | 2009-05-29 A | 2011-12-09 | 15% | 383.35d? | 2009-05-29 | 2011-12-09 | 451d? | 260d | finish no earlier than 2011-12-09 | C1-IETF | 3608h | 541.2h | IMSProtoc3 | PCG-27 | Alcatel-Lucent |  | Rel-9 | CP-52 | Frederic |  |
| 779 | 279 | Operational description of the Inter-IMS Network to Network Interface (II-NNI) | 267d? | 2009-05-29 A | 2010-06-04 A | 100% |  | 2009-05-29 | 2010-06-04 | 267d? |  | finish no earlier than 2010-06-04 | C3 | 2136h | 2136h | II-NNI | PCG-23 | Orange | sebastien.daudet@orange-ftgroup.com | Rel-9 | CP-44 | Jiwan |  |
| 780 | 280 | Definition of Ml interface for Control Plane LCS (Stage 3) | 131d? | 2009-09-18 A | 2010-03-19 A | 100% |  | 2009-09-18 | 2010-03-19 | 131d? |  | finish no earlier than 2010-03-19 | C1 | 1048h | 1048h | EMC2 | PCG-23 | Alcatel-Lucent | Keith Drage (drage@alcatel-lucent.com) | Rel-9 | CP-45 | Frederic |  |
| 781 | 281 | PCC enhancements | 56d? | 2009-09-18 A | 2009-12-04 A | 100% |  | 2009-09-18 | 2009-12-04 | 56d? |  | finish no earlier than 2009-12-04 | C3 | 448h | 448h | PCC-Enh | PCG-23 | Huawei | Wei Weihua (weiwh@huawei.com) | Rel-9 | CP-45 | Jiwan |  |
| 782 | 282 | 3GPP IMS Conferencing Management Object (MO) | 2d? | 2009-12-03 A | 2009-12-04 A | 100% |  | 2009-12-03 | 2009-12-04 | 2d? |  | start no earlier than 2009-12-03 | C1 | 16h | 16h | IMS_ConfMO | PCG-24 |  |  | Rel-9 | CP-46 | Frederic |  |
| 783 | 283 | In Case of Emergency (ICE) Graphics | 3d? | 2010-03-17 A | 2010-03-19 A | 100% |  | 2010-03-17 | 2010-03-19 | 3d? |  | finish no earlier than 2010-03-19 | C6 | 24h | 24h | ICE_Graphics | PCG-24 | Sagem-Orga | heiko.kruse@sagem-orga.com | Rel-9 | CP-47 | Xavier |  |
| 784 | 284 | **Rel-9 Improvements of the Radio Interface** | 397d? | 2008-09-12 A | 2010-03-19 A | 100% |  | 2008-09-12 | 2010-03-19 | 397d? |  |  | RP,GP | 19147.6h | 19147.6h | RInImp9 | PCG-21 |  |  | Rel-9 | RP-41 | Issam |  |
| 785 | 284.1 | LCR TDD UE OTA Performance Requirements | 186d? | 2008-09-12 A | 2009-05-29 A | 100% |  | 2008-09-12 | 2009-05-29 | 186d? |  | finish no earlier than 2009-05-29 | R4 | 1488h | 1488h | RInImp9-RFLCROTA | PCG-21 | RITT | Wu Xiang (wuxiang@chinattl.com) | Rel-9 | RP-41 | Issam | RP-090389 |
| 786 | 284.2 | **RF requirements for Multicarrier and Multi-RAT BS** | 347d? | 2008-11-21 A | 2010-03-19 A | 100% |  | 2008-11-21 | 2010-03-19 | 347d? |  |  | R4,G1 | 7403.6h | 7403.6h | RInImp9-RFmulti | PCG-21 | Ericsson | Johan.skold@ericsson.com | Rel-9 | RP-41 | Issam |  |
| 787 | 284.2.1 | RAN4 part of RF requirements for Multicarrier and Multi RAT BS | 337d? | 2008-12-05 A | 2010-03-19 A | 100% |  | 2008-12-05 | 2010-03-19 | 337d? |  | finish no earlier than 2010-03-19 | R4 | 2696h | 2696h | RInImp9-Rfmulti | PCG-22 | Ericsson | Johan.skold@ericsson.com | Rel-9 | RP-42 | Issam | RP-100027 |
| 788 | 284.2.2 | GERAN part of RF requirements for Multicarrier and Multi RAT BS | 261d? | 2008-11-21 A | 2009-11-20 A | 100% |  | 2008-11-21 | 2009-11-20 | 261d? |  | finish no earlier than 2009-11-20 | G1 | 2088h | 2088h | RInImp9-RFmulti-GERAN | PCG-22 | Ericsson | mats.y.samuelsson@ericsson.com | Rel-9 | GP-40 | Paolo |  |
| 789 | 284.3 | Extended UMTS/LTE 800 MHz | 207d? | 2008-12-05 A | 2009-09-18 A | 100% |  | 2008-12-05 | 2009-09-18 | 207d? |  |  | R4,R2,R3 | 1648h | 1648h | RInImp9-UMTSLTE800 | PCG-22 | NTT DoCoMo | Shingo Suwa (suwas@nttdocomo.co.jp) | Rel-9 | RP-42 | Issam | RP-090687 |
| 790 | 284.4 | UMTS/LTE 800 MHz for Europe | 272d? | 2009-03-06 A | 2010-03-19 A | 100% |  | 2009-03-06 | 2010-03-19 | 272d? |  | finish no earlier than 2010-03-19 | R4,R2,R3 | 2176h | 2176h | RInImp9-UMTSLTE800EU | PCG-22 | Ericsson | olav.queseth@ericsson.com | Rel-9 | RP-43 | Issam | RP-100028 |
| 791 | 284.5 | Performance requirement for LCR TDD with UE speeds up to 350 km/h | 196d? | 2009-03-06 A | 2009-12-04 A | 100% |  | 2009-03-06 | 2009-12-04 | 196d? |  | finish no earlier than 2009-12-04 | R4 | 1568h | 1568h | RInImp9-LCRTDD350 | PCG-22 | CATT | Yuexia Song (songyuexia@datangmobile.cn) | Rel-9 | RP-43 | Issam | RP-091035 |
| 792 | 284.6 | Extended UMTS/LTE 1500 MHz | 211d? | 2009-05-30 A | 2010-03-19 A | 100% |  | 2009-05-30 | 2010-03-19 | 211d? |  | finish no earlier than 2010-03-19 | R4,R2,R3 | 1688h | 1688h | UMTSLTE1500 | PCG-23 | NTT DoCoMo | Shingo Suwa (suwas@nttdocomo.co.jp) | Rel-9 | RP-44 | Issam | RP-100029 |
| 793 | 285 | **Rel-9 Improvements of the Radio Interface - UE Conformance Testing** | 350d? | 2009-05-19 A | 2010-09-17 A | 100% |  | 2009-05-19 | 2010-09-17 | 350d? |  |  | R5 | 8184h | 8184h | RInImp-UEConTest | PCG-23 |  |  | Rel-9 | RP-44 | Ingbert |  |
| 794 | 285.1 | Conformance Test Aspects – UMTS/LTE in 800 MHz for Europe | 350d? | 2009-05-19 A | 2010-09-17 A | 100% |  | 2009-05-19 | 2010-09-17 | 350d? |  | finish no earlier than 2010-09-17 | R5 | 2800h | 2800h | RInImp-UEConTest-UMTSLTE800EU | PCG-23 | Ericsson | fredrik.sundstrom@ericsson.com | Rel-9 | RP-44 | Ingbert | RP-100736 |
| 795 | 285.2 | Conformance Test Aspects – Extended UMTS/LTE 1500 MHz | 186d? | 2009-09-18 A | 2010-06-04 A | 100% |  | 2009-09-18 | 2010-06-04 | 186d? |  | finish no earlier than 2010-06-04 | R5 | 1488h | 1488h | UMTSLTE1500_UEConTest | PCG-23 | NTT DoCoMo | Nguyen Dung Dao (dao@nttdocomo.co.jp) | Rel-9 | RP-45 | Ingbert | RP-100487 |
| 796 | 285.3 | TDD UE Over The Air (Antenna) conformance testing methodology | 81d? | 2009-05-30 A | 2009-09-18 A | 100% |  | 2009-05-30 | 2009-09-18 | 81d? |  | finish no earlier than 2009-09-18 | R5 | 648h | 648h | UEAnt_TDDTest | PCG-23 | CATR | Qu Yan (quyan@emcite.com) | Rel-9 | RP-44 | Ingbert | RP-090727 |
| 797 | 285.4 | Conformance Test Aspects – Performance requirement for LCR TDD with UE speeds up to 350 km/h | 56d? | 2010-03-19 A | 2010-06-04 A | 100% |  | 2010-03-19 | 2010-06-04 | 56d? |  | finish no earlier than 2010-06-04 | R5 | 448h | 448h | RInImp9-LCRTDD350_UEConTest | PCG-24 | CATT | Xiaozhong Chen (chexiaozhong@datangmobile.cn) | Rel-9 | RP-47 | Ingbert | RP-100496 |
| 798 | 286 | Conformance Test Aspects – SMS over IMS in E-UTRAN | 131d? | 2009-09-18 A | 2010-03-19 A | 100% |  | 2009-09-18 | 2010-03-19 | 131d? |  | finish no earlier than 2010-06-18 | R5 | 1048h | 1048h | SMSoverIMS_UEConTest | PCG-23 | Alcatel-Lucent | Nidal Khrais (khrais@alcatel-lucent.com) | Rel-9 | RP-45 | Ingbert | RP-100072 |

Notes:
- 772: CP#47 completed. Continuation of Rel-8 Feature UID_400012 IMS Restoration Procedures
- 773: CP#47 completed / Text3: 23.380, 23.820
- 774: CP#47 completed / Text3: 24.229
- 775: CP#47 completed / Text3: 29.061, 29.212, 29.213, 29.214, 29.215
- 776: CP#47 completed / Text3: 23.218, 24.229, 24.930
- 777: CP#47 completed / Text3: 23.218, 24.229, 24.930
- 778: Not completed internet-draft / Text3: draft-kaplan-dispatch-session-id
- 779: CP#48 completed / Text3: 29.165
- 780: CP#47 completed [Stage 3 for Rel-7 Emergency Calls (EMC1)]. Related to Rel-9 UID_400038 LCS Control Plane Solution for EPS. Stage 2 in Rel-9 UID_400038 (23.271), UID_410037 (23.167) / Text3: 24.229
- 781: CP#46 completed / Text3: 29.212, 29.213, 29.215
- 782: CP#46 completed. Linked to Rel-6 UID_11051 (IMS Management objects) under the Feature UID_32021 (IMS Phase 2). MO compatible with OMA DM v1.2 & upwards and defined using OMA DM Device Description Framework (OMA-ERELD _DM-V1_2) / Text3: new 24.166
- 783: CP#47 approved WID and completed. Added capability to store ICE graphical information (picture). Linked to CT6 Rel-8 ICE Feature UID_380059 In Case of Emergency numbers storage and easy access on UICC / Text3: 31.102 CR#0433
- 784: RP#41 umbrella Feature created to host Rel-9 WIs / Text3: GERAN, UTRA, LTE
- 785: RP#44 completed technical work (RAN4 internal TR abandoned) / Text3: UTRA (no TR 25.8xy produced)
- 786: RP#47 completed. RF requirements specification applicable to Multi-Standard Radio (MSR) Base Station with multiple carriers and/or multiple 3GPP Radio Access Technologies (RAT) / Text3: GERAN, UTRA, LTE
- 787: RP#48 completed / Text3: UTRA, LTE 25.104, 25.105, 36.104, new 37.104, 37.113, 37.141, 37.900
- 788: GP#44 Core spec completed (ongoing BS conformance spec). GP#40 WID approved / Text3: GERAN 45.005, 51.021
- 789: RP#45 completed / Text3: UTRA, LTE 25.101, 25.104, 25.113, 25.133, 34.124, 36.101, 36.104, 36.113, 36.124, 36.133, 36.141, 25.306, 25.307, 25.331, 36.331, 25.461, 25.466, new 36.800
- 790: RP#47 completed / Text3: UTRA, LTE 25.101, 25.104, 25.113, 25.133, 25.141, 34.124, 36.101, 36.104, 36.113, 36.124, 36.133, 36.141, new 36.810, 25.306, 25.307, 25.331, 36.331, 25.461, 25.466
- 791: RP#46 completed / Text3: UTRA 25.102, 25.105, 25.142
- 792: RP#47 completed. For potential deployment in Japan / Text3: UTRA, LTE 25.101, 25.104, 25.113, 25.133, 25.141, 25.306, 25.307, 25.331, 25.461, 25.466, 34.124, 36.101, 36.104, 36.113, 36.124, 36.133, 36.141, 36.331, new (36.821, 36.307)
- 793: - / Text3: UTRA, LTE
- 794: RP#49 completed. Testing for UID_430009 UMTS/LTE 800 MHz for Europe / Text3: UTRA, LTE 34.108, 34.121-1, 34.121-2, 36.508, 36.521-1, 36.521-2, 36.521-3
- 795: RP#48 completed / Text3: UTRA, LTE 34.108, 34.121-1, 34.121-2, 34.123-1, 34.123-2, 36.508, 36.521-1, 36.521-2, 36.521-3, 36.523-1, 36.523-2, 36.523-3
- 796: RP#45 completed. Finalized TDD UE test methodology based on R4 TR 25.914 (UE and MS antenna performance evaluation method) and TS 25.144 Over the Air (Antenna) minimum performance requirements for the speech mode (terminal close to head) / Text3: UTRA 34.114
- 797: RP#48 completed. Testing for UID_430010 Performance requirement for LCR TDD with UE speeds up to 350 km/h / Text3: UTRA 34.122
- 798: RP#47 completed / Text3: LTE 34.229-1, 34.229-2, 34.229-3

| ID | WBS | Task | Duration | Start | Finish | Complete | Remaining | Baseline start | Baseline finish | Baseline duration | Total slack | Constraint | Resources | Work | Actual work | Text1 | Text2 | Text6 | Text7 | Text8 | Text4 | Text5 | Text11 |
| --- | --- | --- | --- | --- | --- | --- | --- | --- | --- | --- | --- | --- | --- | --- | --- | --- | --- | --- | --- | --- | --- | --- | --- |
| 799 | 287 | **Rel-9 RAN improvements** | 272d? | 2009-03-06 A | 2010-03-19 A | 100% |  | 2009-03-06 | 2010-03-19 | 272d? |  |  | RP | 9536h | 9536h | RANimp | PCG-22 | Rel-9 | RP-43 | Issam |  |  |  |
| 800 | 287.1 | Dual-Cell HSUPA | 272d? | 2009-03-06 A | 2010-03-19 A | 100% |  | 2009-03-06 | 2010-03-19 | 272d? |  | finish no earlier than 2010-03-19 | R1,R2,R3,R4 | 1568h | 1568h | RANimp-DC_HSUPA | PCG-22 | Rel-9 | RP-43 | Patrick | Nokia Siemens Networks | Karri Ranta-aho (karri.ranta-aho@nsn.com) | RP-100030 |
| 801 | 287.2 | Support for different bands for Dual-Cell HSDPA | 197d? | 2009-03-06 A | 2009-12-04 A | 100% |  | 2009-03-06 | 2009-12-04 | 197d? |  |  | R4,R2,R3 | 1568h | 1568h | RANimp-MultiBand_DC_HSDPA | PCG-22 | Rel-9 | RP-43 | Issam | Nokia Siemens Networks | Tuomo Säynäjäkangas (tuomo.saynajakangas@nsn.com) | RP-091038 |
| 802 | 287.3 | Combination of DC-HSDPA with MIMO | 197d? | 2009-03-06 A | 2009-12-04 A | 100% |  | 2009-03-06 | 2009-12-04 | 197d? |  |  | R1,R2,R3,R4 | 1568h | 1568h | RANimp-DC_MIMO | PCG-22 | Rel-9 | RP-43 | Patrick | Ericsson | johan.bergman@ericsson.com | RP-091039 |
| 803 | 287.4 | Transmit Antenna Array (TxAA) extension for non-MIMO UEs | 197d? | 2009-03-06 A | 2009-12-04 A | 100% |  | 2009-03-06 | 2009-12-04 | 197d? |  |  | R1,R2,R3,R4 | 1568h | 1568h | RANimp-TxAA_nonMIMO | PCG-22 | Rel-9 | RP-43 | Patrick | Nokia | Arto Lehti (arto.lehti@nokia.com) | RP-091040 |
| 804 | 287.5 | Cell Portion for 1.28 Mcps TDD | 136d? | 2009-05-30 A | 2009-12-04 A | 100% |  | 2009-05-30 | 2009-12-04 | 136d? |  |  | R3,R1,R4 | 1088h | 1088h | CP_LCRTDD | PCG-23 | Rel-9 | RP-44 | Juha | CATT | Ying Zhang (zhangying2@datangmobile.cn) | RP-091041 |
| 805 | 288 | **Rel-9 RAN improvements - UE Conformance Testing** | 321d? | 2010-09-17 A | 2011-12-09 | 51% | 156.04d? | 2010-09-17 | 2011-12-09 | 321d? | 260d |  | R5 | 6632h | 3408.04h |  | PCG-25 | Rel-9 | RP-49 | Ingbert |  |  |  |
| 806 | 288.1 | Conformance Test Aspects – Combination of DC-HSDPA with MIMO | 186d? | 2010-09-17 A | 2011-06-03 A | 100% |  | 2010-09-17 | 2011-06-03 | 186d? |  | finish no earlier than 2011-06-03 | R5 | 1488h | 1488h | RANimp-DC_MIMO_UEConTest | PCG-25 | Rel-9 | RP-49 | Ingbert | Ericsson | leif.mattisson@ericsson.com | RP-110510 |
| 807 | 288.2 | Conformance Test Aspects – Dual-Cell HSUPA | 191d? | 2011-03-18 A | 2011-12-09 | 5% | 181.45d? | 2011-03-18 | 2011-12-09 | 191d? | 260d | finish no earlier than 2011-12-09 | R5 | 1528h | 76.4h | RANimp-DC_HSUPA_UEConTest | PCG-26 | Rel-9 | RP-51 | Ingbert | Ericsson | leif.mattisson@ericsson.com | RP-110515 |
| 808 | 288.3 | Conformance Test Aspects – Support for different bands for Dual-Cell HSDPA | 131d? | 2011-03-18 A | 2011-09-16 | 50% | 65.5d? | 2011-03-18 | 2011-09-16 | 131d? | 320d | finish no earlier than 2011-09-16 | R5 | 1048h | 524h | RANimp-MultiBand_DC_HSDPA_UEConTest | PCG-26 | Rel-9 | RP-51 | Ingbert | Ericsson | leif.mattisson@ericsson.com | RP-110514 |
| 809 | 289 | **LTE improvements** | 587d? | 2009-03-06 A | 2011-06-03 A | 100% |  | 2009-03-06 | 2011-06-03 | 587d? |  |  | RP | 9928h | 9928h | LTEimp | PCG-22 | Rel-9 | RP-42 | Patrick |  |  |  |
| 810 | 289.1 | LTE Pico NodeB RF Requirements | 196d? | 2009-03-06 A | 2009-12-04 A | 100% |  | 2009-03-06 | 2009-12-04 | 196d? |  | finish no earlier than 2010-03-05 | R4 | 1568h | 1568h | LTEimp-Pico_eNB-RF | PCG-22 | Rel-9 | RP-43 | Issam | Huawei | Liyan Yin (yinliyan@huawei.com) | RP-091045 |
| 811 | 289.2 | Enhanced Dual-Layer transmission for LTE | 272d? | 2009-03-06 A | 2010-03-19 A | 100% |  | 2009-03-06 | 2010-03-19 | 272d? |  | finish no earlier than 2010-03-18 | R1,R2,R4 | 2176h | 2176h | LTEimp-eDL | PCG-22 | Rel-9 | RP-43 | Patrick | China Mobile | Xu Xiaodong (xuxiaodong@chinamobile.com) | RP-100034 |
| 812 | 289.3 | UE Conformance Test Aspects – Enhanced Dual-layer transmission for LTE TDD | 186d? | 2010-09-17 A | 2011-06-03 A | 100% |  | 2010-09-17 | 2011-06-03 | 186d? |  | finish no earlier than 2011-06-03 | R5 | 1488h | 1488h | LTEimp-eDL_UEConTest | PCG-25 | Rel-9 | RP-49 | Ingbert | China Mobile | Shanpeng Xiao (xiaoshanpeng@chinamobile.com) | RP-110509 |
| 813 | 290 | Self-Organizing Networks (SON) | 272d? | 2009-03-06 A | 2010-03-19 A | 100% |  | 2009-03-06 | 2010-03-19 | 272d? |  | finish no earlier than 2010-03-19 | R3,R2 | 2176h | 2176h | SON | PCG-22 | Rel-9 | SP-42 | Juha | Nokia Siemens Networks | krzysztof.kordybach@nsn.com | RP-100038 |
| 814 | 291 | **A-GNSS Performances and Testing Procedures** | 787d? | 2008-05-16 A | 2011-05-20 A | 100% |  | 2008-05-16 | 2011-05-20 | 787d? |  |  | GP | 16368h | 16368h | AGNSSPTP |  | Rel-9 |  | Paolo | Thales | Michel.monnerat@thalesaleniaspace.com |  |
| 815 | 291.1 | A-GNSS Minimum Performances | 472d? | 2008-05-16 A | 2010-03-05 A | 100% |  | 2008-05-16 | 2010-03-05 | 472d? |  | finish no earlier than 2010-03-05 | G1 | 3776h | 3776h | AGNSSPTP- Perfreq |  | Rel-9 |  | Paolo | Thales | Michel.monnerat@thalesaleniaspace.com |  |
| 816 | 291.2 | A-GNSS Testing Procedures | 787d? | 2008-05-16 A | 2011-05-20 A | 100% |  | 2008-05-16 | 2011-05-20 | 787d? |  | finish no earlier than 2011-05-20 | G3new | 6296h | 6296h | AGNSSPTP-MStest |  | Rel-9 |  | Ingbert | Thales | Michel.monnerat@thalesaleniaspace.com |  |
| 817 | 292 | **Voice services over Adaptive Multi-user channels on One Slot** | 857d? | 2008-11-21 A | 2012-03-02 | 89% | 97.84d? | 2008-11-21 | 2012-03-02 | 857d? | 200d |  | GP,G1,G2,G3new | 24704h | 18946.4h | VAMOS | PCG-22 | Rel-9 | SP-42 | Paolo | Nokia Siemens Networks, China Mobile | juergen.hofmann@nsn.com, liuxiaoyu@chinamobile.com |  |
| 818 | 292.1 | Stage 2 for Voice services over Adaptive Multi-user channels on One Slot | 392d? | 2008-11-21 A | 2010-05-21 A | 100% |  | 2008-11-21 | 2010-05-21 | 392d? |  | finish no earlier than 2010-05-21 | GP,G1,G2 | 3136h | 3136h | VAMOS | PCG-22 | Rel-9 | GP-40 | Paolo | Nokia Siemens Networks, China Mobile | juergen.hofmann@nsn.com, liuxiaoyu@chinamobile.com |  |
| 819 | 292.2 | Stage 3 for Voice services over Adaptive Multi-user channels on One Slot | 596d? | 2008-11-24 A | 2011-03-04 A | 100% |  | 2008-11-24 | 2011-03-04 | 596d? |  | finish no earlier than 2011-03-04 | GP,G1,G2 | 4768h | 4768h | VAMOS | PCG-22 | Rel-9 | GP-40 | Paolo | Nokia Siemens Networks, China Mobile | juergen.hofmann@nsn.com, liuxiaoyu@chinamobile.com |  |
| 820 | 292.3 | VAMOS Radio Performance Requirements | 651d? | 2008-11-24 A | 2011-05-20 A | 100% |  | 2008-11-24 | 2011-05-20 | 651d? |  | finish no earlier than 2011-05-20 | GP,G1,G2 | 5208h | 5208h | VAMOS | PCG-22 | Rel-9 | GP-40 | Paolo | Nokia Siemens Networks, China Mobile | juergen.hofmann@nsn.com, liuxiaoyu@chinamobile.com |  |
| 821 | 292.4 | VAMOS - MS conformance testing | 391d? | 2010-09-03 A | 2012-03-02 | 40% | 234.6d? | 2010-09-03 | 2012-03-02 | 391d? | 200d | finish no earlier than 2012-03-02 | G3new | 3128h | 1251.2h | VAMOS_MStest | PCG-25 | Rel-9 | GP-47 | Ingbert | Research In Motion | Raveendra Seetharam (rseetharam@rim.com) |  |
| 822 | 292.5 | VAMOS - BTS conformance testing | 201d? | 2010-11-26 A | 2011-09-02 | 90% | 20.1d? | 2010-11-26 | 2011-09-02 | 201d? | 330d | finish no earlier than 2011-09-02 | G1 | 1608h | 1447.2h | VAMOS_BTStest | PCG-26 | Rel-9 | GP-48 | Paolo | Nokia Siemens Networks | eddie.riddington@nsn.com |  |

Notes:
- 799: RP#47 completed / Text3: UTRA
- 800: RP#47 completed / Text3: 25.101, 25.104, 25.133, 25.211, 25.212, 25.213, 25.214, 25.215, 25.319, 25.306, 25.321, 25.331, 25.423, 25.433
- 801: RP#46 completed / Text3: 25.101, 25.104, 25.133, 25.306, 25.308, 25.331, 25.423, 25.433, new 25.317 (Requirements on Ues supporting a release-independent frequency band combination)
- 802: RP#46 completed / Text3: 25.101, 25.104, 25.133, 25.211, 25.212, 25.213, 25.214, 25.215, 25.308, 25.321, 25.331, 26.306, 25.423, 25.433
- 803: RP#46 completed / Text3: 25.101, 25.104, 25.211, 25.212, 25.213, 25.214, 25.215, 25.308, 25.306, 25.321, 25.331, 25.423, 25.433
- 804: RP#46 completed / Text3: 25.102, 25.105, 25.123, 25.225, 25.423, 25.433
- 805: -
- 806: UTRA. RP#52 completed. Testing for Rel-9 UID_430016 Combination of DC-HSDPA with MIMO / Text3: UTRA 34.108, 34.121-1, 34.121-2, 34.123-1, 34.123-2, 34.123-3
- 807: UTRA. Testing for Rel-9 UID_430014 Dual-Cell HSUPA / Text3: UTRA 34.108, 34.121-1, 34.121-2, 34.123-1, 34.123-2, 34.123-3
- 808: UTRA. Testing for Rel-9 UID_430015 Support for different bands for Dual-Cell HSDPA / Text3: UTRA 34.108, 34.121-1, 34.121-2, 34.123-1, 34.123-2, 34.123-3
- 809: - / Text3: LTE
- 810: RP#46 completed / Text3: 36.104, 36.141, new 36.931
- 811: RP#47 completed / Text3: 36.101, 36.211, 36.212, 36.213, 36.331
- 812: RP#52 completed. Testing for UID_430029 (Enhanced Dual-Layer transmission for LTE) / Text3: 36.508, 36.521-1, 36.521-2
- 813: RP#47 completed / Text3: LTE 25.413, 36.300, 36.413, 36.423, 48.018, new 36.902
- 814: GP#46 still ongoing MS testing. Linked to Rel-10 RAN4 UID_450027 (A-GNSS Minimum Performance for UTRAN)
- 815: GP#45 completed (open performance requirements alignment GPS/Galileo) / Text3: 45.005
- 816: GP#50 completed / Text3: 51.010-1, new 51.010-7
- 817: GP#46 completion 05/10=>09/10. GP#44 exception to 05/10 in GP-092470. GP#40 WID approved. Triggered by UID_50590 (MUROS) Study on Multi-User Reusing-One-Slot
- 818: GP#46 completed / Text3: 45.001
- 819: GP#49 completed / Text3: 24.008, 44.018, 45.002, 45.003, 45.004, 45.008, 48.008, 48.058
- 820: GP#50 completed / Text3: 45.005
- 821: GP#47 WID approved / Text3: 51.010-1, 51.010-2
- 822: GP#50 completion 05/11=>08/11. GP#48 WID approved / Text3: 51.021

| ID | WBS | Task | Type | Duration | Start | Finish | Complete | Baseline start | Baseline finish | Baseline duration | Constraint | Resources | Work | Actual work | Text1 | Text2 | Text4 | Text5 | Text6 | Text7 | Text8 | Text9 | Text12 | Text11 |
| --- | --- | --- | --- | --- | --- | --- | --- | --- | --- | --- | --- | --- | --- | --- | --- | --- | --- | --- | --- | --- | --- | --- | --- | --- |
| 823 | 293 | **Cell Broadcast protocol Base Station Controller – Cell Broadcast Centre (BSC-CBC)** |  | 222d? | 2009-05-15 A | 2010-03-19 A | 100% | 2009-05-15 | 2010-03-19 | 222d? |  | GP,C1 | 5248h | 5248h | CEBRO | PCG-23 | Ericsson | claes-goran.persson@ericsson.com | Rel-9 | GP-42 | Paolo |  |  |  |
| 824 | 293.1 | GERAN part of Cell Broadcast protocol Base Station Controller – Cell Broadcast Centre |  | 212d? | 2009-05-15 A | 2010-03-05 A | 100% | 2009-05-15 | 2010-03-05 | 212d? | finish no earlier than 2010-03-05 | GP | 1696h | 1696h | CEBRO | PCG-23 | Ericsson | claes-goran.persson@ericsson.com | Rel-9 | GP-42 | Paolo |  |  |  |
| 825 | 293.2 | CT1 part of Cell Broadcast protocol Base Station Controller – Cell Broadcast Centre |  | 222d? | 2009-05-15 A | 2010-03-19 A | 100% | 2009-05-15 | 2010-03-19 | 222d? | finish no earlier than 2010-03-19 | C1 | 1776h | 1776h | CEBRO | PCG-23 | Ericsson | claes-goran.persson@ericsson.com | Rel-9 | GP-42 | Frederic |  |  |  |
| 826 | 294 | Hybrid Location |  | 136d? | 2009-05-18 A | 2009-11-20 A | 100% | 2009-05-18 | 2009-11-20 | 136d? | finish no earlier than 2009-11-20 | GP | 1088h | 1088h | HILT | PCG-23 | TruePosition | Matt Ward (mward@trueposition.com) | Rel-9 | GP-42 | Paolo |  |  |  |
| 827 | 295 | (Small) Technical Enhancements and Improvements for Rel-9 |  | 325d? | 2008-09-15 A | 2009-12-10 A | 100% | 2008-09-15 | 2009-12-10 | 325d? | finish no earlier than 2009-12-10 | All | 2600h | 2600h | TEI9 | PCG-22 |  |  | Rel-9 | SP-42 | All |  |  |  |
| 828 | 296 | Test - (Small) Technical Enhancements and Improvements for Rel-9 |  | 286d? | 2009-11-20 A | 2010-12-24 A | 100% | 2009-11-20 | 2010-12-24 | 286d? | finish no earlier than 2010-12-24 | R5,G3new | 2288h | 2288h | TEI9_Test | PCG-24 |  |  | Rel-9 | GP-44 | Ingbert |  |  |  |
| 829 | 297 | **Deleted - Services Alignment and Migration** |  | 467d? | 2006-12-06 A | 2008-09-18 A | 100% | 2006-12-06 | 2008-09-18 | 467d? |  | S1 | 7472h | 7472h | ServAl |  | Telefónica O2 | chris.friel@O2.com | Rel-9 | SP-33 | Alain |  |  |  |
| 830 | 297.1 | Deleted - Stage 1 for ServAl |  | 467d? | 2006-12-06 A | 2008-09-18 A | 100% | 2006-12-06 | 2008-09-18 | 467d? | finish no earlier than 2008-12-11 | S1 | 3736h | 3736h | ServAl | PCG-21 | Telefónica O2 | chris.friel@O2.com | Rel-9 | SP-33 | Alain |  |  |  |
| 831 | 298 | Deleted - Harmonization of Gq'/Rx for Common IMS |  | 304d? | 2008-01-14 A | 2009-03-12 A | 100% | 2008-01-14 | 2009-03-12 | 304d? | finish no earlier than 2009-03-12 | S2 | 2432h | 2432h | IMS_Comm_GqRx_Harm | PCG-21 | Alcatel-Lucent | geoffrey.cristallo@alcatel-lucent.be | Rel-9 | SP-38 | Maurice | PCG-22 | SP-43 |  |
| 832 | 299 | Deleted - Support of WiMAX - LTE Mobility |  | 407d? | 2008-06-06 A | 2009-12-25 A | 100% | 2008-06-06 | 2009-12-25 | 407d? | start no earlier than 2008-06-06 | R2 | 3248h | 3248h | WiMAX_LTE_Mobility | PCG-21 | Samsung |  | Rel-9 | RP-38 | Joern | PCG-21 | SP-39 |  |
| 833 | 300 | Deleted - Support of WiMAX - UMTS Mobility |  | 407d? | 2008-06-06 A | 2009-12-25 A | 100% | 2008-06-06 | 2009-12-25 | 407d? | start no earlier than 2008-06-06 | R2 | 3248h | 3248h | WiMAX_UMTS_Mobility | PCG-21 | Intel |  | Rel-9 | RP-38 | Joern | PCG-21 | SP-39 |  |
| 834 | 301 | Deleted - Definition of 3GPP UICC services over the new high-speed interface | milestone | 0d? | 2010-03-19 A | 2010-03-19 A | 100% | 2010-03-19 | 2010-03-19 | 0d? |  | C6 |  |  | UICCHS | PCG-21 | Gemalto | Denis.Lheriteau@gemalto.com | Rel-9 | CP-38 | Xavier | PCG-24 | CP-47 |  |
| 835 | 302 | **Deleted - SAES Enhancements (non RAN aspects)** |  | 381d? | 2007-06-25 A | 2008-12-08 A | 100% | 2007-06-25 | 2008-12-08 | 381d? |  | S2 | 11664h | 11664h | SAES_Ph2 | PCG-21 | Nokia Siemens Networks |  | Rel-9 | SP-39 | Maurice | PCG-21 | SP-39 |  |
| 836 | 302.1 | Deleted - Functions and procedures for SAE to support LTE MBMS |  | 381d? | 2007-06-25 A | 2008-12-08 A | 100% | 2007-06-25 | 2008-12-08 | 381d? | finish no earlier than 2008-12-08 | S2 | 3048h | 3048h | SAES_Ph2 |  |  |  | Rel-9 | SP-35 | Maurice | PCG-21 | SP-39 |  |
| 837 | 302.2 | Deleted - CS over EPS |  | 194d? | 2008-03-12 A | 2008-12-08 A | 100% | 2008-03-12 | 2008-12-08 | 194d? | finish no earlier than 2008-12-08 | S2 | 1552h | 1552h | SAES_Ph2 | PCG-21 |  |  | Rel-9 | SP-39 | Maurice | PCG-21 | SP-39 |  |
| 838 | 302.3 | **Deleted - SAE for generic support for non-3GPP accesses** |  | 251d? | 2007-06-25 A | 2008-06-09 A | 100% | 2007-06-25 | 2008-06-09 | 251d? |  | S2 | 4016h | 4016h | SAES_Ph2 | PCG-21 |  |  | Rel-9 | SP-39 | Maurice | PCG-21 | SP-39 |  |
| 839 | 302.3.1 | Deleted - Single Radio Aspects of SAE for Optimized Handover with WiMAX |  | 251d? | 2007-06-25 A | 2008-06-09 A | 100% | 2007-06-25 | 2008-06-09 | 251d? | finish no earlier than 2008-06-09 | S2 | 2008h | 2008h | SAES_Ph2 | PCG-21 |  |  | Rel-9 | SP-39 | Maurice | PCG-21 | SP-39 |  |
| 840 | 303 | Deleted - Lawful Interception in the 3GPP Rel-9 |  | 211d? | 2009-06-04 A | 2010-03-25 A | 100% | 2009-06-04 | 2010-03-25 | 211d? | finish no earlier than 2010-03-25 | S3 | 1688h | 1688h | LI9 | PCG-23 | PIDS, Nortel | Koen Jaspers, Ronald Ryan | Rel-9 | SP-44 | Dionisio | PCG-24 | SP-47 |  |
| 841 | 304 | Release 9 Studies |  | 468d? | 2008-06-05 A | 2010-03-19 A | 100% | 2008-06-05 | 2010-03-19 | 468d? |  | CP,RP,SP | 3744h | 3744h |  |  |  |  | Rel-9 |  |  |  |  |  |
| 842 | 305 | Study on Service Specific Access Control in EPS |  | 136d? | 2008-06-05 A | 2008-12-11 A | 100% | 2008-06-05 | 2008-12-11 | 136d? | start no earlier than 2008-06-05 | S1 | 1088h | 1088h | FS_SSAC | PCG-21 | NTT DoCoMo | Shin-ichi Isobe (isobes@nttdocomo.co.jp) | Rel-9 | SP-40 | Alain |  |  |  |
| 843 | 306 | Study on CS Domain Services over EPS access |  | 492d? | 2007-04-25 A | 2009-03-12 A | 100% | 2007-04-25 | 2009-03-12 | 492d? | finish no earlier than 2009-03-12 | S2 | 3936h | 3936h | FS_CSoPS |  | T-Mobile | Karl-Heinz.Nenner@T-Mobile.net | Rel-9 | SP-35 | Maurice |  |  |  |
| 844 | 307 | Study on Extended Support of IMS Emergency Calls |  | 319d? | 2007-09-24 A | 2008-12-11 A | 100% | 2007-09-24 | 2008-12-11 | 319d? | finish no earlier than 2009-06-18 | S2 | 2552h | 2552h | FS_IMS-eCall |  | Qualcomm | Stephen Edge | Rel-9 | SP-37 | Maurice |  |  |  |
| 845 | 308 | Study on Service Continuity for Emergency Voice Calls |  | 721d? | 2006-06-08 A | 2009-03-12 A | 100% | 2006-06-08 | 2009-03-12 | 721d? | finish no earlier than 2009-03-12 | S2 | 5768h | 5768h | FS_VCCEm |  | Nortel | Ricky Kaura (rkaura@nortel.com) | Rel-9 | SP-32 | Maurice |  |  |  |
| 846 | 309 | Study on Security Aspects of Remote Provisioning and Change of Subscription for M2M Equipment |  | 582d? | 2004-04-06 A | 2009-12-10 A | 100% | 2004-04-06 | 2009-12-10 | 582d? | finish no earlier than 2009-12-10 | S3,C6 | 4656h | 4656h | FS_UM2M |  | Ericsson | vesa.lehtovirta@ericsson.com | Rel-9 | SP-37 | Dionisio |  |  |  |
| 847 | 310 | Study on System Maintenance over Itf-N |  | 602d? | 2007-06-07 A | 2009-09-24 A | 100% | 2007-06-07 | 2009-09-24 | 602d? | finish no earlier than 2009-09-24 | S5 | 4808h | 4808h | FS_OAM-Maint-Itf-N |  | ZTE | Shuqiang Huang (huangsq@zte.com.cn) | Rel-9 | SP-36 | Dionisio |  |  |  |
| 848 | 311 | Study on Self-Organizing Networks (SON) related OAM interfaces for Home NodeB |  | 522d? | 2007-06-07 A | 2009-06-04 A | 100% | 2007-06-07 | 2009-06-04 | 522d? | finish no earlier than 2009-12-10 | S5 | 4168h | 4168h | FS_OAM-SON-HNB |  | Huawei | Zou Lan (zlan@huawei.com) | Rel-9 | SP-36 | Dionisio |  |  |  |
| 849 | 312 | Study on Self-healing of Self-Organizing Networks (SON) |  | 416d? | 2008-02-22 A | 2009-09-24 A | 100% | 2008-02-22 | 2009-09-24 | 416d? | finish no earlier than 2009-09-24 | S5 | 3320.15h | 3320.15h | FS_OAM-SON-SH | PCG-21 | ZTE | zhu.weihong@zte.com.cn | Rel-9 | SP-39 | Dionisio |  |  |  |
| 850 | 313 | Study on Service Oriented Architecture (SOA) for IRP |  | 262d? | 2008-06-05 A | 2009-06-04 A | 100% | 2008-06-05 | 2009-06-04 | 262d? | finish no earlier than 2009-05-20 | S5 | 2088h | 2088h | FS_OAM_SOA_IRP | PCG-21 | Ericsson | edwin.tse@ericsson.com | Rel-9 | SP-40 | Dionisio |  |  |  |
| 851 | 314 | Study on Evaluation of the inclusion of Path Loss Based Technology in the UTRAN |  | 516d? | 2007-12-17 A | 2009-12-04 A | 100% | 2007-12-17 | 2009-12-04 | 516d? | finish no earlier than 2009-09-18 | R4 | 4120h | 4120h | FS_RAN-Pathloss | PCG-21 | Polaris Wireless | Norman Shaw (nshaw@polariswireless.com) | Rel-9 | RP-38 | Issam |  |  | RP-091080 |
| 852 | 315 | Study on LTE-Advanced |  | 461d? | 2007-03-23 A | 2010-03-19 A | 100% | 2007-03-23 | 2010-03-19 | 461d? | finish no earlier than 2010-03-19 | R1,R2,R3,R4 | 3688h | 3688h | FS_RAN_LTEA | PCG-21 | NTT DoCoMo | Tetsushi Abe | Rel-9 | RP-39 | Patrick |  |  | RP-100080 |
| 853 | 316 | Study on 1.28 Mcps TDD Home NodeB |  | 387d? | 2008-02-20 A | 2009-12-04 A | 100% | 2008-02-20 | 2009-12-04 | 387d? | finish no earlier than 2009-12-04 | R4 | 3096h | 3096h | FS_RAN-HNBLCRTDD | PCG-21 | TD Tech | Li Rong (lirong@td-tech.com) | Rel-9 | RP-41 | Issam |  |  | RP-091081 |
| 854 | 317 | Study on E-UTRAN Mobility Evaluation and Enhancement |  | 126d? | 2008-12-05 A | 2009-05-29 A | 100% | 2008-12-05 | 2009-05-29 | 126d? | finish no earlier than 2009-05-29 | R1 | 1008h | 1008h | FS_EUTRAN_mob | PCG-22 | Qualcomm | Rajat Prakash (rprakash@qualcomm.com) | Rel-9 | RP-42 | Patrick |  |  | RP-090426 |
| 855 | 318 | Study on Minimization of drive-tests in Next Generation Networks |  | 196d? | 2009-03-06 A | 2009-12-04 A | 100% | 2009-03-06 | 2009-12-04 | 196d? | finish no earlier than 2009-12-04 | R2 | 1568h | 1568h | FS_NGN_min_drive-tests | PCG-22 | Qualcomm | Masato Kitazoe (mkitazoe@qualcomm.com) | Rel-9 | RP-43 | Joern |  |  | RP-091084 |
| 856 | 319 | Study on Enhanced Interference Management for HNBs |  | 61d? | 2009-03-06 A | 2009-05-29 A | 100% | 2009-03-06 | 2009-05-29 | 61d? | start no earlier than 2009-03-06 | R4 | 488h | 488h | FS_eInterfMgmt_HNB | PCG-22 | Qualcomm | Farhad Meshkati (fmeshkat@qualcomm.com) | Rel-9 | RP-43 | Issam |  |  | RP-090429 |
| 857 | 320 | Study on Enhanced Interference Management Mechanisms for HNBs |  | 81d? | 2009-05-30 A | 2009-09-18 A | 100% | 2009-05-30 | 2009-09-18 | 81d? | finish no earlier than 2009-09-18 | R3 | 648h | 648h | FS_eInterfMgmtMchsm_HNB | PCG-23 | Qualcomm | Farhad Meshkati (fmeshkat@qualcomm.com) | Rel-9 | RP-44 | Juha |  |  | RP-090733 |
| 858 | 321 | Deleted - Study on Protection against SMS and MMS spam |  | 862d? | 2006-06-08 A | 2009-09-24 A | 100% | 2006-06-08 | 2009-09-24 | 862d? | finish no earlier than 2009-09-24 | S3 | 6896h | 6896h | FS_CPSMal |  | Orange | eric.gauthier@orange.ch | Rel-9 | SP-32 | Dionisio | PCG-23 | SP-45 |  |
| 859 | 322 | Release 8 Features |  | 914.3d? | 2006-09-19 A | 2010-03-19 A | 100% | 2006-09-19 | 2010-03-19 | 914.3d? | start no earlier than 2000-01-03 | CP,GP,RP,SP | 7314.4h | 7314.4h |  |  |  |  | Rel-8 |  |  |  |  |  |

Notes:
- 823: CP#47 completed. GP#45 completed. GP#42 WID approved
- 824: GP#45 completed. GP#42 WID approved / Text3: new 48.049
- 825: CP#47 completed / Text3: 23.041
- 826: GP#44 completed. GP#42 WID approved (Hybrid Integrated Location Technology=HILT) / Text3: 43.059, 48.071
- 827: SP#46 completed
- 828: GP#44 created
- 829: SP#41 closed (no tangible result of this work; no CR against TR 22.983). Triggered by Study UID_370086 (FSServAl)
- 830: SP#41 closed (no tangible result of this work; no CR against TR 22.983) / Text3: 22.983
- 831: SP#43 stopped. LS_out to TISPAN informs about stopping this activity / Text3: 23.822, 23.203
- 832: RP#39: No agreed WID / Text3: 36.306, 36.331, 36.413, 36.300, 36.214, 36.133, 36.304
- 833: RP#39: No agreed WID / Text3: 25.306, 25.331, 25.413
- 834: CP#47 work stopped/abandoned / Text3: 31.xyz
- 835: SP#39 created to host Rel-9 Wis. BUT no agreed WID
- 836: SP#39 SAE functionality moved to Rel-9. WID returned to SA2 for re-consideration & remove MBMS for EPS from Rel 8
- 837: SP#39 SAE functionality moved to Rel-9. BUT no agreed WID
- 838: SP#39 SAE functionality moved to Rel-9. BUT no agreed WID
- 839: SP#39 SAE functionality moved to Rel-9. BUT no agreed WID
- 840: SP#47 stopped. WI + new topics moved to Rel-10 / Text3: 33.106, 33.107, 33.108
- 841: -
- 842: SP#42 completed. Spin-off Feature UID_420020 (SSAC) / Text3: 22.986
- 843: SP#43 completed. Linked to Combinational Services UID_31064, Services Alignment and Migration (ServAl) UID_330017 and 3GPP System Architecture Evolution (SAES) UID_3208 / Text3: 23.879
- 844: SP#42 completed / Text3: 23.868
- 845: SP#43 completed / Text3: 23.826
- 846: SP#46 completed. Triggered by the SA1 Rel-8 Study on Facilitating Machine to Machine Communication in GSM and UMTS (FS_M2M) UID_7027 in TR 22.868. / Text3: 33.812
- 847: SP#45 completed / Text3: 32.822
- 848: SP#44 completed. Linked to SA5 TR 32.816 Study of Management for LTE and SAE (UID_340036) / Text3: 32.821
- 849: SP#45 completed. Linked to SA5 TR 32.816 Study of Management for LTE and SAE (UID_340036) / Text3: 32.823
- 850: SP#44 completed. Spin-off implementation WI UID_440064 Service Oriented Architecture (SOA) for IRP / Text3: 32.824
- 851: RP#46 completed / Text3: 25.907
- 852: RP#47 completed / Text3: 36.913 , new 36.814, 36.912, R2 36.806 (Relay architectures for E-UTRA), R4 36.815 (LTE-Advanced feasibility studies in RAN4)
- 853: RP#46 completed / Text3: 25.866
- 854: RP#44 closed (RP-090452 R1 LS to RAN on Conclusions for LTE Mobility Study Item - no further Rel-9 action / no TR needed) / Text3: none
- 855: RP#46 completed / Text3: 36.805
- 856: RP#44 completed. Linked to UID_420008 LTE FDD Home eNodeB RF Requirements. Spin-off RAN3 UID_440015 Study on Enhanced Interference Management Mechanisms for HNBs / Text3: 25.967
- 857: RP#45 completed. Triggered by RAN4 UID_430027 Study on Enhanced Interference Management for HNBs / Text3: 25.967
- 858: SP#45 work stopped/abandoned / Text3: 33.9xx
- 859: -

| ID | WBS | Task | Duration | Start | Finish | Complete | Remaining | Baseline start | Baseline finish | Baseline duration | Total slack | Constraint | Resources | Work | Actual work | Text1 | Text4 | Text5 | Text6 | Text8 | Text7 | Text2 |
| --- | --- | --- | --- | --- | --- | --- | --- | --- | --- | --- | --- | --- | --- | --- | --- | --- | --- | --- | --- | --- | --- | --- |
| 860 | 323 | **3GPP System Architecture Evolution Specification - Evolved Packet System (non RAN aspects)** | 1479d? | 2006-04-12 A | 2011-12-09 | 98% | 35.76d? | 2006-04-12 | 2011-12-09 | 1479d? | 260d |  | S1,S2,S3,S5,C1,C3,C4,C6,IETF | 282368h | 258107h | SAES | T-Mobile | michael.kurz@t-mobile.at | Rel-8 | Alain |  |  |
| 861 | 323.1 | Requirements for evolution of the 3GPP system architecture | 395d? | 2006-06-08 A | 2007-12-12 A | 100% |  | 2006-06-08 | 2007-12-12 | 395d? |  | finish no earlier than 2007-11-30 | S1 | 3160h | 3160h | AIPN-SAE | T-Mobile | michael.kurz@t-mobile.at | Rel-8 | Alain |  |  |
| 862 | 323.2 | **High level and common (for all accesses) functions** | 629d? | 2007-01-02 A | 2009-05-29 A | 100% |  | 2007-01-02 | 2009-05-29 | 629d? |  |  | S2,S3,C1,C3,C4 | 37504h | 37504h | EPS-ComF | Nokia Siemens Networks | balazs.bertenyi@nsn.com | Rel-8 | Maurice | SP-37 |  |
| 863 | 323.2.1 | Stage 2 for High level functions | 370d? | 2007-01-02 A | 2008-06-02 A | 100% |  | 2007-01-02 | 2008-06-02 | 370d? |  | finish no earlier than 2008-06-02 | S2 | 2960h | 2960h | SAES-SA-HLF | Motorola | Irfan.Ali@motorola.com | Rel-8 | Maurice |  |  |
| 864 | 323.2.2 | Stage 2 Security Architecture | 197d? | 2008-03-12 A | 2008-12-11 A | 100% |  | 2008-03-12 | 2008-12-11 | 197d? |  | finish no earlier than 2008-12-11 | S3 | 1576h | 1576h | SAES | Nokia Siemens Networks | marc.blommaert.ext@nsn.com | Rel-8 | Dionisio | SP-39 | PCG-21 |
| 865 | 323.2.3 | Stage 3 (CT1) for SAE impact on services, network functions and capabilities | 545d? | 2007-02-05 A | 2009-03-06 A | 100% |  | 2007-02-05 | 2009-03-06 | 545d? |  | finish no earlier than 2009-03-06 | C1 | 4360h | 4360h | SAES | Nokia Siemens Networks | robert.zaus@nsn.com | Rel-8 | Frederic |  |  |
| 866 | 323.2.4 | Stage 3 SAE impact on existing capabilities | 480d? | 2007-02-05 A | 2008-12-05 A | 100% |  | 2007-02-05 | 2008-12-05 | 480d? |  | finish no earlier than 2008-12-12 | C3 | 3840h | 3840h | SAES | Huawei | Wei Weihua (weiwh@huawei.com) | Rel-8 | Jiwan |  |  |
| 867 | 323.2.5 | Stage 3 (CT4) of SAE impact on existing capabilities | 545d? | 2007-02-05 A | 2009-03-06 A | 100% |  | 2007-02-05 | 2009-03-06 | 545d? |  | finish no earlier than 2009-03-06 | C4 | 4360h | 4360h | SAES | Huawei | shahab.lavasani@huawei.com | Rel-8 | Kimmo |  |  |
| 868 | 323.2.6 | Stage 2/3 for Network selection procedures | 480d? | 2007-02-05 A | 2008-12-05 A | 100% |  | 2007-02-05 | 2008-12-05 | 480d? |  | finish no earlier than 2009-03-06 | C1 | 3840h | 3840h | SAES | Nokia Siemens Networks | robert.zaus@nsn.com | Rel-8 | Frederic |  |  |
| 869 | 323.2.7 | Stage 3 EPC interworking with external PDNs (SGi) | 605d? | 2007-02-05 A | 2009-05-29 A | 100% |  | 2007-02-05 | 2009-05-29 | 605d? |  | finish no earlier than 2009-05-29 | C3 | 4840h | 4840h | SAES-St3-intwk | Huawei | Wei Weihua (weiwh@huawei.com) | Rel-8 | Jiwan |  |  |
| 870 | 323.2.8 | Stage 3 PCC within SAE | 605d? | 2007-02-05 A | 2009-05-29 A | 100% |  | 2007-02-05 | 2009-05-29 | 605d? |  | finish no earlier than 2009-05-29 | C3 | 4840h | 4840h | SAES-St3-PCC | Ericsson | j.javier.pastor@ericsson.com | Rel-8 | Jiwan |  |  |
| 871 | 323.2.9 | Stage 3 for SAE / LTE identities | 545d? | 2007-02-05 A | 2009-03-06 A | 100% |  | 2007-02-05 | 2009-03-06 | 545d? |  | finish no earlier than 2009-03-06 | C4 | 4360h | 4360h | SAES | Huawei | shahab.lavasani@huawei.com | Rel-8 | Kimmo |  |  |
| 872 | 323.2.10 | Unified guidelines for Diameter usage within 3GPP | 316d? | 2007-09-21 A | 2008-12-05 A | 100% |  | 2007-09-21 | 2008-12-05 | 316d? |  | finish no earlier than 2008-12-05 | C3 | 2528h | 2528h | SAES-DIAM | Huawei | Javier Gonzalez Gallego | Rel-8 | Jiwan | CP-37 |  |
| 873 | 323.3 | **SAE for LTE access** | 569d? | 2007-01-02 A | 2009-03-06 A | 100% |  | 2007-01-02 | 2009-03-06 | 569d? |  |  | S2,C1,C3,C4 | 57824h | 57824h | SAES-LTE | Motorola | Irfan.Ali@motorola.com | Rel-8 | Maurice |  |  |
| 874 | 323.3.1 | CT4 Stage 3 for protocol between EPCs | 545d? | 2007-02-05 A | 2009-03-06 A | 100% |  | 2007-02-05 | 2009-03-06 | 545d? |  | finish no earlier than 2009-03-06 | C4 | 4360h | 4360h | SAES | Huawei | shahab.lavasani@huawei.com | Rel-8 | Kimmo |  |  |
| 875 | 7.2.2.1 | **SAES-SA-FP_LTE with GTP variant** | 569d? | 2007-01-02 A | 2009-03-06 A | 100% |  | 2007-01-02 | 2009-03-06 | 569d? |  |  | S2,C4 | 11896h | 11896h | SAES-SA-FP_LTE-GTP | Nokia Siemens Networks | balazs.bertenyi@nsn.com | Rel-8 | Maurice |  |  |
| 876 | 323.3.2.1 | Stage 2 for SAES-SA-FP_LTE with GTP variant | 373d? | 2007-01-02 A | 2008-06-05 A | 100% |  | 2007-01-02 | 2008-06-05 | 373d? |  | finish no earlier than 2008-06-02 | S2 | 2984h | 2984h | SAES-SA-FP_LTE-GTP-St2 | Nokia Siemens Networks | balazs.bertenyi@nsn.com | Rel-8 | Maurice |  |  |
| 877 | 323.3.2.2 | CT4 Stage 3 for GTP v2 protocol | 545d? | 2007-02-05 A | 2009-03-06 A | 100% |  | 2007-02-05 | 2009-03-06 | 545d? |  | finish no earlier than 2009-03-06 | C4 | 4360h | 4360h | SAES | Huawei | shahab.lavasani@huawei.com | Rel-8 | Kimmo |  |  |
| 878 | 7.2.2.2 | **SAES-SA-FP_LTE with PMIP variant** | 569d? | 2007-01-02 A | 2009-03-06 A | 100% |  | 2007-01-02 | 2009-03-06 | 569d? |  |  | S2,C4 | 15736h | 15736h | SAES-SA-FP_LTE-IETF | Nokia Siemens Networks | balazs.bertenyi@nsn.com | Rel-8 | Maurice |  |  |
| 879 | 323.3.3.1 | Stage 2 for SAES-SA-FP_LTE with PMIP variant | 373d? | 2007-01-02 A | 2008-06-05 A | 100% |  | 2007-01-02 | 2008-06-05 | 373d? |  | finish no earlier than 2008-06-02 | S2 | 2984h | 2984h | SAES-SA-FP_LTE-IETF-St2 | Nokia Siemens Networks | balazs.bertenyi@nsn.com | Rel-8 | Maurice |  |  |
| 880 | 323.3.3.2 | CT4 Stage 3 for PMIP protocol within EPC | 545d? | 2007-02-05 A | 2009-03-06 A | 100% |  | 2007-02-05 | 2009-03-06 | 545d? |  | finish no earlier than 2009-03-06 | C4 | 4360h | 4360h | SAES | Huawei | shahab.lavasani@huawei.com | Rel-8 | Kimmo | CP-37 |  |
| 881 | 323.3.3.3 | Mobile IPv4 (MIPv4) based Mobility protocols | 480d? | 2007-02-05 A | 2008-12-05 A | 100% |  | 2007-02-05 | 2008-12-05 | 480d? |  | finish no earlier than 2008-12-05 | C4 | 3840h | 3840h | SAES | Motorola | Lewis Milton | Rel-8 | Kimmo | CP-41 |  |
| 882 | 323.3.4 | Stage 3 for UE NAS mobility procedures in idle and active mode | 545d? | 2007-02-05 A | 2009-03-06 A | 100% |  | 2007-02-05 | 2009-03-06 | 545d? |  | finish no earlier than 2009-03-06 | C1 | 4360h | 4360h | SAES | Nokia Siemens Networks | robert.zaus@nsn.com | Rel-8 | Frederic |  |  |
| 883 | 323.3.5 | Stage 3 for Session management, bearer control and QoS aspects | 545d? | 2007-02-05 A | 2009-03-06 A | 100% |  | 2007-02-05 | 2009-03-06 | 545d? |  | finish no earlier than 2009-03-06 | C1 | 4360h | 4360h | SAES | Nokia Siemens Networks | robert.zaus@nsn.com | Rel-8 | Frederic |  |  |
| 884 | 323.3.6 | Stage 3 for security aspects of LTE Access | 545d? | 2007-02-05 A | 2009-03-06 A | 100% |  | 2007-02-05 | 2009-03-06 | 545d? |  | finish no earlier than 2009-03-06 | C1 | 4360h | 4360h | SAES | Nokia Siemens Networks | robert.zaus@nsn.com | Rel-8 | Frederic |  |  |
| 885 | 323.3.7 | Stage 3 for QoS mechanisms | 480d? | 2007-02-05 A | 2008-12-05 A | 100% |  | 2007-02-05 | 2008-12-05 | 480d? |  | finish no earlier than 2008-12-12 | C3 | 3840h | 3840h | SAES | Ericsson | j.javier.pastor@ericsson.com | Rel-8 | Jiwan |  |  |
| 886 | 323.3.8 | Stage 3 for EPC - HSS interface | 545d? | 2007-02-05 A | 2009-03-06 A | 100% |  | 2007-02-05 | 2009-03-06 | 545d? |  | finish no earlier than 2009-03-06 | C4 | 4360h | 4360h | SAES | Huawei | shahab.lavasani@huawei.com | Rel-8 | Kimmo |  |  |

Notes:
- 860: SP#39 WID updated SP-070933=>SP-080132. Role model for SAE/LTE system wide project management by SA2 in SP-060166
- 861: SP#38 completed / Text3: 22.011, 22.246, new 22.278
- 862: CP#44 completed
- 863: SP#40 completed / Text3: new 23.402
- 864: SP#42 completed / Text3: 33.210, 33.310, new 33.401
- 865: CP#43 completed / Text3: 24.229, 27.007, new 24.305
- 866: CP#42 completed / Text3: 29.061
- 867: CP#43 completed / Text3: new (29.274, 29.275)
- 868: CP#42 completed / Text3: 23.122, new 24.302
- 869: CP#44 completed / Text3: 29.061
- 870: CP#44 completed / Text3: 29.212, 29.213, 29.214, new 29.215
- 871: CP#43 completed / Text3: 23.003
- 872: CP#42 completed / Text3: new 29.909
- 873: CP#43 completed
- 874: CP#43 completed / Text3: 29.274, 29.275
- 875: CP#43 completed
- 876: SP#40 completed / Text3: 23.401, 23.060, 23.002, 23.246, 23.203, 23.107, 23.234, 23.271
- 877: CP#43 completed / Text3: 29.274
- 878: CP#43 completed
- 879: SP#40 completed
- 880: CP#43 completed / Text3: 29.275, 29.282
- 881: CP#42 completed / Text3: 29.279
- 882: CP#43 completed / Text3: 24.007, 24.301
- 883: CP#43 completed / Text3: 24.007, 24.301
- 884: CP#43 completed / Text3: 24.008, 24.301
- 885: CP#42 completed / Text3: 29.213
- 886: CP#43 completed / Text3: 29.272

| ID | WBS | Task | Type | Duration | Start | Finish | Complete | Remaining | Baseline start | Baseline finish | Baseline duration | Total slack | Constraint | Resources | Work | Actual work | Text1 | Text4 | Text5 | Text6 | Text8 | Text3 | Text7 | Text2 | Text12 |
| --- | --- | --- | --- | --- | --- | --- | --- | --- | --- | --- | --- | --- | --- | --- | --- | --- | --- | --- | --- | --- | --- | --- | --- | --- | --- |
| 887 | 323.4 | **SAE for Interoperation between LTE and legacy cellular PS accesses** |  | 545d? | 2007-02-05 A | 2009-03-06 A | 100% |  | 2007-02-05 | 2009-03-06 | 545d? |  |  | S2,C1,C4 | 40152h | 40152h | SAES-SA-FP_3GPP | Motorola | Irfan.Ali@motorola.com | Rel-8 | Maurice |  |  |  |  |
| 888 | 323.4.1 | Stage 2 for Interoperation between LTE and 2G/3G |  | 424d? | 2007-02-05 A | 2008-09-18 A | 100% |  | 2007-02-05 | 2008-09-18 | 424d? |  | finish no earlier than 2008-09-11 | S2 | 3392h | 3392h | EPSto2_3G | Motorola | Irfan.Ali@motorola.com | Rel-8 | Maurice | 23.401, 23.402 | SP-37 |  |  |
| 889 | 323.4.2 | Stage 3 for Inter-system mobility between E-UTRAN and 2G/3G |  | 545d? | 2007-02-05 A | 2009-03-06 A | 100% |  | 2007-02-05 | 2009-03-06 | 545d? |  | finish no earlier than 2009-03-06 | C1 | 4360h | 4360h | SAES | Nokia Siemens Networks | robert.zaus@nsn.com | Rel-8 | Frederic | 24.008, 24.301 | CP-38 | PCG-21 |  |
| 890 | 323.4.3 | Stage 2 GPRS enhancements for LTE access |  | 272d? | 2007-09-04 A | 2008-09-18 A | 100% |  | 2007-09-04 | 2008-09-18 | 272d? |  | start no earlier than 2007-09-04 | S2 | 2176h | 2176h | SAES-GPRS_LTE | Vodafone | chris.pudney@vodafone.com | Rel-8 | Maurice | 23.401 |  |  |  |
| 891 | 323.4.4 | Stage 2 GPRS for EPC (23.060, etc.) |  | 179d? | 2008-01-14 A | 2008-09-18 A | 100% |  | 2008-01-14 | 2008-09-18 | 179d? |  | finish no earlier than 2008-09-18 | S2 | 1432h | 1432h | SAES | Nokia Siemens Networks | balazs.bertenyi@nsn.com | Rel-8 | Maurice | 23.060 | SP-39 | PCG-21 |  |
| 892 | 323.4.5 | Stage 3 for EPC - GPRS |  | 545d? | 2007-02-05 A | 2009-03-06 A | 100% |  | 2007-02-05 | 2009-03-06 | 545d? |  | finish no earlier than 2009-03-06 | C4 | 4360h | 4360h | SAES | Huawei | shahab.lavasani@huawei.com | Rel-8 | Kimmo | 29.274, 29.275, 29.281 |  |  |  |
| 893 | 323.4.6 | Stage 3 for EPC to UTRAN |  | 545d? | 2007-02-05 A | 2009-03-06 A | 100% |  | 2007-02-05 | 2009-03-06 | 545d? |  | finish no earlier than 2009-03-06 | C4 | 4360h | 4360h | SAES | Huawei | shahab.lavasani@huawei.com | Rel-8 | Kimmo | 29.274, 29.275, 29.281 | CP-38 | PCG-21 |  |
| 894 | 323.4.7 | Stage 3 for EPC to 3GPP2 |  | 545d? | 2007-02-05 A | 2009-03-06 A | 100% |  | 2007-02-05 | 2009-03-06 | 545d? |  | finish no earlier than 2009-03-06 | C4 | 4360h | 4360h | SAES | Huawei | shahab.lavasani@huawei.com | Rel-8 | Kimmo | 29.277, 29.276 | CP-38 | PCG-21 |  |
| 895 | 323.4.8 | Stage 2 for Interoperation between LTE and CDMA2000 |  | 329d? | 2007-06-18 A | 2008-09-18 A | 100% |  | 2007-06-18 | 2008-09-18 | 329d? |  | finish no earlier than 2008-04-25 | S2 | 2632h | 2632h | EPStoC2k | Motorola, Vodafone | Irfan.Ali@motorola.com, chris.pudney@vodafone.com | Rel-8 | Maurice | 23.401, 23.402 | CP-37 |  |  |
| 896 | 323.4.9 | Stage 3 for Inter-system mobility between E-UTRAN and CDMA2000 |  | 545d? | 2007-02-05 A | 2009-03-06 A | 100% |  | 2007-02-05 | 2009-03-06 | 545d? |  | finish no earlier than 2009-03-06 | C1 | 4360h | 4360h | SAES | Nokia Siemens Networks | robert.zaus@nsn.com | Rel-8 | Frederic | 24.301, 24.302 |  |  |  |
| 897 | 323.4.10 | Stage 3 for MME - SGSN signalling free protocol |  | 545d? | 2007-02-05 A | 2009-03-06 A | 100% |  | 2007-02-05 | 2009-03-06 | 545d? |  | finish no earlier than 2009-03-06 | C4 | 4360h | 4360h | SAES | Huawei | shahab.lavasani@huawei.com | Rel-8 | Kimmo | 29.272, 29.274 |  |  |  |
| 898 | 323.5 | **SAE for support for non-3GPP accesses** |  | 1290d? | 2007-01-02 A | 2011-12-09 | 91% | 110.86d? | 2007-01-02 | 2011-12-09 | 1290d? | 260d |  | S2,S3,C1,C4,IETF | 74548.8h | 59615.6h | SAES-SA-FP_n3GPP | Motorola | Irfan.Ali@motorola.com | Rel-8 | Maurice |  |  |  |  |
| 899 | 7.2.4.1 | Stage 2 for Host-based Mobility aspects |  | 373d? | 2007-01-02 A | 2008-06-05 A | 100% |  | 2007-01-02 | 2008-06-05 | 373d? |  | finish no earlier than 2008-04-11 | S2 | 2984h | 2984h | SAES-SA-FP_n3GPP-HBMob | Motorola | Irfan.Ali@motorola.com | Rel-8 | Maurice | 23.402 |  |  |  |
| 900 | 7.2.4.2 | Stage 2 for Network-based Mobility aspects |  | 448d? | 2007-01-02 A | 2008-09-18 A | 100% |  | 2007-01-02 | 2008-09-18 | 448d? |  | finish no earlier than 2008-09-18 | S2 | 3584h | 3584h | SAES-SA-FP_n3GPP-NBMob | Motorola | Irfan.Ali@motorola.com | Rel-8 | Maurice | 23.402 |  |  |  |
| 901 | 323.5.3 | Stage 3 for Mobility management based on DSMIPv6 |  | 480d? | 2007-02-05 A | 2008-12-05 A | 100% |  | 2007-02-05 | 2008-12-05 | 480d? |  | finish no earlier than 2008-12-05 | C1 | 3840h | 3840h | SAES | Nokia Siemens Networks | robert.zaus@nsn.com | Rel-8 | Frederic | 24.303 |  |  |  |
| 902 | 323.5.4 | (IETF) Stage 3 for Mobility management based on DSMIPv6 |  | 451d? | 2007-02-05 A | 2011-12-09 | 75% | 112.75d? | 2007-02-05 | 2011-12-09 | 451d? | 260d | finish no earlier than 2011-12-09 | C1-IETF | 3608h | 2706h | SAES | Nokia Siemens Networks |  | Rel-8 | Frederic | ietf-mip6-hiopt | CP-52 | PCG-27 |  |
| 903 | 323.5.5 | (IETF) Stage 3 for Mobility management based on DSMIPv6 |  | 451d? | 2007-02-05 A | 2011-12-09 | 90% | 45.1d? | 2007-02-05 | 2011-12-09 | 451d? | 260d | finish no earlier than 2011-12-09 | C1-IETF | 3608h | 3247.2h | SAES | Nokia Siemens Networks |  | Rel-8 | Frederic | draft-ietf-mext-rfc3775bis | CP-52 | PCG-27 |  |
| 904 | 323.5.6 | Stage 3 for Mobility management based on MIP v4 |  | 480d? | 2007-02-05 A | 2008-12-05 A | 100% |  | 2007-02-05 | 2008-12-05 | 480d? |  | start no earlier than 2007-02-05 | C1 | 3840h | 3840h | SAES | Nokia Siemens Networks | robert.zaus@nsn.com | Rel-8 | Frederic | 24.304 | CP-39 | PCG-21 |  |
| 905 | 323.5.7 | Stage 3 for Inter-system mobility between E-UTRAN and non 3GPP accesses |  | 545d? | 2007-02-05 A | 2009-03-06 A | 100% |  | 2007-02-05 | 2009-03-06 | 545d? |  | finish no earlier than 2009-03-06 | C1 | 4360h | 4360h | SAES | Nokia Siemens Networks | robert.zaus@nsn.com | Rel-8 | Frederic | 24.008, 24.301 | CP-38 | PCG-21 |  |
| 906 | 323.5.8 | Stage 2 for Optimized Dual-Radio Handover with WiMAX |  | 249d? | 2007-06-25 A | 2008-06-05 A | 100% |  | 2007-06-25 | 2008-06-05 | 249d? |  | finish no earlier than 2008-06-09 | S2 | 1992h | 1992h | SAES-SA-FP_n3GPP-OptWIMAX | Motorola | Irfan.Ali@motorola.com | Rel-8 | Maurice | 23.402 |  |  |  |
| 907 | 323.5.9 | Stage 2 Security aspects for non-3GPP Access |  | 197d? | 2008-03-12 A | 2008-12-11 A | 100% |  | 2008-03-12 | 2008-12-11 | 197d? |  | finish no earlier than 2008-12-11 | S3 | 1576h | 1576h | SAES | Nokia Siemens Networks | marc.blommaert.ext@nsn.com | Rel-8 | Dionisio | 33.402, 33.210, 33.310 | SP-39 | PCG-21 |  |
| 908 | 323.5.10 | Stage 3 security aspects for DSMIPv6 Access |  | 480d? | 2007-02-05 A | 2008-12-05 A | 100% |  | 2007-02-05 | 2008-12-05 | 480d? |  | finish no earlier than 2008-12-05 | C1 | 3840h | 3840h | SAES | Nokia Siemens Networks | robert.zaus@nsn.com | Rel-8 | Frederic | 24.303 | CP-37 |  |  |
| 909 | 323.5.11 | Stage 3 security aspects for MIPv4 Access |  | 480d? | 2007-02-05 A | 2008-12-05 A | 100% |  | 2007-02-05 | 2008-12-05 | 480d? |  | finish no earlier than 2008-12-05 | C1 | 3840h | 3840h | SAES | Nokia Siemens Networks | robert.zaus@nsn.com | Rel-8 | Frederic | 24.304 | CP-39 | PCG-21 |  |
| 910 | 323.5.12 | Stage 3 for Access to the EPC via non-3GPP access networks |  | 545d? | 2007-02-05 A | 2009-03-06 A | 100% |  | 2007-02-05 | 2009-03-06 | 545d? |  | finish no earlier than 2009-03-06 | C1 | 4360h | 4360h | SAES | Nokia Siemens Networks | robert.zaus@nsn.com | Rel-8 | Frederic | 24.302, 24.312 |  |  |  |
| 911 | 323.5.13 | Stage 3 for interfaces within EPC |  | 383d? | 2007-09-19 A | 2009-03-06 A | 100% |  | 2007-09-19 | 2009-03-06 | 383d? |  | finish no earlier than 2009-03-06 | C4 | 3064h | 3064h | SAES | Huawei | shahab.lavasani@huawei.com | Rel-8 | Kimmo | 29.274, 29.281 | CP-37 |  |  |
| 912 | 323.5.14 | Stage 3 for Interfaces EPC - non-3GPP IP access |  | 545d? | 2007-02-05 A | 2009-03-06 A | 100% |  | 2007-02-05 | 2009-03-06 | 545d? |  | finish no earlier than 2009-03-06 | C4 | 4360h | 4360h | SAES | Huawei | shahab.lavasani@huawei.com | Rel-8 | Kimmo | 29.273, 29.275 |  |  |  |
| 913 | 323.5.15 | (IETF) Stage 3 for Interfaces EPC - non-3GPP IP access |  | 1085.6d? | 2007-02-05 A | 2011-12-09 | 50% | 542.8d? | 2007-02-05 | 2011-12-09 | 1085.6d? | 260d | start no earlier than 2007-02-05 | C4-IETF | 8684.8h | 4342.4h | SAES | Huawei |  | Rel-8 | Kimmo | ietf-mip6-bootstrapping-integrated | CP-52 | PCG-27 |  |
| 914 | 323.5.16 | Stage 3 for AAA/HSS related |  | 480d? | 2007-02-05 A | 2008-12-05 A | 100% |  | 2007-02-05 | 2008-12-05 | 480d? |  | finish no earlier than 2008-12-05 | C4 | 3840h | 3840h | SAES | Huawei | shahab.lavasani@huawei.com | Rel-8 | Kimmo | 29.273 |  |  |  |
| 915 | 323.5.17 | Stage 3 for EPC - AAA interface |  | 480d? | 2007-02-05 A | 2008-12-05 A | 100% |  | 2007-02-05 | 2008-12-05 | 480d? |  | finish no earlier than 2008-12-05 | C4 | 3840h | 3840h | SAES | Huawei | shahab.lavasani@huawei.com | Rel-8 | Kimmo | 29.273 |  |  |  |
| 916 | 323.5.18 | Deleted (already covered) SAES-SA-FP_n3GPP Optimized Handover with CDMA | milestone | 0d? | 2007-06-25 A | 2007-06-25 A | 100% |  | 2007-06-25 | 2007-06-25 | 0d? |  | finish no earlier than 2007-06-25 | S2 |  |  | SAES-SA-FP_n3GPP-OptCDMA | Nokia Siemens Networks |  | Rel-8 | Maurice |  |  |  | SP-37 |

Notes:
- 887: CP#43 completed
- 888: SP#41 completed
- 889: CP#43 completed
- 890: SP#41 completed
- 891: SP#41 completed
- 892: CP#43 completed
- 893: CP#43 completed
- 894: CP#43 completed
- 895: SP#41 completed (except: Handover of multiple PDNs=>Rel-9)
- 896: CP#43 completed
- 897: CP#43 completed
- 898: CP#43 completed. SP#39 retained in Rel-8 (in addition to the essential functionality defined in SP-070699). Replaces UID_340037
- 899: SP#40 completed
- 900: SP#41 completed
- 901: CP#42 completed
- 902: Not completed internet-draft
- 903: Not completed internet-draft
- 904: CP#42 completed
- 905: CP#43 completed
- 906: SP#40 completed
- 907: SP#42 completed
- 908: CP#42 completed
- 909: CP#42 completed
- 910: CP#43 completed
- 911: CP#43 completed
- 912: CP#43 completed
- 913: Not completed internet-draft
- 914: CP#42 completed
- 915: CP#42 completed
- 916: SP#37 stopped

| ID | WBS | Task | Type | Duration | Start | Finish | Complete | Baseline start | Baseline finish | Baseline duration | Constraint | Resources | Work | Actual work | Text1 | Text4 | Text6 | Text8 | Text2 | Text7 | Text9 | Text12 | Text11 |
| --- | --- | --- | --- | --- | --- | --- | --- | --- | --- | --- | --- | --- | --- | --- | --- | --- | --- | --- | --- | --- | --- | --- | --- |
| 917 | 323.6 | **Single Radio Voice Call Continuity for 3GPP (SRVCC)** |  | 569d? | 2007-01-02 A | 2009-03-06 A | 100% | 2007-01-02 | 2009-03-06 | 569d? |  | S2,C1,C4 | 10752h | 10752h | SAES-SRVCC | Nokia Siemens Networks | Rel-8 | Maurice |  |  |  |  |  |
| 918 | 323.6.1 | Stage 2 for 2G/3G SRVCC |  | 448d? | 2007-01-02 A | 2008-09-18 A | 100% | 2007-01-02 | 2008-09-18 | 448d? | finish no earlier than 2008-09-15 | S2 | 3584h | 3584h | SAES-SRVCC | Nokia Siemens Networks | Rel-8 | Maurice |  |  |  |  |  |
| 919 | 323.6.2 | Stage 3 for SRVCC in EPS |  | 201d? | 2008-05-30 A | 2009-03-06 A | 100% | 2008-05-30 | 2009-03-06 | 201d? | finish no earlier than 2009-03-06 | C1 | 1608h | 1608h | SAES-SRVCC | Nokia Siemens Networks | Rel-8 | Frederic | PCG-21 | CP-41 |  |  |  |
| 920 | 323.6.3 | MME to MSC interface for SRVCC |  | 126d? | 2008-09-12 A | 2009-03-06 A | 100% | 2008-09-12 | 2009-03-06 | 126d? | finish no earlier than 2009-03-06 | C4 | 1008h | 1008h | SAES-SRVCC | Nokia Siemens Networks | Rel-8 | Kimmo | PCG-21 | CP-41 |  |  |  |
| 921 | 323.7 | Voice Call Continuity for CDMA2000 1X |  | 249d? | 2007-06-25 A | 2008-06-05 A | 100% | 2007-06-25 | 2008-06-05 | 249d? | finish no earlier than 2008-06-13 | S2 | 1992h | 1992h | SAES-VCC_1X | Nokia Siemens Networks | Rel-8 | Maurice |  |  |  |  |  |
| 922 | 323.8 | SAE impacts on IMS |  | 373d? | 2007-01-02 A | 2008-06-05 A | 100% | 2007-01-02 | 2008-06-05 | 373d? | finish no earlier than 2008-06-13 | S2 | 2984h | 2984h | SAES-SA_IMS | Nokia Siemens Networks | Rel-8 | Maurice |  |  |  |  |  |
| 923 | 323.9 | **CS Fallback in EPS** |  | 258d? | 2008-03-12 A | 2009-03-06 A | 100% | 2008-03-12 | 2009-03-06 | 258d? |  | S2,C1,C4 | 4800h | 4800h | SAES-CSFB | T-Mobile, Vodafone | Rel-8 | Maurice | PCG-21 | SP-39 |  |  |  |
| 924 | 323.9.1 | Stage 2 for CS Fallback in EPS |  | 62d? | 2008-03-12 A | 2008-06-05 A | 100% | 2008-03-12 | 2008-06-05 | 62d? | finish no earlier than 2008-12-05 | S2 | 496h | 496h | SAES-CSFB | T-Mobile, Vodafone | Rel-8 | Maurice | PCG-21 | SP-40 |  |  |  |
| 925 | 323.9.2 | Stage 3 for CS Fallback in EPS |  | 201d? | 2008-05-30 A | 2009-03-06 A | 100% | 2008-05-30 | 2009-03-06 | 201d? | finish no earlier than 2009-03-06 | C1 | 1608h | 1608h | SAES-CSFB | NEC | Rel-8 | Frederic | PCG-21 | CP-40 |  |  |  |
| 926 | 323.9.3 | Stage 3 for CS Fallback in EPS |  | 136d? | 2008-05-30 A | 2008-12-05 A | 100% | 2008-05-30 | 2008-12-05 | 136d? | finish no earlier than 2008-12-05 | C4 | 1088h | 1088h | SAES-CSFB | NEC | Rel-8 | Kimmo | PCG-21 | CP-40 |  |  |  |
| 927 | 323.10 | System enhancements for the use of IMS services in local breakout |  | 62d? | 2008-03-12 A | 2008-06-05 A | 100% | 2008-03-12 | 2008-06-05 | 62d? | finish no earlier than 2008-06-05 | S2 | 496h | 496h | SAES-IMS_LBO | Telecom Italia | Rel-8 | Maurice | PCG-21 | SP-39 |  |  |  |
| 928 | 323.11 | **EPC Data Definitions** |  | 309d? | 2008-01-07 A | 2009-03-12 A | 100% | 2008-01-07 | 2009-03-12 | 309d? |  | S5 | 7144h | 7144h | EPC-OAM |  | Rel-8 | Dionisio | PCG-21 | SP-39 |  |  |  |
| 929 | 323.11.1 | EPC Network Resource Model (NRM) Integration Reference Point (IRP) |  | 309d? | 2008-01-07 A | 2009-03-12 A | 100% | 2008-01-07 | 2009-03-12 | 309d? | finish no earlier than 2009-03-12 | S5 | 2472h | 2472h | EPC-OAM | Huawei | Rel-8 | Dionisio | PCG-21 | SP-38 |  |  |  |
| 930 | 323.11.2 | Performance measurements for EPC |  | 275d? | 2008-02-22 A | 2009-03-12 A | 100% | 2008-02-22 | 2009-03-12 | 275d? | finish no earlier than 2009-03-12 | S5 | 2200h | 2200h | EPC-OAM | China Mobile | Rel-8 | Dionisio | PCG-21 | SP-39 |  |  |  |
| 931 | 323.12 | EPC Charging |  | 309d? | 2008-01-07 A | 2009-03-12 A | 100% | 2008-01-07 | 2009-03-12 | 309d? | finish no earlier than 2009-03-12 | S5 | 2472h | 2472h | EPC-CH | Nokia Siemens Networks | Rel-8 | Dionisio | PCG-21 | SP-38 |  |  |  |
| 932 | 323.13 | Domain Name System Procedures for Evolved Packet System (DEPS) |  | 179.75d? | 2008-05-30 A | 2009-03-06 A | 100% | 2008-05-30 | 2009-03-06 | 179.75d? | finish no earlier than 2009-03-06 | C4 | 1438h | 1438h | SAES-DEPS | TeliaSonera | Rel-8 | Kimmo | PCG-21 | CP-40 |  |  |  |
| 933 | 323.14 | InterWorking Function (IWF) between MAP based and Diameter based interfaces |  | 126d? | 2008-09-12 A | 2009-03-06 A | 100% | 2008-09-12 | 2009-03-06 | 126d? | finish no earlier than 2009-03-06 | C4 | 1008h | 1008h | SAES-MAP2Diam | Huawei | Rel-8 | Kimmo | PCG-21 | CP-41 |  |  |  |
| 934 | 323.15 | **CT6 aspects of SAE** |  | 847d? | 2008-03-07 A | 2011-06-03 A | 100% | 2008-03-07 | 2011-06-03 | 847d? |  | C6 | 13480h | 13480h | SAES | Nokia | Rel-8 | Xavier | PCG-21 | SP-39 |  |  |  |
| 935 | 323.15.1 | CT6 aspects of SAE |  | 321d? | 2008-03-07 A | 2009-05-29 A | 100% | 2008-03-07 | 2009-05-29 | 321d? | finish no earlier than 2009-05-29 | C6 | 2568h | 2568h | SAES | Nokia | Rel-8 | Xavier | PCG-21 | CP-39 |  |  |  |
| 936 | 323.15.2 | Test interworking of LTE Terminals with the USIM |  | 526d? | 2008-12-05 A | 2010-12-10 A | 100% | 2008-12-05 | 2010-12-10 | 526d? | finish no earlier than 2010-12-10 | C6 | 4208h | 4208h | SAES-USIM_LTE-Test | Comprion | Rel-8 | Xavier | PCG-22 | CP-42 |  |  |  |
| 937 | 323.15.3 | Test interworking of IP Multimedia Services Identity Module (ISIM) terminals with IP Multimedia Subsystem (IMS) |  | 186d? | 2010-09-17 A | 2011-06-03 A | 100% | 2010-09-17 | 2011-06-03 | 186d? | finish no earlier than 2011-06-03 | C6 | 1488h | 1488h | SAES-ISIM_IMS_Test | Comprion | Rel-8 | Xavier | PCG-25 | CP-49 |  |  |  |
| 938 | 323.16 | Issues for CT1 TR 24.801 |  | 420d? | 2007-01-04 A | 2008-12-05 A | 100% | 2007-01-04 | 2008-12-05 | 420d? | finish no earlier than 2008-12-05 | C1 | 3360h | 3360h | SAES | Nokia Siemens Networks | Rel-8 | Frederic | PCG-21 | CP-39 |  |  |  |
| 939 | 323.17 | Issues for CT3 TR 29.804 |  | 420d? | 2007-02-05 A | 2008-09-12 A | 100% | 2007-02-05 | 2008-09-12 | 420d? | finish no earlier than 2008-12-12 | C3 | 3360h | 3360h | SAES | Ericsson | Rel-8 | Jiwan | PCG-21 | CP-39 |  |  |  |
| 940 | 323.18 | Deleted - Issues for CT4 TR 29.803 |  | 420d? | 2007-01-04 A | 2008-09-12 A | 100% | 2007-01-04 | 2008-09-12 | 420d? | finish no earlier than 2008-12-11 | C4 | 3360h | 3360h | SAES | Huawei | Rel-8 | Kimmo | PCG-21 | CP-39 | PCG-21 | CP-41 |  |
| 941 | 323.19 | Deleted (covered by 380068): Functions and procedures for SAE to support LCS | milestone | 0d? | 2008-03-03 A | 2008-03-03 A | 100% | 2008-03-03 | 2008-03-03 | 0d? | finish no earlier than 2008-03-03 | S2 |  |  | SAES-SA-FP_LCS | Nokia Siemens Networks | Rel-8 | Maurice |  |  |  | SP-37 |  |
| 942 | 323.20 | Deleted (covered by 380064): SAE aspects of Emergency Calls | milestone | 0d? | 2008-03-03 A | 2008-03-03 A | 100% | 2008-03-03 | 2008-03-03 | 0d? | start no earlier than 2008-03-03 | S2 |  |  | SAES-SA-EmCall | Nokia Siemens Networks | Rel-8 | Maurice |  |  |  | SP-37 |  |
| 943 | 323.21 | Deleted - CT1 aspects of SAES |  | 16.7d? | 2007-09-04 A | 2007-09-27 A | 100% | 2007-09-04 | 2007-09-27 | 16.7d? | start no earlier than 2007-09-04 | CP,C1 | 133.62h | 133.62h | SAES-St3 |  | Rel-8 | Frederic |  |  |  | SP-37 |  |
| 944 | 323.22 | Deleted - CT1 aspects of SAES | milestone | 0d? | 2007-09-04 A | 2007-09-04 A | 100% | 2007-09-04 | 2007-09-04 | 0d? | start no earlier than 2007-09-04 | C1 |  |  | SAES-St3 |  | Rel-8 | Frederic |  |  |  | SP-37 |  |
| 945 | 323.23 | Deleted - Interoperability | milestone | 0d? | 2008-03-14 A | 2008-03-14 A | 100% | 2008-03-14 | 2008-03-14 | 0d? | start no earlier than 2008-03-14 | C1 |  |  | SAES-St3-interop |  | Rel-8 | Frederic |  |  |  | SP-37 |  |
| 946 | 323.24 | Deleted - CT3 aspects of SAES | milestone | 0d? | 2007-09-04 A | 2007-09-04 A | 100% | 2007-09-04 | 2007-09-04 | 0d? | start no earlier than 2007-09-04 | C3 |  |  | SAES-St3 |  | Rel-8 | Jiwan |  |  |  | SP-37 |  |
| 947 | 323.25 | Deleted - CT4 aspects of SAES | milestone | 0d? | 2007-09-04 A | 2007-09-04 A | 100% | 2007-09-04 | 2007-09-04 | 0d? | start no earlier than 2007-09-04 | C4 |  |  | SAES-St3 |  | Rel-8 | Kimmo |  |  |  | SP-37 |  |
| 948 | 323.26 | Deleted - UE to EPC NAS signalling (incl. MBMS and QoS aspects) | milestone | 0d? | 2008-03-14 A | 2008-03-14 A | 100% | 2008-03-14 | 2008-03-14 | 0d? | start no earlier than 2008-03-14 | C1 |  |  | SAES-St3-sig |  | Rel-8 | Frederic |  |  |  | SP-37 |  |
| 949 | 323.27 | Deleted - User and Control plane protocols | milestone | 0d? | 2007-09-21 A | 2007-09-21 A | 100% | 2007-09-21 | 2007-09-21 | 0d? | start no earlier than 2007-09-21 | C4 |  |  | SAES-St3-prot |  | Rel-8 | Kimmo |  |  |  | SP-37 |  |
| 950 | 323.28 | Deleted - Architecture enhancements for non-3GPP accesses | milestone | 0d? | 2007-09-04 A | 2007-09-04 A | 100% | 2007-09-04 | 2007-09-04 | 0d? | start no earlier than 2007-09-04 | S2 |  |  | SAES-non_3GPP | Motorola | Rel-8 | Maurice |  |  |  | SP-34 |  |
| 951 | 323.29 | Deleted - Stage 2 of architecture for the 3GPP System Architecture Evolution | milestone | 0d? | 2007-10-02 A | 2007-10-02 A | 100% | 2007-10-02 | 2007-10-02 | 0d? | start no earlier than 2007-10-02 | S2 |  |  | SAES-St2 | Vodafone | Rel-8 | Maurice |  |  |  | SP-34 |  |
| 952 | 323.30 | Deleted - SA aspects of System Architecture Evolution |  | 384d? | 2006-04-12 A | 2007-10-01 A | 100% | 2006-04-12 | 2007-10-01 | 384d? | finish no earlier than 2007-10-02 | S2 | 3072h | 3072h | SAES-SA |  | Rel-8 | Maurice |  |  |  | SP-34 |  |
| 953 | 324 | Conformance Test Aspects – Mobility management based on DSMIPv6 (Dual-Stack Mobile IPv6) |  | 261d? | 2009-09-18 A | 2010-09-17 A | 100% | 2009-09-18 | 2010-09-17 | 261d? | finish no earlier than 2010-09-17 | R5 | 2088h | 2088h | DSMIPv6_UEConTest | Qualcomm | Rel-8 | Ingbert | PCG-23 | RP-45 |  |  | RP-100738 |

Notes:
- 917: CP#43 completed. SP#38 WID approved (extract from SAE WID SP-070817). / Text5: curt.c.wong@nokia.com
- 918: SP#41 completed. SP#38 WID approved / Text3: new 23.216 / Text5: curt.c.wong@nokia.com
- 919: CP#43 completed / Text3: 23.009, 24.008, new 24.301 / Text5: robert.zaus@nsn.com
- 920: CP#43 completed / Text3: 23.003, 23.008, new (29.274, 29.277, 29.280) / Text5: Giorgi Gulbani
- 921: SP#40 completed / Text5: balazs.bertenyi@nsn.com
- 922: SP#40 completed / Text5: balazs.bertenyi@nsn.com
- 923: CP#43 completed / Text5: sabine.demel@t-mobile.at, chris.pudney@vodafone.com
- 924: SP#40 completed / Text3: new (23.272, 23.401) / Text5: sabine.demel@t-mobile.at, chris.pudney@vodafone.com
- 925: CP#43 completed / Text3: 24.007, 24.008, 24.011, 29.018, new (24.301, 24.801, 29.118) / Text5: yannick.lair@nectech.fr
- 926: CP#42 completed / Text3: 23.007, 23.008, 29.274, new 29.277 / Text5: yannick.lair@nectech.fr
- 927: SP#40 completed / Text3: 23.228, 23.221, 23.203 / Text5: mario.madella@telecomitalia.it
- 928: SP#43 completed
- 929: SP#43 completed / Text3: new (32.751, 32.752, 32.753, 32.755) / Text5: WANG, Xuelong
- 930: SP#43 completed / Text3: new 32.426 / Text5: Li Jian (lijian@chinamobile.com), Liang Shuangchun (liangshuangchun@cmdi.chinamobile.com)
- 931: SP#43 completed / Text3: 32.240, 32.296, 32.251, 32.252, 32.298, 32.299 / Text5: Gerald.Goermer@nsn.com
- 932: CP#43 completed / Text3: 23.003, new 29.303 / Text5: jouni.korhonen@teliasonera.com
- 933: CP#43 completed. Triggered by UID_380023 (FS_MAP2Diam) / Text3: new 29.305 / Text5: liming49985@huawei.com
- 934: CP#44 completed core specification / Text5: Rune Lindholm
- 935: CP#44 completed (specified Network Measurement Results collection via USAT) / Text3: 31.102, 31.111 / Text5: Rune Lindholm
- 936: CP#50 completed. Steering of Roaming test cases have been introduced. Remaining issues CSG display testing (Provide Local Information, Call Control for EPS/PDN, Event Download (Access Technology Change - Multiple Access Technologies) / Text3: 31.121, 31.124 / Text5: Udo Willenbrink (uwillenbrink@comprion.com )
- 937: CP#52 completed. Linked to R5 UID_1273 Provisioning of IP-based multimedia services (24.229, 31.103), R8 UID_390021 CT6 aspects of SAE, UID_420018 Test interworking of LTE Terminals with the USIM, R UID_450018 Testing SMS over IMS in E-UTRAN (34.229). / Text3: 31.121, 31.124, new TS 31.134 / Text5: Udo Willenbrink (uwillenbrink@comprion.com )
- 938: CP#43 completed / Text3: 24.801 / Text5: robert.zaus@nsn.com
- 939: CP#41 completed / Text3: 29.804 / Text5: j.javier.pastor@ericsson.com
- 940: CP#41 Work stopped and continued in Normative specifications / Text3: 29.803
- 941: SP#37 stopped
- 942: SP#37 stopped
- 943: SP#37 stopped
- 944: SP#37 stopped
- 945: SP#37 stopped
- 946: SP#37 stopped
- 947: SP#37 stopped / Text3: 29.803
- 948: SP#37 stopped
- 949: SP#37 stopped
- 950: SP#34 stopped. Replaced by UID_350027 and its children / Text3: 23.402 / Text5: Irfan.Ali@motorola.com
- 951: SP#34 stopped. Replaced by UIDs 340018 and 340037. (SP#34 report discussion of SP-060917.) / Text3: 23.002, 23.060, 23.107, 23.203, 23.228, 23.234, 23.246, 23.271, 23.279 / Text5: chris.pudney@vodafone.com
- 952: SP#34 stopped
- 953: RP#49 completed. Testing for CT1's UID_360022 (24.303) under Rel-8 Feature SAES / Text3: 36.508, 36.523-1, 36.523-2, 36.523-3 / Text5: Lena Chaponniere (lchaponn@qualcomm.com)

| ID | WBS | Task | Duration | Start | Finish | Complete | Remaining | Baseline start | Baseline finish | Baseline duration | Total slack | Constraint | Resources | Work | Actual work | Text1 | Text4 | Text5 | Text6 | Text7 | Text8 | Text2 | Text9 | Text12 |
| --- | --- | --- | --- | --- | --- | --- | --- | --- | --- | --- | --- | --- | --- | --- | --- | --- | --- | --- | --- | --- | --- | --- | --- | --- |
| 954 | 325 | **IMS Centralized Service Control (ICSRA)** | 1116d? | 2007-09-03 A | 2011-12-09 | 56% | 488.55d? | 2007-09-03 | 2011-12-09 | 1116d? | 260d |  | S1,S2,C1,C3,C4,IETF | 42580.8h | 15394.4h | ICSRA | AT&T | Randolph Wohlert (rwohlert@tri.sbc.com) | Rel-8 | SP-37 | Alain |  |  |  |
| 955 | 325.1 | Stage 1 for ICSRA | 138d? | 2007-09-03 A | 2008-03-12 A | 100% |  | 2007-09-03 | 2008-03-12 | 138d? |  | finish no earlier than 2007-12-14 | S1 | 1104h | 1104h | ICSRA | AT&T | Randolph Wohlert (rwohlert@tri.sbc.com) | Rel-8 | SP-38 | Alain | PCG-21 |  |  |
| 956 | 325.2 | Stage 2 for ICSRA | 125d? | 2007-12-14 A | 2008-06-05 A | 100% |  | 2007-12-14 | 2008-06-05 | 125d? |  | start no earlier than 2007-12-14 | S2 | 1000h | 1000h | ICSRA-St2 | Alcatel-Lucent |  | Rel-8 | SP-38 | Maurice | PCG-21 |  |  |
| 957 | 325.3 | **Stage 3 for ICSRA – Protocol, Addressing, Subscriber Data** | 922d? | 2008-05-30 A | 2011-12-09 | 53% | 437.22d? | 2008-05-30 | 2011-12-09 | 922d? | 260d |  | C1,C3,C4,IETF | 32652.8h | 13290.4h | ICSRA | Ericsson | sean.schneyer@ericsson.com | Rel-8 |  | Frederic |  |  |  |
| 958 | 325.3.1 | CT1 aspects - Stage 3 for ICSRA | 201d? | 2008-05-30 A | 2009-03-06 A | 100% |  | 2008-05-30 | 2009-03-06 | 201d? |  | finish no earlier than 2009-03-06 | C1 | 1608h | 1608h | ICSRA | Ericsson | Sean Schneyer | Rel-8 | CP-40 | Frederic | PCG-21 |  |  |
| 959 | 325.3.2 | (IETF) CT1 aspects - Stage 3 for ICSRA | 451d? | 2008-05-30 A | 2011-12-09 | 25% | 338.25d? | 2008-05-30 | 2011-12-09 | 451d? | 260d | finish no earlier than 2011-12-09 | C1-IETF | 3608h | 902h | ICSRA | Ericsson |  | Rel-8 | CP-52 | Frederic | PCG-27 |  |  |
| 960 | 325.3.3 | (IETF) CT1 aspects - Stage 3 for ICSRA | 451d? | 2008-05-30 A | 2011-12-09 | 75% | 112.75d? | 2008-05-30 | 2011-12-09 | 451d? | 260d | finish no earlier than 2011-12-09 | C1-IETF | 3608h | 2706h | ICSRA | Ericsson |  | Rel-8 | CP-52 | Frederic | PCG-27 |  |  |
| 961 | 325.3.4 | (IETF) CT1 aspects - Stage 3 for ICSRA | 451d? | 2008-05-30 A | 2011-12-09 | 50% | 225.5d? | 2008-05-30 | 2011-12-09 | 451d? | 260d | finish no earlier than 2011-12-09 | C1-IETF | 3608h | 1804h | ICSRA | Ericsson |  | Rel-8 | CP-52 | Frederic | PCG-27 |  |  |
| 962 | 325.3.5 | (IETF) CT1 aspects - Stage 3 for ICSRA | 451d? | 2008-05-30 | 2011-12-09 |  |  | 2008-05-30 | 2011-12-09 | 451d? | 260d | finish no earlier than 2011-12-09 | C1-IETF | 3608h |  | ICSRA | Ericsson |  | Rel-8 | CP-52 | Frederic | PCG-27 |  |  |
| 963 | 325.3.6 | CT3 aspects - Stage 3 for ICSRA | 201d? | 2008-05-30 A | 2009-03-06 A | 100% |  | 2008-05-30 | 2009-03-06 | 201d? |  | finish no earlier than 2009-03-06 | C3 | 1608h | 1608h | ICSRA | Mavenir | Brett Wallis ( brett@mavenir.com) | Rel-8 | CP-40 | Jiwan | PCG-21 |  |  |
| 964 | 325.3.7 | CT4 aspects - Stage 3 for ICSRA | 136d? | 2008-05-30 A | 2008-12-05 A | 100% |  | 2008-05-30 | 2008-12-05 | 136d? |  | start no earlier than 2008-05-30 | C4 | 1088h | 1088h | ICSRA | Ericsson | Sean Schneyer | Rel-8 | CP-40 | Kimmo | PCG-21 |  |  |
| 965 | 325.3.8 | (IETF) CT4 aspects - Stage 3 for ICSRA | 741.6d? | 2008-05-30 A | 2011-12-09 | 50% | 370.8d? | 2008-05-30 | 2011-12-09 | 741.6d? | 260d | start no earlier than 2008-05-30 | C4-IETF | 5932.8h | 2966.4h | ICSRA | Ericsson |  | Rel-8 | CP-52 | Kimmo | PCG-27 |  |  |
| 966 | 325.3.9 | Deleted - Stage 3 for ICSRA – I1 interface | 76d? | 2008-05-30 A | 2008-09-12 A | 100% |  | 2008-05-30 | 2008-09-12 | 76d? |  | finish no earlier than 2008-09-12 | C1 | 608h | 608h | ICSRA | Huawei | xupeili@huawei.com | Rel-8 | CP-40 | Frederic | PCG-21 | PCG-21 | CP-41 |
| 967 | 326 | **IMS Multimedia Telephony and Supplementary Services** | 1204d? | 2007-05-02 A | 2011-12-09 | 90% | 123.02d? | 2007-05-02 | 2011-12-09 | 1204d? | 260d |  | S1,S5,C1,C3,C4,IETF | 63766.4h | 39206.4h | IMSTSS |  |  | Rel-8 | SP-37 | Alain |  |  |  |
| 968 | 326.1 | **General aspects of IMS Sup Services** | 395d? | 2007-09-03 A | 2009-03-06 A | 100% |  | 2007-09-03 | 2009-03-06 | 395d? |  |  | S1,C1,C3,C4 | 9752h | 9752h | IMSSS-Gal | Ericsson | Susana Sabater | Rel-8 | SP-37 | Alain |  |  |  |
| 969 | 326.1.1 | Service and Capability for Core IMS - inclusion of TISPAN requirements | 75d? | 2007-09-03 A | 2007-12-14 A | 100% |  | 2007-09-03 | 2007-12-14 | 75d? |  | finish no earlier than 2007-12-14 | S1 | 600h | 600h | TISCAPR8 | Ericsson | Susana Sabater | Rel-8 | SP-37 | Alain |  |  |  |
| 970 | 326.1.2 | Documentation of TISPAN R1 and R2 in CT1 | 208d? | 2007-11-28 A | 2008-09-12 A | 100% |  | 2007-11-28 | 2008-09-12 | 208d? |  | finish no earlier than 2008-09-12 | C1 | 1664h | 1664h | REDOC_TIS-C1 | Nokia Siemens Networks | peter.leis@nsn.com | Rel-8 | CP-38 | Frederic | PCG-21 |  |  |
| 971 | 326.1.3 | Documentation of TISPAN R1 and R2 in CT3 | 333d? | 2007-11-28 A | 2009-03-06 A | 100% |  | 2007-11-28 | 2009-03-06 | 333d? |  | finish no earlier than 2009-03-06 | C3 | 2664h | 2664h | REDOC_TIS-C3 | Nokia Siemens Networks | peter.leis@nsn.com | Rel-8 | CP-38 | Jiwan | PCG-21 |  |  |
| 972 | 326.1.4 | Documentation of TISPAN R1 and R2 in CT4 | 208d? | 2007-11-28 A | 2008-09-12 A | 100% |  | 2007-11-28 | 2008-09-12 | 208d? |  | finish no earlier than 2008-09-12 | C4 | 1664h | 1664h | REDOC_TIS-C4 | Nokia Siemens Networks | peter.leis@nsn.com | Rel-8 | CP-38 | Kimmo | PCG-21 |  |  |
| 973 | 326.2 | **IMS Multimedia Telephony Service** | 394d? | 2007-09-10 A | 2009-03-12 A | 100% |  | 2007-09-10 | 2009-03-12 | 394d? |  |  | S1,S5 | 5096h | 5096h | IMS-MMTel |  |  | Rel-8 | SP-37 | Alain |  |  |  |
| 974 | 326.2.1 | Merging TISPAN MMTel [requirements] for Common IMS | 65d? | 2007-09-10 A | 2007-12-07 A | 100% |  | 2007-09-10 | 2007-12-07 | 65d? |  | finish no earlier than 2007-12-07 | S1 | 520h | 520h | TMMTEL | Nokia Siemens Networks |  | Rel-8 | SP-37 | Alain |  |  |  |
| 975 | 326.2.2 | Multimedia Telephony Service and Supplementary Services (MMTel) offline Charging | 309d? | 2008-01-07 A | 2009-03-12 A | 100% |  | 2008-01-07 | 2009-03-12 | 309d? |  | finish no earlier than 2009-03-12 | S5 | 2472h | 2472h | MMTel-CH | Alcatel-Lucent | Maryse.Gardella@alcatel.fr | Rel-8 | SP-38 | Dionisio | PCG-21 |  |  |
| 976 | 326.3 | **Call Completion on Busy Subscriber (CCBS)/Call Completion on Non-Reachable (CCNR) on IMS** | 1204d? | 2007-05-02 A | 2011-12-09 | 92% | 100.41d? | 2007-05-02 | 2011-12-09 | 1204d? | 260d |  | C1,C3,IETF | 17104h | 9914h | CCBS_CCNR | Deutsche Telekom | martin.huelsemann@telekom.de | Rel-8 | SP-38 | Frederic | PCG-21 |  |  |
| 977 | 326.3.1 | Stage 3 CCBS_CCNR | 483d? | 2007-05-02 A | 2009-03-06 A | 100% |  | 2007-05-02 | 2009-03-06 | 483d? |  | finish no earlier than 2009-03-06 | C1 | 3864h | 3864h | CCBS_CCNR | Deutsche Telekom | martin.huelsemann@telekom.de | Rel-8 | CP-38 | Frederic | PCG-21 |  |  |
| 978 | 326.3.2 | Stage 3 CCBS_CCNR | 418d? | 2007-05-02 A | 2008-12-05 A | 100% |  | 2007-05-02 | 2008-12-05 | 418d? |  | finish no earlier than 2008-12-05 | C3 | 3344h | 3344h | CCBS_CCNR | Deutsche Telekom | martin.huelsemann@telekom.de | Rel-8 | CP-38 | Jiwan | PCG-21 |  |  |
| 979 | 326.3.3 | (IETF) Stage 3 CCBS_CCNR | 451d? | 2007-05-02 A | 2011-12-09 | 75% | 112.75d? | 2007-05-02 | 2011-12-09 | 451d? | 260d | finish no earlier than 2011-12-09 | C1-IETF | 3608h | 2706h | CCBS_CCNR | Deutsche Telekom |  | Rel-8 | CP-52 | Frederic | PCG-27 |  |  |

Notes:
- 954: CP#46 completed
- 955: SP#39 completed / Text3: 22.101
- 956: SP#40 completed / Text3: 23.292, 23.206
- 957: CP#46 completed
- 958: CP#46 completed / Text3: 24.229, new (24.292, 24.286)
- 959: Not completed internet-draft / Text3: draft-ietf-salud-alert-info-urns
- 960: Not completed internet-draft / Text3: draft-ietf-mmusic-sdp-media-capabilities
- 961: Not completed internet-draft / Text3: draft-ietf-mmusic-sdp-cs
- 962: Not completed internet-draft / Text3: draft-ietf-mmusic-sdp-misc-cap
- 963: CP#43 completed / Text3: new 29.292
- 964: CP#42 completed / Text3: 23.003, 29.232, 23.018, 29.002
- 965: Not completed internet-draft / Text3: draft-montemurro-gsma-imei-urn
- 966: CP#41 work stopped / Text3: 24.293
- 967: SP#43 completed
- 968: CP#43 completed
- 969: SP#39 completed / Text3: 22.228, 22.115, 22.101
- 970: CP#41 completed / Text3: 24.141, 24.147, 24.173, 24.229, 24.247, 24.341, 24.604, 24.605, 24.606, 24.607, 24.608, 24.610, 24.611, 24.616, 24.623, 24.628, 24.629, 24.647, 24.654
- 971: CP#43 completed / Text3: 29.162, 29.163, 29.658
- 972: CP#41 completed / Text3: 29.228, 29.229
- 973: SP#43 completed
- 974: SP#38 completed / Text3: 22.173
- 975: CP#43 completed / Text3: 32.275, 32.298/299
- 976: CP#43 completed
- 977: CP#43 completed / Text3: 24.642, 24.229, 24.173
- 978: CP#42 completed / Text3: 29.163
- 979: Not completed internet-draft / Text3: draft-ietf-bliss-call-completion

| ID | WBS | Task | Duration | Start | Finish | Complete | Remaining | Baseline start | Baseline finish | Baseline duration | Total slack | Constraint | Resources | Work | Actual work | Text1 | Text2 | Text4 | Text5 | Text6 | Text7 | Text8 |
| --- | --- | --- | --- | --- | --- | --- | --- | --- | --- | --- | --- | --- | --- | --- | --- | --- | --- | --- | --- | --- | --- | --- |
| 980 | 326.4 | **Flexible Alerting** | 288d? | 2008-01-30 A | 2009-03-06 A | 100% |  | 2008-01-30 | 2009-03-06 | 288d? |  |  | S1,C1 | 5278.4h | 5278.4h | FA | PCG-21 | Nortel | milanpa@nortel.com | Rel-8 | SP-39 | Alain |
| 981 | 326.4.1 | Stage 1 FA | 92d? | 2008-01-30 A | 2008-06-05 A | 100% |  | 2008-01-30 | 2008-06-05 | 92d? |  |  | S1 | 670.4h | 670.4h | FA | PCG-21 | Telecom Italia |  | Rel-8 | SP-39 | Alain |
| 982 | 326.4.2 | Stage 3 FA | 288d? | 2008-01-30 A | 2009-03-06 A | 100% |  | 2008-01-30 | 2009-03-06 | 288d? |  | finish no earlier than 2009-03-06 | C1 | 2304h | 2304h | FA | PCG-21 | Nortel | milanpa@nortel.com | Rel-8 | CP-39 | Frederic |
| 983 | 326.5 | **Communication Wait on IMS** | 1167d? | 2007-06-22 A | 2011-12-09 | 68% | 377.02d? | 2007-06-22 | 2011-12-09 | 1167d? | 260d |  | C1,C3,IETF | 14672h | 5670h | CW_IMS | PCG-21 | Deutsche Telekom | martin.huelsemann@telekom.de | Rel-8 | SP-38 | Frederic |
| 984 | 326.5.1 | Stage 3 CW-IMS | 331d? | 2007-11-30 A | 2009-03-06 A | 100% |  | 2007-11-30 | 2009-03-06 | 331d? |  | finish no earlier than 2009-03-06 | C1 | 2648h | 2648h | CW_IMS | PCG-21 | Deutsche Telekom | martin.huelsemann@telekom.de | Rel-8 | CP-38 | Frederic |
| 985 | 326.5.2 | (IETF) Stage 3 CW-IMS | 451d? | 2007-06-22 A | 2011-12-09 | 25% | 338.25d? | 2007-06-22 | 2011-12-09 | 451d? | 260d | finish no earlier than 2011-12-09 | C1-IETF | 3608h | 902h | CW_IMS | PCG-27 | Deutsche Telekom |  | Rel-8 | CP-52 | Frederic |
| 986 | 326.5.3 | Stage 3 CW-IMS | 265d? | 2007-11-30 A | 2008-12-04 A | 100% |  | 2007-11-30 | 2008-12-04 | 265d? |  | finish no earlier than 2008-12-05 | C3 | 2120h | 2120h | CW_IMS | PCG-21 | Deutsche Telekom | martin.huelsemann@telekom.de | Rel-8 | CP-38 | Jiwan |
| 987 | 326.6 | Advice of Charge (AoC) support in IMS Charging | 309d? | 2008-01-07 A | 2009-03-12 A | 100% |  | 2008-01-07 | 2009-03-12 | 309d? |  | finish no earlier than 2009-03-12 | S5 | 2472h | 2472h | IMSTSS | PCG-21 | Nokia Siemens Networks | Gerald.Goermer@nsn.com | Rel-8 | SP-38 | Dionisio |
| 988 | 326.7 | Add Interconnection Border Control Function (IBCF) to IMS Charging | 128d? | 2007-09-17 A | 2008-03-12 A | 100% |  | 2007-09-17 | 2008-03-12 | 128d? |  | finish no earlier than 2008-03-12 | S5 | 1024h | 1024h | IMSTSS |  | Alcatel-Lucent | Maryse.Gardella@alcatel.fr | Rel-8 | SP-37 | Dionisio |
| 989 | 327 | **3GPP2 Input to Common IMS** | 200d? | 2008-03-07 A | 2008-12-11 A | 100% |  | 2008-03-07 | 2008-12-11 | 200d? |  |  | S1,S2,S3,C1,C3,C4 | 8653.2h | 8653.2h | CIMS_3GPP2 | PCG-21 | Nortel | Amar Deol (deola@nortelnetworks.com) | Rel-8 | SP-39 | Alain |
| 990 | 327.1 | Stage 1 CIMS_3GPP2 (SA1) | 30.65d? | 2008-03-12 A | 2008-06-05 A | 100% |  | 2008-03-12 | 2008-06-05 | 30.65d? |  | finish no earlier than 2008-06-12 | S1 | 245.2h | 245.2h | CIMS_3GPP2 | PCG-21 | Nortel | Amar Deol (deola@nortelnetworks.com) | Rel-8 | SP-39 | Alain |
| 991 | 327.2 | Stage 2 CIMS_3GPP2 (SA2) | 62d? | 2008-03-12 A | 2008-06-05 A | 100% |  | 2008-03-12 | 2008-06-05 | 62d? |  | finish no earlier than 2008-09-11 | S2 | 496h | 496h | IMS_Common | PCG-21 | Nortel | Amar Deol (deola@nortelnetworks.com) | Rel-8 | SP-39 | Maurice |
| 992 | 327.3 | Security CIMS_3GPP2 (SA3) | 197d? | 2008-03-12 A | 2008-12-11 A | 100% |  | 2008-03-12 | 2008-12-11 | 197d? |  | finish no earlier than 2008-12-11 | S3 | 1576h | 1576h | IMS_Common | PCG-21 | Nortel | Amar Deol (deola@nortelnetworks.com) | Rel-8 | SP-39 | Dionisio |
| 993 | 327.4 | Stage 3 CIMS_3GPP2 (CT1) | 196d? | 2008-03-07 A | 2008-12-05 A | 100% |  | 2008-03-07 | 2008-12-05 | 196d? |  | finish no earlier than 2008-12-11 | C1 | 1568h | 1568h | REDOC_3GPP2 | PCG-21 | Alcatel-Lucent | orsic@alcatel-lucent.com | Rel-8 | CP-39 | Frederic |
| 994 | 327.5 | Stage 3 CIMS_3GPP2 (CT3) | 196d? | 2008-03-07 A | 2008-12-05 A | 100% |  | 2008-03-07 | 2008-12-05 | 196d? |  | finish no earlier than 2008-12-05 | C3 | 1568h | 1568h | REDOC_3GPP2 | PCG-21 | Alcatel-Lucent | orsic@alcatel-lucent.com | Rel-8 | CP-39 | Jiwan |
| 995 | 327.6 | Stage 3 CIMS_3GPP2 (CT4) | 200d? | 2008-03-07 A | 2008-12-11 A | 100% |  | 2008-03-07 | 2008-12-11 | 200d? |  | finish no earlier than 2008-12-11 | C4 | 1600h | 1600h | REDOC_3GPP2 | PCG-21 | Alcatel-Lucent | orsic@alcatel-lucent.com | Rel-8 | CP-39 | Kimmo |
| 996 | 328 | **IMS Enhancements for support of Packet Cable access** | 388d? | 2006-12-06 A | 2008-05-30 A | 100% |  | 2006-12-06 | 2008-05-30 | 388d? |  |  | S2,S3,C1,C3,C4 | 27448h | 27448h | PktCbl |  | Cablelabs | Bernie McKibben (b.mckibben@cablelabs.com) | Rel-8 |  | Maurice |
| 997 | 328.1 | **IMS Enhancements for Cable Client Types and Deployment Models** | 345d? | 2007-02-05 A | 2008-05-30 A | 100% |  | 2007-02-05 | 2008-05-30 | 345d? |  |  | S2,C1 | 6992h | 6992h | PktCbl-Deploy |  | Cablelabs | Bernie McKibben (b.mckibben@cablelabs.com) | Rel-8 |  | Maurice |
| 998 | 328.1.1 | Architecture aspects of PktCbl-Deploy | 219d? | 2007-02-05 A | 2007-12-06 A | 100% |  | 2007-02-05 | 2007-12-06 | 219d? |  | finish no earlier than 2007-12-03 | S2 | 1752h | 1752h | PktCbl-Deploy |  | Cablelabs | Bernie McKibben (b.mckibben@cablelabs.com) | Rel-8 |  | Maurice |
| 999 | 328.1.2 | CT1 aspects of PktCbl-Deploy | 310d? | 2007-03-26 A | 2008-05-30 A | 100% |  | 2007-03-26 | 2008-05-30 | 310d? |  | finish no earlier than 2008-06-15 | C1 | 2480h | 2480h | PktCbl-Deploy |  | Cablelabs | D.Hancock@CableLabs.com | Rel-8 |  | Frederic |
| 1000 | 328.2 | **IMS Inter-working aspects in Support of Cable Regulatory requirements** | 290d? | 2007-02-05 A | 2008-03-14 A | 100% |  | 2007-02-05 | 2008-03-14 | 290d? |  |  | S2,C1,C3 | 5640h | 5640h | PktCbl-Intw |  | Cablelabs | B.McKibben@CableLabs.com | Rel-8 |  | Maurice |
| 1001 | 328.2.1 | Architecture aspects of PktCbl-Interwork | 160d? | 2007-02-05 A | 2007-09-14 A | 100% |  | 2007-02-05 | 2007-09-14 | 160d? |  | start no earlier than 2007-02-05 | S2 | 1280h | 1280h | PktCbl-Intw |  | Cablelabs | B.McKibben@CableLabs.com | Rel-8 |  | Maurice |
| 1002 | 328.2.2 | CT1,CT3 aspects of PktCbl-Interwork | 255d? | 2007-03-26 A | 2008-03-14 A | 100% |  | 2007-03-26 | 2008-03-14 | 255d? |  | finish no earlier than 2008-03-15 | C1,C3 | 2040h | 2040h | PktCbl-Intw |  | Cablelabs | D.Hancock@CableLabs.com | Rel-8 |  | Frederic |
| 1003 | 328.3 | **IMS Enhancements for Security Requirements in Support of Cable Deployments** | 388d? | 2006-12-06 A | 2008-05-30 A | 100% |  | 2006-12-06 | 2008-05-30 | 388d? |  |  | S3,C1,C3,C4 | 11712h | 11712h | PktCbl-Sec |  | Cablelabs | s.dotson@cablelabs.com | Rel-8 |  | Dionisio |
| 1004 | 328.3.1 | SA3 aspects of PktCbl-Sec | 331d? | 2006-12-06 A | 2008-03-12 A | 100% |  | 2006-12-06 | 2008-03-12 | 331d? |  | finish no earlier than 2007-12-20 | S3 | 2648h | 2648h | PktCbl-Sec |  | Cablelabs | s.dotson@cablelabs.com | Rel-8 |  | Dionisio |
| 1005 | 328.3.2 | CT1 aspects of PktCbl-Sec | 310d? | 2007-03-26 A | 2008-05-30 A | 100% |  | 2007-03-26 | 2008-05-30 | 310d? |  | finish no earlier than 2008-06-06 | C1 | 2480h | 2480h | PktCbl-Sec |  | Cablelabs | D.Hancock@CableLabs.com | Rel-8 |  | Frederic |
| 1006 | 328.3.3 | CT3 aspects of PktCbl-Sec | 180d? | 2007-03-26 A | 2007-11-30 A | 100% |  | 2007-03-26 | 2007-11-30 | 180d? |  | finish no earlier than 2008-03-15 | C3 | 1440h | 1440h | PktCbl-Intw | PCG-21 | Cablelabs | D.Hancock@CableLabs.com | Rel-8 | CP-38 | Jiwan |
| 1007 | 328.3.4 | CT4 aspects of PktCbl-Sec | 255d? | 2007-03-26 A | 2008-03-14 A | 100% |  | 2007-03-26 | 2008-03-14 | 255d? |  | finish no earlier than 2008-03-14 | C4 | 2040h | 2040h | PktCbl-Sec |  | Cablelabs | D.Hancock@CableLabs.com | Rel-8 |  | Kimmo |

Notes:
- 980: CP#43 completed
- 981: SP#40 completed / Text3: 22.173
- 982: CP#43 completed / Text3: 24.239, 24.173
- 983: CP#43 completed
- 984: CP#43 completed / Text3: 24.615, 24.229, 24.173
- 985: Not completed internet-draft / Text3: draft-ietf-salud-alert-info-urns
- 986: CP#42 completed / Text3: 29.163
- 987: SP#43 completed / Text3: 32.240, 32.260, 32.296, 32.298, 32.299, new 32.280
- 988: SP#39 completed / Text3: 32.260, 32.298
- 989: TSG#42 completed
- 990: SP#40 completed / Text3: 22.228, 22.173, 22.101, 22.153
- 991: SP#40 completed / Text3: 23.002, 23.141, 23.203, 23.167, 23.228
- 992: SP#42 completed [issues addressed under UID_370078 (IMS-Sec)] / Text3: 33.141, 33.203, 33.210
- 993: CP#42 completed / Text3: 23.218, 24.141, 24.147, 24.173, 24.229, 24.238, 24.247, 24.604, 24.605, 24.606, 24.607, 24.608, 24.610, 24.611, 24.629, 24.930
- 994: CP#42 completed / Text3: 29.163, 29.212, 29.213, 29.214
- 995: CP#42 completed / Text3: 29.228, 29.229, 29.328, 29.329
- 996: CP#40 completed
- 997: CP#40 completed
- 998: SP#38 completed / Text3: 23.228
- 999: CP#40 completed
- 1000: CP#39 completed
- 1001: SP#37 completed / Text3: 23.228
- 1002: CP#39 completed / Text3: 24.229
- 1003: CP#40 completed
- 1004: SP#39 completed / Text3: 33.203, 33.210, 33.220
- 1005: CP#40 completed / Text3: 24.229
- 1006: CP#38 completed / Text3: 29.163
- 1007: CP#39 completed / Text3: 29.228, 29.229, 23.008

| ID | WBS | Task | Type | Duration | Start | Finish | Complete | Remaining | Baseline start | Baseline finish | Baseline duration | Total slack | Constraint | Resources | Work | Actual work | Text1 | Text4 | Text5 | Text6 | Text8 | Text2 | Text7 |
| --- | --- | --- | --- | --- | --- | --- | --- | --- | --- | --- | --- | --- | --- | --- | --- | --- | --- | --- | --- | --- | --- | --- | --- |
| 1008 | 329 | **IMS System enhancements for corporate network access** |  | 717d? | 2007-06-22 A | 2010-03-19 A | 100% |  | 2007-06-22 | 2010-03-19 | 717d? |  |  | S2,S1,C1,C4 | 14336.9h | 14336.9h | IMS_Corp | Orange | Delphin Barankanira | Rel-8 | Maurice |  |  |
| 1009 | 329.1 | SA1 aspects of IMS_Corp |  | 23.6d? | 2008-03-12 A | 2008-06-05 A | 100% |  | 2008-03-12 | 2008-06-05 | 23.6d? |  | finish no earlier than 2008-06-05 | S1 | 188.8h | 188.8h | IMS_Corp | Telecom Italia |  | Rel-8 | Alain | PCG-21 | SP-39 |
| 1010 | 329.2 | SA2 aspects of IMS_Corp |  | 325d? | 2007-06-22 A | 2008-09-18 A | 100% |  | 2007-06-22 | 2008-09-18 | 325d? |  | finish no earlier than 2008-12-25 | S2 | 2600h | 2600h | IMS_Corp | Orange | Delphin Barankanira | Rel-8 | Maurice |  |  |
| 1011 | 329.3 | CT1 aspects of IMS_Corp |  | 532d? | 2008-03-07 A | 2010-03-19 A | 100% |  | 2008-03-07 | 2010-03-19 | 532d? |  | finish no earlier than 2010-03-19 | C1 | 4244.09h | 4244.09h | IMS_Corp | Alcatel-Lucent | Keith Drage (drage@alcatel-lucent.com) | Rel-8 | Frederic | PCG-21 | CP-39 |
| 1012 | 329.4 | CT4 aspects of IMS_Corp |  | 196d? | 2008-02-26 A | 2008-12-05 A | 100% |  | 2008-02-26 | 2008-12-05 | 196d? |  | finish no earlier than 2008-12-11 | C4 | 1568h | 1568h | IMS_Corp | Alcatel-Lucent | Keith Drage (drage@alcatel-lucent.com) | Rel-8 | Kimmo | PCG-21 | CP-39 |
| 1013 | 330 | **Maintenance of TISPAN documentation** |  | 1161d? | 2007-07-02 A | 2011-12-09 | 65% | 411.21d? | 2007-07-02 | 2011-12-09 | 1161d? | 260d |  | S2,C1,C3,C4,IETF | 16016h | 4934h | MAINTISP |  |  | Rel-8 | Maurice | PCG-21 | SP-38 |
| 1014 | 330.1 | Maintenance of TISPAN R1 |  | 86d? | 2007-11-09 A | 2008-03-07 A | 100% |  | 2007-11-09 | 2008-03-07 | 86d? |  | start no earlier than 2007-11-09 | C1,C3,C4 | 688h | 688h | MAINT_R1 | Alcatel-Lucent | Keith Drage (drage@alcatel-lucent.com) | Rel-7 | Frederic | PCG-21 | CP-38 |
| 1015 | 330.2 | Maintenance of TISPAN R2 |  | 86d? | 2007-11-09 A | 2008-03-07 A | 100% |  | 2007-11-09 | 2008-03-07 | 86d? |  | start no earlier than 2007-11-09 | C1,C3,C4 | 688h | 688h | MAINT_R2 | Alcatel-Lucent | Keith Drage (drage@alcatel-lucent.com) | Rel-8 | Frederic | PCG-21 | CP-38 |
| 1016 | 330.3 | (IETF) Maintenance of TISPAN R2 |  | 451d? | 2007-11-09 A | 2011-12-09 | 25% | 338.25d? | 2007-11-09 | 2011-12-09 | 451d? | 260d | finish no earlier than 2011-12-09 | C1-IETF | 3608h | 902h | MAINT_R2 | Alcatel-Lucent |  | Rel-8 | Frederic | PCG-27 | CP-52 |
| 1017 | 330.4 | Documentation of TISPAN NGN R1 and R2 in 3GPP SA2 |  | 104d? | 2008-01-14 A | 2008-06-05 A | 100% |  | 2008-01-14 | 2008-06-05 | 104d? |  | finish no earlier than 2008-06-20 | S2 | 832h | 832h | IMS_Comm_Doc | Nokia Siemens Networks | jozsef.varga@nsn.com | Rel-8 | Maurice | PCG-21 | SP-38 |
| 1018 | 330.5 | Maintenance of TISPAN release 1 common IMS |  | 114d? | 2007-07-02 A | 2007-12-06 A | 100% |  | 2007-07-02 | 2007-12-06 | 114d? |  | finish no earlier than 2007-12-06 | S2,S1 | 912h | 912h | IMS_Comm_Mtce7 | BT, Ericsson | Dick Knight, Raymond Forbes | Rel-7 | Maurice | PCG-21 | SP-38 |
| 1019 | 330.6 | Maintenance of TISPAN release 2 common IMS |  | 114d? | 2007-07-02 A | 2007-12-06 A | 100% |  | 2007-07-02 | 2007-12-06 | 114d? |  | finish no earlier than 2007-12-06 | S2 | 912h | 912h | IMS_Comm_Mtce8 | Telecom Italia | antonio.ascolese@telecomitalia.it | Rel-8 | Maurice | PCG-21 | SP-38 |
| 1020 | 331 | **IMS Service Continuity** |  | 318d? | 2008-03-12 A | 2009-05-29 A | 100% |  | 2008-03-12 | 2009-05-29 | 318d? |  |  | S2,S1,C1 | 5624h | 5624h | IMS-Cont | LG Electronics | JaeSeung SONG (anthonys@lge.com) | Rel-8 | Maurice | PCG-21 | SP-39 |
| 1021 | 331.1 | Stage 1 IMS Service Continuity |  | 62d? | 2008-03-12 A | 2008-06-05 A | 100% |  | 2008-03-12 | 2008-06-05 | 62d? |  | start no earlier than 2008-03-12 | S1 | 496h | 496h | IMS-Cont | LG Electronics | JaeSeung SONG (anthonys@lge.com) | Rel-8 | Alain | PCG-21 | SP-39 |
| 1022 | 331.2 | Stage 2 IMS Service Continuity |  | 62d? | 2008-03-12 A | 2008-06-05 A | 100% |  | 2008-03-12 | 2008-06-05 | 62d? |  | finish no earlier than 2008-06-05 | S2 | 496h | 496h | IMS-Cont | LG Electronics | JaeSeung SONG (anthonys@lge.com) | Rel-8 | Maurice | PCG-21 | SP-39 |
| 1023 | 331.3 | Stage 3 IMS Service Continuity |  | 261d? | 2008-05-30 A | 2009-05-29 A | 100% |  | 2008-05-30 | 2009-05-29 | 261d? |  | finish no earlier than 2009-05-29 | C1 | 2088h | 2088h | IMS-Cont | Huawei | Lili Yang (kadyyang@huawei.com) | Rel-8 | Frederic | PCG-21 | CP-40 |
| 1024 | 332 | **Security Enhancements for IMS** |  | 643.3d? | 2006-09-19 A | 2009-03-06 A | 100% |  | 2006-09-19 | 2009-03-06 | 643.3d? |  |  | S3,C1,C4 | 18624h | 18624h | IMS-Sec | Ericsson | Bengt.Sahlin@ericsson.com | Rel-8 | Dionisio |  | SP-37 |
| 1025 | 332.1 | Stage 2 for IMS-Sec |  | 466d? | 2007-03-01 A | 2008-12-11 A | 100% |  | 2007-03-01 | 2008-12-11 | 466d? |  | finish no earlier than 2008-12-11 | S3 | 3728h | 3728h | IMS-Sec | Ericsson | Bengt.Sahlin@ericsson.com | Rel-8 | Dionisio |  |  |
| 1026 | 332.2 | CT1 part of Stage 3 for IMS-Sec |  | 392d? | 2006-09-19 A | 2008-12-05 A | 100% |  | 2006-09-19 | 2008-12-05 | 392d? |  | finish no earlier than 2008-12-05 | C1 | 3136h | 3136h | IMS-Sec | Ericsson |  | Rel-8 | Frederic | PCG-21 | CP-39 |
| 1027 | 332.3 | CT4 part of Stage 3 for IMS-Sec |  | 457d? | 2007-06-07 A | 2009-03-06 A | 100% |  | 2007-06-07 | 2009-03-06 | 457d? |  | finish no earlier than 2009-03-06 | C4 | 3656h | 3656h | IMS-Sec | Ericsson |  | Rel-8 | Kimmo | PCG-21 | CP-39 |
| 1028 | 332.4 | CT1 part of NASS Bundled Authentication |  | 343d? | 2007-11-14 A | 2009-03-06 A | 100% |  | 2007-11-14 | 2009-03-06 | 343d? |  | finish no earlier than 2009-03-06 | C1 | 2744h | 2744h | NBA | Alcatel-Lucent | Keith Drage (drage@alcatel-lucent.com) | Rel-8 | Frederic | PCG-21 | CP-39 |
| 1029 | 332.5 | CT4 part of NASS Bundled Authentication |  | 143d? | 2007-11-14 A | 2008-05-30 A | 100% |  | 2007-11-14 | 2008-05-30 | 143d? |  | start no earlier than 2007-11-14 | C4 | 1144h | 1144h | NBA-CT4 | Alcatel-Lucent |  | Rel-8 | Kimmo | PCG-21 | CP-39 |
| 1030 | 333 | **IMS initiated and controlled PSS and MBMS User Service** |  | 979d? | 2008-03-12 A | 2011-12-09 | 50% | 489.5d? | 2008-03-12 | 2011-12-09 | 979d? | 260d |  | S2,S4,C3,C4,IETF | 14220.8h | 3194.4h | IMS_PSS_MBMS_US | FT, Ericsson | olle.franceschi@ericsson.com | Rel-8 | Paolo |  |  |
| 1031 | 333.1 | IMS initiated and controlled PSS and MBMS User Service | milestone | 0d? | 2008-03-12 A | 2008-03-12 A | 100% |  | 2008-03-12 | 2008-03-12 | 0d? |  | finish no earlier than 2009-03-12 | S2,C3,C4 |  |  | IMS_PSS_MBMS_US | FT, Ericsson | olle.franceschi@ericsson.com | Rel-8 | Paolo |  |  |
| 1032 | 333.2 | (IETF) IMS initiated and controlled PSS and MBMS User Service |  | 798.6d? | 2008-03-12 A | 2011-12-09 | 50% | 399.3d? | 2008-03-12 | 2011-12-09 | 798.6d? | 260d | start no earlier than 2008-03-12 | S4-IETF | 6388.8h | 3194.4h | IMS_PSS_MBMS_US | FT, Ericsson |  | Rel-8 | Paolo | PCG-27 | SP-52 |

Notes:
- 1008: CP#47 completed
- 1009: SP#40 completed
- 1010: no Stage 2 impacts / Text3: 23.228
- 1011: CP#47 completed / Text3: 24.229, 24.503
- 1012: CP#42 completed / Text3: 29.228, 29.229, 23.003, 23.008, 29.433
- 1013: SP#40 completed
- 1014: CP#39 completed / Text3: 24.404, 24.405, 24.406, 24.407, 24.408, 24.410, 24.411, 24.416, 29.421, 24.423, 24.428, 24.429, 29.433, 24.441, 24.403, 29.427, 24.430, 29.412
- 1015: CP#39 completed / Text3: 24.406, 24.407, 24.410, 24.411, 24.423, 24.430, 24.447, 24.451, 24.454, 24.503, 24.505, 24.508, 24.516, 24.528, 24.529, 29.412, 29.421, 29.433, 29.458, 29.527, 29.624
- 1016: Not completed internet-draft / Text3: draft-avasarala-dispatch-comm-div-notification
- 1017: SP#40 completed / Text3: 23.228, 23.204, 23.167
- 1018: SP#38 completed / Text3: 22.273, 22.401, 23.406, 23.417, 23.508, 23.509, 23.511, 22.401, 22.173
- 1019: SP#38 completed / Text3: 23.506, 23.507,23.517, 23.521
- 1020: CP#44 completed
- 1021: SP#40 completed
- 1022: SP#40 completed / Text3: 23.237, 23.292
- 1023: CP#44 completed / Text3: 24.237, 24.229, 24.216
- 1024: CP#43 completed
- 1025: SP#42 completed. SP#46 withdrawn draft 33.178-100 and 33.978 from Rel-8 onwards / Text3: 33.203, 33.141, 33.803
- 1026: CP#42 completed
- 1027: CP#43 completed
- 1028: CP#43 completed / Text3: 24.229
- 1029: CP#40 completed / Text3: 29.229, 29.228, 23.008
- 1030: SP#43 completed. SP#39 WID approved / Text3: 26.237, 26.234, 26.346, 33.246
- 1031: SP#43 completed. SP#39 WID approved / Text3: 26.237, 26.234, 26.346, 33.246
- 1032: Not completed internet-draft / Text3: channabasappa-sipping-app-profile-type

| ID | WBS | Task | Duration | Start | Finish | Complete | Remaining | Baseline start | Baseline finish | Baseline duration | Total slack | Constraint | Resources | Work | Actual work | Text1 | Text4 | Text5 | Text6 | Text8 | Text3 | Text2 | Text7 |
| --- | --- | --- | --- | --- | --- | --- | --- | --- | --- | --- | --- | --- | --- | --- | --- | --- | --- | --- | --- | --- | --- | --- | --- |
| 1033 | 334 | **Multimedia interworking between IMS and CS networks** | 836d? | 2005-09-23 A | 2008-12-05 A | 100% |  | 2005-09-23 | 2008-12-05 | 836d? |  |  | C3,C4 | 16112h | 16112h | MIW-IMS | Vodafone | nico.gabriele@vodafone.com | Rel-8 | Jiwan |  |  |  |
| 1034 | 334.1 | Stage 1 and 2 defined in earlier Releases | 49d? | 2005-09-23 A | 2005-11-30 A | 100% |  | 2005-09-23 | 2005-11-30 | 49d? |  | start no earlier than 2005-09-23 | S2 | 392h | 392h | MIW-IMS | Vodafone | nico.gabriele@vodafone.com | Rel-8 | Maurice |  |  |  |
| 1035 | 334.2 | Stage 3 of MW-IMS | 571d? | 2005-09-23 A | 2007-11-30 A | 100% |  | 2005-09-23 | 2007-11-30 | 571d? |  | finish no earlier than 2007-09-14 | C3 | 4568h | 4568h | MIW-IMS-St3 | Vodafone | nico.gabriele@vodafone.com | Rel-8 | Jiwan | 29.863, 29.163 |  |  |
| 1036 | 334.3 | Stage 3 for MW-IMS, MONA extension | 285d? | 2007-11-05 A | 2008-12-05 A | 100% |  | 2007-11-05 | 2008-12-05 | 285d? |  | finish no earlier than 2008-12-05 | C3 | 2280h | 2280h | MIW-IMS | Vodafone | Christer.Holmberg@ericsson.com | Rel-8 | Jiwan | 29.863, 29.163 | PCG-21 | CP-38 |
| 1037 | 334.4 | Mn interface (MGCF – IM MGW) | 273d? | 2007-11-21 A | 2008-12-05 A | 100% |  | 2007-11-21 | 2008-12-05 | 273d? |  | finish no earlier than 2008-12-19 | C4 | 2184h | 2184h | MIW-IMS | Vodafone | Christer.Holmberg@ericsson.com | Rel-8 | Kimmo | 29.332 | PCG-21 | CP-38 |
| 1038 | 335 | **IMS Stage 3 IETF Protocol Alignment** | 1167d? | 2007-06-22 A | 2011-12-09 | 50% | 585.12d? | 2007-06-22 | 2011-12-09 | 1167d? | 260d |  | C1,IETF | 20160h | 7176h | IMSProtoc2 | Alcatel-Lucent | Keith Drage (drage@alcatel-lucent.com) | Rel-8 | Frederic | 23.218, 24.229, 24.930 |  |  |
| 1039 | 335.1 | IMS Stage 3 IETF Protocol Alignment | 446d? | 2007-06-22 A | 2009-03-06 A | 100% |  | 2007-06-22 | 2009-03-06 | 446d? |  | finish no earlier than 2009-03-06 | C1 | 3568h | 3568h | IMSProtoc2 | Alcatel-Lucent | Keith Drage (drage@alcatel-lucent.com) | Rel-8 | Frederic | 23.218, 24.229, 24.930 |  |  |
| 1040 | 335.2 | (IETF) IMS Stage 3 IETF Protocol Alignment | 451d? | 2007-06-22 A | 2011-12-09 | 50% | 225.5d? | 2007-06-22 | 2011-12-09 | 451d? | 260d | finish no earlier than 2011-12-09 | C1-IETF | 3608h | 1804h | IMSProtoc2 | Alcatel-Lucent |  | Rel-8 | Frederic | draft-bakker-sipping-3gpp-ims-xml-body-handling | PCG-27 | CP-52 |
| 1041 | 335.3 | (IETF) IMS Stage 3 IETF Protocol Alignment | 451d? | 2007-06-22 A | 2011-12-09 | 25% | 338.25d? | 2007-06-22 | 2011-12-09 | 451d? | 260d | finish no earlier than 2011-12-09 | C1-IETF | 3608h | 902h | IMSProtoc2 | Alcatel-Lucent |  | Rel-8 | Frederic | draft-ietf-mmusic-ice-tcp | PCG-27 | CP-52 |
| 1042 | 335.4 | (IETF) IMS Stage 3 IETF Protocol Alignment | 451d? | 2007-06-22 A | 2011-12-09 | 25% | 338.25d? | 2007-06-22 | 2011-12-09 | 451d? | 260d | finish no earlier than 2011-12-09 | C1-IETF | 3608h | 902h | IMSProtoc2 | Alcatel-Lucent |  | Rel-8 | Frederic | draft-ietf-salud-alert-info-urns | PCG-27 | CP-52 |
| 1043 | 336 | **Interworking between User-to-User Signalling (UUS) and SIP** | 1052d? | 2007-11-30 A | 2011-12-09 | 68% | 338.25d? | 2007-11-30 | 2011-12-09 | 1052d? | 260d |  | C1,C3,IETF | 14704h | 5710h | UUSIW | Huawei | Lili Yang (kadyyang@huawei.com) | Rel-8 | Kimmo |  | PCG-21 | CP-38 |
| 1044 | 336.1 | Stage 3 MGCF UUSIW | 266d? | 2007-11-30 A | 2008-12-05 A | 100% |  | 2007-11-30 | 2008-12-05 | 266d? |  | finish no earlier than 2008-12-05 | C1 | 2128h | 2128h | UUSIW | Huawei | Lili Yang (kadyyang@huawei.com) | Rel-8 | Frederic | 24.279, 24.229 | PCG-21 | CP-38 |
| 1045 | 336.2 | (IETF) Stage 3 MGCF UUSIW | 451d? | 2007-11-30 A | 2011-12-09 | 25% | 338.25d? | 2007-11-30 | 2011-12-09 | 451d? | 260d | finish no earlier than 2011-12-09 | C1-IETF | 3608h | 902h | UUSIW | Huawei |  | Rel-8 | Frederic | draft-ietf-cuss-sip-uui | PCG-27 | CP-52 |
| 1046 | 336.3 | Stage 3 MGCF UUSIW | 335d? | 2007-11-30 A | 2009-03-12 A | 100% |  | 2007-11-30 | 2009-03-12 | 335d? |  | finish no earlier than 2009-03-12 | C3 | 2680h | 2680h | UUSIW | Huawei | Lili Yang (kadyyang@huawei.com) | Rel-8 | Jiwan | 29.163 | PCG-21 | CP-38 |
| 1047 | 337 | **Support of Overlap signalling** | 331d? | 2007-11-30 A | 2009-03-06 A | 100% |  | 2007-11-30 | 2009-03-06 | 331d? |  |  | C3,C1,C4 | 10008.2h | 10008.2h | Overlap | Deutsche Telekom | r.jesske@telekom.de | Rel-8 | Jiwan |  | PCG-21 | CP-38 |
| 1048 | 337.1 | Stage 3 Overlap (CT1) | 331d? | 2007-11-30 A | 2009-03-06 A | 100% |  | 2007-11-30 | 2009-03-06 | 331d? |  | finish no earlier than 2009-03-06 | C1 | 2648h | 2648h | Overlap | Deutsche Telekom | r.jesske@telekom.de | Rel-8 | Frederic | 24.229 | PCG-21 | CP-38 |
| 1049 | 337.2 | Stage 3 Overlap (CT3) | 331d? | 2007-11-30 A | 2009-03-06 A | 100% |  | 2007-11-30 | 2009-03-06 | 331d? |  | finish no earlier than 2009-03-06 | C3 | 2648h | 2648h | Overlap | Deutsche Telekom | r.jesske@telekom.de | Rel-8 | Jiwan | 29.163 | PCG-21 | CP-38 |
| 1050 | 337.3 | Stage 3 Overlap (CT4) | 258.02d? | 2007-11-30 A | 2008-12-05 A | 100% |  | 2007-11-30 | 2008-12-05 | 258.02d? |  | start no earlier than 2007-11-30 | C4 | 2064.16h | 2064.16h | Overlap | Deutsche Telekom | r.jesske@telekom.de | Rel-8 | Kimmo | 29.228, 29.229 | PCG-21 | CP-38 |
| 1051 | 338 | **AS/MRFC Stage 2 and 3** | 1064d? | 2007-11-14 A | 2011-12-09 | 94% | 65.82d? | 2007-11-14 | 2011-12-09 | 1064d? | 260d |  | C1,IETF | 12120h | 5471.2h | MRFC_TS | Hewlett-Packard | mark.syrett@hp.com | Rel-8 | Frederic | 23.218, 24.229, 24.147, 24.247 | PCG-21 | CP-38 |
| 1052 | 338.1 | AS/MRFC Stage 2 and 3 | 278d? | 2007-11-14 A | 2008-12-05 A | 100% |  | 2007-11-14 | 2008-12-05 | 278d? |  | finish no earlier than 2008-12-05 | C1 | 2224h | 2224h | MRFC_TS | Hewlett-Packard | mark.syrett@hp.com | Rel-8 | Frederic | 23.218, 24.229, 24.147, 24.247 | PCG-21 | CP-38 |
| 1053 | 338.2 | (IETF) AS/MRFC Stage 2 and 3 | 451d? | 2007-11-14 A | 2011-12-09 | 90% | 45.1d? | 2007-11-14 | 2011-12-09 | 451d? | 260d | finish no earlier than 2011-12-09 | C1-IETF | 3608h | 3247.2h | MRFC_TS | Hewlett-Packard |  | Rel-8 | Frederic | mediactrl-mixer-control-package | PCG-27 | CP-52 |
| 1054 | 339 | **IMS Restoration Procedures** | 201d? | 2008-05-30 A | 2009-03-06 A | 100% |  | 2008-05-30 | 2009-03-06 | 201d? |  |  | C4,C1 | 4824h | 4824h | IMS_RP | Ericsson | german.blanco@ericsson.com | Rel-8 | Kimmo |  | PCG-21 | SP-40 |
| 1055 | 339.1 | IMS Restoration Procedures (CT4) | 201d? | 2008-05-30 A | 2009-03-06 A | 100% |  | 2008-05-30 | 2009-03-06 | 201d? |  | finish no earlier than 2009-03-06 | C4 | 1608h | 1608h | IMS_RP | Ericsson | german.blanco@ericsson.com | Rel-8 | Kimmo | 23.380, 29.228, 29.229, 29.230, 23.008 | PCG-21 | SP-40 |
| 1056 | 339.2 | IMS Restoration Procedures (CT1) | 201d? | 2008-05-30 A | 2009-03-06 A | 100% |  | 2008-05-30 | 2009-03-06 | 201d? |  | finish no earlier than 2009-03-06 | C1 | 1608h | 1608h | IMS_RP | Ericsson | german.blanco@ericsson.com | Rel-8 | Frederic | 24.229 | PCG-21 | SP-40 |
| 1057 | 340 | IMS Application Server Service Data Descriptions for AS interoperability | 125d? | 2008-09-12 A | 2009-03-06 A | 100% |  | 2008-09-12 | 2009-03-06 | 125d? |  | finish no earlier than 2009-03-06 | C4 | 1000h | 1000h | IMS_ASIO | Alcatel-Lucent | nhberry@alcatel-lucent.com | Rel-8 | Kimmo | 29.328, 29.329, 29.364 | PCG-21 | CP-41 |

Notes:
- 1033: CP#42 completed
- 1034: SP#31 Moved from FS section Feb 2006
- 1035: Moved from Rel-7. Feature extended in Rel-8 by including Stage 3 covering MONA UID_380021
- 1036: CP#42 completed
- 1037: CP#42 completed
- 1038: CP#43 completed
- 1039: CP#43 completed
- 1040: Not completed internet-draft
- 1041: Not completed internet-draft
- 1042: Not completed internet-draft
- 1043: CP#43 completed
- 1044: CP#42 completed
- 1045: Not completed internet-draft
- 1046: CP#43 completed
- 1047: CP#43 completed
- 1048: CP#43 completed
- 1049: CP#43 completed
- 1050: CP#42 completed
- 1051: CP#42 completed. Triggered by Study UID_7048 (MRFC)
- 1052: CP#42 completed. Triggered by Study UID_7048 (MRFC)
- 1053: Not completed internet-draft
- 1054: CP#43 completed. Triggered by Study TR 23.820 (FS_IMS_RP) UID_350018
- 1055: CP#43 completed
- 1056: CP#43 completed
- 1057: CP#43 completed. Triggered by UID_360030 (FS_IMS_ASIO)

| ID | WBS | Task | Type | Duration | Start | Finish | Complete | Baseline start | Baseline finish | Baseline duration | Constraint | Resources | Work | Actual work | Text1 | Text4 | Text5 | Text6 | Text8 | Text2 | Text3 | Text7 | Text11 | Text12 |
| --- | --- | --- | --- | --- | --- | --- | --- | --- | --- | --- | --- | --- | --- | --- | --- | --- | --- | --- | --- | --- | --- | --- | --- | --- |
| 1058 | 341 | **I-WLAN Network Selection Principle (NSP)** |  | 451d? | 2007-06-14 A | 2009-03-06 A | 100% | 2007-06-14 | 2009-03-06 | 451d? |  | S1,C1,C6 | 6643.2h | 6643.2h | IWLANNSP | Telefónica O2 | chris.friel@O2.com | Rel-8 | Alain |  |  |  |  |  |
| 1059 | 341.1 | Stage 1 for I-WLAN NSP | milestone | 0d? | 2007-06-14 A | 2007-06-14 A | 100% | 2007-06-14 | 2007-06-14 | 0d? |  | S1 |  |  | IWLANNSP | Telefónica O2 | chris.friel@O2.com | Rel-8 | Alain | PCG-21 | 22.234 | SP-39 |  |  |
| 1060 | 341.2 | Stage 3 for I-WLAN NSP |  | 261d? | 2008-03-07 A | 2009-03-06 A | 100% | 2008-03-07 | 2009-03-06 | 261d? | finish no earlier than 2008-12-05 | C1 | 2088h | 2088h | IWLANNSP | Research In Motion | Adrian Buckley (abuckley@rim.com) | Rel-8 | Frederic | PCG-21 | 24.234 | CP-39 |  |  |
| 1061 | 341.3 | Stage 3 for I-WLAN NSP |  | 118.4d? | 2008-03-07 A | 2008-12-11 A | 100% | 2008-03-07 | 2008-12-11 | 118.4d? | finish no earlier than 2008-12-11 | C6 | 947.2h | 947.2h | IWLANNSP | Research In Motion | Adrian Buckley (abuckley@rim.com) | Rel-8 | Xavier | PCG-21 | 31.102, 31.111 | CP-39 |  |  |
| 1062 | 342 | **Mobility between 3GPP-WLAN Interworking and 3GPP Systems** |  | 386d? | 2007-09-14 A | 2009-03-06 A | 100% | 2007-09-14 | 2009-03-06 | 386d? |  | S2,C1 | 6216h | 6216h | IWLAN_Mob | Orange | xiaobao.chen@orange-ftgroup.com | Rel-8 | Maurice |  |  | SP-37 |  |  |
| 1063 | 342.1 | Stage 2: I-WLAN Mobility |  | 190d? | 2007-09-14 A | 2008-06-05 A | 100% | 2007-09-14 | 2008-06-05 | 190d? | finish no earlier than 2008-09-08 | S2 | 1520h | 1520h | IWLAN_Mob | Orange | xiaobao.chen@orange-ftgroup.com | Rel-8 | Maurice | PCG-21 | new 23.327 | SP-38 |  |  |
| 1064 | 342.2 | CT1 aspects of I-WLAN Mobility |  | 201d? | 2008-05-30 A | 2009-03-06 A | 100% | 2008-05-30 | 2009-03-06 | 201d? | finish no earlier than 2009-03-06 | C1 | 1608h | 1608h | IWLAN_Mob | Orange | reina.nader@orange-ftgroup.com | Rel-8 | Frederic | PCG-21 | 24.303, new 24.327 | CP-40 |  |  |
| 1065 | 343 | Conformance Test Aspects – Mobility between 3GPP WLAN Interworking and 3GPP Systems |  | 206d? | 2009-12-04 A | 2010-09-17 A | 100% | 2009-12-04 | 2010-09-17 | 206d? | finish no earlier than 2010-09-17 | R5 | 1648h | 1648h | IWLAN_Mob_UEConTest | Qualcomm | Patrick Stupar (pstupar@qualcomm.com) | Rel-8 | Ingbert | PCG-24 | 34.108, 34.123-1, 34.123-2, 34.123-3 | RP-46 | RP-100740 |  |
| 1066 | 344 | **Enhancements for Voice Group Call Service (VGCS) Applications (EVA)** |  | 919d? | 2006-03-15 A | 2009-09-18 A | 100% | 2006-03-15 | 2009-09-18 | 919d? |  | S1,C1,C4,G2 | 23503.5h | 23503.5h | EVA | Nortel | Amar Deol (deola@nortelnetworks.com) | Rel-8 | Alain |  |  |  |  |  |
| 1067 | 344.1 | SA1 aspects of EVA |  | 191d? | 2006-03-15 A | 2006-12-06 A | 100% | 2006-03-15 | 2006-12-06 | 191d? | finish no earlier than 2006-12-06 | S1 | 1528h | 1528h | EVA | Nortel | Amar Deol (deola@nortelnetworks.com) | Rel-8 | Alain |  | 42.068 |  |  |  |
| 1068 | 344.2 | VGCS/VBS and GPRS Interactions |  | 145d? | 2007-09-03 A | 2008-03-21 A | 100% | 2007-09-03 | 2008-03-21 | 145d? | finish no earlier than 2008-03-21 | S1 | 1160h | 1160h | EVA | Huawei | Ling Liu | Rel-8 | Alain |  | 42.068, 42.069 | SP-37 |  |  |
| 1069 | 344.3 | CT1 aspects of EVA |  | 862d? | 2006-06-02 A | 2009-09-18 A | 100% | 2006-06-02 | 2009-09-18 | 862d? | finish no earlier than 2009-12-04 | C1 | 6887.53h | 6887.53h | EVA | Nortel | milanpa@nortel.com | Rel-8 | Frederic |  | 43.068, 44.068 |  |  |  |
| 1070 | 344.4 | CT4 aspects of EVA |  | 391d? | 2006-06-02 A | 2007-11-30 A | 100% | 2006-06-02 | 2007-11-30 | 391d? | finish no earlier than 2007-06-01 | C4 | 3128h | 3128h | EVA | Nortel |  | Rel-8 | Kimmo |  | 29.002 |  |  |  |
| 1071 | 344.5 | GERAN2 aspects of EVA |  | 431d? | 2006-06-30 A | 2008-02-22 A | 100% | 2006-06-30 | 2008-02-22 | 431d? | finish no earlier than 2008-02-22 | G2 | 3448h | 3448h | EVA | Nortel | frank.billenkamp@nortel.com | Rel-8 | Gert |  | 44.018, 48.008 |  |  |  |
| 1072 | 345 | **Personal Network Management** |  | 955d? | 2005-07-11 A | 2009-03-06 A | 100% | 2005-07-11 | 2009-03-06 | 955d? |  | S1,C1,S3 | 27008h | 27008h | PNM | Vodafone | armin.toepfer@vodafone.com | Rel-8 | Alain |  |  |  |  |  |
| 1073 | 345.1 | Stage 1 for PNM |  | 276d? | 2005-07-11 A | 2006-07-31 A | 100% | 2005-07-11 | 2006-07-31 | 276d? | start no earlier than 2005-07-11 | S1 | 2208h | 2208h | PNM | Vodafone | armin.toepfer@vodafone.com | Rel-8 | Alain |  | 22.259 |  |  |  |
| 1074 | 345.2 | Stage 2 for PNM |  | 445d? | 2007-03-26 A | 2008-12-05 A | 100% | 2007-03-26 | 2008-12-05 | 445d? | finish no earlier than 2008-12-05 | C1 | 3560h | 3560h | PNM | Vodafone | yang.lu@vodafone.com | Rel-8 | Frederic |  | 23.259 |  |  |  |
| 1075 | 345.3 | **Stage 3 for PNM** |  | 510d? | 2007-03-26 A | 2009-03-06 A | 100% | 2007-03-26 | 2009-03-06 | 510d? |  | C1,C4 | 11720h | 11720h | PNM | Vodafone | yang.lu@vodafone.com | Rel-8 | Frederic |  |  |  |  |  |
| 1076 | 345.3.1 | CT1 aspects of Stage 3 PNM |  | 510d? | 2007-03-26 A | 2009-03-06 A | 100% | 2007-03-26 | 2009-03-06 | 510d? | finish no earlier than 2008-12-05 | C1 | 4080h | 4080h | PNM | Vodafone | yang.lu@vodafone.com | Rel-8 | Frederic |  | 24.259, 24.229 |  |  |  |
| 1077 | 345.3.2 | Deleted - CT4 aspects of Stage 3 PNM |  | 445d? | 2007-03-26 A | 2008-12-05 A | 100% | 2007-03-26 | 2008-12-05 | 445d? | finish no earlier than 2008-12-11 | C4 | 3560h | 3560h | PNM | Vodafone | yang.lu@vodafone.com | Rel-8 | Kimmo |  |  |  |  | CP-42 |
| 1078 | 345.4 | Key establishment between a UICC hosting device and a remote device |  | 235d? | 2006-12-06 A | 2007-10-30 A | 100% | 2006-12-06 | 2007-10-30 | 235d? | finish no earlier than 2007-10-30 | S3 | 1880h | 1880h | PNM | Ericsson | Vesa.Lehtovirta@ericsson.com | Rel-8 | Dionisio |  | 33.259 |  |  |  |
| 1079 | 345.5 | Deleted - Actual Requirements of PNM | milestone | 0d? | 2007-03-26 A | 2007-03-26 A | 100% | 2007-03-26 | 2007-03-26 | 0d? | finish no earlier than 2007-03-26 | C1 |  |  | PNM | Ericsson |  | Rel-8 | Frederic |  |  |  |  | SP-37 |
| 1080 | 346 | **eCall Data Transfer** |  | 637d? | 2006-09-28 A | 2009-03-06 A | 100% | 2006-09-28 | 2009-03-06 | 637d? |  | S1,C1 | 9744h | 9744h | EData | Airbiquity | rrobinson@airbiquity.com | Rel-8 | Alain |  |  |  |  |  |
| 1081 | 346.1 | eData Requirements |  | 380d? | 2006-09-28 A | 2008-03-12 A | 100% | 2006-09-28 | 2008-03-12 | 380d? | finish no earlier than 2006-12-07 | S1 | 3040h | 3040h | EData | Airbiquity | rrobinson@airbiquity.com | Rel-8 | Alain |  | 22.101, 22.105 | SP-37 |  |  |
| 1082 | 346.2 | Transfer of data during an emergency call |  | 201d? | 2008-05-30 A | 2009-03-06 A | 100% | 2008-05-30 | 2009-03-06 | 201d? | finish no earlier than 2009-03-06 | C1 | 1608h | 1608h | EData | T-Mobile | Dieter Jacobsohn | Rel-8 | Frederic | PCG-21 | 24.008 | SP-40 |  |  |
| 1083 | 347 | eCall data transfer Phase 2: Comparison of alternative in-band modem solutions and standardization of one in-band modem solution |  | 472d? | 2007-12-06 A | 2009-09-24 A | 100% | 2007-12-06 | 2009-09-24 | 472d? | finish no earlier than 2009-09-24 | S4 | 3768.09h | 3768.09h | eCall_Phase2 | Airbiquity | lhong@airbiquity.com & rrobinson@airbiquity.com | Rel-8 | Paolo |  | 26.267, 26.268, 26.269, 26.967, 26.969 |  |  |  |
| 1084 | 348 | eCall Conformance Testing |  | 261d? | 2009-09-04 A | 2010-09-03 A | 100% | 2009-09-04 | 2010-09-03 | 261d? | finish no earlier than 2010-09-03 | G3new | 2088h | 2088h | eCall_MSTest | Ericsson, Qualcomm | Vikrant Jain (vikrantj@qualcomm.com) | Rel-8 | Ingbert | PCG-23 | 51.010-1, 51.010-2 | GP-45 |  |  |
| 1085 | 349 | Conformance Test Aspects – non-modem procedures of eCall sessions in UTRA |  | 186d? | 2009-09-18 A | 2010-06-04 A | 100% | 2009-09-18 | 2010-06-04 | 186d? | finish no earlier than 2010-06-04 | R5 | 1488h | 1488h | UMTS_eCall_UEConTest | Ericsson, Qualcomm | Shubhang Vora (svora@qualcomm.com) | Rel-8 | Ingbert | PCG-23 | 34.108, 34.123-1, 34.123-2, 34.123-3 | RP-45 | RP-100489 |  |

Notes:
- 1058: CP#43 completed
- 1059: SP#36 completed
- 1060: CP#43 completed
- 1061: CP#42 completed
- 1062: CP#43 completed
- 1063: SP#40 completed
- 1064: CP#43 completed
- 1065: RP#49 completed. Testing for Rel-8 UID_400013 CT1 aspects of mobility between 3GPP WLAN Interworking and 3GPP Systems (24.327)
- 1066: CP#45 completed
- 1067: SP#38 completed
- 1068: SP#39 completed
- 1069: CP#45 completed
- 1070: CP#38 completed
- 1071: GP#37 completed
- 1072: CP#43 completed
- 1073: SP#31 completed
- 1074: CP#42 completed
- 1075: CP#43 completed
- 1076: CP#43 completed
- 1077: CP#42 no impact on CT4 specs
- 1078: SP#37 completed
- 1079: SP#37 stopped
- 1080: SP#39 completed. Linked to SA4 Feature UID_34042 (eCall_Phase2)
- 1081: SP#39 completed
- 1082: CP#43 completed
- 1083: SP#45 completed. Triggered by Study UID_360015 (eCALLIBMS). Linked to SA1 Feature UID_330005 (EData)
- 1084: GP#47 completed. GP#43 WID approved. Testing for Rel-8 eCall_Phase2 (UID_34042) and EData (UID_330005)
- 1085: RP#48 completed. Testing for Rel-8 eCall_Phase2 (UID_34042) and Edata (UID_330005)

| ID | WBS | Task | Type | Duration | Start | Finish | Complete | Baseline start | Baseline finish | Baseline duration | Constraint | Resources | Work | Actual work | Text1 | Text2 | Text4 | Text5 | Text6 | Text7 | Text8 | Text3 | Text12 | Text11 |
| --- | --- | --- | --- | --- | --- | --- | --- | --- | --- | --- | --- | --- | --- | --- | --- | --- | --- | --- | --- | --- | --- | --- | --- | --- |
| 1086 | 350 | **IP Interconnection of Services** |  | 668d? | 2006-08-16 A | 2009-03-06 A | 100% | 2006-08-16 | 2009-03-06 | 668d? |  | S1,S2,S5,C3 | 17520h | 17520h | IPinterc | PCG-21 | Telefónica O2 | chris.friel@O2.com | Rel-8 | SP-38 | Alain |  |  |  |
| 1087 | 350.1 | Stage 1 for IPinterc |  | 70d? | 2007-12-06 A | 2008-03-12 A | 100% | 2007-12-06 | 2008-03-12 | 70d? | start no earlier than 2007-12-06 | S1 | 560h | 560h | IPinterc | PCG-21 | Telefónica O2 | chris.friel@O2.com | Rel-8 | SP-38 | Alain | 22.101, 22.228 |  |  |
| 1088 | 350.2 | **System enhancements for interconnection interfaces between two IMSs** |  | 668d? | 2006-08-16 A | 2009-03-06 A | 100% | 2006-08-16 | 2009-03-06 | 668d? |  | S2,S5,C3 | 11616h | 11616h | IMS_NNI |  | Telecom Italia | Mario Madella (mario.madella@telecomitalia.it) | Rel-8 |  | Maurice |  |  |  |
| 1089 | 350.2.1 | Stage 2 for IMS_NNI |  | 120d? | 2007-06-22 A | 2007-12-06 A | 100% | 2007-06-22 | 2007-12-06 | 120d? | finish no earlier than 2007-12-21 | S2 | 960h | 960h | IMS_NNI |  | Telecom Italia | Mario Madella (mario.madella@telecomitalia.it) | Rel-8 |  | Maurice | 23.002, 23.228 |  |  |
| 1090 | 350.2.2 | IMS inter-operator service interconnection interface |  | 461d? | 2007-06-01 A | 2009-03-06 A | 100% | 2007-06-01 | 2009-03-06 | 461d? | finish no earlier than 2009-03-06 | C3 | 3688h | 3688h | FBI2-IOPSI |  | Telecom Italia | antonio.ascolese@telecomitalia.it | Rel-8 |  | Jiwan | 29.865, 29.165 |  |  |
| 1091 | 350.2.3 | Charging harmonization for NGN between 3GPP and ATIS-TMOC |  | 51d? | 2006-09-28 A | 2006-12-07 A | 100% | 2006-09-28 | 2006-12-07 | 51d? | finish no earlier than 2006-12-07 | S5 | 408h | 408h | FBI2-TISP2-CH |  | Amdocs | yishai.brown@amdocs.com | Rel-8 |  | Dionisio | 32.297 |  |  |
| 1092 | 350.2.4 | Deleted - Protocol impact of FBI for TISPAN R2 |  | 152d? | 2006-08-16 A | 2007-03-15 A | 100% | 2006-08-16 | 2007-03-15 | 152d? | finish no earlier than 2007-03-15 | C1 | 1216h | 1216h | FBI2-TISP2-c1 |  | Ericsson |  | Rel-8 |  | Frederic |  | SP-38 |  |
| 1093 | 350.2.5 | Deleted (never approved) - Stage 2 of FBI for TISPAN R2 - Rel 8 | milestone | 0d? | 2007-11-30 A | 2007-11-30 A | 100% | 2007-11-30 | 2007-11-30 | 0d? | finish no earlier than 2007-11-30 | S2 |  |  | FBI2-TISP2-s2 |  | Nokia Siemens Networks |  | Rel-8 |  | Maurice |  | SP-36 |  |
| 1094 | 351 | **Support of (G)MSC-S – (G)MSC-S Nc Interface based on the SIP-I protocol** |  | 386d? | 2007-09-14 A | 2009-03-06 A | 100% | 2007-09-14 | 2009-03-06 | 386d? |  | C4,C3 | 11872h | 11872h | SIP_Nc |  | Vodafone | David.Hutton@vodafone.com | Rel-8 |  | Kimmo |  |  |  |
| 1095 | 351.1 | Stage 1 for SIP_Nc (covered by Feature IPinterc) |  | 70d? | 2007-12-06 A | 2008-03-12 A | 100% | 2007-12-06 | 2008-03-12 | 70d? | start no earlier than 2007-12-06 | S1 | 560h | 560h | IPinterc | PCG-21 | Telefónica O2 | chris.friel@O2.com | Rel-8 | CP-41 | Alain | 22.101, 22.228 |  |  |
| 1096 | 351.2 | SIP-I based circuit-switched core network; Stage 2 |  | 321d? | 2007-09-14 A | 2008-12-05 A | 100% | 2007-09-14 | 2008-12-05 | 321d? | finish no earlier than 2008-12-11 | C4 | 2568h | 2568h | SIP_Nc-St2 |  | Vodafone | David.Hutton@vodafone.com | Rel-8 |  | Kimmo | 23.231, 23.153, 23.205 |  |  |
| 1097 | 351.3 | Application of SIP-I Protocols to Circuit Switched (CS) core network architecture; Stage 3 |  | 321d? | 2007-09-14 A | 2008-12-05 A | 100% | 2007-09-14 | 2008-12-05 | 321d? | finish no earlier than 2008-12-11 | C4 | 2568h | 2568h | SIP_Nc-St3 |  | Vodafone | David.Hutton@vodafone.com | Rel-8 |  | Kimmo | 29.231, 29.232, 29.332 |  |  |
| 1098 | 351.4 | Interworking between the 3GPP CS domain with SIP-I as signalling protocol and other networks |  | 386d? | 2007-09-14 A | 2009-03-06 A | 100% | 2007-09-14 | 2009-03-06 | 386d? | finish no earlier than 2009-03-06 | C3 | 3088h | 3088h | SIP_Nc |  | Nokia Siemens Networks | Thomas.Belling@nsn.com | Rel-8 |  | Jiwan | 29.235, 23.172, 23.202, 29.007, 29.163, 29.414 |  |  |
| 1099 | 352 | **Earthquake and Tsunami Warning System** |  | 440d? | 2007-09-10 A | 2009-05-15 A | 100% | 2007-09-10 | 2009-05-15 | 440d? |  | S1,S2,C1,C4,G2 | 7200h | 7200h | ETWS |  | NTT DoCoMo | kitaharar@nttdocomo.co.jp | Rel-8 | SP-37 | Alain |  |  |  |
| 1100 | 352.1 | Stage 1 for ETWS |  | 133d? | 2007-09-10 A | 2008-03-12 A | 100% | 2007-09-10 | 2008-03-12 | 133d? | finish no earlier than 2008-03-12 | S1 | 1064h | 1064h | ETWS |  | NTT DoCoMo | kitaharar@nttdocomo.co.jp | Rel-8 | SP-37 | Alain | 22.168 |  |  |
| 1101 | 352.2 | SA2 aspects of ETWS |  | 179d? | 2008-01-14 A | 2008-09-18 A | 100% | 2008-01-14 | 2008-09-18 | 179d? | finish no earlier than 2008-09-08 | S2 | 1432h | 1432h | ETWS | PCG-21 | NTT DoCoMo | tanakai@nttdocomo.co.jp | Rel-8 | SP-38 | Maurice | 23.828, 23.401 |  |  |
| 1102 | 352.3 | CT1 aspects of ETWS |  | 50.5d? | 2008-05-30 A | 2008-12-05 A | 100% | 2008-05-30 | 2008-12-05 | 50.5d? | finish no earlier than 2008-12-05 | C1 | 404h | 404h | ETWS | PCG-21 | NTT DoCoMo | yamashitahi@s1.nttdocomo.co.jp | Rel-8 | CP-40 | Frederic | 23.041 |  |  |
| 1103 | 352.4 | CT4 aspects of ETWS |  | 50.5d? | 2008-09-26 A | 2008-12-05 A | 100% | 2008-09-26 | 2008-12-05 | 50.5d? | finish no earlier than 2008-12-05 | C4 | 404h | 404h | ETWS | PCG-21 | NTT DoCoMo | yamashitahi@s1.nttdocomo.co.jp | Rel-8 | CP-40 | Kimmo | 29.168 |  |  |
| 1104 | 352.5 | ETWS primary notification message definition in GERAN |  | 47d? | 2009-03-12 A | 2009-05-15 A | 100% | 2009-03-12 | 2009-05-15 | 47d? | finish no earlier than 2009-05-15 | G2 | 376h | 376h | ETWS | PCG-22 | Ericsson | claes-goran.persson@ericsson.com | Rel-8 | SP-43 | Gert | 44.018, 44.060 |  |  |
| 1105 | 353 | Conformance Test Aspects – UMTS Earthquake and Tsunami Warning System (ETWS) FDD |  | 207d? | 2009-05-29 A | 2010-03-12 A | 100% | 2009-05-29 | 2010-03-12 | 207d? | finish no earlier than 2010-03-12 | R5 | 1656h | 1656h | ETWS_UMTS_UEConTestFDD | PCG-23 | NTT DoCoMo | Makoto Ito (itohm@nttdocomo.co.jp) | Rel-8 | RP-44 | Ingbert | 34.108, 34.123-1, 34.123-2 |  | RP-100068 |
| 1106 | 354 | **In Case of Emergency numbers storage and easy access on UICC** |  | 519d? | 2007-03-13 A | 2009-03-06 A | 100% | 2007-03-13 | 2009-03-06 | 519d? |  | S1,C6 | 8864h | 8864h | ICE | PCG-21 | Vodafone | armin.toepfer@vodafone.com | Rel-8 | SP-38 | Alain |  |  |  |
| 1107 | 354.1 | Stage 1 for ICE |  | 262d? | 2007-03-13 A | 2008-03-12 A | 100% | 2007-03-13 | 2008-03-12 | 262d? | finish no earlier than 2008-03-12 | S1 | 2096h | 2096h | ICE | PCG-21 | Vodafone | armin.toepfer@vodafone.com | Rel-8 | SP-38 | Alain | 22.030, 22.101 |  |  |
| 1108 | 354.2 | CT6 aspects of ICE |  | 519d? | 2007-03-13 A | 2009-03-06 A | 100% | 2007-03-13 | 2009-03-06 | 519d? | finish no earlier than 2009-03-06 | C6 | 4152h | 4152h | ICE | PCG-21 | Vodafone | armin.toepfer@vodafone.com | Rel-8 | SP-38 | Xavier | 31.102 |  |  |
| 1109 | 355 | Local Charging Zone Requirements |  | 380d? | 2006-09-28 A | 2008-03-12 A | 100% | 2006-09-28 | 2008-03-12 | 380d? | finish no earlier than 2006-12-07 | S1 | 3040h | 3040h | LCZR |  | China Mobile | liuhongyfw@chinamobile.com | Rel-8 |  | Alain | 22.115 |  |  |

Notes:
- 1086: SP#43 completed
- 1087: SP#39 completed.
- 1088: CP#43 completed
- 1089: SP#38 completed
- 1090: CP#43 completed
- 1091: SP#34 completed
- 1092: SP#38 stopped
- 1093: SP#36 stopped
- 1094: CP#43 completed. Stage 1 in Feature UID_380060 (IPinterc). CP#40 updated WID CP-070517=>CP-080282
- 1095: 22/07/08 Created. Stage 1 for SIP_Nc (covered by SA1 Feature UID_380060 Ipinterc)
- 1096: CP#42 completed
- 1097: CP#42 completed
- 1098: CP#43 completed. CP#42 target 12/08=>03/09
- 1099: SP#43 Larger scope Feature UID_380057 (PWS) moved to Rel-9
- 1100: SP#39 completed
- 1101: SP#41 completed
- 1102: CP#42 completed
- 1103: CP#42 completed
- 1104: SP#44 completed with CT1 help (GERAN2 LS_in SP-090154)
- 1105: RP#47 completed. Testing for Rel-8 ETWS UID_370051
- 1106: CP#43 completed (ICE Graphics not included in Rel-8)
- 1107: SP#39 Stage 1 completed
- 1108: CP#43 completed (ICE Graphics not in Rel-8 / not explicitly in SA1 WID either)
- 1109: SP#39 Stage 1 completed

| ID | WBS | Task | Type | Duration | Start | Finish | Complete | Baseline start | Baseline finish | Baseline duration | Constraint | Resources | Work | Actual work | Text1 | Text4 | Text5 | Text6 | Text8 | Text3 | Text7 | Text2 | Text9 | Text12 |
| --- | --- | --- | --- | --- | --- | --- | --- | --- | --- | --- | --- | --- | --- | --- | --- | --- | --- | --- | --- | --- | --- | --- | --- | --- |
| 1110 | 356 | **Customized Alerting Tone (CAT) service** |  | 729d? | 2006-12-06 A | 2009-09-18 A | 100% | 2006-12-06 | 2009-09-18 | 729d? |  | S1,C1,C3,C4 | 12302h | 12302h | CAT | China Mobile | fenglingjuan@chinamobile.com | Rel-8 | Alain |  |  |  |  |  |
| 1111 | 356.1 | Stage 1 for CAT |  | 207d? | 2006-12-06 A | 2007-09-20 A | 100% | 2006-12-06 | 2007-09-20 | 207d? | start no earlier than 2006-12-06 | S1 | 1656h | 1656h | CAT | China Mobile | fenglingjuan@chinamobile.com | Rel-8 | Alain | 22.182 | SP-37 |  |  |  |
| 1112 | 356.2 | TISPAN requirements for customized multimedia information services |  | 71d? | 2007-09-03 A | 2007-12-10 A | 100% | 2007-09-03 | 2007-12-10 | 71d? | finish no earlier than 2007-12-10 | S1 | 568h | 568h | TISCMI | China Mobile | fenglingjuan@chinamobile.com | Rel-8 | Alain | 22.182 | SP-37 |  |  |  |
| 1113 | 356.3 | IMS CAT Supplementary Service |  | 164d? | 2008-04-21 A | 2008-12-04 A | 100% | 2008-04-21 | 2008-12-04 | 164d? | finish no earlier than 2008-12-05 | C1 | 1312h | 1312h | CAT-SS | Nortel | milanpa@nortel.com | Rel-8 | Frederic | 24.182 | CP-39 | PCG-21 |  |  |
| 1114 | 356.4 | CAT solution for voice and video call in CS domain |  | 389.8d? | 2008-03-12 A | 2009-09-18 A | 100% | 2008-03-12 | 2009-09-18 | 389.8d? | finish no earlier than 2009-09-11 | C3 | 3118.4h | 3118.4h | CAT-SS | Nortel | milanpa@nortel.com | Rel-8 | Jiwan | 29.163 | CP-39 | PCG-21 |  |  |
| 1115 | 356.5 | CAT Service in 3GPP CS domain |  | 126d? | 2008-09-12 A | 2009-03-06 A | 100% | 2008-09-12 | 2009-03-06 | 126d? | finish no earlier than 2009-03-06 | C4 | 1008h | 1008h | CAT-3G_CS | China Mobile | zhaoyuyi@chinamobile.com | Rel-8 | Kimmo | 23.205, 23.231, 29.002 | CP-41 | PCG-21 |  |  |
| 1116 | 356.6 | CAT Service in 3GPP CS domain |  | 57.95d? | 2008-09-12 A | 2008-12-05 A | 100% | 2008-09-12 | 2008-12-05 | 57.95d? | start no earlier than 2008-09-12 | C1 | 463.6h | 463.6h | CAT-3G_CS | China Mobile | zhaoyuyi@chinamobile.com | Rel-8 | Frederic | 24.008, 23.014 | CP-41 | PCG-21 |  |  |
| 1117 | 357 | **Service-Level Interworking for Messaging Services** |  | 509d? | 2007-03-26 A | 2009-03-06 A | 100% | 2007-03-26 | 2009-03-06 | 509d? |  | S1,S2,C3,C1 | 8584h | 8584h | MESSIW | Huawei | ling.liu@huawei.com; duanxiaoqin@huawei.com | Rel-8 | Alain |  |  |  |  |  |
| 1118 | 357.1 | Stage 1 for MESSIW | milestone | 0d? | 2007-03-26 A | 2007-03-26 A | 100% | 2007-03-26 | 2007-03-26 | 0d? | finish no earlier than 2007-12-01 | S1 |  |  | MESSIW | Huawei | ling.liu@huawei.com | Rel-8 | Alain | 22.105, 22.340 |  |  |  |  |
| 1119 | 357.2 | Stage 2 for MESSIW |  | 227d? | 2007-04-26 A | 2008-03-07 A | 100% | 2007-04-26 | 2008-03-07 | 227d? | finish no earlier than 2008-03-07 | S2 | 1816h | 1816h | MESSIW | Huawei | patrice.hede@huawei.com | Rel-8 | Maurice | 23.811, 23.204 |  |  |  |  |
| 1120 | 357.3 | Stage 3 for MESSIW |  | 201d? | 2008-05-30 A | 2009-03-06 A | 100% | 2008-05-30 | 2009-03-06 | 201d? | finish no earlier than 2008-12-05 | C3 | 1608h | 1608h | MESSIW | Huawei | xupeili@huawei.com | Rel-8 | Jiwan | 29.311 | CP-40 | PCG-21 |  |  |
| 1121 | 357.4 | Stage 3 for MESSIW |  | 136d? | 2008-05-30 A | 2008-12-05 A | 100% | 2008-05-30 | 2008-12-05 | 136d? | finish no earlier than 2008-12-12 | C1 | 1088h | 1088h | MESSIW | Huawei | xupeili@huawei.com | Rel-8 | Frederic | 24.229 | CP-40 | PCG-21 |  |  |
| 1122 | 358 | **Multimedia Priority Service** |  | 858d? | 2006-06-08 A | 2009-09-18 A | 100% | 2006-06-08 | 2009-09-18 | 858d? |  | S1,C1,C3,C4 | 22424h | 22424h | PRIOR | Telcordia | jgarraha@telcordia.com | Rel-8 | Alain |  | SP-34 |  |  |  |
| 1123 | 358.1 | Service Requirements for PRIOR |  | 391d? | 2006-06-08 A | 2007-12-06 A | 100% | 2006-06-08 | 2007-12-06 | 391d? | finish no earlier than 2007-11-30 | S1 | 3128h | 3128h | PRIOR-EMR | Telcordia | jgarraha@telcordia.com | Rel-8 | Alain | 22.153 | SP-32 |  |  |  |
| 1124 | 358.2 | Stage 3 for PRIOR |  | 732d? | 2006-12-01 A | 2009-09-18 A | 100% | 2006-12-01 | 2009-09-18 | 732d? | finish no earlier than 2009-09-18 | C1 | 5856h | 5856h | PRIOR | Alcatel-Lucent | Keith Drage (drage@alcatel-lucent.com) | Rel-8 | Frederic | 24.229 | CP-34 |  |  |  |
| 1125 | 358.3 | Stage 3 for PRIOR |  | 381d? | 2007-09-21 A | 2009-03-06 A | 100% | 2007-09-21 | 2009-03-06 | 381d? | finish no earlier than 2009-03-06 | C4 | 3048h | 3048h | PRIOR | Alcatel-Lucent | Keith Drage (drage@alcatel-lucent.com) | Rel-8 | Kimmo | 23.008, 29.228, 29.229 | CP-37 |  |  |  |
| 1126 | 358.4 | Deleted - Stage 3 for PRIOR |  | 441d? | 2007-09-21 A | 2009-05-29 A | 100% | 2007-09-21 | 2009-05-29 | 441d? | finish no earlier than 2009-05-29 | C3 | 3528h | 3528h | PRIOR | Alcatel-Lucent | Keith Drage (drage@alcatel-lucent.com) | Rel-8 | Jiwan | 29.212, 29.213, 29.214, 29.163 | CP-37 |  | PCG-23 | CP-44 |
| 1127 | 359 | **OSA Rel-8** |  | 202d? | 2007-08-23 A | 2008-05-30 A | 100% | 2007-08-23 | 2008-05-30 | 202d? |  | S1,C5 | 23552h | 23552h | OSA8 | Orange | Song Dong | Rel-8 | Alain |  |  |  |  |  |
| 1128 | 359.1 | OSA Stage 1 - Service Requirements |  | 145d? | 2007-08-23 A | 2008-03-12 A | 100% | 2007-08-23 | 2008-03-12 | 145d? | finish no earlier than 2007-12-04 | S1 | 1160h | 1160h | OSA8 | Orange, AePONA | Song Dong | Rel-8 | Alain | 22.127 |  |  |  |  |
| 1129 | 359.2 | OSA Stage 1 - NGN Service Requirement |  | 140d? | 2007-09-03 A | 2008-03-14 A | 100% | 2007-09-03 | 2008-03-14 | 140d? | finish no earlier than 2008-03-14 | S1 | 1120h | 1120h | OSA8-IMS | Orange | Song Dong | Rel-8 | Alain | 22.127 | SP-37 |  |  |  |
| 1130 | 359.3 | **OSA Stage 2/3 enhancements** |  | 157d? | 2007-10-25 A | 2008-05-30 A | 100% | 2007-10-25 | 2008-05-30 | 157d? |  | C5 | 20016h | 20016h | OSA8 | Alcatel-Lucent | unmehopa@alcatel-lucent.com | Rel-8 | Kimmo | 23.198, 29.198, 29.199 |  |  |  |  |
| 1131 | 359.3.1 | Deleted - Ensure Parlay-X composable with identity management frameworks, in particular Liberty Alliance |  | 157d? | 2007-10-25 A | 2008-05-30 A | 100% | 2007-10-25 | 2008-05-30 | 157d? | finish no earlier than 2008-12-25 | C5 | 1256h | 1256h | OSA8 | Ericsson | catherine.mulligan@ericsson.com | Rel-8 | Kimmo | existing 29.199-xy | CP-37 | PCG-21 | PCG-21 | CP-40 |
| 1132 | 359.3.2 | Parlay-X Content Management web service (store/manage meta-data) |  | 157d? | 2007-10-25 A | 2008-05-30 A | 100% | 2007-10-25 | 2008-05-30 | 157d? | finish no earlier than 2008-12-04 | C5 | 1256h | 1256h | OSA8 | Alcatel-Lucent | unmehopa@alcatel-lucent.com | Rel-8 | Kimmo | 29.199-21 | CP-37 |  |  |  |
| 1133 | 359.3.3 | Parlay-X Policy web service |  | 157d? | 2007-10-25 A | 2008-05-30 A | 100% | 2007-10-25 | 2008-05-30 | 157d? | finish no earlier than 2008-12-04 | C5 | 1256h | 1256h | OSA8 | Alcatel-Lucent | unmehopa@alcatel-lucent.com | Rel-8 | Kimmo | 29.199-22 | CP-37 |  |  |  |
| 1134 | 359.3.4 | Parlay-X Terminal status web service |  | 157d? | 2007-10-25 A | 2008-05-30 A | 100% | 2007-10-25 | 2008-05-30 | 157d? | finish no earlier than 2008-05-30 | C5 | 1256h | 1256h | OSA8 | Alcatel-Lucent | unmehopa@alcatel-lucent.com | Rel-8 | Kimmo | 29.199-08 | CP-37 |  |  |  |
| 1135 | 359.3.5 | Deleted - Identify communication format used by a particular application |  | 157d? | 2007-10-25 A | 2008-05-30 A | 100% | 2007-10-25 | 2008-05-30 | 157d? | finish no earlier than 2008-05-30 | C5 | 1256h | 1256h | OSA8 | Ericsson | catherine.mulligan@ericsson.com | Rel-8 | Kimmo | existing 29.199-xy | CP-37 | PCG-21 | PCG-21 | CP-40 |
| 1136 | 359.3.6 | Deleted - Security on User Profile Management - reuse GUP API (22.127 CR 0084 S1-071794) |  | 128d? | 2007-12-05 A | 2008-05-30 A | 100% | 2007-12-05 | 2008-05-30 | 128d? | finish no earlier than 2008-12-25 | C5 | 1024h | 1024h | OSA8 | Telecom Italia | vincenzo.amorino@telecomitalia.it | Rel-8 | Kimmo | PXWS Framework | CP-38 | PCG-21 | PCG-21 | CP-40 |
| 1137 | 359.3.7 | Deleted - Privacy on Subscriber Identity (Liberty Alliance, OASIS) (22.127 CR 0085 S1-071835) |  | 128d? | 2007-12-05 A | 2008-05-30 A | 100% | 2007-12-05 | 2008-05-30 | 128d? | finish no earlier than 2008-12-25 | C5 | 1024h | 1024h | OSA8 | Telecom Italia | vincenzo.amorino@telecomitalia.it | Rel-8 | Kimmo | PXWS Framework | CP-38 | PCG-21 | PCG-21 | CP-40 |
| 1138 | 359.3.8 | Deleted - Topology Hiding (22.127 CR 0086 S1-071838) |  | 128d? | 2007-12-05 A | 2008-05-30 A | 100% | 2007-12-05 | 2008-05-30 | 128d? | finish no earlier than 2008-12-25 | C5 | 1024h | 1024h | OSA8 | Telecom Italia | vincenzo.amorino@telecomitalia.it | Rel-8 | Kimmo | PXWS Framework | CP-38 | PCG-21 | PCG-21 | CP-40 |
| 1139 | 359.3.9 | Deleted - Subscriber event notification (22.127 CR 0087 S1-071836) |  | 128d? | 2007-12-05 A | 2008-05-30 A | 100% | 2007-12-05 | 2008-05-30 | 128d? | finish no earlier than 2008-12-25 | C5 | 1024h | 1024h | OSA8 | Telecom Italia | vincenzo.amorino@telecomitalia.it | Rel-8 | Kimmo | PXWS Framework | CP-38 | PCG-21 | PCG-21 | CP-40 |
| 1140 | 359.3.10 | Deleted - Event notification (22.127 CR 0088 S1-071762) |  | 128d? | 2007-12-05 A | 2008-05-30 A | 100% | 2007-12-05 | 2008-05-30 | 128d? | finish no earlier than 2008-12-25 | C5 | 1024h | 1024h | OSA8 | Telecom Italia | vincenzo.amorino@telecomitalia.it | Rel-8 | Kimmo | PXWS Framework | CP-38 | PCG-21 | PCG-21 | CP-40 |
| 1141 | 359.3.11 | Deleted - Access policy (22.127 CR 0089 S1-071763) |  | 128d? | 2007-12-05 A | 2008-05-30 A | 100% | 2007-12-05 | 2008-05-30 | 128d? | finish no earlier than 2008-12-25 | C5 | 1024h | 1024h | OSA8 | Telecom Italia | vincenzo.amorino@telecomitalia.it | Rel-8 | Kimmo | PXWS Framework | CP-38 | PCG-21 | PCG-21 | CP-40 |
| 1142 | 359.3.12 | Deleted - API usage accounting (22.127 CR 0090 S1-071792) |  | 128d? | 2007-12-05 A | 2008-05-30 A | 100% | 2007-12-05 | 2008-05-30 | 128d? | finish no earlier than 2008-12-25 | C5 | 1024h | 1024h | OSA8 | Telecom Italia | vincenzo.amorino@telecomitalia.it | Rel-8 | Kimmo | PXWS Framework | CP-38 | PCG-21 | PCG-21 | CP-40 |
| 1143 | 359.3.13 | Presence alignment with OMA and IETF (22.127 CR 0092 S1-071764) |  | 128d? | 2007-12-05 A | 2008-05-30 A | 100% | 2007-12-05 | 2008-05-30 | 128d? | finish no earlier than 2008-05-30 | C5 | 1024h | 1024h | OSA8 | Alcatel-Lucent | unmehopa@alcatel-lucent.com | Rel-8 | Kimmo | 29.199-14/13 | CP-38 | PCG-21 |  |  |
| 1144 | 359.3.14 | Deleted - Service identification (22.127 CR 0095 S1-071837) |  | 128d? | 2007-12-05 A | 2008-05-30 A | 100% | 2007-12-05 | 2008-05-30 | 128d? | finish no earlier than 2008-05-30 | C5 | 1024h | 1024h | OSA8 | Ericsson | catherine.mulligan@ericsson.com | Rel-8 | Kimmo | existing 29.199-xy | CP-38 | PCG-21 | PCG-21 | CP-40 |
| 1145 | 359.3.15 | Framework Enterprise Operator (Service Subscription function) |  | 102d? | 2008-01-10 A | 2008-05-30 A | 100% | 2008-01-10 | 2008-05-30 | 102d? | finish no earlier than 2008-05-30 | C5 | 816h | 816h | OSA8 | Alcatel-Lucent | unmehopa@alcatel-lucent.com | Rel-8 | Kimmo | 29.198-03 | CP-39 | PCG-21 |  |  |
| 1146 | 359.3.16 | Mobility Emergency Location |  | 102d? | 2008-01-10 A | 2008-05-30 A | 100% | 2008-01-10 | 2008-05-30 | 102d? | finish no earlier than 2008-05-30 | C5 | 816h | 816h | OSA8 | Alcatel-Lucent | unmehopa@alcatel-lucent.com | Rel-8 | Kimmo | 29.198-06 | CP-39 | PCG-21 |  |  |
| 1147 | 359.3.17 | Connectivity Manager SCF |  | 102d? | 2008-01-10 A | 2008-05-30 A | 100% | 2008-01-10 | 2008-05-30 | 102d? |  | C5 | 816h | 816h | OSA8 | Alcatel-Lucent | unmehopa@alcatel-lucent.com | Rel-8 | Kimmo | 29.198-10 | CP-39 | PCG-21 |  |  |
| 1148 | 359.3.18 | PAM Presence Agent |  | 102d? | 2008-01-10 A | 2008-05-30 A | 100% | 2008-01-10 | 2008-05-30 | 102d? | finish no earlier than 2008-05-30 | C5 | 816h | 816h | OSA8 | Alcatel-Lucent | unmehopa@alcatel-lucent.com | Rel-8 | Kimmo | 29.198-14 | CP-39 | PCG-21 |  |  |

Notes:
- 1110: CP#45 completed
- 1111: -
- 1112: SP#38 completed
- 1113: CP#42 completed
- 1114: CP#45 completed. Triggered by Study UID_360031 (TR 29.882)
- 1115: CP#43 completed. Triggered by Study UID_360031 (TR 29.882)
- 1116: CP#42 completed. Triggered by Study UID_360031 (TR 29.882)
- 1117: CP#43 completed
- 1118: SP#35 completed
- 1119: SP#39 completed
- 1120: CP#43 completed
- 1121: CP#42 completed
- 1122: CP#45 completed
- 1123: SP#38 completed
- 1124: CP#45 completed
- 1125: CP#43 completed
- 1126: CP#44 stopped (Reason: No Rel-8 solution expected (LS sent to SA2, but not prioritized in SA2)
- 1127: SP#40 maintenance & new OSA work moved to OMA. Rel-9 onwards 3GPP references to 22.127 changed to OMA Parlay Service Access Requirements (OMA-RD-Parlay_Service_Access-V1_0-20100427-A).
- 1128: SP#40 maintenance & new OSA work moved to OMA. Rel-9 onwards 3GPP references to 22.127 changed to OMA Parlay Service Access Requirements (OMA-RD-Parlay_Service_Access-V1_0-20100427-A).
- 1129: SP#40 maintenance & new OSA work moved to OMA
- 1130: SP#40 maintenance & new OSA work moved to OMA
- 1131: CP#40: Work moved to OMA
- 1132: CP#40 completed
- 1133: CP#40 completed
- 1134: CP#40 completed
- 1135: CP#40: Work moved to OMA
- 1136: SP#38 SP-070853 R8 CRs 22.127 OSA Stage 1. CP#40: Work moved to OMA
- 1137: SP#38 SP-070853 R8 CRs 22.127 OSA Stage 1. CP#40: Work moved to OMA
- 1138: SP#38 SP-070853 R8 CRs 22.127 OSA Stage 1. CP#40: Work moved to OMA
- 1139: SP#38 SP-070853 R8 CRs 22.127 OSA Stage 1. CP#40: Work moved to OMA
- 1140: SP#38 SP-070853 R8 CRs 22.127 OSA Stage 1. CP#40: Work moved to OMA
- 1141: SP#38 SP-070853 R8 CRs 22.127 OSA Stage 1. CP#40: Work moved to OMA
- 1142: SP#38 SP-070853 R8 CRs 22.127 OSA Stage 1. CP#40: Work moved to OMA
- 1143: CP#40 completed
- 1144: SP#38 SP-070853 R8 CRs 22.127 OSA Stage 1. CP#40: Work moved to OMA
- 1145: CP#40 completed
- 1146: CP#40 completed
- 1147: CP#40 completed
- 1148: CP#40 completed

| ID | WBS | Task | Duration | Start | Finish | Complete | Baseline start | Baseline finish | Baseline duration | Constraint | Resources | Work | Actual work | Text1 | Text4 | Text6 | Text8 | Text7 | Text2 | Text11 |
| --- | --- | --- | --- | --- | --- | --- | --- | --- | --- | --- | --- | --- | --- | --- | --- | --- | --- | --- | --- | --- |
| 1149 | 360 | **Paging Permission with Access Control (PPACR)** | 389d? | 2007-06-12 A | 2008-12-05 A | 100% | 2007-06-12 | 2008-12-05 | 389d? |  | S1,C1 | 5888h | 5888h | PPACR | NTT DoCoMo | Rel-8 | Alain |  |  |  |
| 1150 | 360.1 | Stage 1 for PPACR | 69d? | 2007-06-12 A | 2007-09-14 A | 100% | 2007-06-12 | 2007-09-14 | 69d? | finish no earlier than 2007-09-14 | S1 | 552h | 552h | PPACR-S1 | NTT DoCoMo | Rel-8 | Alain | SP-37 |  |  |
| 1151 | 360.2 | Stage 3 for PPACR (CT1) | 278d? | 2007-11-14 A | 2008-12-05 A | 100% | 2007-11-14 | 2008-12-05 | 278d? | finish no earlier than 2008-12-05 | C1 | 2224h | 2224h | PPACR-CT1 | NTT DoCoMo | Rel-8 | Frederic | CP-38 | PCG-21 |  |
| 1152 | 361 | Conformance Test Aspects – Paging Permission with Access Control (PPAC) | 61d? | 2010-09-17 A | 2010-12-10 A | 100% | 2010-09-17 | 2010-12-10 | 61d? | finish no earlier than 2010-12-10 | R5 | 488h | 488h | PPAC_UEConTest | NTT DoCoMo | Rel-8 | Ingbert | RP-49 | PCG-25 | RP-101074 |
| 1153 | 362 | **Charging for multi-phases services** | 70d? | 2007-12-06 A | 2008-03-12 A | 100% | 2007-12-06 | 2008-03-12 | 70d? |  | S1 | 560h | 560h | CHRGMPH | Telecom Italia | Rel-8 | Alain | SP-38 | PCG-21 |  |
| 1154 | 362.1 | Stage 1 for CHRGMPH | 70d? | 2007-12-06 A | 2008-03-12 A | 100% | 2007-12-06 | 2008-03-12 | 70d? | start no earlier than 2007-12-06 | S1 | 560h | 560h | CHRGMPH-s1 | Telecom Italia | Rel-8 | Alain | SP-38 | PCG-21 |  |
| 1155 | 363 | **Home NodeB / eNodeB** | 327d? | 2007-12-06 A | 2009-03-06 A | 100% | 2007-12-06 | 2009-03-06 | 327d? |  | S1,C1,C4 | 5720h | 5720h | HomeNB | Vodafone | Rel-8 | Alain | SP-38 | PCG-21 |  |
| 1156 | 363.1 | Stage 1 for Home NodeB / eNodeB | 70d? | 2007-12-06 A | 2008-03-12 A | 100% | 2007-12-06 | 2008-03-12 | 70d? | start no earlier than 2007-12-06 | S1 | 560h | 560h | HomeNB-S1 | Vodafone | Rel-8 | Alain | SP-38 | PCG-21 |  |
| 1157 | 363.2 | Support of Closed Subscriber Group (CSG) | 66d? | 2008-12-05 A | 2009-03-06 A | 100% | 2008-12-05 | 2009-03-06 | 66d? | finish no earlier than 2009-03-06 | C4 | 528h | 528h | HomeNB | CT#42 | Rel-8 | Kimmo | CP-42 | PCG-22 |  |
| 1158 | 363.3 | CSG and Idle Mode Mobility for LTE Home eNodeB | 126d? | 2008-09-12 A | 2009-03-06 A | 100% | 2008-09-12 | 2009-03-06 | 126d? | finish no earlier than 2009-03-06 | C1 | 1008h | 1008h | HomeNB-LTE | Huawei | Rel-8 | Frederic | CP-41 | PCG-21 |  |
| 1159 | 363.4 | CSG and Idle Mode Mobility for 3G Home NodeB | 126d? | 2008-09-12 A | 2009-03-06 A | 100% | 2008-09-12 | 2009-03-06 | 126d? | finish no earlier than 2009-03-06 | C1 | 1008h | 1008h | HomeNB-3G | Qualcomm | Rel-8 | Frederic | CP-41 | PCG-21 |  |
| 1160 | 364 | **UTRA HNB** | 326d? | 2008-03-07 A | 2009-06-04 A | 100% | 2008-03-07 | 2009-06-04 | 326d? |  | RP,S5 | 6832h | 6832h | HNB |  | Rel-8 | Issam | SP-39 | PCG-21 |  |
| 1161 | 364.1 | Support of UTRA HNB | 201d? | 2008-05-30 A | 2009-03-06 A | 100% | 2008-05-30 | 2009-03-06 | 201d? | finish no earlier than 2009-03-06 | R2 | 1608h | 1608h | HNB-supp | Huawei | Rel-8 | Joern | SP-40 | PCG-21 | RP-090040 |
| 1162 | 364.2 | UTRAN Architecture for 3G HNB | 136d? | 2008-05-30 A | 2008-12-05 A | 100% | 2008-05-30 | 2008-12-05 | 136d? | finish no earlier than 2008-12-05 | R3 | 1088h | 1088h | HNB-arch | Alcatel-Lucent | Rel-8 | Juha | SP-40 | PCG-21 | RP-090042 |
| 1163 | 364.3 | FDD Home NodeB RF requirements | 261d? | 2008-03-07 A | 2009-03-06 A | 100% | 2008-03-07 | 2009-03-06 | 261d? | finish no earlier than 2009-03-06 | R4 | 2088h | 2088h | HNB-RF | Motorola | Rel-8 | Issam | SP-39 | PCG-21 | RP-090041 |
| 1164 | 364.4 | 3G Home NodeB OAM&P Type 1 Management Interface | 127d? | 2008-12-11 A | 2009-06-04 A | 100% | 2008-12-11 | 2009-06-04 | 127d? | finish no earlier than 2009-06-04 | S5 [99.2%] | 1008h | 1008h | HNB-3G_OAM | Huawei | Rel-8 | Dionisio | SP-42 | PCG-22 |  |
| 1165 | 365 | **UTRA HNB – UE Conformance Testing** | 327d? | 2009-03-06 A | 2010-06-04 A | 100% | 2009-03-06 | 2010-06-04 | 327d? |  | R5 | 5224h | 5224h | HNB-UEConTest |  | Rel-8 | Ingbert | RP-43 | PCG-22 |  |
| 1166 | 365.1 | Conformance Test Aspects – UTRA HNB (FDD) | 326d? | 2009-03-06 A | 2010-06-04 A | 100% | 2009-03-06 | 2010-06-04 | 326d? | finish no earlier than 2010-06-04 | R5 | 2608h | 2608h | HNB-UEConTestFDD | Huawei | Rel-8 | Ingbert | RP-43 | PCG-22 | RP-100482 |
| 1167 | 366 | Lawful Interception in the 3GPP Rel-8 | 524d? | 2007-03-12 A | 2009-03-12 A | 100% | 2007-03-12 | 2009-03-12 | 524d? | finish no earlier than 2009-03-12 | S3 | 4192h | 4192h | LI8 | BMWI, Verizon | Rel-8 | Dionisio |  |  |  |
| 1168 | 367 | **Generic Bootstrapping Architecture Push Function** | 258d? | 2008-03-12 A | 2009-03-06 A | 100% | 2008-03-12 | 2009-03-06 | 258d? |  | S3,C1,C4 | 6468.8h | 6468.8h | GBAPush | Ericsson | Rel-8 | Dionisio | SP-39 | PCG-21 |  |
| 1169 | 367.1 | SA3 part of GBAPush (33.223) | 193d? | 2008-03-12 A | 2008-12-05 A | 100% | 2008-03-12 | 2008-12-05 | 193d? | finish no earlier than 2008-12-05 | S3 | 1544h | 1544h | GBAPush | Ericsson | Rel-8 | Dionisio | SP-39 | PCG-21 |  |
| 1170 | 367.2 | CT1 part of GBAPush | 178.8d? | 2008-03-12 A | 2009-03-06 A | 100% | 2008-03-12 | 2009-03-06 | 178.8d? | finish no earlier than 2009-03-06 | C1 | 1430.4h | 1430.4h | GBAPush | Ericsson | Rel-8 | Frederic | SP-39 | PCG-21 |  |
| 1171 | 367.3 | CT4 part of GBAPush | 178.8d? | 2008-03-12 A | 2009-03-06 A | 100% | 2008-03-12 | 2009-03-06 | 178.8d? | finish no earlier than 2009-03-06 | C4 | 1430.4h | 1430.4h | GBAPush | Ericsson | Rel-8 | Kimmo | SP-39 | PCG-21 |  |
| 1172 | 368 | Requirements and Test methods for Wideband Terminals | 197d? | 2008-03-12 A | 2008-12-11 A | 100% | 2008-03-12 | 2008-12-11 | 197d? | start no earlier than 2008-03-12 | S4 | 1576h | 1576h | RETEM_WB_T | FT, Ericsson | Rel-8 | Paolo |  |  |  |
| 1173 | 369 | Extending PSS and MBMS User Services for optimized Mobile TV | 266d? | 2007-12-06 A | 2008-12-11 A | 100% | 2007-12-06 | 2008-12-11 | 266d? | finish no earlier than 2008-12-11 | S4 | 2128h | 2128h | PSS_MBMS_OMTV | Ericsson | Rel-8 | Paolo |  |  |  |

Notes:
- 1149: CP#42 completed. Triggered by Study UID_330016 (PPAC). / Text5: Morita Takashi
- 1150: SP#37 completed / Text3: 22.011 / Text5: Morita Takashi
- 1151: CP#42 completed / Text3: 24.008, 23.122, 24.301
- 1152: RP#50 completed / Text3: UTRA 34.108, 34.123-1, 34.123-2, 34.123-3 / Text5: Takao.Shimizu.rp@nttdocomo.com
- 1153: SP#39 Stage 1 completed / Text3: 22.115 / Text5: Marco.DeLuca1@telecomitalia.it
- 1154: SP#39 completed / Text3: 22.115 / Text5: Marco.DeLuca1@telecomitalia.it
- 1155: CP#43 completed / Text5: John Watson
- 1156: SP#39 completed / Text3: 22.011, 22.115 / Text5: John Watson
- 1157: CP#43 completed. SP#42 SP-080874 22.011CR0141 confirmed Requirement to support roaming subscribers with CSG home network subscription but did NOT confirmed requirement for home network independent support of roamers in CSG / Text3: 29.002, 29.272, 23.008, 23.003 / Text5: Hannu Hietalahti
- 1158: CP#43 completed / Text3: 23.122, new (24.285, 24.301, 24.801) / Text5: zhang.peng@huawei.com
- 1159: CP#43 completed / Text3: 23.122, 24.008, new 24.285 / Text5: Osok Song
- 1160: SP#44 completed
- 1161: RP#43 completed / Text3: 25.304, 25.306, 25.331, new 25.367 / Text5: Yang Xudong (yangxudong@huawei.com)
- 1162: RP#42 completed / Text3: 25.401, 25.410, 25.412, 25.413, 25.414, 25.415, new (25.467, 25.468, 25.469) / Text5: Martin Warner (mw15@alcatel-lucent.com)
- 1163: RP#43 completed / Text3: 25.104, 25.141, new 25.967 / Text5: Ying Cai (yingcai@motorola.com)
- 1164: SP#44 completed. Complements work in BroadBand Forum / Text3: new (32.581, 32.582, 32.583, 32.584) / Text5: Zou Lan (zlan@huawei.com)
- 1165: RP#48 FDD completed. Testing for Feature UID_390033 UTRA HNB
- 1166: RP#48 completed / Text3: 34.108, 34.123-1, 34.123-2, 34.123-3 / Text5: Trica Li (trica_li@huawei.com)
- 1167: SP#43 completed / Text3: 33.106, 33.107, 33.108 / Text5: berthold.wilhelm@bnetza.de, ron_ryan@verizon.net
- 1168: CP#43 completed / Text5: Rolf Blom
- 1169: SP#42 completed 33.223 as Rel-8. TS 33.224 moved to Rel-9 under new UID_420039 / Text3: 33.223 / Text5: Rolf Blom
- 1170: CP#43 completed / Text3: 24.109 / Text5: Rolf Blom
- 1171: CP#43 completed / Text3: 29.109 / Text5: Rolf Blom
- 1172: SP#42 completed. SP#39 WID approved. / Text3: 26.131, 26.132 / Text5: stephane.ragot@orange-ftgroup.com, wanqing.shi@sonyericsson.com
- 1173: SP#42 completed. SP#38 WID approved. / Text3: 26.234, 26.346, 26.946 / Text5: thorsten.lohmar@ericsson.com

| ID | WBS | Task | Duration | Start | Finish | Complete | Remaining | Baseline start | Baseline finish | Baseline duration | Total slack | Constraint | Resources | Work | Actual work | Text1 | Text2 | Text4 | Text6 | Text7 | Text8 | Text12 | Text9 |
| --- | --- | --- | --- | --- | --- | --- | --- | --- | --- | --- | --- | --- | --- | --- | --- | --- | --- | --- | --- | --- | --- | --- | --- |
| 1174 | 370 | **Encoding formats, transport formats and media description signalling for interworking, QoE, and other enhancements to MTSI-MHI** | 331d? | 2007-12-06 A | 2009-03-12 A | 100% |  | 2007-12-06 | 2009-03-12 | 331d? |  |  | S4,C3,C4 | 9640h | 9640h | MTSI_eMHI | PCG-21 | Ericsson, Qualcomm | Rel-8 | SP-40 | Paolo |  |  |
| 1175 | 370.1 | MTSI Video - Dynamic Rate Adaptation/Signalling of Image Size | 331d? | 2007-12-06 A | 2009-03-12 A | 100% |  | 2007-12-06 | 2009-03-12 | 331d? |  | finish no earlier than 2009-03-12 | S4 | 2648h | 2648h | MTSI_eMHI-DRASIS |  | Qualcomm, Samsung | Rel-8 |  | Paolo |  |  |
| 1176 | 370.2 | CT3 part of Enhancement of interworking between MTSI and CS networks | 201d? | 2008-05-30 A | 2009-03-06 A | 100% |  | 2008-05-30 | 2009-03-06 | 201d? |  | finish no earlier than 2009-03-06 | C3 | 1608h | 1608h | MTSI_eMHI | PCG-21 | Huawei | Rel-8 | CP-40 | Jiwan |  |  |
| 1177 | 370.3 | CT4 part of Enhancement of interworking between MTSI and CS networks | 201d? | 2008-05-30 A | 2009-03-06 A | 100% |  | 2008-05-30 | 2009-03-06 | 201d? |  | finish no earlier than 2009-03-06 | C4 | 1608h | 1608h | MTSI_eMHI | PCG-21 | Huawei | Rel-8 | CP-40 | Kimmo |  |  |
| 1178 | 370.4 | Deleted - CT1 part of Enhancement of interworking between MTSI and CS networks | 141d? | 2008-05-30 A | 2008-12-12 A | 100% |  | 2008-05-30 | 2008-12-12 | 141d? |  | start no earlier than 2008-05-30 | C1 | 1128h | 1128h | MTSI_eMHI | PCG-21 | Huawei | Rel-8 | CP-40 | Frederic | CP-42 |  |
| 1179 | 371 | **Rel-8 Operations, Administration, Maintenance and Provisioning (OAM&P)** | 1178d? | 2007-06-07 A | 2011-12-09 | 92% | 98.85d? | 2007-06-07 | 2011-12-09 | 1178d? | 260d |  | S5,C1,C4,IETF | 54742.4h | 38452.4h | OAM8 |  |  | Rel-8 |  | Dionisio |  |  |
| 1180 | 371.1 | **Network Infrastructure Management** | 653d? | 2007-06-07 A | 2009-12-04 A | 100% |  | 2007-06-07 | 2009-12-04 | 653d? |  |  | S5 | 19464h | 19464h | OAM8-NIM |  |  | Rel-8 |  | Dionisio |  |  |
| 1181 | 371.1.1 | Telecom Management Methodology | 461d? | 2007-06-07 A | 2009-03-12 A | 100% |  | 2007-06-07 | 2009-03-12 | 461d? |  | finish no earlier than 2009-03-12 | S5 | 3688h | 3688h | OAM8 |  | Ericsson | Rel-8 |  | Dionisio |  |  |
| 1182 | 371.1.2 | Advanced Alarming on Itf-N | 266d? | 2007-06-07 A | 2008-06-12 A | 100% |  | 2007-06-07 | 2008-06-12 | 266d? |  | finish no earlier than 2008-12-11 | S5 | 2128h | 2128h | OAM8 |  | Nokia Siemens Networks | Rel-8 |  | Dionisio |  |  |
| 1183 | 371.1.3 | CN CS Bearer Transport Network (BTN) relative NRM | 266d? | 2007-06-07 A | 2008-06-12 A | 100% |  | 2007-06-07 | 2008-06-12 | 266d? |  | finish no earlier than 2008-12-11 | S5 | 2128h | 2128h | OAM8 |  | China Mobile | Rel-8 |  | Dionisio |  |  |
| 1184 | 371.1.4 | Alignment with eTOM and M.3060 architectural concepts | 210d? | 2008-02-22 A | 2008-12-11 A | 100% |  | 2008-02-22 | 2008-12-11 | 210d? |  | start no earlier than 2008-02-22 | S5 | 1680h | 1680h | OAM8 | PCG-21 | TeliaSonera | Rel-8 | SP-39 | Dionisio |  |  |
| 1185 | 371.1.5 | IRP SOAP Solution Sets | 201d? | 2008-06-05 A | 2009-03-12 A | 100% |  | 2008-06-05 | 2009-03-12 | 201d? |  | finish no earlier than 2009-03-12 | S5 | 1608h | 1608h | OAM8 | PCG-21 | Ericsson | Rel-8 | SP-40 | Dionisio |  |  |
| 1186 | 371.1.6 | Create missing specifications for IRP XML definitions | 52d? | 2009-09-24 A | 2009-12-04 A | 100% |  | 2009-09-24 | 2009-12-04 | 52d? |  | finish no earlier than 2010-03-12 | S5 | 416h | 416h | OAM8 | PCG-23 | ZTE | Rel-8 | SP-45 | Dionisio |  |  |
| 1187 | 371.1.7 | Deleted - End point modelling for reference point | 324d? | 2007-09-17 A | 2008-12-11 A | 100% |  | 2007-09-17 | 2008-12-11 | 324d? |  | finish no earlier than 2008-12-11 | S5 | 2592h | 2592h | OAM8 |  | Motorola | Rel-8 | SP-37 | Dionisio | SP-41 | PCG-21 |
| 1188 | 371.2 | **Performance Management** | 461d? | 2007-06-07 A | 2009-03-12 A | 100% |  | 2007-06-07 | 2009-03-12 | 461d? |  |  | S5 | 13712h | 13712h | OAM8-PM |  |  | Rel-8 |  | Dionisio |  |  |
| 1189 | 371.2.1 | IP bearer network Performance measurement definitions | 396d? | 2007-06-07 A | 2008-12-11 A | 100% |  | 2007-06-07 | 2008-12-11 | 396d? |  | finish no earlier than 2008-12-11 | S5 | 3168h | 3168h | OAM8 |  | China Mobile | Rel-8 |  | Dionisio |  |  |
| 1190 | 371.2.2 | HSUPA performance measurements | 396d? | 2007-06-07 A | 2008-12-11 A | 100% |  | 2007-06-07 | 2008-12-11 | 396d? |  | finish no earlier than 2008-12-11 | S5 | 3168h | 3168h | OAM8 |  | China Mobile | Rel-8 |  | Dionisio |  |  |
| 1191 | 371.2.3 | Key Performance Indicators (KPIs) for UMTS and GSM | 461d? | 2007-06-07 A | 2009-03-12 A | 100% |  | 2007-06-07 | 2009-03-12 | 461d? |  | finish no earlier than 2009-03-12 | S5 | 3688h | 3688h | OAM8 |  | China Mobile | Rel-8 |  | Dionisio |  |  |
| 1192 | 371.3 | **Trace Management** | 982d? | 2008-03-07 A | 2011-12-09 | 66% | 332.89d? | 2008-03-07 | 2011-12-09 | 982d? | 260d |  | S5,C1,C3,C4,IETF | 14270.4h | 5276.4h | OAM8-Trace |  |  | Rel-8 |  | Dionisio |  |  |
| 1193 | 371.3.1 | Service Level Tracing in IMS | 196d? | 2008-03-07 A | 2008-12-05 A | 100% |  | 2008-03-07 | 2008-12-05 | 196d? |  | finish no earlier than 2008-12-05 | C1 | 1568h | 1568h | OAM8-Trace |  | Vodafone | Rel-8 |  | Frederic |  |  |
| 1194 | 371.3.2 | (IETF) Service Level Tracing in IMS | 451d? | 2008-03-07 A | 2011-12-09 | 25% | 338.25d? | 2008-03-07 | 2011-12-09 | 451d? | 260d | finish no earlier than 2011-12-09 | C1-IETF | 3608h | 902h | OAM8-Trace | PCG-27 | Vodafone | Rel-8 | CP-52 | Frederic |  |  |
| 1195 | 371.3.3 | Service Level Tracing in IMS | 175.4d? | 2008-03-07 A | 2008-12-05 A | 100% |  | 2008-03-07 | 2008-12-05 | 175.4d? |  | finish no earlier than 2008-12-05 | C4 | 1403.2h | 1403.2h | OAM8-Trace | PCG-21 | Vodafone | Rel-8 | CP-40 | Frederic |  |  |
| 1196 | 371.3.4 | Deleted - Service Level Tracing in IMS | 175.4d? | 2008-03-07 A | 2008-12-05 A | 100% |  | 2008-03-07 | 2008-12-05 | 175.4d? |  | finish no earlier than 2008-12-05 | C3 | 1403.2h | 1403.2h | OAM8-Trace | PCG-21 | Vodafone | Rel-8 | CP-40 | Jiwan | CP-42 |  |
| 1197 | 372 | **Rel-8 Charging Management small Enhancements** | 716d? | 2006-03-16 A | 2008-12-11 A | 100% |  | 2006-03-16 | 2008-12-11 | 716d? |  |  | S5 | 12544h | 12544h | CH8 |  |  | Rel-8 |  | Dionisio |  |  |
| 1198 | 372.1 | Online charging correlation | 457d? | 2006-03-16 A | 2007-12-14 A | 100% |  | 2006-03-16 | 2007-12-14 | 457d? |  | start no earlier than 2006-03-16 | S5 | 3656h | 3656h | CH8 |  | Orange | Rel-8 |  | Dionisio |  |  |
| 1199 | 372.2 | SMS online charging | 137d? | 2007-06-07 A | 2007-12-14 A | 100% |  | 2007-06-07 | 2007-12-14 | 137d? |  | finish no earlier than 2007-12-14 | S5 | 1096h | 1096h | CH8 |  | Vodafone | Rel-8 |  | Dionisio |  |  |
| 1200 | 372.3 | Introduce Online Charging from SMS-SC into the SMS Charging Specifications | 61d? | 2008-09-18 A | 2008-12-11 A | 100% |  | 2008-09-18 | 2008-12-11 | 61d? |  | finish no earlier than 2008-12-11 | S5 | 488h | 488h | CH8 | PCG-21 | Acision | Rel-8 | SP-41 | Dionisio |  |  |
| 1201 | 372.4 | Deleted - WLAN Offline Charging | 244d? | 2008-01-07 A | 2008-12-11 A | 100% |  | 2008-01-07 | 2008-12-11 | 244d? |  | finish no earlier than 2008-12-11 | S5 | 1952h | 1952h | CH8 | PCG-21 | Alcatel-Lucent | Rel-8 | SP-38 | Dionisio | SP-42 | PCG-22 |

Notes:
- 1174: TSG#43 completed / Text5: olle.franceschi@ericsson.com, nleung@qualcomm.com
- 1175: SP#43 completed / Text3: 26.114 / Text5: nleung@qualcomm.com & kyunghun.jung@samsung.com
- 1176: CP#43 completed / Text3: 29.163 / Text5: Tingfang Tang (tagna_online@huawei.com)
- 1177: CP#43 completed / Text3: 29.332 / Text5: Tingfang Tang (tagna_online@huawei.com)
- 1178: CP#42 stopped (No CT1-impact). WID updated CP-080422=>CP-080774 / Text5: Tingfang Tang (tagna_online@huawei.com)
- 1179: - / Text3: TR 30.818
- 1180: -
- 1181: SP#43 completed / Text3: 32.155, 32.153 / Text5: thomas.tovinger@ericsson.com
- 1182: SP#40 completed / Text3: 32.121, 32.122, 32.123 / Text5: SUERBAUM, Clemens
- 1183: SP#40 completed / Text3: 32.632, 32.633, 32.635 / Text5: Li Jian (lijian@chinamobile.com)
- 1184: SP#42 completed / Text3: 32.101/2, 32-series / Text5: tommy.berggren@teliasonera.com
- 1185: SP#43 completed / Text3: 32.111-7, 32.617, 32.417, 32.367, 32.347, 32.111-1, 32.111-2, 32.111-3, 32.111-5, 32.307, 32.317, 32.341, 32.342, 32.343, 32.345, 32.361, 32.362, 32.363, 32.365, 32.411, 32.412, 32.413, 32.415, 32.611, 32.612, 32.613, 32.615, 32.625 / Text5: edwin.tse@ericsson.com
- 1186: SP#46 completed. Create missing XML definitions specs for IRPs (Advanced Alarm Management, Communication Surveillance, Self-Configuration of Network Elements, Software Management) needed for implementation of Rel-8 Notification Log IRP (TS 32.33x) / Text3: new (32.125, 32.355, 32.505, 32.535), 32.150, 32.153, 32.335 / Text5: Shuqiang Huang (huangsq@zte.com.cn)
- 1187: SP#41 Work stopped. Contributions related to E-UTRAN/EPC to be submitted to UID_380036 E-UTRAN NRM IRP/ UID_380037 EPC NRM IRP / Text3: 32.152, 32.62/3/4x, 32.73x / Text5: Yizhi Yao (yzyao@motorola.com)
- 1188: - / Text5: Li Jian (lijian@chinamobile.com)
- 1189: SP#42 completed / Text3: 32.321, 32.322, 32.323, 32.325 / Text5: lilianyuan@chinamobile.com
- 1190: SP#42 completed / Text3: 32.405 / Text5: Li Jian (lijian@chinamobile.com)
- 1191: SP#43 completed / Text3: 32.410 / Text5: Li Jian (lijian@chinamobile.com), Liang Shuangchun (liangshuangchun@cmdi.chinamobile.com)
- 1192: -
- 1193: CP#42 completed / Text3: 24.323, 24.229 / Text5: peter.dawes@vodafone.com
- 1194: Not completed internet-draft / Text3: draft-dawes-sipping-debug
- 1195: CP#42 completed / Text3: 29.228, 29.229 / Text5: peter.dawes@vodafone.com
- 1196: CP#42 stopped (No CT3-impact) / Text5: peter.dawes@vodafone.com
- 1197: SP#42 completed / Text3: TR 30.818
- 1198: SP#38 completed / Text3: 32.296 / Text5: Chahine, Rony
- 1199: SP#38 completed / Text3: 32.240, 32.299, new 32.274 / Text5: Gavin.Wong@vodafone.com
- 1200: SP#42 completed. Linked to SA2 UID 32081 (Support of SMS over IP networks) and CT4 UID 340016 (Routeing of MT-SMS via the HPLMN). / Text3: 32.274, 32.299 / Text5: erik.gebler@acision.com
- 1201: SP#42 stopped / Text3: 32.252, 32.298, 32.299 / Text5: Maryse.Gardella@alcatel.fr

| ID | WBS | Task | Type | Duration | Start | Finish | Complete | Baseline start | Baseline finish | Baseline duration | Constraint | Resources | Work | Actual work | Text1 | Text2 | Text4 | Text5 | Text6 | Text8 | Text7 | Text12 | Text11 |
| --- | --- | --- | --- | --- | --- | --- | --- | --- | --- | --- | --- | --- | --- | --- | --- | --- | --- | --- | --- | --- | --- | --- | --- |
| 1202 | 373 | **Conferencing enhancements for Mp interface** |  | 266d? | 2007-11-30 A | 2008-12-05 A | 100% | 2007-11-30 | 2008-12-05 | 266d? |  | C4 | 6384h | 6384h | eMp | PCG-21 | Huawei | Chencheng@huawei.com | Rel-8 | Kimmo |  |  |  |
| 1203 | 373.1 | Stage 2 for eMp |  | 266d? | 2007-11-30 A | 2008-12-05 A | 100% | 2007-11-30 | 2008-12-05 | 266d? | finish no earlier than 2008-12-11 | C4 | 2128h | 2128h | eMp | PCG-21 | Huawei | Chencheng@huawei.com | Rel-8 | Kimmo | CP-38 |  |  |
| 1204 | 373.2 | Stage 3 for eMp |  | 266d? | 2007-11-30 A | 2008-12-05 A | 100% | 2007-11-30 | 2008-12-05 | 266d? | finish no earlier than 2008-12-05 | C4 | 2128h | 2128h | eMp | PCG-21 | Huawei | Chencheng@huawei.com | Rel-8 | Kimmo | CP-38 |  |  |
| 1205 | 374 | **Contact Manager for 3GPP UICC applications** |  | 642d? | 2006-06-22 A | 2008-12-05 A | 100% | 2006-06-22 | 2008-12-05 | 642d? |  | C6 | 13352h | 13352h | eUPHBOOK |  | Gemalto | Jacques.seif@gemalto.com | Rel-8 | Xavier |  |  |  |
| 1206 | 374.1 | Requirements for Contact Manager |  | 392d? | 2006-06-22 A | 2007-12-21 A | 100% | 2006-06-22 | 2007-12-21 | 392d? | finish no earlier than 2007-12-21 | C6 | 3136h | 3136h | eUPHBOOK-St1 |  | Gemalto | Jacques.seif@gemalto.com | Rel-8 | Xavier |  |  |  |
| 1207 | 374.2 | External interface for eUPHBOOK |  | 220d? | 2007-05-07 A | 2008-03-07 A | 100% | 2007-05-07 | 2008-03-07 | 220d? | finish no earlier than 2008-03-07 | C6 | 1760h | 1760h | eUPHBOOK-Ext_Spec |  | Gemalto | Jacques.seif@gemalto.com | Rel-8 | Xavier |  |  |  |
| 1208 | 374.3 | Internal interface for eUPHBOOK |  | 415d? | 2007-05-07 A | 2008-12-05 A | 100% | 2007-05-07 | 2008-12-05 | 415d? | finish no earlier than 2008-12-05 | C6 | 3320h | 3320h | eUPHBOOK-Int_Spec |  | Gemalto | Jacques.seif@gemalto.com | Rel-8 | Xavier | CP-37 |  |  |
| 1209 | 374.4 | Deleted - Implementation of eUPHBOOK | milestone | 0d? | 2007-06-21 A | 2007-06-21 A | 100% | 2007-06-21 | 2007-06-21 | 0d? | start no earlier than 2007-06-21 | C6 |  |  | eUPHBOOK-St23 |  | Giesecke & Devrient | Claus Dietze | Rel-8 | Xavier |  | SP-33 |  |
| 1210 | 375 | **Rel-8 LTE – 3G Long Term Evolution - Evolved Packet System RAN part** |  | 644d? | 2006-09-25 A | 2009-03-12 A | 100% | 2006-09-25 | 2009-03-12 | 644d? |  | RP,S5 | 44896h | 44896h | LTE |  | NTT DoCoMo | Takehiro Nakamura (nakamurata@nttdocomo.co.jp) | Rel-8 |  |  |  | RP-080741 |
| 1211 | 375.1 | LTE – Physical Layer |  | 380d? | 2006-09-25 A | 2008-03-07 A | 100% | 2006-09-25 | 2008-03-07 | 380d? | finish no earlier than 2007-09-14 | R1 | 3040h | 3040h | LTE-Phys |  | NTT DoCoMo | Sadayuki Abeta | Rel-8 | Patrick |  |  | RP-080741 |
| 1212 | 375.2 | LTE – Radio Interface Layer 2 and 3 Protocol Aspect |  | 575d? | 2006-09-25 A | 2008-12-05 A | 100% | 2006-09-25 | 2008-12-05 | 575d? | finish no earlier than 2008-12-11 | R2 | 4600h | 4600h | LTE-L23 |  | Nokia Siemens Networks | benoist.sebire@nokia.com | Rel-8 | Joern |  |  | RP-080741 |
| 1213 | 375.3 | LTE – eUTRAN Interfaces |  | 575d? | 2006-09-25 A | 2008-12-05 A | 100% | 2006-09-25 | 2008-12-05 | 575d? | finish no earlier than 2008-12-11 | R3 | 4600h | 4600h | LTE-interfaces |  | Ericsson | Martin Israelsson | Rel-8 | Juha |  |  | RP-080741 |
| 1214 | 375.4 | LTE – Evolved UTRA and UTRAN RF Radio Transmission/Reception, System Performance Requirements and Conformance Testing |  | 575d? | 2006-09-25 A | 2008-12-05 A | 100% | 2006-09-25 | 2008-12-05 | 575d? | finish no earlier than 2008-12-11 | R4 | 4600h | 4600h | LTE-RF |  | Nokia Siemens Networks | Tuomo Saynajakangas | Rel-8 | Issam |  |  | RP-080741 |
| 1215 | 375.5 | LTE – FDD repeaters |  | 386d? | 2007-09-14 A | 2009-03-06 A | 100% | 2007-09-14 | 2009-03-06 | 386d? | finish no earlier than 2009-03-06 | R4 | 3088h | 3088h | LTE-Repeaters |  | Powerwave Technologies, Andrew Wireless | ralf.michanikl@andrew.com, Alf.Ahlstrom@pwav.com | Rel-8 | Issam | RP-37 |  | RP-090037 |
| 1216 | 375.6 | **E-UTRAN Data Definitions** |  | 389d? | 2007-09-17 A | 2009-03-12 A | 100% | 2007-09-17 | 2009-03-12 | 389d? |  | S5 | 13096h | 13096h | E-UTRAN-OAM | PCG-21 |  |  | Rel-8 | Dionisio | SP-39 |  |  |
| 1217 | 375.6.1 | Subscriber and Equipment Trace for E-UTRAN and EPC |  | 389d? | 2007-09-17 A | 2009-03-12 A | 100% | 2007-09-17 | 2009-03-12 | 389d? | finish no earlier than 2009-03-12 | S5 | 3112h | 3112h | E-UTRAN-OAM |  | Ericsson | robert.petersen@ericsson.com | Rel-8 | Dionisio | SP-37 |  |  |
| 1218 | 375.6.2 | E-UTRAN Network Resource Model (NRM) Integration Reference Point (IRP) |  | 309d? | 2008-01-07 A | 2009-03-12 A | 100% | 2008-01-07 | 2009-03-12 | 309d? | finish no earlier than 2009-03-12 | S5 | 2472h | 2472h | E-UTRAN-OAM | PCG-21 | Ericsson | ELMDAHL, Per | Rel-8 | Dionisio | SP-38 |  |  |
| 1219 | 375.6.3 | Performance measurements for E-UTRAN |  | 275d? | 2008-02-22 A | 2009-03-12 A | 100% | 2008-02-22 | 2009-03-12 | 275d? | finish no earlier than 2009-03-12 | S5 | 2200h | 2200h | E-UTRAN-OAM | PCG-21 | Motorola, Huawei | Yizhi Yao (yzyao@motorola.com) | Rel-8 | Dionisio | SP-39 |  |  |
| 1220 | 375.6.4 | Key Performance Indicators (KPIs) for E-UTRAN |  | 275d? | 2008-02-22 A | 2009-03-12 A | 100% | 2008-02-22 | 2009-03-12 | 275d? | finish no earlier than 2009-03-12 | S5 | 2200h | 2200h | E-UTRAN-OAM | PCG-21 | Ericsson | ulf.hubinette@ericsson.com | Rel-8 | Dionisio | SP-39 |  |  |
| 1221 | 375.7 | **Self-Organizing Networks (SON)** |  | 210d? | 2008-02-22 A | 2008-12-11 A | 100% | 2008-02-22 | 2008-12-11 | 210d? |  | S5 | 6720h | 6720h | LTE_SON-OAM | PCG-21 | Vodafone | GOMPAKIS, Panagiotis | Rel-8 | Dionisio | SP-39 |  |  |
| 1222 | 375.7.1 | SON Concepts and requirements |  | 210d? | 2008-02-22 A | 2008-12-11 A | 100% | 2008-02-22 | 2008-12-11 | 210d? |  | S5 | 1680h | 1680h | LTE_SON-OAM | PCG-21 | Vodafone | GOMPAKIS, Panagiotis | Rel-8 | Dionisio | SP-39 |  |  |
| 1223 | 375.7.2 | Self-Establishment of eNBs, including automated Software Management |  | 210d? | 2008-02-22 A | 2008-12-11 A | 100% | 2008-02-22 | 2008-12-11 | 210d? | start no earlier than 2008-02-22 | S5 | 1680h | 1680h | LTE_SON-OAM | PCG-21 | Nokia Siemens Networks | SUERBAUM, Clemens | Rel-8 | Dionisio | SP-39 |  |  |
| 1224 | 375.7.3 | SON Automatic Neighbour Relations (ANR) List Management |  | 210d? | 2008-02-22 A | 2008-12-11 A | 100% | 2008-02-22 | 2008-12-11 | 210d? | finish no earlier than 2008-12-11 | S5 | 1680h | 1680h | LTE_SON-OAM | PCG-21 | Ericsson | edwin.tse@ericsson.com | Rel-8 | Dionisio | SP-39 |  |  |
| 1225 | 376 | **Rel-8 LTE – Terminal Conformance Test Specification** |  | 657d? | 2007-06-01 A | 2009-12-04 A | 100% | 2007-06-01 | 2009-12-04 | 657d? |  | R5 | 17544h | 17544h | LTE-UEConTest |  |  |  | Rel-8 | Ingbert |  |  |  |
| 1226 | 376.1 | 3G LTE – Terminal Protocol Conformance Test Specifications |  | 657d? | 2007-06-01 A | 2009-12-04 A | 100% | 2007-06-01 | 2009-12-04 | 657d? | finish no earlier than 2009-12-04 | R5 | 5256h | 5256h | LTE-UEConTest_SIG |  | NEC, Motorola | david.lecompte@nectech.fr, Jacob.John@motorola.com | Rel-8 | Ingbert |  |  | RP-091060 |
| 1227 | 376.2 | LTE – Terminal Radio Transmission and Reception Conformance Test Specifications |  | 657d? | 2007-06-01 A | 2009-12-04 A | 100% | 2007-06-01 | 2009-12-04 | 657d? |  | R5 | 5256h | 5256h | LTE-UEConTest_RF |  | Agilent | andrea_leonardi@agilent.com | Rel-8 | Ingbert |  |  | RP-091059 |
| 1228 | 376.3 | Deleted - LTE – Terminal Radio Transmission and Reception Conformance Test Specifications |  | 401d? | 2007-06-01 A | 2008-12-12 A | 100% | 2007-06-01 | 2008-12-12 | 401d? |  | R5 | 3208h | 3208h | LTE-UEConTest_RF |  | Agilent | andrea_leonardi@agilent.com | Rel-8 | Ingbert |  | RP-41 | RP-091059 |

Notes:
- 1202: CP#42 completed
- 1203: CP#42 completed / Text3: 23.333
- 1204: CP#42 completed / Text3: 29.333
- 1205: CP#42 completed. CP#40: WID updated CP-070622=>CP-080382. aka Enhanced USIM phonebook
- 1206: CP#38 completed / Text3: 21.111
- 1207: CP#39 completed / Text3: new 31.220
- 1208: CP#42 completed / Text3: new 31.221
- 1209: SP#33 stopped / Text3: 31.102
- 1210: RP#43 completed. Role model for SAE/LTE system wide project management by SA2 in SP-060166 / Text3: 36.300, 36.938
- 1211: RP#39 completed / Text3: 36.201, 36.211, 36.212, 36.213, 36.214, 25.215, 25.225
- 1212: RP#42 completed / Text3: 36.302, 36.304, 36.306, 36.314, 36.321, 36.322, 36.323, 36.331, 25.302, 25.304, 25.331
- 1213: RP#42 completed / Text3: 36.401, 36.410, 36.411, 36.412, 36.413, 36.414, 36.420, 36.421, 36.422, 36.423, 36.424, 25.413
- 1214: RP#42 completed. RP#47 abandoned draft 36.801, 36.803, 36.804 / Text3: 36.101, 36.104, 36.113, 36.124, 36.133, 36.141, 36.942, 25.123, 25.133
- 1215: RP#43 completed. RP#47 create Rel-9 TR 36.956 (see R4-100386, RP-100320_RAN4 Report) / Text3: 36.106, 36.143, 25.113
- 1216: SP#43 completed
- 1217: SP#43 completed / Text3: 32.421, 2.422, 32.423, 2.441, 32.442, 32.443, 32.445
- 1218: SP#43 completed / Text3: new (32.761, 32.762, 32.763, 32.765)
- 1219: SP#43 completed / Text3: new 32.425
- 1220: SP#43 completed / Text3: new (32.450, 32.451)
- 1221: SP#42 completed (WT UID_390007 moved to Rel-9)
- 1222: SP#42 completed / Text3: new 32.500
- 1223: SP#42 completed / Text3: new (32.501, 32.502, 32.503, 32.531, 32.532, 32.533)
- 1224: SP#42 completed / Text3: 32.761, 32.762, 32.763, 32.765, new 32.511
- 1225: Testing for Feature UID_20068 (LTE)
- 1226: RP#46 completed / Text3: 36.521-1, 36.521-2, 36.508, 36.509, 36.523-1, 36.523-2, 36.523-3
- 1227: RP#46 completed. RP#50 TR 36.903 v100 for Approval / Text3: 36.521-1, 36.521-2, 36.521-3, new TR 36.903
- 1228: RP#41 stopped / Text3: 36.521-1, 36.521-2, 36.521-3

| ID | WBS | Task | Duration | Start | Finish | Complete | Baseline start | Baseline finish | Baseline duration | Constraint | Resources | Work | Actual work | Text1 | Text6 | Text8 | Text4 | Text5 | Text11 | Text2 | Text7 | Text9 | Text12 |
| --- | --- | --- | --- | --- | --- | --- | --- | --- | --- | --- | --- | --- | --- | --- | --- | --- | --- | --- | --- | --- | --- | --- | --- |
| 1229 | 377 | **Rel-8 Improvements of the Radio Interface** | 525d? | 2007-03-05 A | 2009-03-06 A | 100% | 2007-03-05 | 2009-03-06 | 525d? |  | RP | 18152h | 18152h | RInImp8 | Rel-8 | Issam |  |  |  |  |  |  |  |
| 1230 | 377.1 | UMTS 1500 MHz | 140d? | 2007-03-05 A | 2007-09-14 A | 100% | 2007-03-05 | 2007-09-14 | 140d? | finish no earlier than 2007-09-14 | R4 | 1120h | 1120h | RInImp8-UMTS1500 | Rel-8 | Issam | NTT DoCoMo | Takehiro Nakamura (nakamurata@nttdocomo.co.jp) | RP-070526 |  |  |  |  |
| 1231 | 377.2 | UMTS 700 MHz FDD | 325d? | 2007-03-05 A | 2008-05-30 A | 100% | 2007-03-05 | 2008-05-30 | 325d? | finish no earlier than 2008-06-12 | R4 | 2600h | 2600h | RInImp8-UMTS700 | Rel-8 | Issam | Nokia | Tuomo Saynajakangas | RP-080260 |  |  |  |  |
| 1232 | 377.3 | UMTS 1880 MHz TDD | 126d? | 2008-09-12 A | 2009-03-06 A | 100% | 2008-09-12 | 2009-03-06 | 126d? | finish no earlier than 2009-03-09 | R4 | 1008h | 1008h | RInImp9-UMTS1880TDD | Rel-8 | Issam | CATT | Yuexia Song (songyuexia@datangmobile.cn) | RP-090044 | PCG-21 | RP-41 |  |  |
| 1233 | 377.4 | UMTS 2300 MHz TDD LCR | 195d? | 2007-12-17 A | 2008-09-12 A | 100% | 2007-12-17 | 2008-09-12 | 195d? | finish no earlier than 2008-09-12 | R4 | 1560h | 1560h | RInImp8-UMTS2300TDD | Rel-8 | Issam | CATT | songyuexia@datangmobile.cn | RP-080517 | PCG-21 | RP-38 |  |  |
| 1234 | 377.5 | Further Improved Minimum Performance Requirements for HSDPA UE (FDD) - Two-Branch Interference Cancellation | 265d? | 2007-03-05 A | 2008-03-07 A | 100% | 2007-03-05 | 2008-03-07 | 265d? | finish no earlier than 2008-03-12 | R4 | 2120h | 2120h | RInImp8-2BIC | Rel-8 | Issam | AT&T | Marc Grant | RP-080041 |  |  |  |  |
| 1235 | 377.6 | CS Voice Service over HSPA | 167d? | 2007-07-19 A | 2008-03-07 A | 100% | 2007-07-19 | 2008-03-07 | 167d? |  | R2 | 1336h | 1336h | RInImp8-CsHspa | Rel-8 | Joern | Nokia Siemens Networks | woonhee.hwang@nsn.com | RP-080042 |  | RP-37 |  |  |
| 1236 | 377.7 | Performance requirements for 15 code reception with 16QAM/QPSK (FDD) | 126d? | 2007-06-11 A | 2008-03-07 A | 100% | 2007-06-11 | 2008-03-07 | 126d? | finish no earlier than 2008-06-12 | R4 | 1008h | 1008h | RInImp8-Hsdpa15codes | Rel-8 | Issam | Vodafone | tim.frost@vodafone.com | RP-080043 |  | RP-37 |  |  |
| 1237 | 377.8 | Deleted - UMTS 2300 MHz FDD/TDD | 400d? | 2007-03-05 A | 2008-09-12 A | 100% | 2007-03-05 | 2008-09-12 | 400d? | finish no earlier than 2008-12-11 | R4 | 3200h | 3200h | RInImp8-UMTS2300 | Rel-8 | Issam | AT&T | Marc Grant | RP-080515 |  |  | PCG-21 | RP-41 |
| 1238 | 378 | **Rel-8 Improvements of the Radio Interface - UE Conformance Testing** | 396d? | 2007-06-01 A | 2008-12-05 A | 100% | 2007-06-01 | 2008-12-05 | 396d? |  | R5 | 6256h | 6256h | RInImp-UEConTest | Rel-8 | Ingbert |  |  |  |  |  |  |  |
| 1239 | 378.1 | Conformance Test Aspects – CS Voice Service over HSPA | 336d? | 2007-06-01 A | 2008-09-12 A | 100% | 2007-06-01 | 2008-09-12 | 336d? | finish no earlier than 2008-09-12 | R5 | 2688h | 2688h | RInImp8-CsHspa_UEConTest | Rel-8 | Ingbert | Huawei | baoyi@huawei.com | RP-080542 |  |  |  |  |
| 1240 | 378.2 | Conformance Test Aspects – Performance requirements for 15 code reception with 16QAM/QPSK (FDD) | 195d? | 2008-03-07 A | 2008-12-05 A | 100% | 2008-03-07 | 2008-12-05 | 195d? | finish no earlier than 2008-12-05 | R5 | 1560h | 1560h | RInImp8-UEConTest_ Hsdpa15codes | Rel-8 | Ingbert | Ericsson | Mikael.Ziren@Ericsson.com | RP-080818 | PCG-21 | RP-40 |  |  |
| 1241 | 379 | **Rel-8 RAN improvements** | 520d? | 2007-06-04 A | 2009-05-29 A | 100% | 2007-06-04 | 2009-05-29 | 520d? |  | RP | 29776h | 29776h | RANimp | Rel-8 |  |  |  |  |  |  |  |  |
| 1242 | 379.1 | Combination of 64QAM and MIMO for HSDPA (FDD) | 205d? | 2007-06-04 A | 2008-09-12 A | 100% | 2007-06-04 | 2008-09-12 | 205d? | finish no earlier than 2008-09-12 | R1 | 1640h | 1640h | RANimp-64QamMimoHsdpa | Rel-8 | Patrick | Ericsson | Johan.Bergman@ericsson.com | RP-080518 |  |  |  |  |
| 1243 | 379.2 | Improved L2 for uplink | 186d? | 2007-09-14 A | 2008-05-30 A | 100% | 2007-09-14 | 2008-05-30 | 186d? | finish no earlier than 2008-05-30 | R2 | 1488h | 1488h | RANimp-UplinkL2dataRates | Rel-8 | Joern | Ericsson | Janne.Peisa@ericsson.com | RP-080265 |  | RP-37 |  |  |
| 1244 | 379.3 | Enhanced Uplink for CELL_FACH State in FDD | 321d? | 2007-09-14 A | 2008-12-05 A | 100% | 2007-09-14 | 2008-12-05 | 321d? | finish no earlier than 2008-12-12 | R2 | 2568h | 2568h | RANimp-UplinkEnhState | Rel-8 | Joern | Nokia Siemens Networks | markus.wimmer@nsn.com | RP-080804 |  | RP-37 |  |  |
| 1245 | 379.4 | Enhanced UE Discontinuous Reception (DRX) for FDD | 261d? | 2007-09-14 A | 2008-09-12 A | 100% | 2007-09-14 | 2008-09-12 | 261d? | finish no earlier than 2008-09-12 | R2 | 2088h | 2088h | RANimp-DRX | Rel-8 | Joern | Nokia | luis.barreto@nokia.com | RP-080520 |  | RP-37 |  |  |
| 1246 | 379.5 | Enhancements for Serving Radio Network Subsystem (SRNS) Relocation Procedure | 261d? | 2007-09-14 A | 2008-09-12 A | 100% | 2007-09-14 | 2008-09-12 | 261d? | finish no earlier than 2008-09-12 | R3 | 2088h | 2088h | RANimp-SrnsReloc | Rel-8 | Juha | Nokia Siemens Networks | masatoshi.nakamata@nsn.com | RP-080521 |  | RP-37 |  |  |
| 1247 | 379.6 | Enhancements for FDD HSPA Evolution | 321d? | 2007-09-14 A | 2008-12-05 A | 100% | 2007-09-14 | 2008-12-05 | 321d? | finish no earlier than 2008-12-05 | R3,R2 | 2568h | 2568h | RANimp-HSPAEvo | Rel-8 | Juha | Nokia Siemens Networks | masatoshi.nakamata@nsn.com | RP-080805 |  | RP-37 |  |  |
| 1248 | 379.7 | 64QAM for 1.28 Mcps TDD HSDPA | 264d? | 2007-12-04 A | 2008-12-05 A | 100% | 2007-12-04 | 2008-12-05 | 264d? | finish no earlier than 2008-12-05 | R1 | 2112h | 2112h | RANimp-64Qam1.28TDD | Rel-8 | Patrick | ZTE | zfmail@zte.com.cn | RP-080806 | PCG-21 | RP-38 |  |  |
| 1249 | 379.8 | Enhanced CELL_FACH state in 1.28 Mcps TDD | 264d? | 2007-12-04 A | 2008-12-05 A | 100% | 2007-12-04 | 2008-12-05 | 264d? | finish no earlier than 2008-12-12 | R2 | 2112h | 2112h | RANimp-EnhState1.28TDD | Rel-8 | Joern | ZTE | zhang.yincheng@zte.com.cn | RP-080807 | PCG-21 | RP-38 |  |  |
| 1250 | 379.9 | Continuous Connectivity for packet data users for 1.28 Mcps TDD | 321d? | 2008-03-07 A | 2009-05-29 A | 100% | 2008-03-07 | 2009-05-29 | 321d? | finish no earlier than 2009-05-29 | R1 | 2568h | 2568h | RANimp-LCRCPC | Rel-8 | Patrick | TD Tech | chenying@td-tech.com | RP-090394 | PCG-21 | RP-39 |  |  |
| 1251 | 379.10 | HSPA VoIP to WCDMA/GSM CS continuity | 261d? | 2008-03-07 A | 2009-03-06 A | 100% | 2008-03-07 | 2009-03-06 | 261d? | finish no earlier than 2009-03-06 | R2 | 2088h | 2088h | RANimp-HSPAVoIP | Rel-8 | Joern | Nokia | Simone.Provvedi@nokia.com | RP-090050 | PCG-21 | RP-39 |  |  |
| 1252 | 379.11 | HS-DSCH Serving Cell Change Enhancements | 196d? | 2008-03-07 A | 2008-12-05 A | 100% | 2008-03-07 | 2008-12-05 | 196d? | finish no earlier than 2008-12-12 | R2 | 1568h | 1568h | RANimp-HSDSCH | Rel-8 | Joern | Ericsson | henrik.enbuske@ericsson.com | RP-080811 | PCG-21 | RP-39 |  |  |
| 1253 | 379.12 | MIMO for 1.28 Mcps TDD. Linked to Rel-8 Study on Scope of future HSPA Evolution for 1.28 Mcps TDD (UID_370041) TR 25.824 | 201d? | 2007-11-01 A | 2009-03-06 A | 100% | 2007-11-01 | 2009-03-06 | 201d? | finish no earlier than 2009-05-29 | R1,R4 | 1608h | 1608h | RANimp-MIMOLCR | Rel-8 | Patrick | CATT | wangke@datangmobile.cn | RP-090313 | PCG-21 | RP-40 |  |  |
| 1254 | 379.13 | Dual-Cell HSDPA operation on adjacent carriers | 140d? | 2008-05-30 A | 2008-12-11 A | 100% | 2008-05-30 | 2008-12-11 | 140d? | finish no earlier than 2009-05-29 | R1,R4 | 1120h | 1120h | RANimp-DCHSDPA | Rel-8 | Patrick | Ericsson | johan.bergman@ericsson.com | RP-080814 | PCG-21 | RP-40 |  |  |

Notes:
- 1229: -
- 1230: RP#37 completed / Text3: 25.101, 25.104, 25.133, 25.141, 25.331, 25.942, 25.306, 25.307, 34.121
- 1231: RP#40 completed / Text3: 25.101, 25.104, 25.133, 25.141, 25.331, 25.942, 25.306, 25.307, 34.121
- 1232: RP#43 completed / Text3: 25.102, 25.105, 25.113, 25.123, 25.142, 34.124, 25.307
- 1233: RP#41 completed. RP#47 abandoned draft 25.828 / Text3: 25.102, 25.105, 25.113, 25.123, 25.142, 34.124, 25.306, 25.331, 34.122
- 1234: RP#39 completed / Text3: 25.101
- 1235: RP#39 completed / Text3: 25.323, 25.331, 25.322
- 1236: RP#39 completed / Text3: 25.101
- 1237: RP#41 stopped / Text3: 25.101, 25.104, 25.133, 25.141, 25.331, 25.942, 25.306, 25.307, 34.121
- 1238: 05/08: Linked to Feature UID_20028 (RInImp)
- 1239: RP#41 completed / Text3: 34.108, 34.123-1, 34.123-2, 34.123-3
- 1240: RP#42 completed / Text3: 34.121-1, 34.121-2
- 1241: -
- 1242: RP#41 completed / Text3: 25.308, 25.211, 25.212, 25.213, 25.306, 25.331, 25.433, 25.435, 25.423, 25.425, 25.101, 25.104, 25.141
- 1243: RP#40 completed. Linked to UID_370037 Enhanced Uplink for CELL_FACH State in FDD / Text3: 25.319, 25.301, 25.306, 25.321, 25.331, 25.433, 25.435, 25.423, 25.425, 25.427
- 1244: RP#42 completed. Linked to UID_370036 Improved L2 for uplink / Text3: 25.309, 25.211, 25.214, 25.321, 25.331, 25.423, 25.433
- 1245: RP#41 completed. Continuation of Rel-7 work item "Continuous connectivity for packet data users" UID_20046. / Text3: 25.306, 25.308, 25.321, 25.331, 25.423
- 1246: RP#41 completed. Linked to UID_370040 Enhancements for FDD HSPA Evolution / Text3: 25.306, 25.308, 25.321, 25.331, 25.423, 25.433, 25.214, 25.133
- 1247: RP#42 completed. Triggered by Rel-7 Study on Scope of future FDD HSPA Evolution (UID_20065) TR 25.999 / Text3: 25.401, 25.413, 25.420, 25.423, 25.427, 25.433, 25.446, 25.301, 25.346
- 1248: RP#42 completed. Linked to Rel-8 Study on Scope of future HSPA Evolution for 1.28 Mcps TDD (UID_370041) TR 25.824 / Text3: 25.102, 25.105, 25.123, 25.142, 25.201, 25.221, 25.222, 25.223, 25.224, 25.306, 25.308, 25.321, 25.331, 25.423, 25.433
- 1249: RP#42 completed. Linked to Rel-8 Study on Scope of future HSPA Evolution for 1.28 Mcps TDD (UID_370041) TR 25.824 / Text3: 25.123, 25.221, 25.222, 25.224, 25.301, 25.302, 25.304, 25.306, 25.308, 25.319, 25.321, 25.331, 25.401, 25.423, 25.425, 25.433, 25.435
- 1250: RP#44 completed. Linked to Rel-8 Study on Scope of future HSPA Evolution for 1.28 Mcps TDD (UID_370041) TR 25.824 / Text3: 25.929, 25.308, 25.319
- 1251: RP#43 completed / Text3: 25.331, 25.413
- 1252: RP#42 completed / Text3: 25.101, 25.104, 25.133, 25.212, 25.214, 25.308, 25.321, 25.331, 25.423, 25.433
- 1253: RP#43 completed / Text3: 25.201, 25.221, 25.222, 25.223, 25.224, 25.306, 25.308, 25.321, 25.331, 25.423, 25.433, 25.102, 25.105, 25.142
- 1254: RP#42 completed. Triggered by UID_390032 Study on Dual-Cell HSDPA (withdrawn TR 25.825 v100). / Text3: 25.101, 25.104, 25.133, 25.141, 25.211, 25.212, 25.213, 25.214, 25.215, 25.306, 25.308, 25.321, 25.331, 25.423, 25.433

| ID | WBS | Task | Duration | Start | Finish | Complete | Remaining | Baseline start | Baseline finish | Baseline duration | Total slack | Constraint | Resources | Work | Actual work | Text1 | Text6 | Text8 | Text2 | Text4 | Text7 | Text11 |
| --- | --- | --- | --- | --- | --- | --- | --- | --- | --- | --- | --- | --- | --- | --- | --- | --- | --- | --- | --- | --- | --- | --- |
| 1255 | 380 | **Rel-8 RAN improvements - UE Conformance Testing** | 602d? | 2008-05-30 A | 2010-09-17 A | 100% |  | 2008-05-30 | 2010-09-17 | 602d? |  |  | R5 | 29391.2h | 29391.2h | RANimp-UEConTest | Rel-8 | Ingbert |  |  |  |  |
| 1256 | 380.1 | Conformance Test Aspects – Combination of 64QAM and MIMO for HSDPA (FDD) | 322d? | 2008-09-12 A | 2009-12-04 A | 100% |  | 2008-09-12 | 2009-12-04 | 322d? |  | finish no earlier than 2009-12-04 | R5 | 2576h | 2576h | RANimp-UEConTest_64QamMimoHsdpa | Rel-8 | Ingbert | PCG-21 | Ericsson | RP-41 | RP-091058 |
| 1257 | 380.2 | Conformance Test Aspects – Improved L2 for uplink | 341d? | 2008-05-30 A | 2009-09-18 A | 100% |  | 2008-05-30 | 2009-09-18 | 341d? |  | finish no earlier than 2009-09-18 | R5 | 2728h | 2728h | RANimp-UEConTest_UplinkL2dataRates | Rel-8 | Ingbert | PCG-21 | Ericsson | RP-40 | RP-090712 |
| 1258 | 380.3 | Conformance Test Aspects – 1.28 Mcps TDD Improved L2 support for high data rates | 342d? | 2009-05-29 A | 2010-09-17 A | 100% |  | 2009-05-29 | 2010-09-17 | 342d? |  | finish no earlier than 2010-09-17 | R5 | 2736h | 2736h | RANimp-UEConTest_ImprovedL2LCRTDD | Rel-8 | Ingbert | PCG-23 | CATT | RP-44 | RP-100737 |
| 1259 | 380.4 | Conformance Test Aspects – 64QAM for 1.28 Mcps TDD HSDPA | 261d? | 2008-05-30 A | 2009-05-29 A | 100% |  | 2008-05-30 | 2009-05-29 | 261d? |  | finish no earlier than 2009-05-29 | R5 | 2088h | 2088h | RANimp-UEConTest_64Qam1.28TDD | Rel-8 | Ingbert | PCG-21 | ZTE | RP-40 | RP-090415 |
| 1260 | 380.5 | Conformance Test Aspects – Dual-Cell HSDPA operation on adjacent carriers | 391d? | 2008-12-05 A | 2010-06-04 A | 100% |  | 2008-12-05 | 2010-06-04 | 391d? |  | finish no earlier than 2010-06-04 | R5 | 3128h | 3128h | RANimp-UEConTest_DCHSDPA | Rel-8 | Ingbert | PCG-22 | Qualcomm | RP-42 | RP-100479 |
| 1261 | 380.6 | Conformance Test Aspects – Enhanced Uplink for CELL_FACH State in FDD | 326d? | 2009-03-06 A | 2010-06-04 A | 100% |  | 2009-03-06 | 2010-06-04 | 326d? |  | finish no earlier than 2010-06-04 | R5 | 2608h | 2608h | RANimp-UEConTest_EnhancedRACHCellFACHState | Rel-8 | Ingbert | PCG-22 | Nokia | RP-43 | RP-100483 |
| 1262 | 380.7 | Conformance Test Aspects – Receiver Type3i | 196d? | 2009-03-06 A | 2009-12-04 A | 100% |  | 2009-03-06 | 2009-12-04 | 196d? |  | finish no earlier than 2009-12-04 | R5 | 1568h | 1568h | RANimp-UEConTest_ReceiverType3i | Rel-8 | Ingbert | PCG-22 | Qualcomm | RP-43 | RP-091066 |
| 1263 | 380.8 | Conformance Test Aspects – Enhanced CELL_FACH State in LCR TDD | 341d? | 2009-05-30 A | 2010-09-17 A | 100% |  | 2009-05-30 | 2010-09-17 | 341d? |  | finish no earlier than 2010-09-17 | R5 | 2728h | 2728h | RANimp-UEConTest_EnhancedCellFACHStateLCRTDD | Rel-8 | Ingbert | PCG-23 | CATT | RP-44 | RP-100735 |
| 1264 | 380.9 | Conformance Test Aspects – Continuous Connectivity for packet data users for 1.28 Mcps TDD | 261d? | 2009-09-18 A | 2010-09-17 A | 100% |  | 2009-09-18 | 2010-09-17 | 261d? |  | finish no earlier than 2010-09-17 | R5 | 2088h | 2088h | RANimp-UEConTest_CPCLCRTDD | Rel-8 | Ingbert | PCG-23 | ZTE | RP-45 | RP-100739 |
| 1265 | 380.10 | Conformance Test Aspects – MIMO for 1.28 Mcps TDD | 186d? | 2009-09-18 A | 2010-06-04 A | 100% |  | 2009-09-18 | 2010-06-04 | 186d? |  | finish no earlier than 2010-06-04 | R5 | 1488h | 1488h | RANimp-UEConTest_MIMOLCRTDD | Rel-8 | Ingbert | PCG-23 | ZTE | RP-45 | RP-100660 |
| 1266 | 380.11 | Conformance Test Aspects – HS-DSCH Serving Cell Change Enhancements | 131d? | 2009-09-18 A | 2010-03-19 A | 100% |  | 2009-09-18 | 2010-03-19 | 131d? |  | finish no earlier than 2010-03-12 | R5 | 1048h | 1048h | HSDSCH_UEConTest | Rel-8 | Ingbert | PCG-23 | Qualcomm | RP-45 | RP-100077 |
| 1267 | 381 | 3.84 Mcps TDD MBSFN Integrated Mobile Broadcast | 395d? | 2007-06-04 A | 2008-12-05 A | 100% |  | 2007-06-04 | 2008-12-05 | 395d? |  |  | R1 | 3160h | 3160h | MBSFN-DOB | Rel-8 | Patrick |  | Ericsson |  | RP-080218 |
| 1268 | 382 | Conformance Test Aspects – 3.84 Mcps TDD MBSFN Integrated Mobile Broadcast | 211d? | 2009-05-30 A | 2010-03-19 A | 100% |  | 2009-05-30 | 2010-03-19 | 211d? |  | finish no earlier than 2010-03-19 | R5 | 1688h | 1688h | MBSFN_IMB_UEConTest | Rel-8 | Ingbert | PCG-23 | IPwireless | RP-44 | RP-100070 |
| 1269 | 383 | **GERAN support for GERAN - 3G Long Term Evolution interworking** | 1302d? | 2006-09-08 A | 2011-09-02 | 92% | 105.13d? | 2006-09-08 | 2011-09-02 | 1302d? | 330d |  | GP,G1,C1 | 36216h | 33291.8h | GELTE | Rel-8 | Paolo |  | Nokia, Nokia Siemens Networks |  |  |
| 1270 | 383.1 | G1 part of GERAN support for GERAN - 3G Long Term Evolution interworking | 641d? | 2006-09-08 A | 2009-02-20 A | 100% |  | 2006-09-08 | 2009-02-20 | 641d? |  | finish no earlier than 2009-02-20 | G1 | 5128h | 5128h | GELTE | Rel-8 | Paolo |  | Nokia, Nokia Siemens Networks |  |  |
| 1271 | 383.2 | G2 part of GERAN support for GERAN - 3G Long Term Evolution interworking | 641d? | 2006-09-08 A | 2009-02-20 A | 100% |  | 2006-09-08 | 2009-02-20 | 641d? |  | finish no earlier than 2009-02-20 | G2 | 5128h | 5128h | GELTE | Rel-8 | Paolo |  | Nokia, Nokia Siemens Networks |  |  |
| 1272 | 383.3 | CT1 part of GERAN support for GERAN - 3G Long Term Evolution interworking | 641d? | 2006-09-08 A | 2009-02-20 A | 100% |  | 2006-09-08 | 2009-02-20 | 641d? |  | finish no earlier than 2009-02-20 | C1 | 5128h | 5128h | GELTE | Rel-8 | Paolo |  | Nokia, Nokia Siemens Networks |  |  |
| 1273 | 383.4 | Testing for GERAN support for GERAN - 3G Long Term Evolution interworking | 1302d? | 2006-09-08 A | 2011-09-02 | 80% | 260.4d? | 2006-09-08 | 2011-09-02 | 1302d? | 330d | finish no earlier than 2011-09-02 | G3new | 10416h | 8332.8h | GELTE | Rel-8 | Ingbert |  | Nokia, Nokia Siemens Networks |  |  |
| 1274 | 384 | U-TDOA Enhancement | 131d? | 2007-05-18 A | 2007-11-16 A | 100% |  | 2007-05-18 | 2007-11-16 | 131d? |  | finish no earlier than 2007-05-18 | GP | 1048h | 1048h | GUTEN | Rel-8 | Paolo |  | TruePosition |  |  |
| 1275 | 385 | **GAN Enhancements** | 604.2d? | 2007-05-15 A | 2009-09-04 A | 100% |  | 2007-05-15 | 2009-09-04 | 604.2d? |  |  | GP | 9432h | 9432h | GANENH | Rel-8 | Paolo |  | T-Mobile |  |  |
| 1276 | 385.1 | Update to GAN specifications | 126d? | 2007-08-31 A | 2008-02-22 A | 100% |  | 2007-08-31 | 2008-02-22 | 126d? |  | finish no earlier than 2008-02-22 | GP | 1008h | 1008h | GANENH-SPEC | Rel-8 | Paolo |  | T-Mobile |  |  |
| 1277 | 385.2 | Update TS 51.010 Mobile Station (MS) Conformance Specification for GAN Enhancements | 526d? | 2007-05-15 A | 2009-09-04 A | 100% |  | 2007-05-15 | 2009-09-04 | 526d? |  | finish no earlier than 2009-09-04 | G3new | 4208h | 4208h | GANENH-MStest | Rel-8 | Ingbert |  | T-Mobile |  |  |
| 1278 | 386 | **AoIP (A-interface over IP)** | 2335d? | 2000-01-03 A | 2008-12-11 A | 100% |  | 2000-01-03 | 2008-12-11 | 2335d? |  |  | GP,S4,C4,C1,C3 | 41412.1h | 41412.1h | AoIP | Rel-8 | Paolo | PCG-21 | China Mobile, Ericsson |  |  |
| 1279 | 386.1 | GERAN aspects of AoIP | 2321d? | 2000-01-03 A | 2008-11-21 A | 100% |  | 2000-01-03 | 2008-11-21 | 2321d? |  | finish no earlier than 2008-11-21 | GP | 18560h | 18560h | AoIP | Rel-8 | Paolo | PCG-21 | China Mobile, Ericsson | SP-40 |  |
| 1280 | 386.2 | Media Requirements for CS over IP based User Plane | 267d? | 2007-12-05 A | 2008-12-11 A | 100% |  | 2007-12-05 | 2008-12-11 | 267d? |  | finish no earlier than 2008-12-11 | S4 | 1996.09h | 1996.09h | AoIP-CSoIP | Rel-8 | Paolo | PCG-21 | China Mobile, Ericsson | SP-40 |  |
| 1281 | 386.3 | Core Network Impacts for A-Interface User Plane over IP | 136d? | 2008-05-30 A | 2008-12-05 A | 100% |  | 2008-05-30 | 2008-12-05 | 136d? |  | start no earlier than 2008-05-30 | C4 | 1088h | 1088h | AoIP-CN | Rel-8 | Kimmo | PCG-21 | Ericsson | CP-40 |  |
| 1282 | 386.4 | Core Network Impacts for A-Interface User Plane over IP | 68d? | 2008-05-30 A | 2008-12-05 A | 100% |  | 2008-05-30 | 2008-12-05 | 68d? |  | finish no earlier than 2008-12-05 | C1 | 544h | 544h | AoIP-CN | Rel-8 | Frederic | PCG-21 | Ericsson | CP-40 |  |
| 1283 | 386.5 | Core Network Impacts for A-Interface User Plane over IP | 68d? | 2008-05-30 A | 2008-12-05 A | 100% |  | 2008-05-30 | 2008-12-05 | 68d? |  | finish no earlier than 2008-12-05 | C3 | 544h | 544h | AoIP-CN | Rel-8 | Jiwan | PCG-21 | Ericsson | CP-40 |  |
| 1284 | 387 | New multicarrier BTS class | 261d? | 2007-08-31 A | 2008-08-29 A | 100% |  | 2007-08-31 | 2008-08-29 | 261d? |  | finish no earlier than 2008-08-29 | G1 | 2088h | 2088h | MCBTS | Rel-8 | Paolo |  | Alcatel-Lucent |  |  |

Notes:
- 1255: Linked to Feature UID_20029 (RANimp)
- 1256: RP#46 completed. Testing for UID_360013 / Text3: 34.108, 34.121-1, 34.121-2, 34.123-1, 34.123-2 / Text5: leif.mattisson@ericsson.com
- 1257: RP#45 completed. Testing for UID_370036 / Text3: 34.108, 34.123-1, 34.123-2, 34.123-3 / Text5: leif.mattisson@ericsson.com
- 1258: RP#49 completed. Testing for Rel-7 UID_340039 Improved L2 support for high data rates and Rel-8 UID_370036 Improved L2 for uplink / Text3: 34.108, 34.123-1, 34.123-2, 34.123-3 / Text5: Xiaozhong Chen (chenxiaozhong@datangmobile.cn)
- 1259: RP#44 completed. Testing for UID_380075 / Text3: 34.108, 34.122, 34.123-1, 34.123-2, 34.123-3 / Text5: ma.zijiang@zte.com.cn
- 1260: RP#48 completed. Testing for UID_400052 / Text3: 34.108, 34.121-1, 34.121-2, 34.123-1, 34.123-2, 34.123-3 / Text5: Shubhang Vora (svora@qualcomm.com)
- 1261: RP#48 completed. Testing for UID_370037 / Text3: 34.108, 34.121-1, 34.121-2, 34.123-1, 34.123-2, 34.123-3 / Text5: jarkko.hellsten@nokia.com
- 1262: RP#46 completed. Testing for Receiver Type3i in 25.101 UE radio Tx and Rx FDD / Text3: 34.108, 34.121-1, 34.121-2 / Text5: Ashok Kumar Narayanaswamy (anarayan@qualcomm.com)
- 1263: RP#49 completed. Testing for UID_380076 / Text3: 34.108, 34.123-1, 34.123-2, 34.123-3 / Text5: Xiaozhong Chen (chenxiaozhong@datangmobile.cn)
- 1264: RP#49 completed. Testing for UID_390028 / Text3: 34.108, 34.123-1, 34.123-2, 34.123-3 / Text5: huang.he4@zte.com.cn
- 1265: PR#48 completed. Testing for UID_400050 / Text3: 34.108, 34.122, 34.123-1, 34.123-2, 34.123-3 / Text5: huang.chun2@zte.com.cn
- 1266: RP#47 completed. Testing for UID_390030 / Text3: 34.108, 34.121-1, 34.121-2, 34.123-1, 34.123-2, 34.123-3 / Text5: Shubhang Vora (svora@qualcomm.com)
- 1267: RP#42 completed. WID updated RP-070493=>RP-081124 (changed WI title "MBSFN Downlink Optimized Broadcast (DOB) 3.84 Mcps TDD" => "3.84Mcps TDD MBSFN Integrated Mobile Broadcast"). / Text3: 25.102, 25.105, 25.123, 25.201, 25.221, 25.222, 25.223, 25.224, 25.304, 25.306, 25.331, 25.346, 25.402, 25.433 / Text5: Lars.Lindbom@ericsson.com
- 1268: RP#47 completed. Testing for Rel-8 MBSFN-DOB UID_360008 / Text3: 34.108, 34.122, 34.123-1, 34.123-2, 34.123-3 / Text5: Phil Young (pyoung@ipwireless.com)
- 1269: GP#41 completed (MS conformance testing open) / Text3: 44.018, 44.060, 45.002, 45.008, 45.010, 48.008, 48.018, 51.010 / Text5: sergio.parolari@nsn.com, vlora.rexhepi@nokia.com
- 1270: GP#41 completed / Text3: 43.055, 43.129, 43.246, 45.002, 45.008, 45.010 / Text5: sergio.parolari@nsn.com, vlora.rexhepi@nokia.com
- 1271: GP#41 completed / Text3: 44.018, 44.060, 48.008, 48.018 / Text5: sergio.parolari@nsn.com, vlora.rexhepi@nokia.com
- 1272: - / Text3: 24.008 / Text5: sergio.parolari@nsn.com, vlora.rexhepi@nokia.com
- 1273: GP#50 completion 05/11=>09/11 / Text3: 51.010 / Text5: sergio.parolari@nsn.com, vlora.rexhepi@nokia.com
- 1274: GP#36 completed U-TDOA (Uplink Time Difference of Arrival) / Text3: 43.059, 45.008, 48.071 / Text5: Terry Brooks (terri.brooks@trueposition.com)
- 1275: GP#37 completed. GP#43 completed Testing / Text5: mohammed.versi@t-mobile.com
- 1276: GP#37 completed / Text3: 43.318, 44.318 / Text5: mohammed.versi@t-mobile.com
- 1277: GP#43 completed / Text3: 51.010 / Text5: mohammed.versi@t-mobile.com
- 1278: GP#40/TSG#42 completed . Triggered by TR 43.903 Study on A-interface over IP (AINTIP) UID_50589. / Text5: wangshuaiyu@chinamobile.com, paul.schliwa-bertling@ericsson.com
- 1279: GP#40 completed. GP#39 updated WID GP-080901=>GP-081362. / Text3: 48.001, 48.002, 48.008, 48.020, 49.008, 48.103 / Text5: wangshuaiyu@chinamobile.com, paul.schliwa-bertling@ericsson.com
- 1280: SP#42 completed / Text3: 26.102, 26.103, 26.202 / Text5: Karl.Hellwig@Ericsson.com
- 1281: CP#42 completed. Updated WID CP-080278=>CP-080722 / Text3: 23.205, 23.153, 23.231, 29.232 / Text5: philip.hodges@ericsson.com
- 1282: CP#42 completed. Updated WID CP-080278=>CP-080722 / Text3: 23.009 / Text5: philip.hodges@ericsson.com
- 1283: CP#42 completed. Updated WID CP-080278=>CP-080722 / Text3: 29.007 / Text5: philip.hodges@ericsson.com
- 1284: GP#39 completed / Text3: 45.005, 45.050, 51.021 / Text5: thomas.bitzer@alcatel-lucent.de

| ID | WBS | Task | Type | Duration | Start | Finish | Complete | Remaining | Baseline start | Baseline finish | Baseline duration | Total slack | Constraint | Resources | Work | Actual work | Text1 | Text4 | Text6 | Text8 | Text2 | Text3 | Text7 | Text11 | Text12 | Text9 |
| --- | --- | --- | --- | --- | --- | --- | --- | --- | --- | --- | --- | --- | --- | --- | --- | --- | --- | --- | --- | --- | --- | --- | --- | --- | --- | --- |
| 1285 | 388 | **Support for Additional Navigation Satellite Systems (ANSS) for LCS** |  | 150d? | 2008-05-16 A | 2008-12-11 A | 100% |  | 2008-05-16 | 2008-12-11 | 150d? |  |  | S1,G2 | 3384h | 3384h | ANSS | Qualcomm | Rel-8 | Paolo |  |  |  |  |  |  |
| 1286 | 388.1 | Stage 1 for ANSS for LCS |  | 1d? | 2008-12-11 A | 2008-12-11 A | 100% |  | 2008-12-11 | 2008-12-11 | 1d? |  | start no earlier than 2008-12-11 | S1 | 8h | 8h | ANSS |  | Rel-8 | Alain | PCG-22 | 22.071 | SP-42 |  |  |  |
| 1287 | 388.2 | Support for Additional Navigation Satellite Systems (ANSS) for LCS |  | 136d? | 2008-05-16 A | 2008-11-21 A | 100% |  | 2008-05-16 | 2008-11-21 | 136d? |  | start no earlier than 2008-05-16 | G2 | 1088h | 1088h | ANSS | Qualcomm | Rel-8 | Paolo |  | 43.059, 44.031, 49.031, 44.071, 48.031, 51.010 |  |  |  |  |
| 1288 | 388.3 | Support for Additional Navigation Satellite Systems (ANSS) for LCS |  | 136d? | 2008-05-30 A | 2008-12-05 A | 100% |  | 2008-05-30 | 2008-12-05 | 136d? |  | finish no earlier than 2008-12-08 | R2 | 1088h | 1088h | RANimp-ANSS | Qualcomm | Rel-8 | Joern | PCG-21 | 25.305, 25.306, 25.331, 25.413, 25.423, 25.433, 25.453 | RP-40 | RP-080813 |  |  |
| 1289 | 389 | **Conformance testing for the Latency Reductions feature** |  | 532d? | 2008-02-22 A | 2010-03-05 A | 100% |  | 2008-02-22 | 2010-03-05 | 532d? |  |  | G1, G3new | 10592h | 10592h | CTLATRED | Ericsson | Rel-8 | Paolo | PCG-21 |  |  |  |  |  |
| 1290 | 389.1 | MS conformance testing for the Latency Reductions feature |  | 532d? | 2008-02-22 A | 2010-03-05 A | 100% |  | 2008-02-22 | 2010-03-05 | 532d? |  | finish no earlier than 2010-03-05 | G3new | 4248h | 4248h | CTLATRED-MStest | Ericsson | Rel-8 | Ingbert | PCG-21 | 51.010 |  |  |  |  |
| 1291 | 389.2 | BTS conformance testing for the Latency Reductions feature |  | 261d? | 2008-02-22 A | 2009-02-20 A | 100% |  | 2008-02-22 | 2009-02-20 | 261d? |  | finish no earlier than 2009-02-20 | G1 | 2088h | 2088h | CTLATRED-BTStest | Ericsson | Rel-8 | Paolo | PCG-21 | 51.021 |  |  |  |  |
| 1292 | 390 | MS conformance testing of changes introduced by WI "Support of Packet-switched Handover for GERAN A/Gb mode" |  | 196d? | 2008-02-22 A | 2008-11-21 A | 100% |  | 2008-02-22 | 2008-11-21 | 196d? |  | finish no earlier than 2008-11-21 | G3new | 1568h | 1568h | PSHCT-MStest | Rohde & Schwarz | Rel-8 | Ingbert | PCG-21 | 51.010 |  |  |  |  |
| 1293 | 391 | (Small) Technical Enhancements and Improvements for Rel-8 |  | 509d? | 2007-01-01 A | 2008-12-11 A | 100% |  | 2007-01-01 | 2008-12-11 | 509d? |  | finish no earlier than 2008-12-11 | All | 4072h | 4072h | TEI8 |  | Rel-8 | All |  |  |  |  |  |  |
| 1294 | 392 | (IETF) (Small) Technical Enhancements and Improvements for Rel-8 |  | 451d? | 2007-01-01 A | 2011-12-09 | 50% | 225.5d? | 2007-01-01 | 2011-12-09 | 451d? | 260d | finish no earlier than 2011-12-09 | C1-IETF | 3608h | 1804h | TEI8 |  | Rel-8 | Frederic | PCG-27 | draft-ietf-simple-msrp-sessmatch | CP-52 |  |  |  |
| 1295 | 393 | Test - (Small) Technical Enhancements and Improvements for Rel-8 |  | 672d? | 2007-03-07 A | 2010-12-24 A | 100% |  | 2007-03-07 | 2010-12-24 | 672d? |  | finish no earlier than 2010-12-24 | R5,G3new | 5376h | 5376h | TEI8_Test |  | Rel-8 | Ingbert | PCG-21 |  | RP-40 |  |  |  |
| 1296 | 394 | **Deleted - All-IP Network** |  | 448d? | 2004-06-28 A | 2006-03-15 A | 100% |  | 2004-06-28 | 2006-03-15 | 448d? |  |  | S1 | 7168h | 7168h | AIPN | NTT DoCoMo | Rel-8 | Alain |  |  |  |  | SP-38 |  |
| 1297 | 394.1 | Deleted - Stage 1 |  | 448d? | 2004-06-28 A | 2006-03-15 A | 100% |  | 2004-06-28 | 2006-03-15 | 448d? |  | finish no earlier than 2006-03-15 | S1 | 3584h | 3584h | AIPN | NTT DoCoMo | Rel-8 | Alain |  | 22.258 |  |  | SP-38 |  |
| 1298 | 395 | Deleted - was Rel7 - LCS for 3GPP Interworking WLAN | milestone | 0d? | 2007-09-28 A | 2007-09-28 A | 100% |  | 2007-09-28 | 2007-09-28 | 0d? |  | start no earlier than 2007-09-28 | S2 |  |  | LCS4_IWLAN | LG Electronics | Rel-8 | Maurice |  | 23.234, 23.271, 23.167 |  |  | SP-35 |  |
| 1299 | 396 | Deleted - never approved- FBI Phase 2 | milestone | 0d | 2007-09-28 A | 2007-09-28 A | 100% |  | 2007-09-28 | 2007-09-28 | 0d |  | start no earlier than 2007-09-28 | S2 |  |  | FBI2 | Nokia Siemens Networks | Rel-8 | Maurice |  |  |  |  | SP-38 |  |
| 1300 | 397 | Deleted -Enhancements to BS30 Bearer service for Videotelephony | milestone | 0d? | 2007-03-15 A | 2007-03-15 A | 100% |  | 2007-03-15 | 2007-03-15 | 0d? |  | finish no earlier than 2007-03-15 | S1 |  |  | BS30 |  | Rel-8 | Alain |  | 22.002, 22.004, 22.101, 22.105, 24.008 |  |  | SP-38 |  |
| 1301 | 398 | Deleted - IMS Enhancements Rel-8 |  | 75d? | 2007-09-03 A | 2007-12-14 A | 100% |  | 2007-09-03 | 2007-12-14 | 75d? |  |  | S1 | 600h | 600h | IMS8 | Telecom Italia | Rel-8 | Alain |  |  | SP-37 |  | SP-38 |  |
| 1302 | 399 | **Deleted - Contact Manager Conformance Test specifications** |  | 471d? | 2008-06-02 A | 2010-03-19 A | 100% |  | 2008-06-02 | 2010-03-19 | 471d? |  |  | C6 | 11304h | 11304h | eUPHBOOK-Test | Comprion, Gemalto | Rel-8 | Xavier | PCG-21 |  | CP-40 |  | CP-47 | PCG-24 |
| 1303 | 399.1 | Deleted - Contact Manager for 3GPP UICC applications test specifications |  | 471d? | 2008-06-02 A | 2010-03-19 A | 100% |  | 2008-06-02 | 2010-03-19 | 471d? |  | finish no earlier than 2010-03-19 | C6 | 3768h | 3768h | eUPHBOOK-Test | Comprion | Rel-8 | Xavier | PCG-21 | 31.320 (external interface for communication with the ME) | CP-40 |  | CP-47 | PCG-24 |
| 1304 | 399.2 | Deleted - Contact Manager API for Java™ Card test specification |  | 471d? | 2008-06-02 A | 2010-03-19 A | 100% |  | 2008-06-02 | 2010-03-19 | 471d? |  | finish no earlier than 2010-03-19 | C6 | 3768h | 3768h | eUPHBOOK-Test | Gemalto | Rel-8 | Xavier | PCG-21 | 31.321 (internal interface (API)) | CP-40 |  | CP-47 | PCG-24 |
| 1305 | 400 | Deleted - MS conformance testing of Support of Conversational Services in A/Gb mode via the PS domain |  | 401d? | 2008-02-25 A | 2009-09-04 A | 100% |  | 2008-02-25 | 2009-09-04 | 401d? |  | finish no earlier than 2009-09-04 | G3new | 3208h | 3208h | SCSAGBCT-MStest | Nokia | Rel-8 | Ingbert | PCG-21 | 51.010 |  |  | GP-43 | PCG-23 |
| 1306 | 401 | Release 8 Studies |  | 1332d? | 2005-10-07 A | 2010-11-12 A | 100% |  | 2005-10-07 | 2010-11-12 | 1332d? |  | start no earlier than 2000-01-03 | CP,GP,RP,SP | 10656h | 10656h |  |  | Rel-8 | All |  |  |  |  |  |  |
| 1307 | 402 | Study on Customised Alerting Tone (CAT) Requirements |  | 245d? | 2005-10-07 A | 2006-09-14 A | 100% |  | 2005-10-07 | 2006-09-14 | 245d? |  | start no earlier than 2005-10-07 | S1 | 1960h | 1960h | FS_CAT | China Mobile | Rel-8 | Alain |  | 22.982 |  |  |  |  |
| 1308 | 403 | Study on Facilitating Machine to Machine Communication in GSM and UMTS (M2M) |  | 350d? | 2005-11-04 A | 2007-03-08 A | 100% |  | 2005-11-04 | 2007-03-08 | 350d? |  | finish no earlier than 2006-06-16 | S1 | 2800h | 2800h | FS_M2M | Siemens | Rel-8 | Alain |  | 22.868 |  |  |  |  |
| 1309 | 404 | Study on Network Composition |  | 526d? | 2005-12-07 A | 2007-12-12 A | 100% |  | 2005-12-07 | 2007-12-12 | 526d? |  | finish no earlier than 2006-09-27 | S1 | 4208h | 4208h | FS_NetComp | Nokia Siemens Networks | Rel-8 | Alain |  | 22.980 |  |  |  |  |
| 1310 | 405 | Study on Requirements of IMS Multimedia Conferencing |  | 330d? | 2006-06-08 A | 2007-09-12 A | 100% |  | 2006-06-08 | 2007-09-12 | 330d? |  | finish no earlier than 2007-03-21 | S1 | 2640h | 2640h | FS_IMSconf | China Mobile | Rel-8 | Alain |  | 22.948 |  |  |  |  |
| 1311 | 406 | Study on support of a Public Warning System |  | 140d? | 2007-09-03 A | 2008-03-14 A | 100% |  | 2007-09-03 | 2008-03-14 | 140d? |  |  | S1 | 1120h | 1120h | FS_PWS | T-Mobile | Rel-8 | Alain |  | 22.968 |  |  |  |  |
| 1312 | 407 | Study on Paging Permission with Access Control |  | 256d? | 2006-09-28 A | 2007-09-20 A | 100% |  | 2006-09-28 | 2007-09-20 | 256d? |  | finish no earlier than 2007-09-20 | S1 | 2048h | 2048h | FS_PPAC | NTT DoCoMo | Rel-8 | Alain |  | 22.908 |  |  |  |  |
| 1313 | 408 | Study on Non-3GPP access Network Selection Principles (NSP) |  | 392d? | 2006-12-06 A | 2008-06-05 A | 100% |  | 2006-12-06 | 2008-06-05 | 392d? |  | finish no earlier than 2007-11-19 | S1 | 3136h | 3136h | FS_N3GtoNSP | Telefónica O2 | Rel-8 | Alain |  | 22.912 |  |  |  |  |
| 1314 | 409 | Study on Value Added Services for Short Message Service |  | 263d? | 2006-12-06 A | 2007-12-07 A | 100% |  | 2006-12-06 | 2007-12-07 | 263d? |  | finish no earlier than 2007-12-07 | S1 | 2104h | 2104h | FS_VAS4SMS | China Mobile | Rel-8 | Alain |  | 22.942 |  |  |  |  |
| 1315 | 410 | Study on Service continuity between mobile and WLAN networks |  | 262d? | 2006-12-06 A | 2007-12-06 A | 100% |  | 2006-12-06 | 2007-12-06 | 262d? |  | finish no earlier than 2008-12-25 | S1 | 2096h | 2096h | FS_SMLSWLAN | NEC | Rel-8 | Alain |  | 22.937 |  |  |  |  |
| 1316 | 411 | Study on Services Alignment and Migration |  | 331d? | 2006-12-06 A | 2008-03-12 A | 100% |  | 2006-12-06 | 2008-03-12 | 331d? |  | finish no earlier than 2007-09-20 | S1 | 2648h | 2648h | FS_ServAl | Telefónica O2 | Rel-8 | Alain |  | 22.983 | SP-37 |  |  |  |

Notes:
- 1285: GP#40 completed. Align with RANimp-ANSS ongoing work item. GP#40 WID updated GP-080776=>GP-081784 (Conformance testing moved to A-GNSS WID) / Text5: Mungal Dhanda
- 1286: SP#42 completed by 22.071 CR0077
- 1287: GP#40 completed. Align with RANimp-ANSS ongoing work item. GP#40 WID updated GP-080776=>GP-081784 (Conformance testing moved to A-GNSS WID) / Text5: Mungal Dhanda
- 1288: SR in RP-080813. RP#42 WI closed at 95%. GERAN leading the work / considers performance requirements for Rel-9 / Text5: Etienne Chaponniere (echaponn@qualcomm.com)
- 1289: GP#45 completed / Text5: mats.y.samuelsson@ericsson.com, hakan.e.grunditz@ericsson.com
- 1290: GP#45 completed / Text5: hakan.e.grunditz@ericsson.com
- 1291: GP#41 completed / Text5: mats.y.samuelsson@ericsson.com
- 1292: GP#40 completed / Text5: Franz.Segerer@ROHDE-SCHWARZ.COM
- 1293: SP#42 completed
- 1294: Not completed internet-draft
- 1295: -
- 1296: SP#38 stopped. 25/07/08 Moved UID_31059 Study on All-IP Network (FS_AIPN/was AIPFS ) to Rel-7 out of the stopped Rel-8 Feature UID_31067 Deleted - All-IP Network (AIPN) / Text5: c.masyu@nttdocomo.co.jp
- 1297: 22.258 withdrawn, superseded by 22.278 (UID 320022). SP#38 stopped / Text5: c.masyu@nttdocomo.co.jp
- 1298: SP-35 stopped / Text5: dhshim@lge.com
- 1299: SP#38 stopped
- 1300: SP#38 stopped (no support) / Text5: andre.jarvis@three.co.uk
- 1301: SP#38 stopped
- 1302: CP#47 work stopped/abandoned / Text5: Udo Willenbrink, Jacques Seif
- 1303: CP#47 work stopped/abandoned / Text5: Udo Willenbrink (uwillenbrink@comprion.com )
- 1304: CP#47 work stopped/abandoned / Text5: jacques.seif@gemalto.com
- 1305: GP#43 work stopped/abandoned (completion 0%) / Text5: arsi.heino@nokia.com
- 1306: -
- 1307: Spin-off Rel-8 Feature Customized Alerting Tone (CAT) Service UID_340029 / Text5: Qing Huang (huangqing@chinamobile.com)
- 1308: SP#35 completed. Spin-off SA3 Study on Security Aspects of Remote Provisioning and Change of Subscription for M2M (UID_370053). SP#40 Spin-off new Feature UID_410030 (NIMTC) / Text5: Juergen Merkel
- 1309: SP#38 completed / Text5: Joerg Swetina (joerg.swetina@nw.neclab.eu)
- 1310: SP#37 completed. Spin-off New Feature UID_370026 Value-Added Services for Short Message Service (VAS4SMS) / Text5: Qing Huang (huangqing@chinamobile.com)
- 1311: SP#39 completed. Spin-off Rel-9 Feature UID_380057 (PWS) / Text5: mark.younge@t-mobile.com
- 1312: SP#37 completed. Spin-off new Feature UID_370084 (PPACR) / Text5: Katsuhiro NOGUCHI (noguchi@nttdocomo.co.jp)
- 1313: SP#38 completed. Spin-off New Feature UID_380062 (N3GTONSP). SP#40 WID updated SP-060930=>SP-080318. TR re-approved with new # 22.812=>22.912 / Text5: chris.friel@O2.com
- 1314: SP#38 completed. Spin-off New Feature UID_370026 (VAS4SM) / Text5: Qing Huang (huangqing@chinamobile.com)
- 1315: SP#38 completed / Text5: joerg.swetina@neclab.eu
- 1316: SP#39 completed. Spin-off Rel-9 Feature UID_330017 Services Alignment and Migration (ServAl) / Text5: chris.friel@O2.com

| ID | WBS | Task | Duration | Start | Finish | Complete | Baseline start | Baseline finish | Baseline duration | Constraint | Resources | Work | Actual work | Text1 | Text4 | Text5 | Text6 | Text8 | Text3 | Text2 | Text7 | Text11 | Text9 | Text12 |
| --- | --- | --- | --- | --- | --- | --- | --- | --- | --- | --- | --- | --- | --- | --- | --- | --- | --- | --- | --- | --- | --- | --- | --- | --- |
| 1317 | 412 | **Study on 3GPP System Architecture Evolution** | 1115d? | 2004-12-03 A | 2009-03-12 A | 100% | 2004-12-03 | 2009-03-12 | 1115d? |  | S2,S3 | 23456h | 23456h | FS_SAE | Vodafone | Chris Pudney | Rel-8 | Maurice |  |  |  |  |  |  |
| 1318 | 412.1 | Stage 2 Interim conclusion for RAN Work to start | 990d? | 2004-12-03 A | 2008-09-18 A | 100% | 2004-12-03 | 2008-09-18 | 990d? | finish no earlier than 2005-09-23 | S2 | 7920h | 7920h | FS_SAE | Vodafone | Chris Pudney | Rel-8 | Maurice | 23.882 |  |  |  |  |  |
| 1319 | 412.2 | Stage 2 study on 3GPP architectural development | 704d? | 2006-01-09 A | 2008-09-18 A | 100% | 2006-01-09 | 2008-09-18 | 704d? | finish no earlier than 2007-09-28 | S2 | 5632h | 5632h | FS_SAE | Vodafone | Chris Pudney | Rel-8 | Maurice | 23.882 |  |  |  |  |  |
| 1320 | 412.3 | Security study for Inter-access mobility between non-3GPP and 3GPP system | 334d? | 2007-09-03 A | 2009-03-12 A | 100% | 2007-09-03 | 2009-03-12 | 334d? | finish no earlier than 2009-03-12 | S3 | 2672h | 2672h | FS_SAE | Nokia | dajiang.zhang@nokia.com | Rel-8 | Dionisio | 33.821, 33.822 |  |  |  |  |  |
| 1321 | 413 | Study on Stage 2 aspects of IMS Service Brokering | 589d? | 2006-06-19 A | 2008-09-18 A | 100% | 2006-06-19 | 2008-09-18 | 589d? | finish no earlier than 2008-09-18 | S2 | 4712h | 4712h | FS_ISB_ST2 | Telcordia | raquel@research.telcordia.com | Rel-8 | Maurice | 23.810 |  |  |  |  |  |
| 1322 | 414 | Study on IMS utilizing multicast bearer services | 447d? | 2006-03-22 A | 2007-12-06 A | 100% | 2006-03-22 | 2007-12-06 | 447d? | finish no earlier than 2007-12-03 | S2 | 3576h | 3576h | FS_MLTICAST-IMS | Nokia Siemens Networks |  | Rel-8 | Maurice | 23.847 |  |  |  |  |  |
| 1323 | 415 | Study on Multimedia Session Continuity | 291d? | 2007-04-26 A | 2008-06-05 A | 100% | 2007-04-26 | 2008-06-05 | 291d? | finish no earlier than 2008-06-05 | S2 | 2328h | 2328h | FS_MMSC | LG Electronics |  | Rel-8 | Maurice | 23.893 |  |  |  |  |  |
| 1324 | 416 | **Study on centralized IMS service control** | 363d? | 2006-10-23 A | 2008-03-12 A | 100% | 2006-10-23 | 2008-03-12 | 363d? |  | S2,S1 | 7952h | 7952h | FS_ICS | Ericsson | peter.bleckert@ericsson.com | Rel-8 | Alain |  | PCG-21 | SP-38 |  |  |  |
| 1325 | 416.1 | Study on centralized IMS services requirements | 268d? | 2007-03-05 A | 2008-03-12 A | 100% | 2007-03-05 | 2008-03-12 | 268d? | start no earlier than 2007-03-05 | S1 | 2144h | 2144h | FS_ICS-S1 | NEC | joerg.swetina@neclab.eu | Rel-8 | Alain | 22.892 |  | SP-37 |  |  |  |
| 1326 | 416.2 | Study on centralized IMS services control | 363d? | 2006-10-23 A | 2008-03-12 A | 100% | 2006-10-23 | 2008-03-12 | 363d? | finish no earlier than 2008-02-21 | S2 | 2904h | 2904h | FS_IMS_CSC | Alcatel-Lucent | andy.bennett@alcatel-lucent.com | Rel-8 | Maurice | 23.892 |  |  |  |  |  |
| 1327 | 417 | Study on Architecture of IMS based Customized Alerting Tone (CAT) | 208d? | 2007-12-04 A | 2008-09-18 A | 100% | 2007-12-04 | 2008-09-18 | 208d? | finish no earlier than 2008-09-08 | S2 | 1664h | 1664h | FS_CAT-St2 | China Mobile | WANG, Jing (wangjing@chinamobilecom) | Rel-8 | Maurice | 23.872 | PCG-21 | SP-38 |  |  |  |
| 1328 | 418 | Study on Home (e)NodeB Security | 321d? | 2007-12-20 A | 2009-03-12 A | 100% | 2007-12-20 | 2009-03-12 | 321d? | finish no earlier than 2009-03-10 | S3 | 2568h | 2568h | FS_HNB_Sec | Huawei | yangyanmei@huawei.com | Rel-8 | Dionisio | 33.820 | PCG-21 | SP-38 |  |  |  |
| 1329 | 419 | Study on Transferring of emergency call data – in-band modem solution | 265d? | 2006-12-07 A | 2007-12-12 A | 100% | 2006-12-07 | 2007-12-12 | 265d? | finish no earlier than 2008-09-18 | S4 | 2120h | 2120h | eCALLIBMS | Airbiquity | lhong@airbiquity.com | Rel-8 | Paolo | 26.967 |  |  |  |  |  |
| 1330 | 420 | Study on Element Operations Systems Function (EOSF) definition | 266d? | 2007-06-07 A | 2008-06-12 A | 100% | 2007-06-07 | 2008-06-12 | 266d? | finish no earlier than 2008-12-11 | S5 | 2128h | 2128h | OAM7-NIM- EOSF | China Mobile | Li Jian (lijian@chinamobile.com) | Rel-8 | Dionisio | 32.819 |  |  |  |  |  |
| 1331 | 421 | Study on SA5 MTOSI XML Harmonization | 351d? | 2006-05-10 A | 2007-09-12 A | 100% | 2006-05-10 | 2007-09-12 | 351d? | finish no earlier than 2007-12-14 | S5 | 2808h | 2808h | OAM8-NIM-XML | Nortel | jduguay@nortel.com | Rel-8 | Dionisio | 32.818 |  |  |  |  |  |
| 1332 | 422 | Study on Common Profile Storage (CPS) Framework of User Data for network services and management | 244d? | 2006-07-03 A | 2007-06-07 A | 100% | 2006-07-03 | 2007-06-07 | 244d? | finish no earlier than 2007-06-07 | S5 | 1952h | 1952h | OAM7-CPS | T-Mobile | istvan.aba@t-mobile.at | Rel-8 | Dionisio | 32.808 |  |  |  |  |  |
| 1333 | 423 | Study on Management for LTE and SAE | 526d? | 2006-12-07 A | 2008-12-11 A | 100% | 2006-12-07 | 2008-12-11 | 526d? | finish no earlier than 2008-12-11 | S5 | 4208h | 4208h | FS_OAM_LTE_SAE | Ericsson | robert.petersen@ericsson.com | Rel-8 | Dionisio | 32.816 |  |  |  |  |  |
| 1334 | 424 | Study on Charging Aspects of 3GPP System Evolution | 179d? | 2007-04-02 A | 2007-12-06 A | 100% | 2007-04-02 | 2007-12-06 | 179d? | finish no earlier than 2007-12-06 | S5 | 1432h | 1432h | FS_SAEcharg | Nokia Siemens Networks | Gerald.Goermer@nsn.com | Rel-8 | Dionisio | 32.820 |  |  |  |  |  |
| 1335 | 425 | Study on AS-MRFC media server control protocol | 583d? | 2006-03-22 A | 2008-06-13 A | 100% | 2006-03-22 | 2008-06-13 | 583d? | finish no earlier than 2008-06-13 | C1 | 4664h | 4664h | MRFC | Hewlett-Packard | mark.syrett@hp.com | Rel-8 | Frederic | 24.880 |  |  |  |  |  |
| 1336 | 426 | Study on IMS Restoration Procedures | 310d? | 2007-03-26 A | 2008-05-30 A | 100% | 2007-03-26 | 2008-05-30 | 310d? | finish no earlier than 2008-05-30 | C4 | 2480h | 2480h | FS_IMS_RP | Ericsson | german.blanco@ericsson.com | Rel-8 | Kimmo | 23.820 |  |  |  |  |  |
| 1337 | 427 | Study on IMS Application Server Service Data Descriptions for AS interoperability | 261d? | 2007-09-14 A | 2008-09-12 A | 100% | 2007-09-14 | 2008-09-12 | 261d? | finish no earlier than 2008-09-12 | C4 | 2088h | 2088h | FS_IMS_ASIO | Alcatel-Lucent | Jean-Jacques Trottin | Rel-8 | Kimmo | 29.864 |  |  |  |  |  |
| 1338 | 428 | Study on Customized Alerting Tone (CAT) solution for voice and video call in CS domain | 261d? | 2007-09-14 A | 2008-09-12 A | 100% | 2007-09-14 | 2008-09-12 | 261d? |  | C4 | 626.4h | 626.4h | FS_CAT_VVC_CS | China Mobile | zhanghao@chinamobile.com | Rel-8 | Kimmo | 29.882 |  |  |  |  |  |
| 1339 | 429 | Study on InterWorking Function between MAP based and Diameter based interfaces | 266d? | 2007-11-30 A | 2008-12-05 A | 100% | 2007-11-30 | 2008-12-05 | 266d? | finish no earlier than 2008-12-05 | C4 | 2128h | 2128h | FS_MAP2Diam | Huawei | liming49985@huawei.com | Rel-8 | Kimmo | 29.805 | PCG-21 | CP-38 |  |  |  |
| 1340 | 430 | Study on Scope of future HSPA Evolution for 1.28 Mcps TDD | 186d? | 2007-09-14 A | 2008-05-30 A | 100% | 2007-09-14 | 2008-05-30 | 186d? | finish no earlier than 2008-05-30 | R1 | 1488h | 1488h | FS_RAN-LCRTDDHSPAEvo | RITT | Xu Fei | Rel-8 | Patrick | 25.824 |  | RP-37 | RP-080290 |  |  |
| 1341 | 431 | Study on Synchronized E-DCH for UTRA FDD | 126d? | 2007-09-14 A | 2008-03-07 A | 100% | 2007-09-14 | 2008-03-07 | 126d? | finish no earlier than 2008-03-14 | R1 | 1008h | 1008h | FS_RAN-UplinkSync | Nokia Siemens Networks | Karri.Ranta-aho@nsn.com | Rel-8 | Patrick | 25.823 |  | RP-37 | RP-080068 |  |  |
| 1342 | 432 | Study on Improved network controlled mobility between LTE and 3GPP2/mobile WiMAX radio technologies | 131d? | 2007-06-04 A | 2007-12-03 A | 100% | 2007-06-04 | 2007-12-03 | 131d? | finish no earlier than 2007-12-03 | R4 | 1048h | 1048h | FS_RAN-LTEmob | Motorola | hao.bi@Motorola.com | Rel-8 | Issam | 36.938 |  |  | RP-070827 |  |  |
| 1343 | 433 | Study on 3G Home NodeB/eNodeB | 325d? | 2007-03-05 A | 2008-05-30 A | 100% | 2007-03-05 | 2008-05-30 | 325d? | finish no earlier than 2008-05-30 | R4 | 2600h | 2600h | FS_RAN-HNBeNB | Motorola | howard.thomas@motorola.com | Rel-8 | Issam | 25.820 |  |  | RP-080289 |  |  |
| 1344 | 434 | Study on A-interface over IP | 126d? | 2007-08-31 A | 2008-02-22 A | 100% | 2007-08-31 | 2008-02-22 | 126d? | finish no earlier than 2008-02-22 | GP | 1008h | 1008h | AINTIP | China Mobile, Ericsson | paul.schliwa-bertling@ericsson.com | Rel-8 | Paolo | 43.903 |  |  |  |  |  |
| 1345 | 435 | Study on Multi-User Reusing-One-Slot | 782d? | 2007-11-16 A | 2010-11-12 A | 100% | 2007-11-16 | 2010-11-12 | 782d? | finish no earlier than 2010-11-12 | GP | 6248h | 6248h | MUROS | Nokia Siemens Networks | juergen.hofmann@nsn.com | Rel-8 | Paolo | 45.914 |  |  |  |  |  |
| 1346 | 436 | Study on Optimized Transmit Pulse Shape for Downlink EGPRS2-B | 657d? | 2007-11-16 A | 2010-05-21 A | 100% | 2007-11-16 | 2010-05-21 | 657d? | finish no earlier than 2010-05-27 | G1 | 5248.44h | 5248.44h | WIDER | Research In Motion, Nokia Siemens Networks | jdwyer@RIM.COM and eddie.riddington@nsn.com | Rel-8 | Paolo | 45.913 |  |  |  |  |  |
| 1347 | 437 | Deleted - Study on Mobility between 3GPP-WLAN Interworking and 3GPP Systems | 393d? | 2007-03-20 A | 2008-09-18 A | 100% | 2007-03-20 | 2008-09-18 | 393d? | finish no earlier than 2008-09-18 | S2 | 3144h | 3144h | FS_SM3GWLAN | Orange |  | Rel-8 | Maurice | withdrawn 23.827 |  |  |  | PCG-21 | SP-41 |
| 1348 | 438 | Deleted - equals 340035 -FS on Service continuity between mobile and WLAN networks | 75d? | 2007-09-03 A | 2007-12-14 A | 100% | 2007-09-03 | 2007-12-14 | 75d? | finish no earlier than 2007-12-14 | S1 | 600h | 600h | FSSCMobToW | BT | mike.meyerstein@bt.com | Rel-8 | Alain | 22.937 |  | SP-37 |  | PCG-21 | SP-39 |
| 1349 | 439 | Deleted - Study on Evaluation of LCS Control Plane Solution for EPS | 100d? | 2008-01-14 A | 2008-05-30 A | 100% | 2008-01-14 | 2008-05-30 | 100d? | finish no earlier than 2009-03-20 | S2 | 800h | 800h | FS_LCS_EPS | SiRF |  | Rel-8 | Maurice | 23.891 |  | SP-38 |  | PCG-21 | SP-40 |
| 1350 | 440 | Deleted - Study on HS-PDSCH serving cell change enhancements | 60d? | 2007-12-17 A | 2008-03-07 A | 100% | 2007-12-17 | 2008-03-07 | 60d? | finish no earlier than 2008-06-12 | R4 | 480h | 480h | FS_RAN-HSPDSCH | Qualcomm |  | Rel-8 | Issam | none | PCG-21 | RP-38 | RP-080070 | PCG-21 | RP-39 |
| 1351 | 441 | Deleted - Study on Dual-Cell HSDPA operation | 261d? | 2007-08-15 A | 2009-03-06 A | 100% | 2007-08-15 | 2009-03-06 | 261d? | finish no earlier than 2009-03-06 | R1 | 2088h | 2088h | FS_RAN-DCHS | Qualcomm | Josef Blanz | Rel-8 | Patrick | withdrawn 25.825 v100 | PCG-21 | RP-39 | RP-090066 | PCG-22 | RP-43 |
| 1352 | 442 | Release 7 Features | 679d? | 2005-05-02 A | 2007-12-06 A | 100% | 2005-05-02 | 2007-12-06 | 679d? | start no earlier than 2000-01-01 | CP,GP,RP,SP | 5432h | 5432h |  |  |  | Rel-7 | All |  |  |  |  |  |  |

Notes:
- 1317: SP#43 completed
- 1318: SP#41 completed
- 1319: SP#41 completed
- 1320: SP#43 completed
- 1321: SP#41 completed. No spin-off activity proposed. [Note: IMS Service Brokering enhancements UID_31088 moved back from R8 to R7 to give a home to 22228CR0036_(Rel-7)_S1-051232. Hence, Rel-7 ISB has Stage 1 only (and is misaligned with Rel-7 Stages 2/3.]
- 1322: SP#38 completed
- 1323: SP#40 completed
- 1324: SP#39 completed
- 1325: SP#39 completed
- 1326: SP#39 completed
- 1327: SP#41 completed as Rel-8
- 1328: SP#43 completed. Linked to RAN4 Study on 3G Home NodeB/eNodeB (UID_350039) and to SA5 Study on Self-Organizing Networks (SON) related OAM interfaces for Home NodeB (UID_360007)
- 1329: SP#38 completed. Spin-off WID UID_34042 (eCall_Phase2)
- 1330: SP#40 completed. WID updated SP-050608=>SP-070307
- 1331: SP#37 completed. WID updated SP-050295=>SP-070305
- 1332: SP#36 completed. Spin-off New Feature UID_400034 User Data Convergence (UDC)
- 1333: SP#42 completed
- 1334: SP#38 completed
- 1335: CP#40 completed. Spin-off New Feature UID_380035 (MRFC_TS)
- 1336: CP#40 completed. Spin-off WID UID_400012 (IMS_RP)
- 1337: CP#41 completed. Linked to SA5 Study on Common Profile Storage framework UID_320006. Spin-off WID UID_410003 (IMS_ASIO)
- 1338: CP#41 completed. Spin-off WID under Feature CAT UID_340029
- 1339: CP#42 completed. Spin-off implementation Building Block UID_410007 (MAP2Diam) under the SAES Feature UID_320005
- 1340: RP#40 completed
- 1341: RP#39 completed
- 1342: RP#38 completed
- 1343: RP#40 completed
- 1344: GP#37 completed. Spin-off implementation Feature AoIP (A-interface over IP) UID_50591
- 1345: GP#48 completed as Rel-8. Spin-off implementation WI UID_420002 VAMOS (Voice services over Adaptive Multi-user channels on One Slot)
- 1346: GP#46 completed
- 1347: SP#41 stopped. Draft TR 23.827 content implemented in TS 23.327.
- 1348: SP#39 stopped
- 1349: SP#40 spin-off Feature UID_400038 (LCS_CPS_EPS). SP#40 FS stopped
- 1350: RP#39 stopped (no TR produced). Spin-off HS-DSCH Serving Cell Change Enhancements (UID_39003)
- 1351: RP#43 stopped (draft TR 25.825 v100 withdrawn). Conclusions in RP-090318 (RAN1 findings of the UTRA Multi-Carrier Evolution study). RP#42 New WI approved on Dual-Cell HSDPA operation on adjacent carriers (UID_400052)
- 1352: -

| ID | WBS | Task | Type | Duration | Start | Finish | Complete | Remaining | Baseline start | Baseline finish | Baseline duration | Total slack | Constraint | Resources | Work | Actual work | Text1 | Text4 | Text5 | Text6 | Text8 | Text12 | Text11 | Text7 | Text2 |
| --- | --- | --- | --- | --- | --- | --- | --- | --- | --- | --- | --- | --- | --- | --- | --- | --- | --- | --- | --- | --- | --- | --- | --- | --- | --- |
| 1353 | 443 | **Identification of Communication Services in IMS** |  | 620d? | 2005-05-02 A | 2007-09-14 A | 100% |  | 2005-05-02 | 2007-09-14 | 620d? |  |  | S2,S1,C1,S5 | 13016h | 13016h | ServID | Ericsson | stephen.terrill@ericsson.com | Rel-7 | Maurice |  |  |  |  |
| 1354 | 443.1 | TR on ServID |  | 232d? | 2005-05-02 A | 2006-03-21 A | 100% |  | 2005-05-02 | 2006-03-21 | 232d? |  | finish no earlier than 2006-03-20 | S2 | 1856h | 1856h | ServID | Ericsson | stephen.terrill@ericsson.com | Rel-7 | Maurice |  |  |  |  |
| 1355 | 443.2 | Stage 1,2 of ServID |  | 144d? | 2005-11-11 A | 2006-05-31 A | 100% |  | 2005-11-11 | 2006-05-31 | 144d? |  | start no earlier than 2005-11-11 | S1,S2 | 1152h | 1152h | ServID | Ericsson | stephen.terrill@ericsson.com | Rel-7 | Maurice |  |  |  |  |
| 1356 | 443.3 | Stage 3 of ServID |  | 250d? | 2006-03-31 A | 2007-03-15 A | 100% |  | 2006-03-31 | 2007-03-15 | 250d? |  | finish no earlier than 2007-03-15 | C1 | 2000h | 2000h | ServID | Ericsson | christer.holmberg@ericsson.com | Rel-7 | Frederic |  |  |  |  |
| 1357 | 443.4 | Charging of ServID |  | 381d? | 2006-03-31 A | 2007-09-14 A | 100% |  | 2006-03-31 | 2007-09-14 | 381d? |  | finish no earlier than 2007-09-14 | S5 | 3048h | 3048h | ServID | Orange | alain.bibas@orange-ft.com | Rel-7 | Dionisio |  |  |  |  |
| 1358 | 444 | **Supporting Globally Routable User Agent URIs in IMS** |  | 415d? | 2005-11-14 A | 2007-06-15 A | 100% |  | 2005-11-14 | 2007-06-15 | 415d? |  |  | S2,S1,C1 | 7760h | 7760h | GRUU | Research In Motion | Adrian Buckley (abuckley@rim.com) | Rel-7 | Maurice |  |  |  |  |
| 1359 | 444.1 | Deleted - TR on GRUU |  | 219d? | 2005-11-14 A | 2006-09-14 A | 100% |  | 2005-11-14 | 2006-09-14 | 219d? |  | finish no earlier than 2006-09-14 | S2 | 1752h | 1752h | GRUU | Research In Motion | Adrian Buckley (abuckley@rim.com) | Rel-7 | Maurice | SP-32 |  |  |  |
| 1360 | 444.2 | Stage 1,2 of GRUU |  | 65d? | 2006-07-03 A | 2006-09-29 A | 100% |  | 2006-07-03 | 2006-09-29 | 65d? |  | start no earlier than 2006-07-03 | S1,S2 | 520h | 520h | GRUU | Research In Motion | Adrian Buckley (abuckley@rim.com) | Rel-7 | Maurice |  |  |  |  |
| 1361 | 444.3 | Stage 3 of GRUU |  | 271d? | 2006-06-02 A | 2007-06-15 A | 100% |  | 2006-06-02 | 2007-06-15 | 271d? |  | finish no earlier than 2007-06-15 | C1 | 2168h | 2168h | GRUU | CableLabs | Bernie McKibben (b.mckibben@cablelabs.com) | Rel-7 | Frederic |  |  |  |  |
| 1362 | 445 | **Multimedia Telephony Service for IMS** |  | 357d? | 2006-02-01 A | 2007-06-15 A | 100% |  | 2006-02-01 | 2007-06-15 | 357d? |  |  | S1,C1,S4 | 8976h | 8976h | MTSI | Ericsson | peter.bleckert@ericsson.com | Rel-7 | Alain |  |  |  |  |
| 1363 | 445.1 | Stage 1 of MTSI |  | 173d? | 2006-02-01 A | 2006-09-29 A | 100% |  | 2006-02-01 | 2006-09-29 | 173d? |  | start no earlier than 2006-02-01 | S1 | 1384h | 1384h | MTSI-REQ | Ericsson | peter.bleckert@ericsson.com | Rel-7 | Alain |  |  |  |  |
| 1364 | 445.2 | Stage 3 of MTSI |  | 330d? | 2006-03-10 A | 2007-06-14 A | 100% |  | 2006-03-10 | 2007-06-14 | 330d? |  | finish no earlier than 2007-06-15 | C1 | 2640h | 2640h | MTSI | Ericsson | christer.holmberg@ericsson.com | Rel-7 | Frederic |  |  |  |  |
| 1365 | 445.3 | Media handling and interaction in MTSI |  | 262d? | 2006-03-15 A | 2007-03-15 A | 100% |  | 2006-03-15 | 2007-03-15 | 262d? |  | finish no earlier than 2007-03-15 | S4 | 2096h | 2096h | MTSI-MHI | Ericsson | olle.franceschi@ericsson.com | Rel-7 | Paolo |  |  |  |  |
| 1366 | 445.4 | Deleted - duplicates UID7039 - IMS Multimedia Telephony Service | milestone | 0d? | 2007-06-15 A | 2007-06-15 A | 100% |  | 2007-06-15 | 2007-06-15 | 0d? |  | start no earlier than 2007-06-15 | S1 |  |  | MMTEL | Ericsson | peter.bleckert@ericsson.com | Rel-7 | Alain | SP-32 |  |  |  |
| 1367 | 446 | Multimedia Telephony Service for IMS (MTSI) - UE Conformance Testing |  | 387d | 2007-09-19 A | 2009-03-12 A | 100% |  | 2007-09-19 | 2009-03-12 | 387d |  | finish no earlier than 2009-03-13 | R5 | 1664h | 1664h | MTSI-UEConTest | Ericsson, Motorola | Leif.Mattisson@ericsson.com, Jacob.John@motorola.com | Rel-7 | Ingbert |  | RP-090056 |  |  |
| 1368 | 447 | TISPAN requirements for Multimedia Telephony with PSTN/ISDN simulation services |  | 58d? | 2007-09-18 A | 2007-12-06 A | 100% |  | 2007-09-18 | 2007-12-06 | 58d? |  | start no earlier than 2007-09-18 | S1 | 464h | 464h | TMMTEL7 |  |  | Rel-7 | Alain |  |  | SP-37 |  |
| 1369 | 448 | **Maintenance of TISPAN release 1 common IMS** |  | 58d? | 2007-09-18 A | 2007-12-06 A | 100% |  | 2007-09-18 | 2007-12-06 | 58d? |  |  | S2 | 1392h | 1392h | MCIMSTR1 | Ericsson | Raymond Forbes | Rel-7 | Maurice |  |  | SP-38 | PCG-21 |
| 1370 | 448.1 | SA1 aspects of MCIMSTR1 |  | 58d? | 2007-09-18 A | 2007-12-06 A | 100% |  | 2007-09-18 | 2007-12-06 | 58d? |  | finish no earlier than 2007-12-06 | S1 | 464h | 464h | MCIMSTR1-S1 | Telecom Italia | Marco.DeLuca1@telecomitalia.it | Rel-7 | Alain |  |  | SP-38 | PCG-21 |
| 1371 | 448.2 | SA2 aspects of MCIMSTR1 |  | 58d? | 2007-09-18 A | 2007-12-06 A | 100% |  | 2007-09-18 | 2007-12-06 | 58d? |  | finish no earlier than 2007-12-06 | S2 | 464h | 464h | MCIMSTR1-S2 | Ericsson | Raymond Forbes | Rel-7 | Maurice |  |  | SP-38 | PCG-21 |
| 1372 | 449 | **PS domain and IMS impacts for supporting IMS Emergency calls** |  | 2931d? | 2000-09-18 A | 2011-12-09 | 97% | 85.6d? | 2000-09-18 | 2011-12-09 | 2931d? | 260d |  | S2,S1 | 65261.8h | 52747h | EMC1 | Siemens | Rainer Liebhart | Rel-7 | Maurice |  |  |  |  |
| 1373 | 10.1.1 | Service Requirements for IP-based emergency calls |  | 985d | 2000-09-18 A | 2004-06-25 A | 100% |  | 2000-09-18 | 2004-06-25 | 985d |  | finish no earlier than 2004-06-25 | S1 | 7880h | 7880h | EMC1 | Siemens | Rainer Liebhart | Rel-7 | Alain |  |  |  |  |
| 1374 | 449.2 | Study on Stage 2 for IMS-level solution |  | 668d? | 2003-02-26 A | 2005-09-16 A | 100% |  | 2003-02-26 | 2005-09-16 | 668d? |  | finish no earlier than 2005-09-16 | S2 | 5344h | 5344h | EMC1 | Siemens | Rainer Liebhart | Rel-7 | Maurice |  |  |  |  |
| 1375 | 449.3 | Study on Stage 2 for GPRS-level solution |  | 301d? | 2004-10-14 A | 2005-12-08 A | 100% |  | 2004-10-14 | 2005-12-08 | 301d? |  | finish no earlier than 2005-12-08 | S2 | 2408h | 2408h | EMC1 | Siemens | Rainer Liebhart | Rel-7 | Maurice |  |  |  |  |
| 1376 | 449.4 | Stage 2 Specification Phase - IMS-level |  | 200d? | 2005-09-05 A | 2006-06-09 A | 100% |  | 2005-09-05 | 2006-06-09 | 200d? |  | finish no earlier than 2006-06-09 | S2 | 1600h | 1600h | EMC1 | Siemens | Rainer Liebhart | Rel-7 | Maurice |  |  |  |  |
| 1377 | 449.5 | Deleted - Stage 2 Specification Phase - GPRS-level | milestone | 0d? | 2007-03-02 A | 2007-03-02 A | 100% |  | 2007-03-02 | 2007-03-02 | 0d? |  | start no earlier than 2007-03-02 | S2 |  |  | EMC1 | Siemens | Rainer Liebhart | Rel-7 | Maurice | SP-32 |  |  |  |

Notes:
- 1353: WID approved SP#28. WID updated SP#32
- 1354: - / Text3: 23.816
- 1355: - / Text3: 22.228, 23.228, 23.203
- 1356: CP#32 approved WID / Text3: 23.218, 24.229
- 1357: - / Text3: 32.260, 32.298, 32.299
- 1358: SP#29 approved WID
- 1359: Abandoned
- 1360: SP#29 approved WID / Text3: 22.228, 23.228, 23.218, 24.229
- 1361: CP#32 approved WID / Text3: 24.229
- 1362: -
- 1363: - / Text3: 22.173
- 1364: - / Text3: 24.173
- 1365: - / Text3: 26.114
- 1366: - / Text3: 22.173
- 1367: RP#43 completed. Linked UID_7038 (MTSI) / Text3: 34.123-1, 34.123-2, 34.123-3, 34.229-1, 34.229-2
- 1368: - / Text3: 22.273 (EI 181 002 maintenance)
- 1369: - / Text3: http://www.3gpp.org/specs/TISPAN-IMS-ansfer.htm
- 1370: - / Text3: 22.173, 22.273
- 1371: - / Text3: 23.406, 23.417, 23.508,23.509, 23.511
- 1372: -
- 1373: - / Text3: 22.976 (DB shows 04/2003 withdrawn Study on PS domain services and capabilities (az: belongs this really here ?!)
- 1374: - / Text3: 23.867
- 1375: - / Text3: 23.867
- 1376: - / Text3: 23.167, 23.228, 23.060, 23.002, 23.271
- 1377: -

| ID | WBS | Task | Type | Duration | Start | Finish | Complete | Remaining | Baseline start | Baseline finish | Baseline duration | Total slack | Constraint | Resources | Work | Actual work | Text1 | Text4 | Text5 | Text6 | Text8 | Text3 | Text2 | Text7 | Text12 | Text10 | Text11 |
| --- | --- | --- | --- | --- | --- | --- | --- | --- | --- | --- | --- | --- | --- | --- | --- | --- | --- | --- | --- | --- | --- | --- | --- | --- | --- | --- | --- |
| 1378 | 10.1 | **Emergency Call Enhancements for IP& PS Based Calls – stage 3** |  | 1546d? | 2006-01-09 A | 2011-12-09 | 93% | 102.13d? | 2006-01-09 | 2011-12-09 | 1546d? | 260d |  | C1,IETF | 24581.8h | 12751.8h | EMC1 | Ericsson | alf.heidermark@ericsson.com | Rel-7 | Frederic |  |  |  |  |  |  |
| 1379 | 10.1.2 | CT1 IMS aspects to support IMS Emergency sessions |  | 350.82d | 2006-01-09 A | 2007-06-15 A | 100% |  | 2006-01-09 | 2007-06-15 | 350.82d |  | finish no earlier than 2007-06-15 | C1 | 2806.57h | 2806.57h | EMC1 | Ericsson | alf.heidermark@ericsson.com | Rel-7 | Frederic | 24.229 |  |  |  |  |  |
| 1380 | 449.6.2 | (IETF) CT1 IMS aspects to support IMS Emergency sessions |  | 451d? | 2006-01-09 A | 2011-12-09 | 75% | 112.75d? | 2006-01-09 | 2011-12-09 | 451d? | 260d | finish no earlier than 2011-12-09 | C1-IETF | 3608h | 2706h | EMC1 | Ericsson |  | Rel-7 | Frederic | ietf-sipcore-location-conveyance | PCG-27 | CP-52 |  |  |  |
| 1381 | 10.1.2 | Deleted - CT3 IMS aspects to support IMS Emergency sessions |  | 95d | 2006-05-08 A | 2006-09-15 A | 100% |  | 2006-05-08 | 2006-09-15 | 95d |  | finish no earlier than 2006-09-15 | C3 | 760h | 760h | EMC1 | Ericsson | alf.heidermark@ericsson.com | Rel-7 | Jiwan | 29.163 |  |  | CP-33 |  |  |
| 1382 | 10.1.5 | Deleted - CT3 PS domain aspects to support IMS Emergency sessions |  | 95d | 2006-05-08 A | 2006-09-15 A | 100% |  | 2006-05-08 | 2006-09-15 | 95d |  | start no earlier than 2006-05-08 | C3 | 760h | 760h | EMC1 | Ericsson | alf.heidermark@ericsson.com | Rel-7 | Jiwan | 29.061 |  |  | CP-33 |  |  |
| 1383 | 10.1.5 | CT1 PS domain aspects to support IMS Emergency sessions |  | 349.9d | 2006-01-09 A | 2007-06-15 A | 100% |  | 2006-01-09 | 2007-06-15 | 349.9d |  | finish no earlier than 2007-06-15 | C1 | 2799.2h | 2799.2h | EMC1 | Ericsson | alf.heidermark@ericsson.com | Rel-7 | Frederic | 24.008, 24.234 |  |  |  |  |  |
| 1384 | 10.1.5 | CT4 PS domain aspects to support IMS Emergency sessions |  | 365d | 2006-01-09 A | 2007-06-01 A | 100% |  | 2006-01-09 | 2007-06-01 | 365d |  | finish no earlier than 2007-06-01 | C4 | 2920h | 2920h | EMC1-GPRSc4 | Ericsson | alf.heidermark@ericsson.com | Rel-7 | Kimmo | 29.060 |  |  |  |  |  |
| 1385 | 450 | IMS Support of Conferencing |  | 355d? | 2005-11-04 A | 2007-03-15 A | 100% |  | 2005-11-04 | 2007-03-15 | 355d? |  | finish no earlier than 2007-03-15 | C1 | 2840h | 2840h | IMSconf | Alcatel-Lucent | Keith Drage (drage@alcatel-lucent.com) | Rel-7 | Frederic | 24.147, 24.229 |  |  |  |  |  |
| 1386 | 451 | Performance Characterization of VoIMS over HSDPA\EUL channels |  | 713d? | 2005-03-15 A | 2007-12-06 A | 100% |  | 2005-03-15 | 2007-12-06 | 713d? |  | finish no earlier than 2007-12-06 | S4 | 5704h | 5704h | VoIMS-PCVoIMS | Alcatel-Lucent | mcgowan@alcatel-lucent.com | Rel-7 | Paolo | 26.935 |  |  |  |  |  |
| 1387 | 452 | **WLAN-UMTS Interworking Phase 2** |  | 371d? | 2004-01-05 A | 2005-06-07 A | 100% |  | 2004-01-05 | 2005-06-07 | 371d? |  |  | S1 | 3888h | 3888h | WLAN2 | Telenor | frederic.paint@telenor.com | Rel-7 | Alain | 33.234 (SP-36 SA3 CRs approved) |  |  |  |  |  |
| 1388 | 452.1 | Stage 1 on Session Continuity |  | 115d? | 2004-01-05 A | 2004-06-11 A | 100% |  | 2004-01-05 | 2004-06-11 | 115d? |  | start no earlier than 2004-01-05 | S1 | 920h | 920h | WLAN-SC |  |  | Rel-7 | Alain | 22.234 |  |  |  | SP-24 |  |
| 1389 | 452.2 | Stage 2 on Session Continuity: covered by SAE | milestone | 0d? | 2005-06-07 A | 2005-06-07 A | 100% |  | 2005-06-07 | 2005-06-07 | 0d? |  | finish no earlier than 2005-06-07 | S2 |  |  | WLAN-SC |  |  | Rel-7 | Maurice |  |  |  |  |  |  |
| 1390 | 453 | **WLAN Interworking – Private Network access from WLAN 3GPP IP Access** |  | 252d? | 2005-10-10 A | 2006-09-26 A | 100% |  | 2005-10-10 | 2006-09-26 | 252d? |  |  | S2,C1,C3,C4 | 8936h | 8936h | WLANPNA | NEC | Toshiyuki Tamura (tamurato@aj.jp.nec.com) | Rel-7 | Maurice |  |  |  |  |  |  |
| 1391 | 453.1 | WLAN-PNA - Stage 2 |  | 185d? | 2005-10-10 A | 2006-06-23 A | 100% |  | 2005-10-10 | 2006-06-23 | 185d? |  | start no earlier than 2005-10-10 | S2 | 1480h | 1480h | WLANPNA-st2 | NEC | Toshiyuki Tamura (tamurato@aj.jp.nec.com) | Rel-7 | Maurice | 23.234, 33.234 |  |  |  |  |  |
| 1392 | 453.2 | **WLAN-PNA - Stage 3** |  | 170d? | 2006-02-01 A | 2006-09-26 A | 100% |  | 2006-02-01 | 2006-09-26 | 170d? |  |  | C1,C3,C4 | 5440h | 5440h | WLANPNA-st3 | NEC |  | Rel-7 | Frederic |  |  |  |  |  |  |
| 1393 | 453.2.1 | CT1 aspets for WLAN-PNA |  | 170d? | 2006-02-01 A | 2006-09-26 A | 100% |  | 2006-02-01 | 2006-09-26 | 170d? |  | start no earlier than 2006-02-01 | C1 | 1360h | 1360h | WLANPNA-st3 | NEC |  | Rel-7 | Frederic | 24.234 |  |  |  |  |  |
| 1394 | 453.2.2 | CT3 aspets for WLAN-PNA |  | 170d? | 2006-02-01 A | 2006-09-26 A | 100% |  | 2006-02-01 | 2006-09-26 | 170d? |  | start no earlier than 2006-02-01 | C3 | 1360h | 1360h | WLANPNA-st3 | NEC |  | Rel-7 | Jiwan | 29.161 |  |  |  |  |  |
| 1395 | 453.2.3 | Deleted - CT4 aspets for WLAN-PNA |  | 170d? | 2006-02-01 A | 2006-09-26 A | 100% |  | 2006-02-01 | 2006-09-26 | 170d? |  | start no earlier than 2006-02-01 | C4 | 1360h | 1360h | WLANPNA-st3 | NEC |  | Rel-7 | Kimmo | 29.234 |  |  | CP-32 |  |  |
| 1396 | 454 | **Enhancements to support QoS provisioning over 3GPP/WLAN Interworking** |  | 520d? | 2005-03-14 A | 2007-03-09 A | 100% |  | 2005-03-14 | 2007-03-09 | 520d? |  |  | S2,C4,C1 | 8360h | 8360h | WLANQOS | Samsung |  | Rel-7 | Maurice |  |  |  |  |  |  |
| 1397 | 454.1 | Deleted - TR on support of QoS on WLAN |  | 232d? | 2005-03-14 A | 2006-01-31 A | 100% |  | 2005-03-14 | 2006-01-31 | 232d? |  | start no earlier than 2005-03-14 | S2 | 1856h | 1856h | WLANQOS | Samsung |  | Rel-7 | Maurice | 23.836 |  |  | SP-32 |  |  |
| 1398 | 454.2 | Stage 2 on support of QoS over 3GPP/WLAN interworking |  | 108d? | 2006-02-01 A | 2006-06-30 A | 100% |  | 2006-02-01 | 2006-06-30 | 108d? |  | start no earlier than 2006-02-01 | S2 | 864h | 864h | WLANQOS | Samsung |  | Rel-7 | Maurice | 23.234 |  |  |  |  |  |
| 1399 | 454.3 | Stage 3 CT4 on support of QoS over 3GPP/WLAN Interworking |  | 121d? | 2006-09-22 A | 2007-03-09 A | 100% |  | 2006-09-22 | 2007-03-09 | 121d? |  | finish no earlier than 2007-03-09 | C4 | 968h | 968h | WLANQOS | Huawei | zhang.peng@huawei.com | Rel-7 | Kimmo | 29.234, 23.008 |  |  |  |  |  |
| 1400 | 454.4 | Stage 3 CT1 on support of QoS over 3GPP/WLAN Interworking |  | 64d? | 2006-09-04 A | 2006-11-30 A | 100% |  | 2006-09-04 | 2006-11-30 | 64d? |  | finish no earlier than 2006-11-30 | C1 | 512h | 512h | WLANQOS | Huawei | zhang.peng@huawei.com | Rel-7 | Frederic | 24.234 |  |  |  |  |  |
| 1401 | 455 | **Location Services enhancements** |  | 906d? | 2004-06-28 A | 2007-12-17 A | 100% |  | 2004-06-28 | 2007-12-17 | 906d? |  |  | S1,S2,GP,C4,R2 | 46933.6h | 46933.6h | LCS3 |  |  | Rel-7 | Alain |  |  |  |  |  |  |
| 1402 | 455.1 | Stage 2 for LCS3 (including IMS emergency location aspects) |  | 446d? | 2004-12-31 A | 2006-09-15 A | 100% |  | 2004-12-31 | 2006-09-15 | 446d? |  | finish no earlier than 2006-09-15 | S2 | 3568h | 3568h | LCS3 | SiRF | brodilitz@sirf.com | Rel-7 | Maurice | 23.271 |  |  |  |  |  |
| 1403 | 455.2 | LCS Enhancements related to Location-Based Services |  | 695d? | 2005-01-03 A | 2007-08-31 A | 100% |  | 2005-01-03 | 2007-08-31 | 695d? |  | finish no earlier than 2007-08-31 | GP | 5560h | 5560h | LCS3-LBS | SiRF | kjudge@sirf.com | Rel-7 | Paolo | 43.059, 44.031, 48.008, 49.031 |  |  |  |  |  |
| 1404 | 455.3 | CT4 aspects for LCS UEPos-LBS |  | 240d? | 2006-01-02 A | 2006-12-01 A | 100% |  | 2006-01-02 | 2006-12-01 | 240d? |  | finish no earlier than 2006-12-01 | C4 | 1920h | 1920h | LCS3-UEPos-LBS | SiRF | brodilitz@sirf.com | Rel-7 | Kimmo | 24.030, 24.080, 29.002 |  |  |  |  |  |
| 1405 | 455.4 | UE positioning - Velocity |  | 394d? | 2005-03-15 A | 2006-09-15 A | 100% |  | 2005-03-15 | 2006-09-15 | 394d? |  | finish no earlier than 2006-09-15 | R2 | 3152h | 3152h | LCS3-UEPos-Velocity | SiRF | BRodilitz@SiRF.com | Rel-7 | Joern | 25.305, 25.331, 25.410, 25.413, 25.453 |  |  |  |  | RP-060459 |
| 1406 | 455.5 | Inclusion of Uplink TDOA UE positioning method in the UTRAN specifications |  | 849d? | 2004-09-15 A | 2007-12-17 A | 100% |  | 2004-09-15 | 2007-12-17 | 849d? |  | finish no earlier than 2007-12-17 | R2 | 6792h | 6792h | LCS3-UEPos-UTDOA | TruePosition | Robert Gross (rgross@polariswireless.com) | Rel-7 | Joern | 25.305, 25.453 |  |  |  |  | RP-070797 |

Notes:
- 1378: -
- 1379: -
- 1380: Not completed internet-draft
- 1381: Cancelled for Rel-7 and there is now corresponding Rel-8 WI
- 1382: Cancelled for Rel-7 and there is now corresponding Rel-8 WI
- 1383: -
- 1384: -
- 1385: CP#35 revised WID
- 1386: -
- 1387: Created at TSG#27 because of WLAN items belonging to Rel-7
- 1388: -
- 1389: -
- 1390: -
- 1391: Approved at SP#29
- 1392: Approved at CP#29
- 1393: Approved at CP#29
- 1394: Approved at CP#29
- 1395: CT4#31; no impacts identified, therefore completed. CP-32 stopped
- 1396: Moved from FS section Feb 06. SP-30 updated WID
- 1397: SP-32 stopped
- 1398: SP-30 updated WID
- 1399: CP-32 approved WID
- 1400: CP-32 approved WID
- 1401: -
- 1402: SP#27 approved WID.
- 1403: -
- 1404: -
- 1405: Completed Sept 2006; SR in RP-060459
- 1406: Completed Nov 2007; SR in RP-070797

| ID | WBS | Task | Type | Duration | Start | Finish | Complete | Baseline start | Baseline finish | Baseline duration | Constraint | Resources | Work | Actual work | Text1 | Text4 | Text5 | Text6 | Text8 | Text12 | Text11 | Text2 | Text7 |
| --- | --- | --- | --- | --- | --- | --- | --- | --- | --- | --- | --- | --- | --- | --- | --- | --- | --- | --- | --- | --- | --- | --- | --- |
| 1407 | 455.6 | **LCS for 3GPP Interworking WLAN** |  | 700d? | 2004-06-28 A | 2007-03-02 A | 100% | 2004-06-28 | 2007-03-02 | 700d? |  | S1 | 11901.6h | 11901.6h | LCS3-IWLAN | Telcordia | Mike Loushine | Rel-7 | Alain |  |  |  |  |
| 1408 | 455.6.1 | FS on 3GPP system to WLAN Interworking with LCS |  | 512.7d? | 2004-06-28 A | 2006-06-30 A | 100% | 2004-06-28 | 2006-06-30 | 512.7d? | finish no earlier than 2005-09-29 | S1 | 4101.6h | 4101.6h | LCS3-IWLAN-FSs1 | Telcordia | Mike Loushine | Rel-7 | Alain |  |  |  |  |
| 1409 | 455.6.2 | Deleted - Study of work on an LCS architecture for I-WLAN. |  | 180d? | 2006-06-26 A | 2007-03-02 A | 100% | 2006-06-26 | 2007-03-02 | 180d? | finish no earlier than 2007-03-02 | S2 | 1440h | 1440h | LCS3-IWLAN-FSs2 | LG Electronics | dhshim@lge.com ; phede@lge.com | Rel-7 | Maurice | SP-35 |  |  |  |
| 1410 | 455.6.3 | Stage 2 for LCS architecture for I-WLAN |  | 95d? | 2006-10-23 A | 2007-03-02 A | 100% | 2006-10-23 | 2007-03-02 | 95d? | finish no earlier than 2007-03-02 | S2 | 760h | 760h | LCS3-IWLAN | LG Electronics | dhshim@lge.com ; phede@lge.com | Rel-7 | Maurice |  |  |  |  |
| 1411 | 455.7 | Deleted - UE positioning Rel-7 |  | 849d? | 2004-09-15 A | 2007-12-17 A | 100% | 2004-09-15 | 2007-12-17 | 849d? |  | RP | 6792h | 6792h | LCS3-UEpos |  |  | Rel-7 | Joern | RP-38 |  |  |  |
| 1412 | 455.8 | Deleted - RAN2 aspects for LBS | milestone | 0d? | 2005-06-15 A | 2005-06-15 A | 100% | 2005-06-15 | 2005-06-15 | 0d? | start no earlier than 2005-06-15 | R2 |  |  | LCS3-UEPos-LBS | SiRF | BRodilitz@SiRF.com | Rel-7 | Joern | RP-31 |  |  |  |
| 1413 | 456 | **MBMS Enhancements** |  | 625d? | 2005-07-11 A | 2007-11-30 A | 100% | 2005-07-11 | 2007-11-30 | 625d? |  | S1,R1,C3 | 10844.6h | 10844.6h | MBMSE | China Mobile | liuhongyfw@chinamobile.com | Rel-7 | Alain |  |  |  |  |
| 1414 | 456.1 | Stage 1 of MBMSE |  | 109d? | 2005-07-11 A | 2005-12-08 A | 100% | 2005-07-11 | 2005-12-08 | 109d? | finish no earlier than 2005-12-08 | S1 | 872h | 872h | MBMSE | China Mobile | liuhongyfw@chinamobile.com | Rel-7 | Alain |  |  |  |  |
| 1415 | 456.2 | MBMS FDD Physical layer Enhancements |  | 117.29d? | 2006-12-15 A | 2007-06-04 A | 100% | 2006-12-15 | 2007-06-04 | 117.29d? | finish no earlier than 2007-06-04 | R1 | 938.32h | 938.32h | MBMSE-RANPhysFDD | Ericsson | Lars.Lindbom@ericsson.com | Rel-7 | Patrick |  | RP-070290 |  |  |
| 1416 | 456.3 | MBMS TDD Physical layer Enhancements |  | 117.29d? | 2006-12-15 A | 2007-06-04 A | 100% | 2006-12-15 | 2007-06-04 | 117.29d? | finish no earlier than 2007-06-04 | R1 | 938.32h | 938.32h | MBMSE-RANPhysTDD | IPWireless | Nicholas Anderson | Rel-7 | Patrick |  | RP-070291 |  |  |
| 1417 | 456.4 | MBMS Low Chip Rate TDD Physical Layer Enhancement |  | 127d? | 2007-03-16 A | 2007-09-10 A | 100% | 2007-03-16 | 2007-09-10 | 127d? | finish no earlier than 2007-09-10 | R1 | 1016h | 1016h | MBMSE-RANPhysLCRTDD | RITT | Lin Hui | Rel-7 | Patrick |  | RP-070292 |  |  |
| 1418 | 456.5 | MBMS Mz interface |  | 260d? | 2006-12-04 A | 2007-11-30 A | 100% | 2006-12-04 | 2007-11-30 | 260d? | finish no earlier than 2007-05-11 | C3 | 2080h | 2080h | MBMSMz | Huawei | Deng Tingting (ttdeng@huawei.com) | Rel-7 | Jiwan |  |  |  |  |
| 1419 | 457 | **MBMS - UE Conformance Testing** |  | 657d? | 2007-06-01 A | 2009-12-04 A | 100% | 2007-06-01 | 2009-12-04 | 657d? |  | R5 | 13848h | 13848h | MBMSE_UEConTest |  |  | Rel-7 | Ingbert |  |  | PCG-21 | SP-40 |
| 1420 | 457.1 | Conformance Test Aspects – MBMS TDD Physical layer Enhancements – MBSFN for HCR and VHCR TDD |  | 336d? | 2007-06-01 A | 2008-09-12 A | 100% | 2007-06-01 | 2008-09-12 | 336d? | start no earlier than 2007-06-01 | R5 | 2688h | 2688h | MBMSE-RANPhysTDD_UEConTest | IPWireless | tspeight@ipwireless.com | Rel-7 | Ingbert |  | RP-080541 |  |  |
| 1421 | 457.2 | Conformance Test Aspects – MBMS LCR TDD Physical Layer Enhancement |  | 342d? | 2008-05-30 A | 2009-09-18 A | 100% | 2008-05-30 | 2009-09-18 | 342d? | finish no earlier than 2009-09-18 | R5 | 2728h | 2728h | MBMSE-RANPhysLCRTDD_UEConTest | CATT | chenxiaozhong@datangmobile.cn | Rel-7 | Ingbert |  | RP-090715 | PCG-21 | RP-40 |
| 1422 | 457.3 | Conformance Test Aspects – MBSFN for FDD |  | 397d? | 2008-05-30 A | 2009-12-04 A | 100% | 2008-05-30 | 2009-12-04 | 397d? | finish no earlier than 2009-12-04 | R5 | 3176h | 3176h | MBMSE-UEConTest_RANPhysFDD | Huawei | Xiang Li (trica_li@huawei.com) | Rel-7 | Ingbert |  | RP-091214 | PCG-21 | RP-40 |
| 1423 | 458 | MBMS User Service Extensions |  | 392d? | 2005-12-07 A | 2007-06-07 A | 100% | 2005-12-07 | 2007-06-07 | 392d? | finish no earlier than 2007-06-07 | S4 | 3136h | 3136h | MBMSUSE | Ericsson | Thorsten.Lohmar@ericsson.com | Rel-7 | Paolo |  |  |  |  |
| 1424 | 459 | **Advanced Global Navigation Satellite System (A-GNSS) concept** |  | 830d? | 2004-06-28 A | 2007-08-31 A | 100% | 2004-06-28 | 2007-08-31 | 830d? |  | S1,GP,R2 | 9553.6h | 9553.6h | LCS3-AGNSS | Alcatel | Michel.monnerat@thalesaleniaspace.com | Rel-7 | Alain |  |  |  |  |
| 1425 | 459.1 | Towards A-GNSS Concept |  | 811.2d? | 2004-06-28 A | 2007-08-31 A | 100% | 2004-06-28 | 2007-08-31 | 811.2d? | finish no earlier than 2007-08-31 | GP | 6489.6h | 6489.6h | AGNSS-GP | Alcatel | richard.couty@space.alcatel.fr | Rel-7 | Paolo |  |  |  |  |
| 1426 | 459.2 | Global Navigation Satellite System (GNSS) in UTRAN |  | 383d? | 2005-12-15 A | 2007-06-04 A | 100% | 2005-12-15 | 2007-06-04 | 383d? | finish no earlier than 2007-06-04 | R2 | 3064h | 3064h | LCS3-GNSS-UTRAN | France Telecom | alain.abinakhoul@francetelecom.com | Rel-7 | Joern |  | RP-070482 |  |  |
| 1427 | 459.3 | Deleted - Towards A-GNSS Concept | milestone | 0d? | 2007-02-16 A | 2007-02-16 A | 100% | 2007-02-16 | 2007-02-16 | 0d? | start no earlier than 2007-02-16 | S1 |  |  | GNSS | Alcatel | richard.couty@space.alcatel.fr | Rel-7 | Alain | SP-34 |  |  |  |
| 1428 | 460 | A-GPS Minimum Performance |  | 351d? | 2006-04-28 A | 2007-08-31 A | 100% | 2006-04-28 | 2007-08-31 | 351d? | finish no earlier than 2007-08-31 | GP | 2808h | 2808h | GAGR | Spirent | richard.catmur@spirentcom.com | Rel-7 | Paolo |  |  |  |  |
| 1429 | 461 | **USSD message delivery and transfer to USIM** |  | 376d? | 2004-03-05 A | 2005-08-12 A | 100% | 2004-03-05 | 2005-08-12 | 376d? |  | S1,C6 | 2762.4h | 2762.4h | USSD-USIM | Axalto | Christophe Dubois (cdubois@axalto.com) | Rel-7 | Alain |  |  |  |  |
| 1430 | 461.1 | Stage 1 |  | 152d? | 2004-03-18 A | 2004-10-15 A | 100% | 2004-03-18 | 2004-10-15 | 152d? | start no earlier than 2004-03-18 | S1 | 1216h | 1216h | USSD-USIM | Axalto | Christophe Dubois (cdubois@axalto.com) | Rel-7 | Alain |  |  |  |  |
| 1431 | 461.2 | Alignment with requirements regarding USSD usage |  | 193.3d? | 2004-03-05 A | 2005-08-12 A | 100% | 2004-03-05 | 2005-08-12 | 193.3d? | finish no earlier than 2005-08-12 | C6 | 1546.4h | 1546.4h | USSD-USIM | Axalto | Christophe Dubois (cdubois@axalto.com) | Rel-7 | Xavier |  |  |  |  |

Notes:
- 1407: -
- 1408: - / Text3: 22.935
- 1409: Updated WID at SP#32 to change "stage 2" to "study" , duplicated UID 320017 deleted. SP#33 TR for Information. Last mention SP-35 Mar 2007 (abandoned ?) / Text3: 23.837
- 1410: WID at SP#55 / Text3: 23.234, 23.271, 23.167
- 1411: -
- 1412: - / Text3: 25.305, 25.331, 25.410, 25.413, 25.453
- 1413: -
- 1414: Structure created by MCC to include RAN aspects under SA1 Feature / Text3: 22.146, 22.246, 22.228
- 1415: Completed May 2007; SR in RP-070290 / Text3: 25.211, 25.212, 25.213, 25.101, 25.104, 25.331, 25.433, 25.346, 25.306
- 1416: Completed May 2007; SR in RP-070291 / Text3: 25.346, 25.221, 25.222, 25.223, 25.224, 25.306, 25.331, 25.402, 25.433, 25.102, 25.105, 25.123
- 1417: Completed May 2007; SR in RP-070292 / Text3: 25.346, 25.221, 25.222, 25.223, 25.224, 25.306, 25.331, 25.402, 25.433, 25.102, 25.105, 25.123
- 1418: - / Text3: 29.061
- 1419: Linked to Rel-7 Feature UID_31084 (MBMSE)
- 1420: RP#41 completed / Text3: 34.108, 34.122, 34.123-1/2/3
- 1421: RP#45 completed / Text3: 34.108, 34.123-1
- 1422: RP#46 completed / Text3: 34.108, 34.109, 34.121-1, 34.121-2, 34.123-1, 34.123-2, 34.123-3
- 1423: - / Text3: 26.346, 26.946
- 1424: -
- 1425: GP#36 completed
- 1426: Completed Sept 2006; SR in RP-070482 / Text3: 25.305, 25.331, 25.306, 25.413, 25.423, 25.433, 25.453, 25.302, 25.215, 25.401, 25.402, 25.450, 25.452
- 1427: -
- 1428: - / Text3: 45.005, 51.010
- 1429: -
- 1430: - / Text3: 22.090
- 1431: -

| ID | WBS | Task | Type | Duration | Start | Finish | Complete | Baseline start | Baseline finish | Baseline duration | Constraint | Resources | Work | Actual work | Text1 | Text4 | Text5 | Text6 | Text8 | Text3 | Text12 |
| --- | --- | --- | --- | --- | --- | --- | --- | --- | --- | --- | --- | --- | --- | --- | --- | --- | --- | --- | --- | --- | --- |
| 1432 | 462 | **Combinational Services** |  | 296d? | 2005-01-17 A | 2006-03-06 A | 100% | 2005-01-17 | 2006-03-06 | 296d? |  | S1,S2,C1,S4 | 5176h | 5176h | CSICS | TeliaSonera | Robert.Frank@teliasonera.com | Rel-7 | Alain |  |  |
| 1433 | 462.1 | Stage 1 for CSICS |  | 104d? | 2005-01-17 A | 2005-06-09 A | 100% | 2005-01-17 | 2005-06-09 | 104d? | start no earlier than 2005-01-17 | S1 | 832h | 832h | CSICS | TeliaSonera | Robert.Frank@teliasonera.com | Rel-7 | Alain | 22.279 |  |
| 1434 | 462.2 | Stage 2 for CSICS |  | 130d? | 2005-01-17 A | 2005-07-15 A | 100% | 2005-01-17 | 2005-07-15 | 130d? | start no earlier than 2005-01-17 | S2 | 1040h | 1040h | CSICS | TeliaSonera | Robert.Frank@teliasonera.com | Rel-7 | Maurice | 23.279 |  |
| 1435 | 462.3 | Stage 3 for CSICS CN aspects |  | 221d? | 2005-05-02 A | 2006-03-06 A | 100% | 2005-05-02 | 2006-03-06 | 221d? | finish no earlier than 2006-03-06 | C1 | 1768h | 1768h | CSICS | Vodafone | peter.dawes@vodafone.com | Rel-7 | Frederic | 24.879, 24.279, 24.229, 24.008 |  |
| 1436 | 462.4 | Stage 3 for codec aspects |  | 192d? | 2005-03-15 A | 2005-12-07 A | 100% | 2005-03-15 | 2005-12-07 | 192d? | finish no earlier than 2005-12-07 | S4 | 1536h | 1536h | CSICS-Codec | Ericsson | Per.Frojdh@ericsson.com | Rel-7 | Paolo | 26.141, 26.235 |  |
| 1437 | 463 | **CAMEL Trunk Triggers** |  | 251d? | 2004-12-17 A | 2005-12-05 A | 100% | 2004-12-17 | 2005-12-05 | 251d? |  | S1,C4 | 6024h | 6024h | TTCAMEL | Nortel | Amar Deol (deola@nortelnetworks.com) | Rel-7 | Alain |  |  |
| 1438 | 463.1 | Stage 1 for CAMEL Trunk Triggers |  | 251d? | 2004-12-17 A | 2005-12-05 A | 100% | 2004-12-17 | 2005-12-05 | 251d? |  | S1 | 2008h | 2008h | TTCAMEL | Nortel | Amar Deol (deola@nortelnetworks.com) | Rel-7 | Alain | 22.078 |  |
| 1439 | 463.2 | CAMEL Trunk Originated Trigger Detection Points |  | 251d? | 2004-12-17 A | 2005-12-05 A | 100% | 2004-12-17 | 2005-12-05 | 251d? | start no earlier than 2004-12-17 | C4 | 2008h | 2008h | CamelR7 | Nortel | David Hutton (dhutton@nortel.com) | Rel-7 | Kimmo |  |  |
| 1440 | 464 | **IMS Service Brokering enhancements** |  | 69d? | 2005-12-07 A | 2006-03-13 A | 100% | 2005-12-07 | 2006-03-13 | 69d? |  | S1 | 1104h | 1104h | ISB | Telcordia | jbakker@telcordia.com | Rel-7 | Alain | 22.228 |  |
| 1441 | 464.1 | Stage 1 for ISB |  | 69d? | 2005-12-07 A | 2006-03-13 A | 100% | 2005-12-07 | 2006-03-13 | 69d? | finish no earlier than 2006-03-13 | S1 | 552h | 552h | ISB-s1 | Telcordia | jbakker@telcordia.com | Rel-7 | Alain | 22.228 |  |
| 1442 | 465 | **Enhancements of VGCS for public authority officials** |  | 731d? | 2004-08-27 A | 2007-06-15 A | 100% | 2004-08-27 | 2007-06-15 | 731d? |  | S1,C1,C4,G2 | 25920h | 25920h | EVGCS |  |  | Rel-7 | Alain | 43.068, 44.068, 24.008, 29.002 |  |
| 1443 | 465.1 | Stage 1 | milestone | 0d? | 2004-08-27 A | 2004-08-27 A | 100% | 2004-08-27 | 2004-08-27 | 0d? | finish no earlier than 2004-08-27 | S1 |  |  | EVGCS | Siemens | Joerg Swetina (joerg.swetina@nw.neclab.eu) | Rel-7 | Alain | 42.068, 43.068 |  |
| 1444 | 465.2 | **Architecture and protocol aspects** |  | 731d? | 2004-08-27 A | 2007-06-15 A | 100% | 2004-08-27 | 2007-06-15 | 731d? |  | C1,C4 | 14904h | 14904h | EVGCS | Siemens | robert.zaus@nsn.com | Rel-7 | Frederic | 43.068, 44.068 |  |
| 1445 | 465.2.1 | CT1 aspects of EVGCS |  | 731d? | 2004-08-27 A | 2007-06-15 A | 100% | 2004-08-27 | 2007-06-15 | 731d? | finish no earlier than 2006-09-15 | C1 | 5848h | 5848h | EVGCS | Siemens | robert.zaus@nsn.com | Rel-7 | Frederic | 43.068, 44.068, 24.008 |  |
| 1446 | 465.2.2 | CT4 aspects of EVGCS |  | 401d? | 2004-08-27 A | 2006-03-10 A | 100% | 2004-08-27 | 2006-03-10 | 401d? | finish no earlier than 2006-03-10 | C4 | 3208h | 3208h | EVGCS | Siemens | robert.zaus@nsn.com | Rel-7 | Kimmo | 29.002 |  |
| 1447 | 465.3 | GERAN2 aspects |  | 646d? | 2004-08-27 A | 2007-02-16 A | 100% | 2004-08-27 | 2007-02-16 | 646d? | finish no earlier than 2007-02-16 | G2 | 5168h | 5168h | EVGCS | Siemens | kenneth.isaacs@roke.co.uk | Rel-7 | Gert |  |  |
| 1448 | 466 | **Improvements of VGCS for parallel use of services** |  | 523d? | 2005-03-15 A | 2007-03-15 A | 100% | 2005-03-15 | 2007-03-15 | 523d? |  | S1 | 12230.2h | 12230.2h | IVGCS |  |  | Rel-7 | Alain |  |  |
| 1449 | 466.1 | Service Requirements for VGCS improvements |  | 62d? | 2005-03-15 A | 2005-06-08 A | 100% | 2005-03-15 | 2005-06-08 | 62d? | finish no earlier than 2005-06-08 | S1 | 496h | 496h | IVGCS | T-Mobile | kurt.bischinger@t-mobile.at | Rel-7 | Alain | 42.068 |  |
| 1450 | 466.2 | Stage 2 modifications for VGCS improvements |  | 335d? | 2005-12-01 A | 2007-03-14 A | 100% | 2005-12-01 | 2007-03-14 | 335d? | start no earlier than 2005-12-01 | C1 | 2680h | 2680h | IVGCS | T-Mobile | kurt.bischinger@t-mobile.at | Rel-7 | Frederic | 43.068 |  |
| 1451 | 466.3 | **Protocol aspects** |  | 336d? | 2005-12-01 A | 2007-03-15 A | 100% | 2005-12-01 | 2007-03-15 | 336d? |  | C1 | 5376h | 5376h | IVGCS | T-Mobile | Dieter Jacobsohn | Rel-7 | Frederic | 44.068 |  |
| 1452 | 466.3.1 | CT1 aspects of IVGCS |  | 336d? | 2005-12-01 A | 2007-03-15 A | 100% | 2005-12-01 | 2007-03-15 | 336d? | finish no earlier than 2007-03-15 | C1 | 2688h | 2688h | IVGCS | T-Mobile |  | Rel-7 | Frederic | 43.068, 44.068 |  |
| 1453 | 466.3.2 | Deleted - CT4 aspects of IVGCS | milestone | 0d? | 2007-03-09 A | 2007-03-09 A | 100% | 2007-03-09 | 2007-03-09 | 0d? | finish no earlier than 2007-03-09 | C4 |  |  | IVGCS-St3-c4 | T-mobile |  | Rel-7 | Kimmo | 29.002 | CP-35 |
| 1454 | 467 | **OSA Rel-7** |  | 584d? | 2005-03-15 A | 2007-06-08 A | 100% | 2005-03-15 | 2007-06-08 | 584d? |  | S1,C5 | 17920h | 17920h | OSA7 | AePONA | eamonn.murray@aepona.com | Rel-7 | Alain |  |  |
| 1455 | 467.1 | Service Requirements for OSA Service Broker |  | 62d? | 2005-03-15 A | 2005-06-08 A | 100% | 2005-03-15 | 2005-06-08 | 62d? | finish no earlier than 2005-06-08 | S1 | 496h | 496h | OSA7-SB | AePONA | eamonn.murray@aepona.com | Rel-7 | Alain | 22.127 |  |
| 1456 | 467.2 | Stage 2 OSA API Service Brokering |  | 156d? | 2006-04-28 A | 2006-12-01 A | 100% | 2006-04-28 | 2006-12-01 | 156d? |  | C5 | 1248h | 1248h | OSA7-SB | AePONA | damian.oneill@aepona.com | Rel-7 | Kimmo | 23.198 |  |
| 1457 | 467.3 | Stage 3 OSA API Service Brokering |  | 156d? | 2006-04-28 A | 2006-12-01 A | 100% | 2006-04-28 | 2006-12-01 | 156d? | finish no earlier than 2006-12-01 | C5 | 1248h | 1248h | OSA7-SB | AePONA | damian.oneill@aepona.com | Rel-7 | Kimmo | 29.198-16 |  |

Notes:
- 1432: -
- 1433: -
- 1434: -
- 1435: -
- 1436: -
- 1437: -
- 1438: -
- 1439: -
- 1440: No CR submitted in rel-8 (according to CR database).
- 1441: No Rel-8 changes
- 1442: Moved from Rel-6 UID_50563 Enhancements of VGCS in public networks for communication of public authority officials
- 1443: Voice Group Call Service
- 1444: -
- 1445: -
- 1446: -
- 1447: -
- 1448: Voice Group Call Service
- 1449: -
- 1450: -
- 1451: Previous name (before CT32) was Architecture and protocol aspects
- 1452: -
- 1453: CT4#33 stage 2 solution is still open. ...
- 1454: -
- 1455: az: WID URL corrected
- 1456: -
- 1457: -

| ID | WBS | Task | Type | Duration | Start | Finish | Complete | Remaining | Baseline start | Baseline finish | Baseline duration | Total slack | Constraint | Resources | Work | Actual work | Text1 | Text3 | Text4 | Text5 | Text6 | Text8 | Text12 | Text11 |
| --- | --- | --- | --- | --- | --- | --- | --- | --- | --- | --- | --- | --- | --- | --- | --- | --- | --- | --- | --- | --- | --- | --- | --- | --- |
| 1458 | 467.4 | **OSA Stage 2/3 enhancements** |  | 291d? | 2006-04-28 A | 2007-06-08 A | 100% |  | 2006-04-28 | 2007-06-08 | 291d? |  |  | C5 | 10256h | 10256h | OSA7 | 29.198/9, 23.198 | AePONA | damian.oneill@aepona.com | Rel-7 | Kimmo |  |  |
| 1459 | 467.4.1 | Parlay X Message Broadcast Web Service |  | 156d? | 2006-04-28 A | 2006-12-01 A | 100% |  | 2006-04-28 | 2006-12-01 | 156d? |  | finish no earlier than 2006-12-01 | C5 | 1248h | 1248h | OSA7 | 29.199-15, 23.198 | ETRI |  | Rel-7 | Kimmo |  |  |
| 1460 | 467.4.2 | Parlay X Geocoding Web Service |  | 156d? | 2006-04-28 A | 2006-12-01 A | 100% |  | 2006-04-28 | 2006-12-01 | 156d? |  | finish no earlier than 2006-12-01 | C5 | 1248h | 1248h | OSA7 | 29.199-16, 23.198 | ETRI |  | Rel-7 | Kimmo |  |  |
| 1461 | 467.4.3 | Parlay X Application driven QoS Web Service |  | 226d? | 2006-04-28 A | 2007-03-09 A | 100% |  | 2006-04-28 | 2007-03-09 | 226d? |  | finish no earlier than 2007-03-09 | C5 | 1808h | 1808h | OSA7 | 29.199-17, 23.198 | BT |  | Rel-7 | Kimmo |  |  |
| 1462 | 467.4.4 | Parlay-X Device Capabilities and Configuration |  | 162d? | 2006-10-26 A | 2007-06-08 A | 100% |  | 2006-10-26 | 2007-06-08 | 162d? |  | finish no earlier than 2007-06-09 | C5 | 1296h | 1296h | OSA7 | 29.199-18, 23.198 | Telenor |  | Rel-7 | Kimmo |  |  |
| 1463 | 467.4.5 | Parlay-X Multimedia Streaming Session Management Web Service |  | 97d? | 2006-10-26 A | 2007-03-09 A | 100% |  | 2006-10-26 | 2007-03-09 | 97d? |  | start no earlier than 2006-10-26 | C5 | 776h | 776h | OSA7 | 29.199-19, 23.198 | Telenor |  | Rel-7 | Kimmo |  |  |
| 1464 | 467.4.6 | Parlay-X Multimedia Multicast Control Web Service |  | 97d? | 2006-10-26 A | 2007-03-09 A | 100% |  | 2006-10-26 | 2007-03-09 | 97d? |  | start no earlier than 2006-10-26 | C5 | 776h | 776h | OSA7 | 29.199-20, 23.198 | ETRI |  | Rel-7 | Kimmo |  |  |
| 1465 | 467.4.7 | OSA API Conference Call Control SCF |  | 97d? | 2006-10-26 A | 2007-03-09 A | 100% |  | 2006-10-26 | 2007-03-09 | 97d? |  | start no earlier than 2006-10-26 | C5 | 776h | 776h | OSA7 | 29.198-04-5, 23.198 | Ericsson |  | Rel-7 | Kimmo |  |  |
| 1466 | 468 | **Selective Disabling of UE Capabilities** |  | 624.36d? | 2005-01-24 A | 2007-06-15 A | 100% |  | 2005-01-24 | 2007-06-15 | 624.36d? |  |  | S1,S2,C1 | 12351.7h | 12351.7h | SDoUE |  | Motorola |  | Rel-7 | Alain |  |  |
| 1467 | 468.1 | Stage 1 of SDoUE |  | 393.6d? | 2005-01-24 A | 2006-12-08 A | 100% |  | 2005-01-24 | 2006-12-08 | 393.6d? |  | finish no earlier than 2006-12-08 | S1 | 3148.8h | 3148.8h | SDoUE-CR | 22.011 | Motorola |  | Rel-7 | Alain |  |  |
| 1468 | 468.2 | Deleted - TR on different possible architectures |  | 195d? | 2005-03-21 A | 2005-12-16 A | 100% |  | 2005-03-21 | 2005-12-16 | 195d? |  | finish no earlier than 2005-12-16 | S2 | 1560h | 1560h | SDoUE-FS | 23.805 abandonned at SP-30; descendant C1 24.305 | Vodafone | Gavin.Wong@vodafone.com | Rel-7 | Maurice | SP-30 |  |
| 1469 | 468.3 | Stage 3 of SDoUE |  | 331d? | 2006-03-10 A | 2007-06-15 A | 100% |  | 2006-03-10 | 2007-06-15 | 331d? |  | finish no earlier than 2007-06-15 | C1 | 2648h | 2648h | SDoUE | 24.305 | Ericsson | christian.herrero@ericsson.com | Rel-7 | Frederic |  |  |
| 1470 | 469 | **Network selection enhancements (NSP)** |  | 328d? | 2006-03-15 A | 2007-06-15 A | 100% |  | 2006-03-15 | 2007-06-15 | 328d? |  |  | S1 | 6320h | 6320h | NSP-CR | 22.101, 22.011, 23.122, 24.008, 25.304, 31.102, 45.008 | O2 | chris.friel@O2.com | Rel-7 | Alain |  |  |
| 1471 | 469.1 | Stage 1 of NSP |  | 191d? | 2006-03-15 A | 2006-12-06 A | 100% |  | 2006-03-15 | 2006-12-06 | 191d? |  | start no earlier than 2006-03-15 | S1 | 1528h | 1528h | NSP-TS | 22.101, 22.011, 23.122, 24.008, 25.304, 31.102, 45.008 | O2 | chris.friel@O2.com | Rel-7 | Alain |  |  |
| 1472 | 469.2 | Procedural aspects of NSP |  | 271d? | 2006-06-02 A | 2007-06-15 A | 100% |  | 2006-06-02 | 2007-06-15 | 271d? |  | finish no earlier than 2007-06-15 | C1 | 2168h | 2168h | NSP-CR | 23.122, 24.008, 31.102 | Motorola | Andrew Howell | Rel-7 | Frederic |  |  |
| 1473 | 470 | Network selection enhancements (NSP) - UE Conformance Testing |  | 396d? | 2007-06-01 A | 2008-12-05 A | 100% |  | 2007-06-01 | 2008-12-05 | 396d? |  | finish no earlier than 2008-12-05 | R5 | 3168h | 3168h | NSP-CR_UEConTest | 34.108, 34.123-1, 34.123-2, 34.123-3 | Nokia | jarkko.hellsten@nokia.com | Rel-7 | Ingbert |  | RP-080819 |
| 1474 | 471 | **Access Class Barring and Overload Protection** |  | 650d? | 2004-03-15 A | 2006-09-08 A | 100% |  | 2004-03-15 | 2006-09-08 | 650d? |  |  | S2,C1 | 3568h | 3568h | ACBOP | 23.898 | Vodafone | Chris Pudney | Rel-7 | Maurice |  |  |
| 1475 | 471.1 | TR on Stage 2 |  | 274d? | 2004-03-15 A | 2005-03-31 A | 100% |  | 2004-03-15 | 2005-03-31 | 274d? |  | finish no earlier than 2005-03-31 | S2 | 2192h | 2192h | ACBOP | 23.898 | NTT DoCoMo | Jean-Jacques Davidian (davidian@docomo.fr) | Rel-7 | Maurice |  |  |
| 1476 | 471.2 | Stage 3 CN aspects of ACBOP |  | 172d? | 2005-06-06 A | 2006-01-31 A | 100% |  | 2005-06-06 | 2006-01-31 | 172d? |  | start no earlier than 2005-06-06 | C1 | 1376h | 1376h | ACBOP | 24.008 |  |  | Rel-7 | Frederic |  |  |
| 1477 | 471.3 | Deleted - Potential impact on Iu interface Overload functionality | milestone | 0d? | 2004-03-15 A | 2004-03-15 A | 100% |  | 2004-03-15 | 2004-03-15 | 0d? |  | finish no earlier than 2004-03-15 | RP |  |  | ACBOP | 25.413 |  |  | Rel-7 | Issam | RP-25 |  |
| 1478 | 471.4 | Deleted - Extra ACBOP information in RAN | milestone | 0d? | 2004-03-15 A | 2004-03-15 A | 100% |  | 2004-03-15 | 2004-03-15 | 0d? |  | finish no earlier than 2004-03-15 | RP |  |  | ACBOP | 25.331 |  |  | Rel-7 | Issam | RP-25 |  |
| 1479 | 471.5 | Deleted - Extra ACBOP information in GERAN | milestone | 0d? | 2006-09-08 A | 2006-09-08 A | 100% |  | 2006-09-08 | 2006-09-08 | 0d? |  | start no earlier than 2006-09-08 | GP |  |  | ACBOP | 44.018 |  |  | Rel-7 | Paolo | RP-33 |  |
| 1480 | 472 | **System enhancements for fixed broadband access to IMS** |  | 2114d? | 2003-11-05 A | 2011-12-09 | 81% | 411.76d? | 2003-11-05 | 2011-12-09 | 2114d? | 260d |  | S2,S3,S5,C1,C3,C4,IETF | 75276.8h | 31974.4h | FBI |  |  |  | Rel-7 | Maurice |  |  |
| 1481 | 472.1 | **TISPAN Rel 1 related aspects** |  | 2114d? | 2003-11-05 A | 2011-12-09 | 78% | 472.27d? | 2003-11-05 | 2011-12-09 | 2114d? | 260d |  | S2,S3,C1,C3,C4,IETF | 57652.8h | 26886.4h | FBI-TIS1 |  |  |  | Rel-7 | Maurice |  |  |
| 1482 | 472.1.1 | Stage 2 of FBI for TISPAN R1 |  | 365d? | 2004-10-14 A | 2006-03-08 A | 100% |  | 2004-10-14 | 2006-03-08 | 365d? |  | start no earlier than 2004-10-14 | S2 | 2920h | 2920h | FBI-TIS1 |  |  |  | Rel-7 | Maurice |  |  |

Notes:
- 1458: CP#34: WID updated. Completion 12/06 =>03/07
- 1459: -
- 1460: -
- 1461: -
- 1462: -
- 1463: -
- 1464: -
- 1465: -
- 1466: Moved from FS section Feb 06
- 1467: Moved from FS section Feb 06
- 1468: Moved from FS section Feb 06. Abandoned at SP-30
- 1469: -
- 1470: -
- 1471: -
- 1472: -
- 1473: RP#42 completed. Testing for Feature UID_7041 (NSP-CR)
- 1474: -
- 1475: -
- 1476: -
- 1477: -
- 1478: -
- 1479: -
- 1480: -
- 1481: -
- 1482: -

| ID | WBS | Task | Duration | Start | Finish | Complete | Remaining | Baseline start | Baseline finish | Baseline duration | Total slack | Constraint | Resources | Work | Actual work | Text1 | Text4 | Text5 | Text6 | Text8 | Text2 | Text3 | Text7 | Text12 |
| --- | --- | --- | --- | --- | --- | --- | --- | --- | --- | --- | --- | --- | --- | --- | --- | --- | --- | --- | --- | --- | --- | --- | --- | --- |
| 1483 | 472.1.2 | **Protocol impact of FBI for TISPAN R1** | 2114d? | 2003-11-05 A | 2011-12-09 | 75% | 531.61d? | 2003-11-05 | 2011-12-09 | 2114d? | 260d |  | S3,C1,C3,C4,IETF | 41252.8h | 23022.4h | FBI-TIS1 | Siemens | peter.leis@nsn.com | Rel-7 | Frederic |  |  |  |  |
| 1484 | 472.1.2.1 | (IETF) CT aspects of FBI for TISPAN R1 | 1933.6d? | 2003-11-05 A | 2011-12-09 | 50% | 966.8d? | 2003-11-05 | 2011-12-09 | 1933.6d? | 260d | start no earlier than 2003-11-05 | C1-IETF, C3-IETF | 15468.8h | 7734.4h | FBI-TIS1 | Siemens |  | Rel-7 | Frederic | PCG-27 | draft-jesske-dispatch-update3326-reason-responses | CP-52 |  |
| 1485 | 472.1.2.2 | CT1 aspects of FBI for TISPAN R1 | 802d? | 2003-11-05 A | 2006-11-30 A | 100% |  | 2003-11-05 | 2006-11-30 | 802d? |  | finish no earlier than 2006-11-30 | C1 | 6416h | 6416h | FBI-TIS1 | Siemens | peter.leis@nsn.com | Rel-7 | Frederic |  | 24.819, 24.229 |  |  |
| 1486 | 472.1.2.3 | CT3 aspects of FBI for TISPAN R1 | 808d? | 2003-11-05 A | 2006-12-08 A | 100% |  | 2003-11-05 | 2006-12-08 | 808d? |  | finish no earlier than 2006-12-08 | C3 | 6464h | 6464h | FBI-TIS1 | Siemens | peter.leis@nsn.com | Rel-7 | Jiwan |  | 29.163, 29.209 |  |  |
| 1487 | 472.1.2.4 | CT4 aspects of FBI for TISPAN R1 | 301d? | 2006-01-13 A | 2007-03-09 A | 100% |  | 2006-01-13 | 2007-03-09 | 301d? |  | finish no earlier than 2007-03-09 | C4 | 2408h | 2408h | FBI-TIS1-st3-c4 | Siemens | peter.leis@nsn.com | Rel-7 | Kimmo |  | 29.229 |  |  |
| 1488 | 472.1.3 | Security Enhancements for FBI | 118d? | 2005-06-28 A | 2005-12-08 A | 100% |  | 2005-06-28 | 2005-12-08 | 118d? |  | start no earlier than 2005-06-28 | S3 | 944h | 944h | FBI-ISE | Ericsson | Bengt.Sahlin@ericsson.com | Rel-7 | Dionisio |  | 33.203 |  |  |
| 1489 | 472.2 | **PacketCable Related aspects** | 291d? | 2006-02-01 A | 2007-03-14 A | 100% |  | 2006-02-01 | 2007-03-14 | 291d? |  |  | S2,S5,C1 | 5088h | 5088h | FBI-PCBL | CableLabs | Bernie McKibben (b.mckibben@cablelabs.com) | Rel-7 | Maurice |  |  |  |  |
| 1490 | 472.2.1 | Stage 1,2 of FBI for PacketCable | 228d? | 2006-02-01 A | 2006-12-15 A | 100% |  | 2006-02-01 | 2006-12-15 | 228d? |  | finish no earlier than 2006-12-15 | S2 | 1824h | 1824h | FBI-PCBL | CableLabs | Bernie McKibben (b.mckibben@cablelabs.com) | Rel-7 | Maurice |  | 22.228, 23.228 |  |  |
| 1491 | 472.2.2 | Protocol impact of FBI for PacketCable | 228d? | 2006-05-01 A | 2007-03-14 A | 100% |  | 2006-05-01 | 2007-03-14 | 228d? |  | finish no earlier than 2007-03-15 | C1 | 1824h | 1824h | FBI-PCBL |  |  | Rel-7 | Frederic |  |  |  |  |
| 1492 | 472.2.3 | SA5 Charging aspects of FBI for PacketCable | 180d? | 2006-03-31 A | 2006-12-07 A | 100% |  | 2006-03-31 | 2006-12-07 | 180d? |  | finish no earlier than 2006-12-07 | S5 | 1440h | 1440h | FBI-PCBL-CH | CableLabs | Bernie McKibben (b.mckibben@cablelabs.com) | Rel-7 | Dionisio |  | 32.240, 32.260, 32.298, 32.299 |  |  |
| 1493 | 473 | **Support of SMS over generic 3GPP IP access** | 696d? | 2004-10-14 A | 2007-06-14 A | 100% |  | 2004-10-14 | 2007-06-14 | 696d? |  |  | S2,C4,C1 | 12408h | 12408h | SMSIP | Huawei | zhangwenlin@huawei.com | Rel-7 | Maurice |  |  |  |  |
| 1494 | 473.1 | FS on SMSIP | 173d? | 2004-10-14 A | 2005-06-13 A | 100% |  | 2004-10-14 | 2005-06-13 | 173d? |  | start no earlier than 2004-10-14 | S2 | 1384h | 1384h | SMSIP | Huawei | zhangwenlin@huawei.com | Rel-7 | Maurice |  | 23.804 |  |  |
| 1495 | 473.2 | Stage 2 for SMSIP | 333d? | 2005-06-08 A | 2006-09-15 A | 100% |  | 2005-06-08 | 2006-09-15 | 333d? |  | finish no earlier than 2006-09-15 | S2 | 2664h | 2664h | SMSIP | Huawei | zhangwenlin@huawei.com | Rel-7 | Maurice |  | 23.204 |  |  |
| 1496 | 473.3 | **Stage 3 for SMSIP** | 527d? | 2005-06-08 A | 2007-06-14 A | 100% |  | 2005-06-08 | 2007-06-14 | 527d? |  |  | C4,C1 | 8360h | 8360h | SMSIP-St3 | Nokia | jari.jansson@nokia.com | Rel-7 | Kimmo |  |  |  |  |
| 1497 | 473.3.1 | CT1 aspects for SMSIP | 527d? | 2005-06-08 A | 2007-06-14 A | 100% |  | 2005-06-08 | 2007-06-14 | 527d? |  | finish no earlier than 2007-06-15 | C1 | 4216h | 4216h | SMSIP | Nokia | jari.jansson@nokia.com | Rel-7 | Frederic |  | 23.040, 24.229 |  |  |
| 1498 | 473.3.2 | CT4 aspects for SMSIP | 518d? | 2005-06-08 A | 2007-06-01 A | 100% |  | 2005-06-08 | 2007-06-01 | 518d? |  | finish no earlier than 2007-06-01 | C4 | 4144h | 4144h | SMSIP-St3-c4 | Nokia | jari.jansson@nokia.com | Rel-7 | Kimmo |  | 23.008, 29.002 |  |  |
| 1499 | 474 | **Evolution of Policy Control and Charging** | 817d? | 2004-10-14 A | 2007-11-30 A | 100% |  | 2004-10-14 | 2007-11-30 | 817d? |  |  | S2,S5,C3,C1 | 30336h | 30336h | PCC | Nokia | balazs.bertenyi@nsn.com | Rel-7 | Maurice |  |  |  |  |
| 1500 | 474.1 | Deleted - TR for PCC | 315d? | 2004-10-14 A | 2005-12-29 A | 100% |  | 2004-10-14 | 2005-12-29 | 315d? |  | finish no earlier than 2005-12-28 | S2 | 2520h | 2520h | PCC | Nokia | balazs.bertenyi@nsn.com | Rel-7 | Maurice |  | 23.803 |  | SP-33 |
| 1501 | 474.2 | Stage 2 for PCC | 315d? | 2005-07-04 A | 2006-09-15 A | 100% |  | 2005-07-04 | 2006-09-15 | 315d? |  | finish no earlier than 2006-09-15 | S2 | 2520h | 2520h | PCC | Nokia | balazs.bertenyi@nsn.com | Rel-7 | Maurice |  | 23.203 |  |  |
| 1502 | 474.3 | Evolution of policy control and flow based bearer level charging | 109d? | 2006-08-01 A | 2006-12-29 A | 100% |  | 2006-08-01 | 2006-12-29 | 109d? |  | start no earlier than 2006-08-01 | S2 | 872h | 872h | PCC | Nokia | balazs.bertenyi@nsn.com | Rel-7 | Maurice |  | 23.207, 23.002, 23.228 |  |  |
| 1503 | 474.4 | SA5 Charging aspects of PCC | 316d? | 2006-03-31 A | 2007-06-15 A | 100% |  | 2006-03-31 | 2007-06-15 | 316d? |  | finish no earlier than 2007-06-15 | S5 | 2528h | 2528h | PCC-CH | Orange | alain.bibas@orange-ft.com | Rel-7 | Dionisio |  | 32.250, 32.251, 32.298, 32.299 |  |  |
| 1504 | 474.5 | Gx reference point for Policy and Charging Control | 521d? | 2005-12-02 A | 2007-11-30 A | 100% |  | 2005-12-02 | 2007-11-30 | 521d? |  | finish no earlier than 2007-09-14 | C3 | 4168h | 4168h | PCC-Gx | Siemens | Thomas.Belling@nsn.com | Rel-7 | Jiwan |  | 29.212 (not progressed to Rel-7: 29.210, 29.207, 29.208) |  |  |
| 1505 | 474.6 | **Rx reference point for PCC CT3 aspects** | 521d? | 2005-12-02 A | 2007-11-30 A | 100% |  | 2005-12-02 | 2007-11-30 | 521d? |  |  | C3,C1 | 11192h | 11192h | PCC-Rx | Ericsson | j.javier.pastor@ericsson.com | Rel-7 | Jiwan |  |  |  |  |
| 1506 | 474.6.1 | PCC-Rx CT3 aspects | 521d? | 2005-12-02 A | 2007-11-30 A | 100% |  | 2005-12-02 | 2007-11-30 | 521d? |  | finish no earlier than 2007-09-14 | C3 | 4168h | 4168h | PCC-Rx-c3 | Ericsson | j.javier.pastor@ericsson.com | Rel-7 | Jiwan |  | 29.213, 29.214 (not progressed to Rel-7: 29.209, 29.211) |  |  |
| 1507 | 474.6.2 | PCC-Rx CT1 aspects | 357d? | 2005-12-02 A | 2007-06-15 A | 100% |  | 2005-12-02 | 2007-06-15 | 357d? |  | finish no earlier than 2007-06-15 | C1 | 2856h | 2856h | PCC-Rx-Gx-c1 | Ericsson | j.javier.pastor@ericsson.com | Rel-7 | Frederic |  | 24.229 |  |  |

Notes:
- 1483: -
- 1484: Not completed internet-draft
- 1485: end date updated by CT1-chairman after CP#33
- 1486: -
- 1487: CT4#32: a set of CRs on FBI for cable labs
- 1488: Duplicated entry ("ACCSEC2", "Access Security Enhancements", SP-040865) deleted by A.Sultan
- 1489: -
- 1490: -
- 1491: -
- 1492: 03/2006 SP#31 WID approved
- 1493: SP#33 updated WID (removed MMS)
- 1494: SP#33 updated WID
- 1495: SP#33 updated WID
- 1496: CP#34 updated WID
- 1497: CP#34 updated WID
- 1498: CP#34 updated WID
- 1499: SP-29 approved WID. SP-31 updated WID adding SA5 charging. 23.125 will be discontinued from Rel-7.
- 1500: SP-30: S2 has no intention for TR completion
- 1501: SP-29 approved WID. SP-31 updated WID. 23.125 will be discontinued from Rel-7.
- 1502: SP-29 approved WID. SP-31 updated WID. 23.125 will be discontinued from Rel-7.
- 1503: SP-31 updated WID with SA5 charging.
- 1504: -
- 1505: WID approved at CP#30, Revised at CP#31, Revised at CP#33
- 1506: -
- 1507: -

| ID | WBS | Task | Type | Duration | Start | Finish | Complete | Baseline start | Baseline finish | Baseline duration | Constraint | Resources | Work | Actual work | Text1 | Text4 | Text5 | Text6 | Text8 | Text3 | Text12 |
| --- | --- | --- | --- | --- | --- | --- | --- | --- | --- | --- | --- | --- | --- | --- | --- | --- | --- | --- | --- | --- | --- |
| 1508 | 475 | **Voice call continuity between CS and IMS (incl. I-WLAN)** |  | 641d? | 2004-12-31 A | 2007-06-15 A | 100% | 2004-12-31 | 2007-06-15 | 641d? |  | S2,S1,S5,C1,C4 | 12224h | 12224h | VCC | Alcatel-Lucent | Keith Drage (drage@alcatel-lucent.com) | Rel-7 | Maurice |  |  |
| 1509 | 475.1 | TR for VCC |  | 245d? | 2004-12-31 A | 2005-12-08 A | 100% | 2004-12-31 | 2005-12-08 | 245d? | finish no earlier than 2005-12-08 | S2 | 1960h | 1960h | VCC | Alcatel-Lucent | andy.bennett@alcatel-lucent.com | Rel-7 | Maurice | 23.806 |  |
| 1510 | 475.2 | Stage 1 for VCC |  | 140d? | 2005-03-17 A | 2005-09-28 A | 100% | 2005-03-17 | 2005-09-28 | 140d? | finish no earlier than 2005-09-28 | S1 | 1120h | 1120h | VCC | Alcatel-Lucent | andy.bennett@alcatel-lucent.com | Rel-7 | Alain | 22.101 |  |
| 1511 | 475.3 | Stage 2 for VCC |  | 264d? | 2005-09-06 A | 2006-09-08 A | 100% | 2005-09-06 | 2006-09-08 | 264d? | finish no earlier than 2006-09-08 | S2 | 2112h | 2112h | VCC | Alcatel-Lucent | andy.bennett@alcatel-lucent.com | Rel-7 | Maurice | 23.206 |  |
| 1512 | 475.4 | SA5 Charging aspects of VCC |  | 325d? | 2006-03-17 A | 2007-06-14 A | 100% | 2006-03-17 | 2007-06-14 | 325d? | finish no earlier than 2007-06-14 | S5 | 2600h | 2600h | VCC-CH | Orange | alain.bibas@orange-ft.com | Rel-7 | Dionisio | 32.250, 32.260 |  |
| 1513 | 475.5 | **Stage 3 for VCC** |  | 358d? | 2006-02-01 A | 2007-06-15 A | 100% | 2006-02-01 | 2007-06-15 | 358d? |  | C1,C4 | 4432h | 4432h | VCC | Alcatel-Lucent | Keith Drage (drage@alcatel-lucent.com) | Rel-7 | Frederic |  |  |
| 1514 | 475.5.1 | CT1 aspects of VCC |  | 358d? | 2006-02-01 A | 2007-06-15 A | 100% | 2006-02-01 | 2007-06-15 | 358d? | finish no earlier than 2007-06-15 | C1 | 2864h | 2864h | VCC | Alcatel-Lucent | Keith Drage (drage@alcatel-lucent.com) | Rel-7 | Frederic | 24.206, 24.216 |  |
| 1515 | 475.5.2 | CT4 aspects of VCC |  | 196d? | 2006-06-09 A | 2007-03-09 A | 100% | 2006-06-09 | 2007-03-09 | 196d? | start no earlier than 2006-06-09 | C4 | 1568h | 1568h | VCC-St3-c4 | Alcatel-Lucent | Keith Drage (drage@alcatel-lucent.com) | Rel-7 | Kimmo | 23.003 |  |
| 1516 | 475.5.3 | Deleted - CT3 aspects of VCC | milestone | 0d? | 2006-11-02 A | 2006-11-02 A | 100% | 2006-11-02 | 2006-11-02 | 0d? | finish no earlier than 2006-11-02 | C3 |  |  | VCC | Alcatel-Lucent | Keith Drage (drage@alcatel-lucent.com) | Rel-7 | Jiwan | 29.163 | CP-33 |
| 1517 | 476 | **One Tunnel solution for optimization of Packet Data Traffic** |  | 418d? | 2006-03-27 A | 2007-10-31 A | 100% | 2006-03-27 | 2007-10-31 | 418d? |  | S2 | 7048h | 7048h | OPTUNEL | Nokia | antti.j.pasanen@nokia.com | Rel-7 | Maurice |  |  |
| 1518 | 476.1 | Deleted - Study on Stage 2 for One Tunnel solution |  | 125d? | 2006-03-27 A | 2006-09-15 A | 100% | 2006-03-27 | 2006-09-15 | 125d? | finish no earlier than 2005-09-12 | S2 | 1000h | 1000h | OPTUNEL-Study | Nokia | antti.j.pasanen@nokia.com | Rel-7 | Maurice | 23.809 | SP-34 |
| 1519 | 476.2 | One Tunnel Deployment Guideline |  | 268d? | 2006-10-23 A | 2007-10-31 A | 100% | 2006-10-23 | 2007-10-31 | 268d? | finish no earlier than 2007-10-31 | S2 | 2144h | 2144h | OPTUNEL-Guide | Huawei | lan.liu@huawei.com | Rel-7 | Maurice | 23.919 |  |
| 1520 | 476.3 | Stage 2 specification for One Tunnel solution |  | 70d? | 2006-09-11 A | 2006-12-15 A | 100% | 2006-09-11 | 2006-12-15 | 70d? | finish no earlier than 2006-12-15 | S2 | 560h | 560h | OPTUNEL-Stage2 | Nokia | antti.j.pasanen@nokia.com | Rel-7 | Maurice | 23.060 |  |
| 1521 | 477 | **CSI Terminating Session handling** |  | 267d? | 2006-06-08 A | 2007-06-15 A | 100% | 2006-06-08 | 2007-06-15 | 267d? |  | S2,C1 | 4728h | 4728h | CSItermS | Samsung | Osok Song | Rel-7 | Maurice |  |  |
| 1522 | 477.1 | Stage 2 of CStermS |  | 192d? | 2006-06-08 A | 2007-03-02 A | 100% | 2006-06-08 | 2007-03-02 | 192d? | start no earlier than 2006-06-08 | S2 | 1536h | 1536h | CSItermS | Samsung | Osok Song | Rel-7 | Maurice | 23.279 |  |
| 1523 | 477.2 | Stage 3 of CStermS |  | 132d? | 2006-12-14 A | 2007-06-15 A | 100% | 2006-12-14 | 2007-06-15 | 132d? | finish no earlier than 2007-06-15 | C1 | 1056h | 1056h | CSItermS | Samsung | chenho.chin@samsung.com | Rel-7 | Frederic | 24.229, 24.279 |  |
| 1524 | 477.3 | Deleted - duplicated with UID 340015 -Stage 3 CSI Terminating Session handling | milestone | 0d? | 2007-03-09 A | 2007-03-09 A | 100% | 2007-03-09 | 2007-03-09 | 0d? | start no earlier than 2007-03-09 | C1 |  |  | CSItermS | Samsung | chenho.chin@samsung.com | Rel-7 | Frederic | 24.229, 24.179, 24.279 | CP-34 |
| 1525 | 478 | Liberty Alliance and 3GPP Security Interworking |  | 451d? | 2005-03-10 A | 2006-11-30 A | 100% | 2005-03-10 | 2006-11-30 | 451d? | finish no earlier than 2006-11-30 | S3 | 3608h | 3608h | LibSec | Nokia | Silke.Holtmanns@nokia.com | Rel-7 | Dionisio | 33.980 |  |
| 1526 | 479 | Trust Requirements for Open Platforms in 3GPP |  | 499d? | 2005-01-03 A | 2006-11-30 A | 100% | 2005-01-03 | 2006-11-30 | 499d? | finish no earlier than 2006-11-30 | S3 | 3992h | 3992h | TrustOP | Nokia | Silke.Holtmanns@nokia.com | Rel-7 | Dionisio | 33.905 |  |
| 1527 | 480 | Development of UEA2 and UIA2 |  | 268d? | 2004-12-01 A | 2005-12-09 A | 100% | 2004-12-01 | 2005-12-09 | 268d? | finish no earlier than 2005-12-09 | S3 | 2144h | 2144h | AlgUEA2 | TeliaSonera | per.christoffersson@teliasonera.com | Rel-7 | Dionisio | 35.919, 35.215, 35.216, 35.217, 35.218 |  |
| 1528 | 481 | Lawful Interception in the 3GPP Rel-7 architecture |  | 118d? | 2005-06-28 A | 2005-12-08 A | 100% | 2005-06-28 | 2005-12-08 | 118d? | start no earlier than 2005-06-28 | S3 | 944h | 944h | LI-7A | BMWI | berthold.wilhelm@regtp.de | Rel-7 | Dionisio | 33.106, 33.107, 33.108 |  |
| 1529 | 482 | Key establishment between a UICC and a terminal |  | 201.45d? | 2005-12-07 A | 2006-09-28 A | 100% | 2005-12-07 | 2006-09-28 | 201.45d? | finish no earlier than 2006-09-28 | S3 | 1611.6h | 1611.6h | KeyEstUTerm | Gemalto | mireille.pauliac@gemplus.com | Rel-7 | Dionisio | 33.110 |  |
| 1530 | 483 | NDS Authentication Framework Extension for Transport Layer Security |  | 50d? | 2006-09-28 A | 2006-12-06 A | 100% | 2006-09-28 | 2006-12-06 | 50d? | finish no earlier than 2006-09-28 | S3 | 400h | 400h | NDSAFTLS | Nokia | tiina.s.koskinen@nokia.com | Rel-7 | Dionisio | 33.310 |  |
| 1531 | 484 | **Security enhancements** |  | 319d? | 2005-09-12 A | 2006-11-30 A | 100% | 2005-09-12 | 2006-11-30 | 319d? |  | S3,C1,C4 | 4856h | 4856h | SEC7 |  |  | Rel-7 | Dionisio |  |  |
| 1532 | 484.1 | HTTPS connection between a UICC and a NAF |  | 1d? | 2005-09-12 A | 2005-09-12 A | 100% | 2005-09-12 | 2005-09-12 | 1d? | start no earlier than 2005-09-12 | S3,C1 | 8h | 8h | SEC7-HSUN | Gemalto | JSeif@axalto.com, mireille.pauliac@gemplus.com | Rel-7 | Dionisio | 33.918, 33.222, 24.109 |  |
| 1533 | 484.2 | 2G GBA: 2G SIM usage in 3GPP GAA framework |  | 61d? | 2005-09-12 A | 2005-12-05 A | 100% | 2005-09-12 | 2005-12-05 | 61d? | finish no earlier than 2005-12-05 | S3 | 488h | 488h | SEC7-2GGBA | Nokia | Silke.Holtmanns@nokia.com | Rel-7 | Dionisio | 33.920, 33.220 |  |
| 1534 | 484.3 | Generic Authentication Architecture usage extensions and optimizations |  | 319d? | 2005-09-12 A | 2006-11-30 A | 100% | 2005-09-12 | 2006-11-30 | 319d? | finish no earlier than 2006-11-30 | S3 | 2552h | 2552h | SEC7-GAA2 | Nokia | Silke.Holtmanns@nokia.com | Rel-7 | Dionisio | 33.220, 29.109, 24.109, (33.223 goes to R8) |  |

Notes:
- 1508: WID approved SP#27; updated SP#28; updated SP#32
- 1509: -
- 1510: -
- 1511: -
- 1512: 03/2006 SP#31 WID approved
- 1513: -
- 1514: -
- 1515: -
- 1516: -
- 1517: -
- 1518: TR for Info SP-33. SP-34: S2 Report intention to discontinue TR
- 1519: -
- 1520: -
- 1521: Triggered by the abandoned Study UID_32117
- 1522: -
- 1523: CP-34 approved WID. CP-35 updated WID
- 1524: CP-34 approved WID
- 1525: WID approved SP#27.
- 1526: WID approved SP#26.
- 1527: WID approved SP#26, Dependant on Funding Availability.
- 1528: -
- 1529: -
- 1530: TLS profile is moved to Rel-8
- 1531: -
- 1532: -
- 1533: -
- 1534: 33.223 goes to R8

| ID | WBS | Task | Duration | Start | Finish | Complete | Baseline start | Baseline finish | Baseline duration | Constraint | Resources | Work | Actual work | Text1 | Text4 | Text5 | Text6 | Text8 | Text3 | Text12 | Text2 | Text7 |
| --- | --- | --- | --- | --- | --- | --- | --- | --- | --- | --- | --- | --- | --- | --- | --- | --- | --- | --- | --- | --- | --- | --- |
| 1535 | 484.4 | **SS7 TCAP security Gateway** | 241d? | 2005-09-12 A | 2006-08-14 A | 100% | 2005-09-12 | 2006-08-14 | 241d? |  | S3,C4 | 1808h | 1808h | SEC7-NDS-TCAPsec | Siemens | marc.blommaert.ext@nsn.com | Rel-7 | Dionisio |  |  |  |  |
| 1536 | 484.4.1 | SA3 aspects of SEC7-NDS-TCAPsec | 130d? | 2005-09-12 A | 2006-03-10 A | 100% | 2005-09-12 | 2006-03-10 | 130d? | finish no earlier than 2006-03-10 | S3 | 1040h | 1040h | SEC7-NDS-TCAPsec-SA3 | Siemens | marc.blommaert.ext@nsn.com | Rel-7 | Dionisio | 33.204 |  |  |  |
| 1537 | 484.4.2 | TCAPsec Gateway | 96d? | 2006-04-03 A | 2006-08-14 A | 100% | 2006-04-03 | 2006-08-14 | 96d? | start no earlier than 2006-04-01 | C4 | 768h | 768h | SEC7-TCAP | Siemens | Ulrich.wiehe@gksag.de | Rel-7 | Kimmo | 29.204, 29.002 |  |  |  |
| 1538 | 485 | IMS Stage 3 IETF Protocol alignment | 589d? | 2004-12-10 A | 2007-03-14 A | 100% | 2004-12-10 | 2007-03-14 | 589d? | finish no earlier than 2007-03-15 | C1 | 4712h | 4712h | IMSProtoc |  |  | Rel-7 | Frederic | 24.930 |  |  |  |
| 1539 | 486 | **Interoperability between VGCS/VBS and A/Gb flexibility** | 253d? | 2006-03-22 A | 2007-03-09 A | 100% | 2006-03-22 | 2007-03-09 | 253d? |  | C1,C4 | 3296h | 3296h | VGCSFlex | Siemens | robert.zaus@nsn.com | Rel-7 | Frederic |  |  |  |  |
| 1540 | 486.1 | CT1 aspects of VGCSFlex | 159d? | 2006-03-22 A | 2006-10-30 A | 100% | 2006-03-22 | 2006-10-30 | 159d? | finish no earlier than 2006-10-30 | C1 | 1272h | 1272h | VGCSFlex | Siemens | robert.zaus@nsn.com | Rel-7 | Frederic | 43.068, 43.069 |  |  |  |
| 1541 | 486.2 | CT4 aspects of VGCSFlex | 253d? | 2006-03-22 A | 2007-03-09 A | 100% | 2006-03-22 | 2007-03-09 | 253d? | finish no earlier than 2007-03-09 | C4 | 2024h | 2024h | VGCSFlex-c4 | Siemens | robert.zaus@nsn.com | Rel-7 | Kimmo | 29.002 |  |  |  |
| 1542 | 487 | DIAMETER on the GGSN Gi interface | 586d? | 2004-09-10 A | 2006-12-08 A | 100% | 2004-09-10 | 2006-12-08 | 586d? | finish no earlier than 2006-12-08 | C3 | 4688h | 4688h | DIAMGi | Vodafone | Nico.Gabriele@vodafone.com | Rel-7 | Jiwan | 29.061 |  |  |  |
| 1543 | 488 | DIAMETER on the PDG Wi interface | 586d? | 2004-09-10 A | 2006-12-08 A | 100% | 2004-09-10 | 2006-12-08 | 586d? | finish no earlier than 2006-12-08 | C3 | 4688h | 4688h | DIAMWi | Vodafone | Nico.Gabriele@vodafone.com | Rel-7 | Jiwan | 29.161 |  |  |  |
| 1544 | 489 | Interworking between the 3GPP CS domain with BICC or ISUP as signalling protocol and external SIP-I networks | 478d? | 2006-09-22 A | 2008-07-22 A | 100% | 2006-09-22 | 2008-07-22 | 478d? | finish no earlier than 2007-09-14 | C3 | 3824h | 3824h | ExtSIPI | Siemens | Thomas.Belling@nsn.com | Rel-7 | Jiwan | 29.164 |  |  |  |
| 1545 | 490 | PDU multiplexing at Nb Interface with IP transport | 427d? | 2006-12-04 A | 2008-07-22 A | 100% | 2006-12-04 | 2008-07-22 | 427d? | start no earlier than 2006-12-04 | C3 | 3416h | 3416h | NbIPMux | Alcatel-Lucent | Jean.Rzeznik@alcatel-lucent.fr | Rel-7 | Jiwan | 29.414 |  |  |  |
| 1546 | 491 | **Mp (MRFC - MRFP) interface** | 345d? | 2006-02-13 A | 2007-06-08 A | 100% | 2006-02-13 | 2007-06-08 | 345d? |  | C4,C1 | 4384h | 4384h | Mp | Ericsson | philip.hodges@ericsson.com | Rel-7 | Kimmo |  |  |  |  |
| 1547 | 491.1 | CT1 aspects of Mp | 1d | 2006-02-13 A | 2006-02-13 A | 100% | 2006-02-13 | 2006-02-13 | 1d | finish no earlier than 2006-02-13 | C1 | 8h | 8h | Mp | Ericsson | philip.hodges@ericsson.com | Rel-7 | Frederic | 24.229 |  |  |  |
| 1548 | 491.2 | Deleted - CT3 aspects of Mp | 1d | 2006-09-22 A | 2006-09-22 A | 100% | 2006-09-22 | 2006-09-22 | 1d | start no earlier than 2006-09-22 | C3 | 8h | 8h | Mp | Ericsson | philip.hodges@ericsson.com | Rel-7 | Jiwan | 29.162 | CP-33 |  |  |
| 1549 | 491.3 | Procedures description | 201d? | 2006-06-02 A | 2007-03-09 A | 100% | 2006-06-02 | 2007-03-09 | 201d? | finish no earlier than 2007-03-09 | C4 | 1608h | 1608h | Mp-PROCc4 | Huawei | Chencheng@huawei.com | Rel-7 | Kimmo | 23.333 |  |  |  |
| 1550 | 491.4 | Stage 3 | 345d | 2006-02-13 A | 2007-06-08 A | 100% | 2006-02-13 | 2007-06-08 | 345d | finish no earlier than 2007-06-08 | C4 | 2760h | 2760h | Mp-St3c4 | Ericsson | philip.hodges@ericsson.com | Rel-7 | Kimmo | 29.333 |  |  |  |
| 1551 | 492 | Routeing of MT-SMS via the HPLMN | 71d? | 2006-12-01 A | 2007-03-09 A | 100% | 2006-12-01 | 2007-03-09 | 71d? | finish no earlier than 2007-03-09 | C4,C1 | 568h | 568h | SMSviaH | Vodafone | Nick.Russell@vodafone.com | Rel-7 | Kimmo | 23.040, 29.002 |  |  |  |
| 1552 | 493 | Mobile Termination whilst the MS is moving to another MSC | 60d? | 2007-03-09 A | 2007-05-31 A | 100% | 2007-03-09 | 2007-05-31 | 60d? | start no earlier than 2007-03-09 | C4 | 480h | 480h | MTmovMS | Alcatel-Lucent | bruno.landais@alcatel-lucent.fr | Rel-7 | Kimmo | 23.008, 23.012, 23.018, 23.078, 23.079, 29.002 |  |  |  |
| 1553 | 494 | ISIM API for Java Card | 620d? | 2005-03-14 A | 2007-07-27 A | 100% | 2005-03-14 | 2007-07-27 | 620d? | finish no earlier than 2007-07-27 | C6 | 4960h | 4960h | APIJAVA | Sun | Sebastian Hans | Rel-7 | Xavier | 31.103, 102 241 |  |  |  |
| 1554 | 495 | Rel-7 (U)SIM API Testing (TS 31.213) | 211d? | 2009-05-30 A | 2010-03-19 A | 100% | 2009-05-30 | 2010-03-19 | 211d? | finish no earlier than 2010-03-12 | C6 | 1688h | 1688h | USIM_API_test | Sagem Orga | gerrit.hartbrod@sagem-orga.com | Rel-7 | Xavier | 31.213 |  | PCG-23 | CP-44 |
| 1555 | 496 | High speed interface between the UICC and the ME | 311d? | 2006-09-22 A | 2007-11-30 A | 100% | 2006-09-22 | 2007-11-30 | 311d? | finish no earlier than 2007-11-30 | C6 | 2488h | 2488h | HSI | Gemalto | jacques.seif@GEMALTO.COM | Rel-7 | Xavier | 31.101 |  |  |  |
| 1556 | 497 | Video Codec Performance Requirements | 634d? | 2005-01-03 A | 2007-06-07 A | 100% | 2005-01-03 | 2007-06-07 | 634d? | finish no earlier than 2007-06-07 | S4 | 5072h | 5072h | VICPer | Siemens | juergen.pandel@siemens.com | Rel-7 | Paolo | 26.234, 26.235, 26.346, 26.140, 26.902 |  |  |  |
| 1557 | 498 | Dynamic and Interactive Multimedia Scenes | 583d? | 2005-03-15 A | 2007-06-07 A | 100% | 2005-03-15 | 2007-06-07 | 583d? | finish no earlier than 2007-06-07 | S4 | 4664h | 4664h | DIMS | Streamezzo | gaelle.martin-cocher@streamezzo.com | Rel-7 | Paolo | 26.140, 26.142, 26.234, 26.244, 23.346 |  |  |  |
| 1558 | 499 | 3G-324M Video Telephony Call Setup Times Improvements | 341d? | 2005-06-08 A | 2006-09-27 A | 100% | 2005-06-08 | 2006-09-27 | 341d? | finish no earlier than 2006-09-27 | S4 | 2728h | 2728h | VTCSTI | Vodafone | edward.hall@vodafone.co.uk | Rel-7 | Paolo | 26.911 |  |  |  |

Notes:
- 1535: -
- 1536: -
- 1537: -
- 1538: TR 24.930: Signalling flows for the session setup in the IM CN subsystem based on Session Initiation Protocol (SIP)
- 1539: Voice Group Call Service
- 1540: -
- 1541: -
- 1542: -
- 1543: -
- 1544: -
- 1545: -
- 1546: -
- 1547: -
- 1548: CP#34: CT3 not involved in Mp interface definition
- 1549: -
- 1550: -
- 1551: WID approved in CP#34
- 1552: -
- 1553: -
- 1554: CP#47 completed. Update of Rel-6 (U)SIM API for Java Card Testing UID_43007 under Rel-6 UICC/USIM enhancements and interworking UID_1800
- 1555: Following ETSI publication of TS 102 600, expected to be completed at CT6 meeting 45
- 1556: -
- 1557: -
- 1558: -

| ID | WBS | Task | Type | Duration | Start | Finish | Complete | Baseline start | Baseline finish | Baseline duration | Constraint | Resources | Work | Actual work | Text1 | Text4 | Text5 | Text6 | Text8 | Text12 |
| --- | --- | --- | --- | --- | --- | --- | --- | --- | --- | --- | --- | --- | --- | --- | --- | --- | --- | --- | --- | --- |
| 1559 | 500 | **Optimizations for Multimedia Telephony over IMS** |  | 0d? | 2005-09-28 A | 2005-09-28 A | 100% | 2005-09-28 | 2005-09-28 | 0d? |  | S4 |  |  | OMTIMS | Ericsson | olle.franceschi@ericsson.com | Rel-7 | Paolo |  |
| 1560 | 500.1 | Deleted - Characterisation of Adaptive Jitter Management Performance for VoIP Services | milestone | 0d? | 2005-09-28 A | 2005-09-28 A | 100% | 2005-09-28 | 2005-09-28 | 0d? | start no earlier than 2007-03-15 | S4 |  |  | OMTIMS-CAJMP | Lucent | dhuo@lucent.com | Rel-7 | Paolo | SP-35 |
| 1561 | 501 | End-to-End Multimedia Services Performance Metrics |  | 382d? | 2005-09-28 A | 2007-03-15 A | 100% | 2005-09-28 | 2007-03-15 | 382d? | finish no earlier than 2007-03-15 | S4 | 3056h | 3056h | E2EMSPM | China Mobile | zhangyanyf@chinamobile.com | Rel-7 | Paolo |  |
| 1562 | 502 | Packet Switched Streaming Enhancements |  | 261d? | 2006-06-08 A | 2007-06-07 A | 100% | 2006-06-08 | 2007-06-07 | 261d? | finish no earlier than 2007-06-07 | S4 | 2088h | 2088h | PSSe | Ericsson | olle.franceschi@ericsson.com | Rel-7 | Paolo |  |
| 1563 | 503 | **Rel-7 Operations, Administration, Maintenance and Provisioning (OAM&P)** |  | 472.86d? | 2005-09-02 A | 2007-06-26 A | 100% | 2005-09-02 | 2007-06-26 | 472.86d? |  | S5 | 82725.8h | 82725.8h | OAM7 | Huawei | Christian.Toche@huawei.com | Rel-7 | Dionisio |  |
| 1564 | 503.1 | **Network Infrastructure Management** |  | 465d? | 2005-09-02 A | 2007-06-14 A | 100% | 2005-09-02 | 2007-06-14 | 465d? |  | S5 | 41800h | 41800h | OAM7-NIM |  |  | Rel-7 | Dionisio |  |
| 1565 | 503.1.1 | Enhance NRM to accommodate NGN (IMS as basis of the Next Generation Network) |  | 465d? | 2005-09-02 A | 2007-06-14 A | 100% | 2005-09-02 | 2007-06-14 | 465d? | finish no earlier than 2007-06-14 | S5 | 3720h | 3720h | OAM7-NIM | Motorola |  | Rel-7 | Dionisio |  |
| 1566 | 503.1.2 | Co-operative Element Management interface (CO-OP) (Study + Implementation) |  | 400d? | 2005-09-02 A | 2007-03-15 A | 100% | 2005-09-02 | 2007-03-15 | 400d? | finish no earlier than 2007-03-15 | S5 | 3200h | 3200h | OAM7-NIM | Motorola |  | Rel-7 | Dionisio |  |
| 1567 | 503.1.3 | Network Management (NM) Itf-N performance criteria |  | 465d? | 2005-09-02 A | 2007-06-14 A | 100% | 2005-09-02 | 2007-06-14 | 465d? | finish no earlier than 2007-06-14 | S5 | 3720h | 3720h | OAM7-NIM | China Mobile |  | Rel-7 | Dionisio |  |
| 1568 | 503.1.4 | Delta synchronization between IRP Manager and IRP Agent (Study + Implementation) |  | 465d? | 2005-09-02 A | 2007-06-14 A | 100% | 2005-09-02 | 2007-06-14 | 465d? | finish no earlier than 2007-06-14 | S5 | 3720h | 3720h | OAM7-NIM | Siemens |  | Rel-7 | Dionisio |  |
| 1569 | 503.1.5 | Subscription Management (SuM) IRP Solution Sets |  | 330d? | 2005-09-02 A | 2006-12-07 A | 100% | 2005-09-02 | 2006-12-07 | 330d? | finish no earlier than 2006-12-07 | S5 | 2640h | 2640h | OAM7-NIM | Ericsson |  | Rel-7 | Dionisio |  |
| 1570 | 503.1.6 | Integration Reference Point (IRP) Security Management |  | 400d? | 2005-09-02 A | 2007-03-15 A | 100% | 2005-09-02 | 2007-03-15 | 400d? | finish no earlier than 2007-03-15 | S5 | 3200h | 3200h | OAM7-NIM | Huawei | Christian.Toche@huawei.com | Rel-7 | Dionisio |  |
| 1571 | 503.1.7 | Partial suspension of Itf-N during maintenance/testing (Study + Implementation) |  | 465d? | 2005-09-02 A | 2007-06-14 A | 100% | 2005-09-02 | 2007-06-14 | 465d? | finish no earlier than 2007-06-14 | S5 | 3720h | 3720h | OAM7-NIM | Siemens |  | Rel-7 | Dionisio |  |
| 1572 | 503.1.8 | Deleted - Management of Legacy Equipment |  | 336d? | 2005-09-02 A | 2006-12-15 A | 100% | 2005-09-02 | 2006-12-15 | 336d? | finish no earlier than 2006-12-15 | S5 | 2688h | 2688h | OAM7-NIM | Siemens |  | Rel-7 | Dionisio | SP-35 |
| 1573 | 503.1.9 | Deleted - Rules for Vendor Specific Extensions |  | 400d? | 2005-09-02 A | 2007-03-15 A | 100% | 2005-09-02 | 2007-03-15 | 400d? | finish no earlier than 2007-03-15 | S5 | 3200h | 3200h | OAM7-NIM | Siemens |  | Rel-7 | Dionisio | SP-35 |
| 1574 | 503.1.10 | Backward and Forward Compatibility of IRP systems |  | 465d? | 2005-09-02 A | 2007-06-14 A | 100% | 2005-09-02 | 2007-06-14 | 465d? | finish no earlier than 2007-06-14 | S5 | 3720h | 3720h | OAM7-NIM | Ericsson |  | Rel-7 | Dionisio |  |
| 1575 | 503.1.11 | Repeater Network Resource Model (NRM) definition |  | 214d? | 2006-02-13 A | 2006-12-07 A | 100% | 2006-02-13 | 2006-12-07 | 214d? | finish no earlier than 2006-12-07 | S5 | 1712h | 1712h | OAM7-NIM | China Mobile |  | Rel-7 | Dionisio |  |
| 1576 | 503.1.12 | UTRAN radio channel power monitoring |  | 284d? | 2006-02-13 A | 2007-03-15 A | 100% | 2006-02-13 | 2007-03-15 | 284d? | finish no earlier than 2007-03-15 | S5 | 2272h | 2272h | OAM7-NIM | China Mobile |  | Rel-7 | Dionisio |  |
| 1577 | 503.1.13 | Notification XML Schema |  | 71d? | 2006-12-07 A | 2007-03-15 A | 100% | 2006-12-07 | 2007-03-15 | 71d? | finish no earlier than 2007-03-15 | S5 | 568h | 568h | OAM7-NIM | Huawei | Christian.Toche@huawei.com | Rel-7 | Dionisio |  |
| 1578 | 503.2 | **Performance Management** |  | 465d? | 2005-09-02 A | 2007-06-14 A | 100% | 2005-09-02 | 2007-06-14 | 465d? |  | S5 | 22992h | 22992h | OAM7-PM |  |  | Rel-7 | Dionisio |  |
| 1579 | 503.2.1 | Performance measurements definition for CN CS |  | 400d? | 2005-09-02 A | 2007-03-15 A | 100% | 2005-09-02 | 2007-03-15 | 400d? | finish no earlier than 2007-03-15 | S5 | 3200h | 3200h | OAM7-PM | China Mobile |  | Rel-7 | Dionisio |  |
| 1580 | 503.2.2 | Enhancement UTRAN performance measurements definition |  | 465d? | 2005-09-02 A | 2007-06-14 A | 100% | 2005-09-02 | 2007-06-14 | 465d? | finish no earlier than 2007-06-14 | S5 | 3720h | 3720h | OAM7-PM | China Mobile |  | Rel-7 | Dionisio |  |
| 1581 | 503.2.3 | Add TDD specific counters in Performance measurement |  | 330d? | 2005-09-02 A | 2006-12-07 A | 100% | 2005-09-02 | 2006-12-07 | 330d? | finish no earlier than 2006-12-15 | S5 | 2640h | 2640h | OAM7-PM | CATT |  | Rel-7 | Dionisio |  |
| 1582 | 503.2.4 | ATM bearer network Performance measurements |  | 400d? | 2005-09-02 A | 2007-03-15 A | 100% | 2005-09-02 | 2007-03-15 | 400d? | finish no earlier than 2007-03-15 | S5 | 3200h | 3200h | OAM7-PM | ZTE |  | Rel-7 | Dionisio |  |
| 1583 | 503.2.5 | Performance measurements definition for IMS |  | 465d? | 2005-09-02 A | 2007-06-14 A | 100% | 2005-09-02 | 2007-06-14 | 465d? | finish no earlier than 2007-06-14 | S5 | 3720h | 3720h | OAM7-PM | China Mobile |  | Rel-7 | Dionisio |  |
| 1584 | 503.2.6 | HSDPA performance measurements |  | 349d? | 2006-02-13 A | 2007-06-14 A | 100% | 2006-02-13 | 2007-06-14 | 349d? | finish no earlier than 2007-06-14 | S5 | 2792h | 2792h | OAM7-PM | China Mobile |  | Rel-7 | Dionisio |  |

Notes:
- 1559: - / Text3: 26.235, 26.236
- 1560: SP-35 stopped
- 1561: - / Text3: 26.944
- 1562: - / Text3: 26.234, 26.244
- 1563: - / Text3: TR 30.817
- 1564: -
- 1565: - / Text3: 32.731/2/3/5, 32.631/2/3/5
- 1566: - / Text3: 32.806, 32.814, 32.101
- 1567: - / Text3: 32.811
- 1568: - / Text3: 32.391/2/3/5
- 1569: - / Text3: 32.307/317/607/667/665, 32.101, 32.175
- 1570: - / Text3: 32.372/3/5, 32.111,32.30x,32.32x,32.33x,32.34x,32.35x,32.36x,32.41x,32.60x,32.61x,32.66x
- 1571: - / Text3: 32.381/2/3/5
- 1572: Request to TSG#35 to STOP the WI / Text3: new 32.xxx
- 1573: Request to TSG#35 to STOP the WI / Text3: 32.62n; For n = 1 to 5
- 1574: - / Text3: 32.154
- 1575: - / Text3: 32.721/2/3/5
- 1576: - / Text3: 32.405, 32.64n; For n = 1 to 5
- 1577: 12/2006 SP#34 WID approved / Text3: New 32.325/345/365/415, CR to 32.335/615/665
- 1578: -
- 1579: - / Text3: 32.407, 32.408
- 1580: - / Text3: 32.405
- 1581: - / Text3: 32.405
- 1582: - / Text3: No impact on 32.404, 32.405, 32.406, 32.407
- 1583: - / Text3: 32.404,32.409,32.437, 32.632/3/4/5
- 1584: - / Text3: 32.405

| ID | WBS | Task | Type | Duration | Start | Finish | Complete | Baseline start | Baseline finish | Baseline duration | Constraint | Resources | Work | Actual work | Text1 | Text4 | Text6 | Text8 | Text12 | Text5 | Text11 |
| --- | --- | --- | --- | --- | --- | --- | --- | --- | --- | --- | --- | --- | --- | --- | --- | --- | --- | --- | --- | --- | --- |
| 1585 | 44.5 | **Trace Management** |  | 472.86d? | 2005-09-02 A | 2007-06-26 A | 100% | 2005-09-02 | 2007-06-26 | 472.86d? |  | S5 | 14150.9h | 14150.9h | OAM7-Trace | Vodafone | Rel-7 | Dionisio |  |  |  |
| 1586 | 503.3.1 | End-to-end Service Level tracing for IMS |  | 350d? | 2005-11-11 A | 2007-03-15 A | 100% | 2005-11-11 | 2007-03-15 | 350d? | finish no earlier than 2007-03-15 | S5 | 2800h | 2800h | OAM7-Trace | Vodafone | Rel-7 | Dionisio | SP-31 |  |  |
| 1587 | 503.3.2 | Trace record content for UTRAN TDD |  | 330d? | 2005-09-02 A | 2006-12-07 A | 100% | 2005-09-02 | 2006-12-07 | 330d? | finish no earlier than 2006-12-07 | S5 | 2640h | 2640h | OAM7-Trace | Nokia | Rel-7 | Dionisio |  |  |  |
| 1588 | 503.3.3 | IRP for Subscriber and Equipment Trace Management |  | 465d? | 2005-09-02 A | 2007-06-14 A | 100% | 2005-09-02 | 2007-06-14 | 465d? | finish no earlier than 2007-06-14 | S5 | 3720h | 3720h | OAM7-Trace | Nokia | Rel-7 | Dionisio |  |  |  |
| 1589 | 503.3.4 | Deleted - SIP enhancements for trace | milestone | 0d? | 2007-06-15 A | 2007-06-26 A | 100% | 2007-06-15 | 2007-06-26 | 0d? | start no earlier than 2007-06-15 | C1 |  |  | OAM7-Trace |  | Rel-7 | Frederic | CP-32 |  |  |
| 1590 | 503.3.5 | Deleted - duplicated with UID 35063 - IRP for Subscriber and Equipment Trace Management |  | 336d? | 2005-09-02 A | 2006-12-15 A | 100% | 2005-09-02 | 2006-12-15 | 336d? | finish no earlier than 2006-12-15 | S5 | 2688h | 2688h | OAM7-Trace | Nokia | Rel-7 | Dionisio | SP-33 |  |  |
| 1591 | 504 | **Rel-7 Charging Management small Enhancements** |  | 279d? | 2006-05-22 A | 2007-06-14 A | 100% | 2006-05-22 | 2007-06-14 | 279d? |  | S5 | 5952h | 5952h | CH7 | Orange | Rel-7 | Dionisio |  | alain.bibas@orange-ft.com |  |
| 1592 | 504.1 | Alternate Charged Party (ACP) for IMS |  | 279d? | 2006-05-22 A | 2007-06-14 A | 100% | 2006-05-22 | 2007-06-14 | 279d? | finish no earlier than 2007-06-14 | S5 | 2232h | 2232h | CH7-IMS-ACP | Lucent | Rel-7 | Dionisio |  | njmazzarella@alcatel-lucent.com |  |
| 1593 | 504.2 | Align 3GPP Charging with OMA PoC Enabler Release 2.0 |  | 186d? | 2006-09-28 A | 2007-06-14 A | 100% | 2006-09-28 | 2007-06-14 | 186d? | finish no earlier than 2007-06-14 | S5 | 1488h | 1488h | CH7-PoC | Siemens | Rel-7 | Dionisio |  | Gerald.Goermer@nsn.com |  |
| 1594 | 8.5 | **Multiple-Input Multiple-Output (MIMO) antennas** |  | 1301d? | 2003-03-14 A | 2008-03-07 A | 100% | 2003-03-14 | 2008-03-07 | 1301d? |  | R1,R5 | 45440h | 45440h | MIMO | Alcatel-Lucent | Rel-7 | Patrick |  | hchuang@Alcatel-Lucent.com | RP-070037, RP-070531 |
| 1595 | 505.1 | MIMO - Physical layer |  | 915d? | 2003-09-12 A | 2007-03-15 A | 100% | 2003-09-12 | 2007-03-15 | 915d? | finish no earlier than 2007-03-15 | R1 | 7320h | 7320h | MIMO-Phys | Alcatel-Lucent | Rel-7 | Patrick |  | hchuang@Alcatel-Lucent.com | RP-070037 |
| 1596 | 505.2 | MIMO - Layer 2,3 aspects |  | 915d? | 2003-09-12 A | 2007-03-15 A | 100% | 2003-09-12 | 2007-03-15 | 915d? | finish no earlier than 2007-03-15 | R2 | 7320h | 7320h | MIMO-L23 | Alcatel-Lucent | Rel-7 | Joern |  | hchuang@Alcatel-Lucent.com | RP-070037 |
| 1597 | 505.3 | MIMO - Iub/Iur Protocol Aspects |  | 1045d? | 2003-03-14 A | 2007-03-15 A | 100% | 2003-03-14 | 2007-03-15 | 1045d? | finish no earlier than 2007-03-15 | R3 | 8360h | 8360h | MIMO-IurIub | Alcatel-Lucent | Rel-7 | Juha |  | hchuang@Alcatel-Lucent.com | RP-070037 |
| 1598 | 505.4 | MIMO - RF Radio Transmission/Reception, System Performance Requirements and Conformance Testing |  | 982d? | 2003-12-12 A | 2007-09-17 A | 100% | 2003-12-12 | 2007-09-17 | 982d? | finish no earlier than 2007-09-17 | R4 | 7856h | 7856h | MIMO-RF | Alcatel-Lucent | Rel-7 | Issam |  | ngm@Alcatel-Lucent.com | RP-070531 |
| 1599 | 505.5 | **UE Conformance Testing for Multiple Input Multiple Output antennas (MIMO)** |  | 261d? | 2007-03-09 A | 2008-03-07 A | 100% | 2007-03-09 | 2008-03-07 | 261d? |  | R5 | 4176h | 4176h | MIMO-UEConTest | Qualcomm | Rel-7 | Ingbert |  | svora@qualcomm.com |  |
| 1600 | 505.5.1 | Conformance Test Aspects – Multiple Input Multiple Output Antennas (MIMO) for FDD |  | 261d? | 2007-03-09 A | 2008-03-07 A | 100% | 2007-03-09 | 2008-03-07 | 261d? | finish no earlier than 2008-03-07 | R5 | 2088h | 2088h | MIMO-UEConTest_FDD | Qualcomm | Rel-7 | Ingbert |  | svora@qualcomm.com |  |
| 1601 | 506 | **Rel-7 Improvements of the Radio Interface** |  | 709d? | 2004-09-15 A | 2007-06-04 A | 100% | 2004-09-15 | 2007-06-04 | 709d? |  | RP | 29696h | 29696h | RInImp |  | Rel-7 | Issam |  |  |  |
| 1602 | 506.1 | Extended UMTS 1.7/2.1 GHz |  | 198d? | 2006-03-15 A | 2006-12-15 A | 100% | 2006-03-15 | 2006-12-15 | 198d? | finish no earlier than 2006-12-15 | R4 | 1584h | 1584h | RInImp-UMTS1721Ext | Ericsson | Rel-7 | Issam |  | Johan Sköld (johan.skold@ericsson.com) | RP-060681 |
| 1603 | 506.2 | UMTS 2.6 GHz 7.68 Mcps TDD |  | 67d? | 2006-06-15 A | 2006-09-15 A | 100% | 2006-06-15 | 2006-09-15 | 67d? | finish no earlier than 2006-09-15 | R4 | 536h | 536h | RInImp-UMTS26VHCRTDD | IPWireless | Rel-7 | Issam |  | Shin Horng Wong (shwong@ipwireless.com) | RP-060451 |
| 1604 | 506.3 | UMTS 2.6 GHz |  | 195d? | 2004-09-15 A | 2005-06-14 A | 100% | 2004-09-15 | 2005-06-14 | 195d? | finish no earlier than 2005-06-14 | R4 | 1560h | 1560h | RInImp-UMTS2600 | Nokia | Rel-7 | Issam |  | jussi.numminen@nokia.com | RP-050184 |
| 1605 | 506.4 | UMTS 2.6 GHz TDD |  | 261d? | 2004-12-15 A | 2005-12-14 A | 100% | 2004-12-15 | 2005-12-14 | 261d? | finish no earlier than 2005-12-15 | R4 | 2088h | 2088h | RInImp-UMTS2600TDD | IPWireless | Rel-7 | Issam |  | Shin Horng Wong (shwong@ipwireless.com) | RP-050661 |
| 1606 | 506.5 | UMTS 900 MHz |  | 261d? | 2004-12-15 A | 2005-12-14 A | 100% | 2004-12-15 | 2005-12-14 | 261d? | finish no earlier than 2005-12-15 | R4 | 2088h | 2088h | RInImp-UMTS900 | Nortel | Rel-7 | Issam |  | Yannick Li (yli@nortelnetworks.com) | RP-050662 |
| 1607 | 506.6 | UMTS 1700 MHz |  | 197d? | 2005-03-15 A | 2005-12-14 A | 100% | 2005-03-15 | 2005-12-14 | 197d? | finish no earlier than 2005-12-15 | R4 | 1576h | 1576h | RInImp-UMTS1700 | NTT DoCoMo | Rel-7 | Issam |  | Takehiro Nakamura (nakamurata@nttdocomo.co.jp) | RP-050824 |
| 1608 | 506.7 | UE Antenna Performance Evaluation Method and Requirements |  | 644d? | 2004-12-15 A | 2007-06-04 A | 100% | 2004-12-15 | 2007-06-04 | 644d? | finish no earlier than 2007-06-04 | R4 | 5152h | 5152h | RInImp-UEAnt | TeliaSonera | Rel-7 | Issam |  | Christian.Bergljung@TeliaSonera.com | RP-070281 |
| 1609 | 506.8 | Improved Performance Requirements for HSDPA UE based on Rx Diversity (type 1) & LMMSE equalizer (type 2) | milestone | 0d? | 2005-03-15 A | 2005-03-15 A | 100% | 2005-03-15 | 2005-03-15 | 0d? | finish no earlier than 2005-03-15 | R4 |  |  | RInImp-HSPerf-Type3 | Cingular | Rel-7 | Issam |  | Marc Grant | RP-060015 |

Notes:
- 1585: -
- 1586: 07/2005: OMA (Stage 1), Stage 2/3 SA5, CT1/3/4 / Text3: CR 32.101, 32.421/2/3.
- 1587: - / Text3: CR 32.421/2/3.
- 1588: - / Text3: 32.441/2/3/5, CRs 32.632/3/5
- 1589: combined with UID 11067
- 1590: - / Text3: 32.421,32.422,32.423. 3 new 32.4x1,2,3
- 1591: - / Text3: TR 30.817
- 1592: - / Text3: 32.240, 32.260, 32.298, 32.299
- 1593: 09/2006 SP#33 WID approved / Text3: 32.240, 32.272, 32.299, 32.298
- 1594: Completed Sep 2007; SR in RP-070037and RP-070531 / Text3: 25.876, 25.996
- 1595: Completed Sep 2007; SR in RP-070037 / Text3: 25.211, 25.212, 25.213, 25.214, 25.215, 25.221
- 1596: Completed Sep 2007; SR in RP-070037 / Text3: 25.876
- 1597: Completed Sep 2007; SR in RP-070037
- 1598: Completed Sep 2007; SR in RP-070531
- 1599: BB place holder for a number of RAN5 Tasks
- 1600: - / Text3: TS 34.108, TS 34.109, TS 34.121-1, TS 34.121-2, TS 34.123-1, TS 34.123-2, TS 34.123-3
- 1601: Generic feature
- 1602: RP#34 completed. Introduction of Band X (Extended UMTS 1.7/2.1 GHz) in 25.307 / Text3: 25.806, 25.101, 25.104, 25.133, 24.141, 25.331, 25.306, 25.307, 25.423, 25.461, 25.463, 34.121
- 1603: RP#33 completed / Text3: 25.102, 25.105, 25.123, 25.113, 25.142, 34.124
- 1604: RP#28 completed / Text3: 25.101, 25.104, 25.133, 25.141, 25.331, 25.942, 25.306, 25.307, 34.121
- 1605: RP#30 completed / Text3: 25.102, 25.105, 25.113, 25.123, 25.142, 25.331, 25.942, 25.306, 25.307, 34.122, 34.124
- 1606: RP#30 completed / Text3: 25.101, 25.104, 25.113, 25.133, 25.141, 25.331, 25.942, 25.306, 25.307, 34.121
- 1607: RP#30 completed / Text3: 25.101, 25.104, 25.113, 25.133, 25.141, 25.306, 25.307, 25.331, 34.121
- 1608: RP#36 completed / Text3: 25.101, 25.963
- 1609: RP#27 completed / Text3: 25.101

| ID | WBS | Task | Type | Duration | Start | Finish | Complete | Baseline start | Baseline finish | Baseline duration | Constraint | Deadline | Resources | Work | Actual work | Text1 | Text4 | Text5 | Text6 | Text8 | Text11 | Text12 | Text9 | Text10 |
| --- | --- | --- | --- | --- | --- | --- | --- | --- | --- | --- | --- | --- | --- | --- | --- | --- | --- | --- | --- | --- | --- | --- | --- | --- |
| 1610 | 506.9 | **Additional minimum UE performance requirement for non-HSDPA channels based on type 1 enhanced receiver (Rx Diversity)** |  | 327d? | 2005-09-15 A | 2006-12-15 A | 100% | 2005-09-15 | 2006-12-15 | 327d? |  |  | R4 | 7344h | 7344h | RInImp-RxDiv | Qualcomm | Serge Willenegger (sergew@qualcomm.com) | Rel-7 | Issam |  |  |  |  |
| 1611 | 506.9.1 | Additional minimum UE performance requirement for DL physical channels in support of DCH/HS-DSCH operation based on type 1 enhanced receiver (RX-Diversity) |  | 195d? | 2005-09-15 A | 2006-06-14 A | 100% | 2005-09-15 | 2006-06-14 | 195d? | finish no earlier than 2006-06-15 |  | R4 | 1560h | 1560h | RInImp-RxDiv-DCH | Cingular | Marc Grant | Rel-7 | Issam | RP-060235 |  |  |  |
| 1612 | 506.9.2 | Additional minimum UE performance requirement for downlink physical channels in support of MTCH and MCCH operation based on type 1 enhanced receiver (Rx-Diversity) |  | 198d? | 2006-03-15 A | 2006-12-15 A | 100% | 2006-03-15 | 2006-12-15 | 198d? | finish no earlier than 2006-12-15 |  | R4 | 1584h | 1584h | RInImp-RxDiv-MBMS | Qualcomm | Serge Willenegger (sergew@qualcomm.com) | Rel-7 | Issam | RP-060678 |  |  |  |
| 1613 | 506.9.3 | Additional minimum UE performance requirement for downlink physical channels in support of E-DCH operation based on type 1 enhanced receiver (Rx-Diversity) |  | 198d? | 2006-03-15 A | 2006-12-15 A | 100% | 2006-03-15 | 2006-12-15 | 198d? | finish no earlier than 2006-12-15 |  | R4 | 1584h | 1584h | RInImp-RxDiv-EDCH | Qualcomm | Serge Willenegger (sergew@qualcomm.com) | Rel-7 | Issam | RP-060679 |  |  |  |
| 1614 | 506.10 | Deleted Improved support of gaming over HSDPA/EDCH |  | 262d? | 2005-12-15 A | 2006-12-15 A | 100% | 2005-12-15 | 2006-12-15 | 262d? | finish no earlier than 2006-12-15 |  | R2 | 2096h | 2096h | RInImp-Gaming | Cingular | Don Zelmer (dz1069@att.com) | Rel-7 | Joern | RP-060680 | RP-34 |  |  |
| 1615 | 506.11 | Deleted (not approved at PCG) - UMTS 2.6 GHz FDD DL External | milestone | 0d? | 2005-09-15 A | 2005-09-15 A | 100% | 2005-09-15 | 2005-09-15 | 0d? | finish no earlier than 2005-09-15 |  | R4 |  |  | RInImp-UMTS2600Ext | T-mobile | han.van.bussel@t-mobile.de | Rel-7 | Issam |  | RP-31 | PCG-16 |  |
| 1616 | 507 | **Rel-7 Improvements of the Radio Interface - UE Conformance Testing** |  | 741d? | 2005-11-11 A | 2008-09-12 A | 100% | 2005-11-11 | 2008-09-12 | 741d? |  |  | R5 | 17568h | 17568h | RInImp-UEConTest |  |  | Rel-7 | Ingbert |  |  |  |  |
| 1617 | 16.5.1 | UE Conformance Test for UMTS 2600 MHz |  | 146d | 2005-11-11 A | 2006-06-02 A | 100% | 2005-11-11 | 2006-06-02 | 146d | finish no earlier than 2006-06-02 | 2006-06-02 | R5 | 1168h | 1168h | RInImp-UMTS2600_Test | Nokia | Aleksi.Heino@nokia.com | Rel-7 | Ingbert |  |  |  | Fri 7/11/05 |
| 1618 | 16.5.1 | UE Conformance Test for UMTS 900 MHz (band VIII) |  | 146d | 2005-11-11 A | 2006-06-02 A | 100% | 2005-11-11 | 2006-06-02 | 146d | finish no earlier than 2006-06-02 | 2006-06-02 | R5 | 1168h | 1168h | RInImp-UMTS900_Test | Qualcomm | hanye@qualcomm.com | Rel-7 | Ingbert |  |  |  | Fri 11/03/05 |
| 1619 | 507.3 | Conformance Test Aspects – Improved Performance of HSDPA Receiver type 3 |  | 191d? | 2006-03-10 A | 2006-12-01 A | 100% | 2006-03-10 | 2006-12-01 | 191d? | finish no earlier than 2006-12-01 |  | R5 | 1528h | 1528h | RInImp-HSPerf-Type3_Test | Motorola | carolyn.taylor@motorola.com | Rel-7 | Ingbert |  |  |  |  |
| 1620 | 507.4 | UE antenna Over The Air (OTA) conformance testing |  | 518d? | 2006-09-20 A | 2008-09-12 A | 100% | 2006-09-20 | 2008-09-12 | 518d? | finish no earlier than 2008-09-12 |  | R5 | 4144h | 4144h | RInImp-UEAnt_Test | Nokia | Aleksi.Heino@nokia.com | Rel-7 | Ingbert | RP-080535 |  |  |  |
| 1621 | 507.5 | UE conformance testing for FDD Inter-Band Operation |  | 131d? | 2006-06-02 A | 2006-12-01 A | 100% | 2006-06-02 | 2006-12-01 | 131d? | finish no earlier than 2006-12-01 |  | R5 | 1048h | 1048h | RInImp-InterBand_Test | NEC, Motorola | Jacob.John@motorola.com | Rel-7 | Ingbert |  |  |  |  |
| 1622 | 507.6 | Conformance Test Aspects – Extended UMTS 1.7/2.1 GHz |  | 131d? | 2006-12-01 A | 2007-06-01 A | 100% | 2006-12-01 | 2007-06-01 | 131d? | finish no earlier than 2007-06-01 |  | R5 | 1048h | 1048h | RInImp-UEConTest_UMTS1721Ext | Motorola | carolyn.taylor@motorola.com | Rel-7 | Ingbert | RP-070312 |  |  |  |
| 1623 | 507.7 | Conformance Test Aspects – Minimum UE performance requirement for downlink physical channels in support of E-DCH operation based on type 1 enhanced receiver (Rx-Diversity) |  | 136d? | 2007-06-01 A | 2007-12-07 A | 100% | 2007-06-01 | 2007-12-07 | 136d? | finish no earlier than 2007-12-07 |  | R5 | 1088h | 1088h | RInImp-UEConTest_RxDivEDCH | Motorola | carolyn.taylor@motorola.com | Rel-7 | Ingbert | RP-070810 |  |  |  |
| 1624 | 507.8 | Conformance Test Aspects – Minimum UE performance requirement for downlink physical channels in support of MTCGH and MCCH operation based on type 1 enhanced receiver (Rx-Diversity) |  | 201d? | 2007-06-01 A | 2008-03-07 A | 100% | 2007-06-01 | 2008-03-07 | 201d? | finish no earlier than 2008-03-07 |  | R5 | 1608h | 1608h | RInImp-UEConTest_RxDivMBMS | Ericsson | leif.mattisson@ericsson.com | Rel-7 | Ingbert | RP-080056 |  |  |  |
| 1625 | 508 | **Rel-7 RAN improvements** |  | 653d? | 2004-12-15 A | 2007-06-15 A | 100% | 2004-12-15 | 2007-06-15 | 653d? |  |  | RP,S5 | 24728h | 24728h | RANimp |  |  | Rel-7 |  |  |  |  |  |
| 1626 | 508.1 | Optimization of channelisation code utilisation for 1.28 Mcps TDD |  | 523d? | 2004-12-15 A | 2006-12-15 A | 100% | 2004-12-15 | 2006-12-15 | 523d? | finish no earlier than 2006-12-15 |  | R1 | 4184h | 4184h | RANimp-RABSE-CodOptLCRTDD | UTStarcom | Ka Leong Lo (kaleong.lo@UTSTAR.COM) | Rel-7 | Patrick | RP-060682 |  |  |  |
| 1627 | 508.2 | Delay optimization for procedures applicable to CS and PS Connections |  | 394d? | 2005-03-15 A | 2006-09-15 A | 100% | 2005-03-15 | 2006-09-15 | 394d? | finish no earlier than 2006-09-15 |  | R2 | 3152h | 3152h | RANimp-DelayOpt | Nokia | juho.pirskanen@nokia.com | Rel-7 | Joern | RP-060453 |  |  |  |
| 1628 | 508.3 | Improved support of IMS Realtime Services using HSDPA/HSUPA |  | 197d? | 2005-03-15 A | 2005-12-14 A | 100% | 2005-03-15 | 2005-12-14 | 197d? | start no earlier than 2005-03-15 |  | R2 | 1576h | 1576h | RANimp-IMSRealTime | Cingular | Don Zelmer (dz1069@att.com) | Rel-7 | Joern | RP-050667 |  |  |  |
| 1629 | 508.4 | UE Performance Requirements for MBMS (TDD) |  | 328d? | 2005-03-15 A | 2006-06-15 A | 100% | 2005-03-15 | 2006-06-15 | 328d? | finish no earlier than 2006-06-15 |  | R4 | 2624h | 2624h | MBMS-RAN-RF-TDD | IPwireless | shwong@ipwireless.com | Rel-7 | Issam | RP-060477 |  |  |  |
| 1630 | 508.5 | Continuous connectivity for packet data users |  | 524d? | 2005-03-14 A | 2007-03-15 A | 100% | 2005-03-14 | 2007-03-15 | 524d? | finish no earlier than 2007-03-15 |  | R1 | 4192h | 4192h | RANimp-CPC | Siemens | Joern.Krause@siemens.com | Rel-7 | Patrick | RP-070033 |  |  |  |
| 1631 | 508.6 | Extended WCDMA Cell Range |  | 198d? | 2006-03-15 A | 2006-12-15 A | 100% | 2006-03-15 | 2006-12-15 | 198d? | finish no earlier than 2006-12-15 |  | R3 | 1584h | 1584h | RANimp-ExtCell | Ericsson | Muhammad Kazmi | Rel-7 | Juha | RP-060685 |  |  |  |
| 1632 | 508.7 | 7.68 Mcps TDD Enhanced Uplink |  | 198d? | 2006-03-15 A | 2006-12-15 A | 100% | 2006-03-15 | 2006-12-15 | 198d? | finish no earlier than 2006-12-15 |  | R1 | 1584h | 1584h | RANimp-VHCRTDD-EDCH | IPwireless | nanderson@ipwireless.com | Rel-7 | Patrick | RP-060684 |  |  |  |
| 1633 | 508.8 | Enhanced CELL_FACH State in FDD |  | 181d? | 2006-09-25 A | 2007-06-04 A | 100% | 2006-09-25 | 2007-06-04 | 181d? | finish no earlier than 2007-06-04 |  | R2 | 1448h | 1448h | RANimp-EnhState | Nokia | juho.pirskanen@nokia.com | Rel-7 | Joern | RP-070286 |  |  |  |
| 1634 | 508.9 | 64QAM for HSDPA (FDD) |  | 110d? | 2006-12-15 A | 2007-06-04 A | 100% | 2006-12-15 | 2007-06-04 | 110d? | finish no earlier than 2007-06-04 |  | R1 | 880h | 880h | RANimp-64QamDownlink | Ericsson | Johan.Bergman@ericsson.com | Rel-7 | Patrick | RP-070287 |  |  |  |
| 1635 | 508.10 | Improved L2 support for high data rates |  | 122d? | 2006-12-15 A | 2007-06-04 A | 100% | 2006-12-15 | 2007-06-04 | 122d? | finish no earlier than 2007-06-04 |  | R2 | 976h | 976h | RANimp-L2DataRates | Ericsson | Janne.Peisa@ericsson.com | Rel-7 | Joern | RP-070289 |  |  |  |
| 1636 | 508.11 | Introduction of 16QAM in HSUPA (FDD) |  | 110d? | 2006-12-15 A | 2007-06-04 A | 100% | 2006-12-15 | 2007-06-04 | 110d? | finish no earlier than 2007-06-04 |  | R1 | 880h | 880h | RANimp-16QamUplink | Nokia | Karri.Ranta-aho@nsn.com | Rel-7 | Patrick | RP-070288 |  |  |  |

Notes:
- 1610: - / Text3: 25.101
- 1611: RP#32 completed / Text3: 25.101
- 1612: RP#34 completed / Text3: 25.101
- 1613: RP#34 completed / Text3: 25.101
- 1614: RP#34 stopped. SR in RP-060680
- 1615: This item was conditionnaly approved pending decision of PCG#16 who decided not to approve it / Text3: 25.101, 25.104, 25.133, 25.141, 25.331, 25.942, 25.306, 25.307, 34.121
- 1616: Linked to Feature UID_20028 (RInImp)
- 1617: RP#32 completed / Text3: 34.108, 34.121
- 1618: RP#32 completed / Text3: 34.108, 34.121
- 1619: RP#34 completed / Text3: 34.121, 34.108
- 1620: RP#41 completed (GERAN aspects might need to be included later) / Text3: 34.114
- 1621: RP#34 completed / Text3: 34.108, 34.123-1, 34.123-2, 34.123-3
- 1622: RP#36 completed / Text3: 34.108, 34.121-1, 34.121-2
- 1623: RP#38 completed
- 1624: RP#39 completed
- 1625: Generic feature
- 1626: RP#34 completed
- 1627: RP#33 completed / Text3: 25.815, 25.321, 25.322, 25.331
- 1628: RP#30 completed
- 1629: RP#32 completed / Text3: 25.102, 25.123
- 1630: RP#35 completed / Text3: 25.903, 25.201, 25.211, 25.212, 25.214, 25.308, 25.321, 25.331, 25.423, 25.433, 25.101, 25.133
- 1631: RP#34 completed / Text3: 25.133, 25.423, 25.425, 25.433, 25.435, 25.453, 25.331
- 1632: RP#34 completed / Text3: 25.201, 25.202, 25.221, 25.222, 25.223, 25.224, 25.225, 25.331, 23.321, 25.306, 25.302, 25.401, 25.420, 25.423, 25.427, 25.433, 25.102, 25.105, 25.142
- 1633: RP#36 completed / Text3: 25.308, 25.304, 25.306, 25.321, 25.331, 25.433, 25.435, 25.423, 25.425,
- 1634: RP#36 completed / Text3: 25.308, 25.211, 25.212, 25.213, 25.306, 25.331, 25.433, 25.435, 25.423, 25.425, 25.101, 25.104, 25.141
- 1635: RP#36 completed / Text3: 25.301, 25.308,25.306, 25.321, 25.322, 25.331, 25.433, 25.435, 25.423, 25.425, 25.999
- 1636: RP#36 completed / Text3: 25.319, 25.101, 25.104, 25.133, 25.141, 25.211, 25.212, 25.213, 25.214, 25.306, 25.321, 25.331, 25.423, 25.433

| ID | WBS | Task | Duration | Start | Finish | Complete | Remaining | Baseline start | Baseline finish | Baseline duration | Total slack | Constraint | Resources | Work | Actual work | Text1 | Text4 | Text5 | Text6 | Text8 | Text11 | Text2 | Text7 |
| --- | --- | --- | --- | --- | --- | --- | --- | --- | --- | --- | --- | --- | --- | --- | --- | --- | --- | --- | --- | --- | --- | --- | --- |
| 1637 | 508.12 | **Interface to control Tower Mounted Amplifiers (TMAs)** | 271d? | 2006-06-02 A | 2007-06-15 A | 100% |  | 2006-06-02 | 2007-06-15 | 271d? |  |  | R3,S5 | 1648h | 1648h | RANImp-TMA | Vodafone | alexej.kulakov@vodafone.com | Rel-7 | Juha | RP-070140 |  |  |
| 1638 | 508.12.1 | Interface to control Tower Mounted Amplifiers (TMAs) | 206d? | 2006-06-02 A | 2007-03-16 A | 100% |  | 2006-06-02 | 2007-03-16 | 206d? |  |  | R3 | 840h | 840h | RANImp-TMA | Vodafone | alexej.kulakov@vodafone.com | Rel-7 | Juha | RP-070140 |  |  |
| 1639 | 508.12.2 | OAM aspects to Interface to control TMAs | 101d? | 2007-01-26 A | 2007-06-15 A | 100% |  | 2007-01-26 | 2007-06-15 | 101d? |  | finish no earlier than 2007-06-15 | S5 | 808h | 808h | RANImp-TMA-OAM | Vodafone | Adrian.Neal@vodafone.com | Rel-7 | Dionisio |  |  |  |
| 1640 | 509 | **Rel-7 RAN improvements - UE Conformance Testing** | 784d? | 2006-09-20 A | 2009-09-18 A | 100% |  | 2006-09-20 | 2009-09-18 | 784d? |  |  | R5 | 25472h | 25472h | RANimp-UEConTest |  |  | Rel-7 | Ingbert |  |  |  |
| 1641 | 509.1 | Conformance Test Aspects - 3.84 Mcps and 7.68 Mcps TDD Enhanced Uplink | 518d? | 2006-09-20 A | 2008-09-12 A | 100% |  | 2006-09-20 | 2008-09-12 | 518d? |  | finish no earlier than 2008-09-12 | R5 | 4144h | 4144h | RANimp-UEConTest_EDCHTDH | IPWireless | tspeight@ipwireless.com | Rel-7 | Ingbert | RP-080536 |  |  |
| 1642 | 509.2 | Conformance Test Aspects – 64QAM for HSDPA (FDD) | 257d? | 2007-03-09 A | 2008-03-03 A | 100% |  | 2007-03-09 | 2008-03-03 | 257d? |  | finish no earlier than 2008-03-03 | R5 | 2056h | 2056h | RANimp-UEConTest_64QamDownlink | Ericsson | leif.mattisson@ericsson.com | Rel-7 | Ingbert | RP-080059 |  |  |
| 1643 | 509.3 | Conformance Test Aspects – 16QAM for HSUPA (FDD) | 321d? | 2007-03-09 A | 2008-05-30 A | 100% |  | 2007-03-09 | 2008-05-30 | 321d? |  | finish no earlier than 2008-05-30 | R5 | 2568h | 2568h | RANimp-UEConTest_16QamUplink | Motorola | carolyn.taylor@motorola.com | Rel-7 | Ingbert | RP-080281 |  |  |
| 1644 | 509.4 | Conformance Test Aspects – Improved L2 support for high data rates | 321d? | 2007-03-09 A | 2008-05-30 A | 100% |  | 2007-03-09 | 2008-05-30 | 321d? |  | finish no earlier than 2008-05-30 | R5 | 2568h | 2568h | RANimp-UEConTest_L2DataRates | Ericsson | leif.mattisson@ericsson.com | Rel-7 | Ingbert | RP-080256 |  |  |
| 1645 | 509.5 | Conformance Test Aspects – Continuous connectivity for packet data users | 321d? | 2007-03-09 A | 2008-05-30 A | 100% |  | 2007-03-09 | 2008-05-30 | 321d? |  | finish no earlier than 2008-05-30 | R5 | 2568h | 2568h | RANimp-UEConTest_CPC | Nokia | jarkko.hellsten@nokia.com | Rel-7 | Ingbert | RP-080282 |  |  |
| 1646 | 509.6 | Conformance Test Aspects – Enhanced CELL_FACH state in FDD | 662d? | 2007-03-09 A | 2009-09-18 A | 100% |  | 2007-03-09 | 2009-09-18 | 662d? |  | finish no earlier than 2009-09-18 | R5 | 5296h | 5296h | RANimp-UEConTest_EnhancedCellFACHState | Nokia | jarkko.hellsten@nokia.com | Rel-7 | Ingbert | RP-090711 |  |  |
| 1647 | 510 | **7.68 Mcps TDD option** | 783d? | 2004-09-15 A | 2007-09-14 A | 100% |  | 2004-09-15 | 2007-09-14 | 783d? |  |  | RP | 24496h | 24496h | VHCRTDD | IPwireless | Martin Beale (mbeale@ipwireless.com) | Rel-7 |  | RP-060684 |  |  |
| 1648 | 510.1 | VHCRTDD: Stage 2 | 391d? | 2004-09-15 A | 2006-03-15 A | 100% |  | 2004-09-15 | 2006-03-15 | 391d? |  | finish no earlier than 2006-03-15 | R1 | 3128h | 3128h | VHCRTDD-Stage2 | IPwireless | Martin Beale (mbeale@ipwireless.com) | Rel-7 | Patrick | RP-060684 |  |  |
| 1649 | 510.2 | VHCRTDD: Physical Layer | 391d? | 2004-09-15 A | 2006-03-15 A | 100% |  | 2004-09-15 | 2006-03-15 | 391d? |  | finish no earlier than 2006-03-15 | R1 | 3128h | 3128h | VHCRTDD-Phys | IPwireless | Martin Beale (mbeale@ipwireless.com) | Rel-7 | Patrick | RP-060684 |  |  |
| 1650 | 510.3 | VHCRTDD: Layer 2 and layer 3 protocol aspects | 391d? | 2004-09-15 A | 2006-03-15 A | 100% |  | 2004-09-15 | 2006-03-15 | 391d? |  | finish no earlier than 2006-03-15 | R2 | 3128h | 3128h | VHCRTDD-L23 | IPwireless | drichards@ipwireless.com | Rel-7 | Joern | RP-060684 |  |  |
| 1651 | 510.4 | VHCRTDD: UTRAN Iub/Iur Protocol Aspects | 391d? | 2004-09-15 A | 2006-03-15 A | 100% |  | 2004-09-15 | 2006-03-15 | 391d? |  | finish no earlier than 2006-03-15 | R3 | 3128h | 3128h | VHCRTDD-IurIub | IPwireless | Peter Legg (plegg@ipwireless.com) | Rel-7 | Juha | RP-060684 |  |  |
| 1652 | 510.5 | VHCRTDD: RF Radio Transmission/ Reception, System Performance Requirements and Conformance Testing | 457d? | 2004-09-15 A | 2006-06-15 A | 100% |  | 2004-09-15 | 2006-06-15 | 457d? |  | finish no earlier than 2006-06-15 | R4 | 3656h | 3656h | VHCRTDD-RF | IPwireless | Shin Horng Wong (shwong@ipwireless.com) | Rel-7 | Issam | RP-060684 |  |  |
| 1653 | 510.6 | Conformance Test Aspects - 7.68 Mcps TDD | 258d? | 2006-09-20 A | 2007-09-14 A | 100% |  | 2006-09-20 | 2007-09-14 | 258d? |  | finish no earlier than 2007-09-10 | R5 | 2064h | 2064h | VHCRTDD-UEConTest | IPWireless | tspeight@ipwireless.com | Rel-7 | Ingbert | RP-070307 |  |  |
| 1654 | 511 | **3.84 Mcps TDD Enhanced Uplink** | 394d? | 2005-03-15 A | 2006-09-15 A | 100% |  | 2005-03-15 | 2006-09-15 | 394d? |  |  | RP | 18384h | 18384h | EDCHTDD | IPwireless | nanderson@ipwireless.com | Rel-7 |  | RP-060462 |  |  |
| 1655 | 511.1 | EDCHTDD: Stage 2 | 328d? | 2005-03-15 A | 2006-06-15 A | 100% |  | 2005-03-15 | 2006-06-15 | 328d? |  | finish no earlier than 2006-06-15 | R2 | 2624h | 2624h | EDCHTDD-Stage2 | IPwireless | nanderson@ipwireless.com | Rel-7 | Joern | RP-060462 |  |  |
| 1656 | 511.2 | EDCHTDD: Physical Layer | 394d? | 2005-03-15 A | 2006-09-15 A | 100% |  | 2005-03-15 | 2006-09-15 | 394d? |  | finish no earlier than 2006-09-15 | R1 | 3152h | 3152h | EDCHTDD-Phys | IPwireless | nanderson@ipwireless.com | Rel-7 | Patrick | RP-060462 |  |  |
| 1657 | 511.3 | EDCHTDD: Layer 2 and 3 Protocol Aspects | 394d? | 2005-03-15 A | 2006-09-15 A | 100% |  | 2005-03-15 | 2006-09-15 | 394d? |  | finish no earlier than 2006-09-15 | R2 | 3152h | 3152h | EDCHTDD-L23 | IPwireless | drichards@ipwireless.com | Rel-7 | Joern | RP-060462 |  |  |
| 1658 | 511.4 | EDCHTDD: UTRAN Iub/Iur Protocol Aspects | 394d? | 2005-03-15 A | 2006-09-15 A | 100% |  | 2005-03-15 | 2006-09-15 | 394d? |  | finish no earlier than 2006-09-15 | R3 | 3152h | 3152h | EDCHTDD-IurIub | Interdigital | jim.miller@interdigital.com | Rel-7 | Juha | RP-060462 |  |  |
| 1659 | 511.5 | EDCHTDD: RF Radio Transmission/ Reception, System Performance Requirements and Conformance Testing | 394d? | 2005-03-15 A | 2006-09-15 A | 100% |  | 2005-03-15 | 2006-09-15 | 394d? |  | finish no earlier than 2006-09-15 | R4 | 3152h | 3152h | EDCHTDD-RF | IPwireless | Shin Horng Wong (shwong@ipwireless.com) | Rel-7 | Issam | RP-060462 |  |  |
| 1660 | 512 | **1.28 Mcps TDD Enhanced Uplink** | 653d? | 2006-03-15 A | 2008-09-12 A | 100% |  | 2006-03-15 | 2008-09-12 | 653d? |  |  | RP | 14760h | 14760h | LCRTDD-EDCH | CATT | Haijing Hu | Rel-7 |  | RP-070296 |  |  |
| 1661 | 512.1 | 1.28 Mcps TDD Enhanced Uplink: Physical Layer | 262d? | 2006-03-15 A | 2007-03-15 A | 100% |  | 2006-03-15 | 2007-03-15 | 262d? |  | finish no earlier than 2007-03-15 | R1 | 2096h | 2096h | LCRTDD-EDCH-Phys | CATT | Ke Wang | Rel-7 | Patrick | RP-070038 |  |  |
| 1662 | 512.2 | 1.28 Mcps TDD Enhanced Uplink: Layer 2 and 3 Protocol Aspects | 262d? | 2006-03-15 A | 2007-03-15 A | 100% |  | 2006-03-15 | 2007-03-15 | 262d? |  | finish no earlier than 2007-03-15 | R2 | 2096h | 2096h | LCRTDD-EDCH-L23 | CATT | Haiyang Quan | Rel-7 | Joern | RP-070038 |  |  |
| 1663 | 512.3 | 1.28 Mcps TDD Enhanced Uplink: UTRAN Iub/Iur Protocol Aspects | 262d? | 2006-03-15 A | 2007-03-15 A | 100% |  | 2006-03-15 | 2007-03-15 | 262d? |  | finish no earlier than 2007-03-15 | R3 | 2096h | 2096h | LCRTDD-EDCH-IubIur | CATT | Yincheng Zhang | Rel-7 | Juha | RP-070038 |  |  |
| 1664 | 512.4 | 1.28 Mcps TDD Enhanced Uplink: RF Radio Transmission/ Reception, System Performance Requirements and Conformance Testing | 328d? | 2006-03-15 A | 2007-06-15 A | 100% |  | 2006-03-15 | 2007-06-15 | 328d? |  | finish no earlier than 2007-06-15 | R4 | 2624h | 2624h | LCRTDD-EDCH-RF | CATT | Yuexia Song | Rel-7 | Issam | RP-070296 |  |  |
| 1665 | 512.5 | 1.28 Mcps TDD Enhanced Uplink - UE Conformance Testing | 257d? | 2007-09-20 A | 2008-09-12 A | 100% |  | 2007-09-20 | 2008-09-12 | 257d? |  | finish no earlier than 2008-09-11 | R5 | 624h | 624h | LCRTDD-EDCH-UEConTest | CATT | chenxiaozhong@datangmobile.cn | Rel-7 | Ingbert | RP-080539 |  |  |
| 1666 | 513 | Conformance Test Aspects – Multiple Band and Multiple Frequency operation for LCR TDD | 321d? | 2010-09-17 A | 2011-12-09 | 80% | 64.2d? | 2010-09-17 | 2011-12-09 | 321d? | 260d | finish no earlier than 2011-12-09 | R5 | 2568h | 2054.4h | LCRTDD_MB_MF_UEConTest | CATR | Ms Jun Chen (chenjun@catr.cn) | Rel-7 | Ingbert | RP-110508 | PCG-25 | RP-49 |
| 1667 | 514 | MS Antenna Performance Evaluation Method and Requirements | 731d? | 2005-01-28 A | 2007-11-16 A | 100% |  | 2005-01-28 | 2007-11-16 | 731d? |  | finish no earlier than 2007-11-16 | GP | 5848h | 5848h | APEMR | TeliaSonera | Ulf.Tegth@teliasonera.com | Rel-7 | Paolo |  |  |  |

Notes:
- 1637: RP#35 completed
- 1638: RP#35 completed
- 1639: SP#36 completed / Text3: 32.642, 32.643, 32.645 – Align with RAN 25.466
- 1640: Linked to Feature UID_20029 (RANimp)
- 1641: RP#41 completed / Text3: 34.108, 34.122, 34.123-1, 34.123-2, 34.123-3
- 1642: RP#39 completed / Text3: 34.108, 34.121-1, 34.121-2, 34.123-1, 34.123-2, 34.123-3
- 1643: RP#40 completed / Text3: 34.108, 34.121-1, 34.121-2, 34.123-1, 34.123-2, 34.123-3
- 1644: RP#40 completed / Text3: 34.108, 34.123-1, 34.123-2, 34.123-3
- 1645: RP#40 completed / Text3: 34.108, 34.121-1, 34.121-2, 34.123-1, 34.123-2, 34.123-3
- 1646: RP#45 completed / Text3: 34.108, 34.123-1, 34.123-2, 34.123-3
- 1647: RP#31 completed
- 1648: RP#31 completed / Text3: 25.202
- 1649: RP#31 completed / Text3: 25.221, 25.222, 25.223, 25.224,25.225
- 1650: RP#31 completed / Text3: 25.301, 25.302, 25.305, 25.306, 25.321, 25.331
- 1651: RP#31 completed / Text3: 25.401, 25.420, 25.423, 25.425, 25.427, 25.430, 25.433, 25.435
- 1652: RP#32 completed / Text3: 25.102, 25.105, 25.123, 25.133, 25.142
- 1653: RP#37 completed / Text3: 34.108, 34.122, 34.123-1, 34.123-2, 34.123-3
- 1654: RP#33 completed
- 1655: RP#33 completed
- 1656: RP#33 completed / Text3: 25.201, 25.221,25.222, 25.223, 25.224, 25.225
- 1657: RP#33 completed / Text3: 25.301, 25.302, 25.306, 25.321, 25.331
- 1658: RP#33 completed / Text3: 25.401, 25.420, 25.423, 25.427, 25.430, 25.433, 25.435
- 1659: RP#33 completed / Text3: 25.102, 25.105, 25.123, 25.142
- 1660: RP#35 completed
- 1661: RP#35 completed / Text3: 25.201, 25.221, 25.222, 25.223, 25.224, 25.225
- 1662: RP#35 completed / Text3: 25.301, 25.302, 25.306, 25.321, 25.331
- 1663: RP#35 completed / Text3: 25.401, 25.420, 25.423, 25.425, 25.427, 25.430, 25.433, 25.435
- 1664: RP#36 completed / Text3: 25.102, 25.105, 25.123, 25.142
- 1665: RP#41 completed / Text3: 34.108, 34.122, 34.123-1/2/3
- 1666: Core specification was introduced via Rel-7 CR under TEI7 (RP#37 RP-070650) and via 2 Rel-8 work items: RInImp9-UMTS1880TDD and RInImp8-UMTS2300TDD. / Text3: UTRA 34.108, 34.123-1, 34.123-2, 34.123-3
- 1667: GP#36 completed for R7 / Text3: 25.914, 25.144, 45.005

| ID | WBS | Task | Type | Duration | Start | Finish | Complete | Baseline start | Baseline finish | Baseline duration | Constraint | Resources | Work | Actual work | Text1 | Text4 | Text5 | Text6 | Text8 | Text12 |
| --- | --- | --- | --- | --- | --- | --- | --- | --- | --- | --- | --- | --- | --- | --- | --- | --- | --- | --- | --- | --- |
| 1668 | 515 | **Lower 700 MHz Inclusion in the GERAN Specifications** |  | 390d? | 2005-01-03 A | 2006-06-30 A | 100% | 2005-01-03 | 2006-06-30 | 390d? |  | GP | 7632h | 7632h | GSM710 | UTC | dcotton@mtview.union-tel.com | Rel-7 | Paolo |  |
| 1669 | 515.1 | Inclusion of the 698 – 746 MHz band into GERAN core specifications |  | 129d? | 2005-01-03 A | 2005-06-30 A | 100% | 2005-01-03 | 2005-06-30 | 129d? | finish no earlier than 2005-06-30 | G1 | 1032h | 1032h | GSM710-core |  |  | Rel-7 | Paolo |  |
| 1670 | 515.2 | G1 aspects of GSM710 |  | 217.5d? | 2005-08-31 A | 2006-06-30 A | 100% | 2005-08-31 | 2006-06-30 | 217.5d? | finish no earlier than 2006-06-30 | G1 | 1740h | 1740h | GSM-710-test |  |  | Rel-7 | Paolo |  |
| 1671 | 515.3 | G3 aspects of GSM710 |  | 217.5d? | 2005-08-31 A | 2006-06-30 A | 100% | 2005-08-31 | 2006-06-30 | 217.5d? | finish no earlier than 2006-06-30 | G3new | 1740h | 1740h | GSM-710-test |  |  | Rel-7 | Ingbert |  |
| 1672 | 516 | **Support of Conversational Services in A/Gb mode via the PS domain** |  | 626d? | 2005-04-08 A | 2007-08-31 A | 100% | 2005-04-08 | 2007-08-31 | 626d? |  | GP | 15442.8h | 15442.8h | SCSAGB | Ericsson | gunnar.hedby@ericsson.com | Rel-7 | Paolo |  |
| 1673 | 516.1 | Minimise the transfer delay between the SGSN and the MS |  | 604.95d? | 2005-04-08 A | 2007-08-31 A | 100% | 2005-04-08 | 2007-08-31 | 604.95d? | finish no earlier than 2007-08-31 | GP | 4839.6h | 4839.6h | SCSAGB-MTD | Ericsson | gunnar.hedby@ericsson.com | Rel-7 | Paolo |  |
| 1674 | 516.2 | Definition of radio resource management functionality |  | 626d? | 2005-04-08 A | 2007-08-31 A | 100% | 2005-04-08 | 2007-08-31 | 626d? | finish no earlier than 2007-08-31 | G1 | 5008h | 5008h | SCSAGB-RRM | Ericsson | gunnar.hedby@ericsson.com | Rel-7 | Paolo |  |
| 1675 | 516.3 | Support of Conversational Services in A/Gb mode via the PS domain – RLC Non-Persistent mode |  | 101d? | 2006-06-30 A | 2006-11-17 A | 100% | 2006-06-30 | 2006-11-17 | 101d? | finish no earlier than 2006-11-17 | G2 | 808h | 808h | SCSAGB-RLCNP | Ericsson | gunnar.hedby@ericsson.com | Rel-7 | Gert |  |
| 1676 | 516.4 | Deleted- Radio Channel Support | milestone | 0d? | 2006-07-17 A | 2006-07-17 A | 100% | 2006-07-17 | 2006-07-17 | 0d? | start no earlier than 2006-07-17 | G2 |  |  | SCSAGB-RCHS | Ericsson | gunnar.hedby@ericsson.com | Rel-7 | Gert | SP-32 |
| 1677 | 516.5 | Deleted- Modifications to FLO | milestone | 0d? | 2006-07-17 A | 2006-07-17 A | 100% | 2006-07-17 | 2006-07-17 | 0d? | start no earlier than 2006-07-17 | G2 |  |  | SCSAGB-FLO | Ericsson | gunnar.hedby@ericsson.com | Rel-7 | Gert | SP-32 |
| 1678 | 517 | **Addition of new frequency band to GSM (T-GSM810)** |  | 626d? | 2005-04-08 A | 2007-08-31 A | 100% | 2005-04-08 | 2007-08-31 | 626d? |  | GP | 12112h | 12112h | TGSM810 | Huawei | chende@huawei.com | Rel-7 | Paolo |  |
| 1679 | 517.1 | Changes to core specification |  | 106d? | 2005-04-08 A | 2005-09-02 A | 100% | 2005-04-08 | 2005-09-02 | 106d? | finish no earlier than 2005-09-02 | GP | 848h | 848h | TGSM810-Core | Huawei | chende@huawei.com | Rel-7 | Paolo |  |
| 1680 | 517.2 | Changes to MS testing specification |  | 626d? | 2005-04-08 A | 2007-08-31 A | 100% | 2005-04-08 | 2007-08-31 | 626d? | finish no earlier than 2007-08-31 | G3new | 5008h | 5008h | TGSM810-MStest | Huawei | chende@huawei.com | Rel-7 | Ingbert |  |
| 1681 | 517.3 | Changes to BTS testing specification |  | 156d? | 2005-04-08 A | 2005-11-11 A | 100% | 2005-04-08 | 2005-11-11 | 156d? | finish no earlier than 2005-11-11 | G1 | 1248h | 1248h | TGSM810-BTStest | Huawei | chende@huawei.com | Rel-7 | Paolo |  |
| 1682 | 518 | **Handover of dedicated and shared resources while in Dual Transfer Mode** |  | 421d? | 2005-04-08 A | 2006-11-17 A | 100% | 2005-04-08 | 2006-11-17 | 421d? |  | GP | 12672h | 12672h | HODSRDTM | Nokia | rami.vaittinen@nokia.com | Rel-7 | Paolo |  |
| 1683 | 518.1 | Handover of dedicated and shared resources while in Dual Transfer Mode |  | 321d? | 2005-04-08 A | 2006-06-30 A | 100% | 2005-04-08 | 2006-06-30 | 321d? | finish no earlier than 2006-06-30 | G2 | 2568h | 2568h | HODSRDTM-G2 | Nokia | rami.vaittinen@nokia.com | Rel-7 | Gert |  |
| 1684 | 518.2 | Deleted - MS Conformance Testing |  | 421d? | 2005-04-08 A | 2006-11-17 A | 100% | 2005-04-08 | 2006-11-17 | 421d? | finish no earlier than 2006-11-17 | G3new | 3368h | 3368h | HODSRDTM-Mstest | Nokia | rami.vaittinen@nokia.com | Rel-7 | Ingbert | GP-32 |
| 1685 | 518.3 | Deleted - BTS conformance testing |  | 421d? | 2005-04-08 A | 2006-11-17 A | 100% | 2005-04-08 | 2006-11-17 | 421d? | finish no earlier than 2006-11-17 | G1 | 3368h | 3368h | HODSRDTM-BTStest | Nokia | rami.vaittinen@nokia.com | Rel-7 | Paolo | GP-32 |
| 1686 | 519 | **Mobile Station Receive Diversity (DARP Phase II)** |  | 526d? | 2005-11-11 A | 2007-11-16 A | 100% | 2005-11-11 | 2007-11-16 | 526d? |  | GP | 16360h | 16360h | MSRD2 | Nokia | kent.pedersen@nokia.com | Rel-7 | Paolo |  |
| 1687 | 519.1 | Performance Requirements for Mobile Station Receive Diversity, DARP Phase II |  | 331d? | 2005-11-11 A | 2007-02-16 A | 100% | 2005-11-11 | 2007-02-16 | 331d? | finish no earlier than 2007-02-16 | GP | 2648h | 2648h | MSRD2-PerfReq | Nokia | kent.pedersen@nokia.com | Rel-7 | Paolo |  |
| 1688 | 519.2 | Capability signalling of Mobile Station Receive Diversity, DARP Phase II |  | 331d? | 2005-11-11 A | 2007-02-16 A | 100% | 2005-11-11 | 2007-02-16 | 331d? | finish no earlier than 2007-02-16 | GP | 2648h | 2648h | MSRD2-CapSig | Nokia | kent.pedersen@nokia.com | Rel-7 | Paolo |  |
| 1689 | 519.3 | Test Scenarios for Mobile Station Receive Diversity, DARP Phase II |  | 331d? | 2005-11-11 A | 2007-02-16 A | 100% | 2005-11-11 | 2007-02-16 | 331d? | finish no earlier than 2007-02-16 | GP | 2648h | 2648h | MSRD2-TestSc | Nokia | kent.pedersen@nokia.com | Rel-7 | Paolo |  |
| 1690 | 519.4 | MS conformance test of DARP Phase II (MSRD) |  | 526d? | 2005-11-11 A | 2007-11-16 A | 100% | 2005-11-11 | 2007-11-16 | 526d? | finish no earlier than 2007-11-16 | GP | 4208h | 4208h | MSRD2-Msconf | Nokia | kent.pedersen@nokia.com | Rel-7 | Ingbert |  |
| 1691 | 520 | **Downlink Dual Carrier** |  | 947d? | 2006-01-20 A | 2009-09-04 A | 100% | 2006-01-20 | 2009-09-04 | 947d? |  | GP | 15446.6h | 15446.6h | GDCDL | Nokia Siemens Networks | leonardo.provvedi@roke.co.uk | Rel-7 | Paolo |  |
| 1692 | 520.1 | Downlink Dual Carrier Stage 2 |  | 116d? | 2006-01-20 A | 2006-06-30 A | 100% | 2006-01-20 | 2006-06-30 | 116d? | finish no earlier than 2006-06-30 | G1 | 928h | 928h | GDCDL-Stage2 | Nokia Siemens Networks | leonardo.provvedi@roke.co.uk | Rel-7 | Paolo |  |
| 1693 | 520.2 | Downlink Dual Carrier Stage 3 |  | 421d? | 2006-01-20 A | 2007-08-31 A | 100% | 2006-01-20 | 2007-08-31 | 421d? | finish no earlier than 2007-08-31 | G1 | 3368h | 3368h | GDCDL-Stage2 | Nokia Siemens Networks | leonardo.provvedi@roke.co.uk | Rel-7 | Paolo |  |
| 1694 | 520.3 | Downlink Dual Carrier – MS Conformance Test |  | 446.82d? | 2006-01-20 A | 2009-09-04 A | 100% | 2006-01-20 | 2009-09-04 | 446.82d? | finish no earlier than 2009-09-04 | G3new | 3574.6h | 3574.6h | GDCDL-MStest | Nokia Siemens Networks | leonardo.provvedi@roke.co.uk | Rel-7 | Ingbert |  |
| 1695 | 521 | Support of SIGTRAN in GERAN |  | 116d? | 2006-01-20 A | 2006-06-30 A | 100% | 2006-01-20 | 2006-06-30 | 116d? | finish no earlier than 2006-06-30 | GP | 928h | 928h | GSIGT | Ericsson | peter.ostrup@ericsson.com | Rel-7 | Ingbert |  |

Notes:
- 1668: - / Text3: 24.008, 43.022, 44.018, 44.118, 45, 001, 45.005, 51.010, 51.021
- 1669: Completed / Text3: 24.008, 43.022, 44.018, 44.118, 45, 001, 45.005,
- 1670: - / Text3: 51.021
- 1671: - / Text3: 51.010
- 1672: Originally started Nov. 2003 as GP-030443
- 1673: -
- 1674: -
- 1675: - / Text3: 43.955, 43.064, 44.060, 45.001, 45.002, 45.003, 45.005, 45.010, 51.010, 51.021
- 1676: -
- 1677: -
- 1678: - / Text3: 45.005, 45.050, 24.008, 45.008, 45.001, 43.022, 43.030, 44.018, 44.060, 51.010-1, 51.021
- 1679: - / Text3: 45.005, 45.050, 24.008, 45.008, 45.001, 43.022, 43.030, 44.018, 44.060
- 1680: - / Text3: 51010-1
- 1681: - / Text3: 51021
- 1682: GP#30 completed. Started at GP#24
- 1683: GP#30 completed / Text3: 43.055, 44.018, 44.060
- 1684: Stopped, no work done. 12/2008 Marked as stopped ("deleted") / Text3: 51-010
- 1685: Stopped, no work done. 12/2008 Marked as stopped ("deleted") / Text3: 51.026
- 1686: GP#36 completed
- 1687: GP#33 completed / Text3: 45.005
- 1688: GP#33 completed / Text3: 24.008
- 1689: GP#33 completed / Text3: 45.005
- 1690: GP#36 completed / Text3: 51.010
- 1691: GP#35 completed
- 1692: GP#30 completed / Text3: 43.055, 43.064
- 1693: GP#35 completed / Text3: 24.008, 44.018, 44.060, 45.001, 45.002, 45.005, 45.008
- 1694: GP#43 completed / Text3: 51.010
- 1695: GP#30 completed / Text3: 48.001, 48.006, 43.059, 49.031

| ID | WBS | Task | Type | Duration | Start | Finish | Complete | Baseline start | Baseline finish | Baseline duration | Constraint | Resources | Work | Actual work | Text1 | Text4 | Text5 | Text6 | Text8 | Text12 |
| --- | --- | --- | --- | --- | --- | --- | --- | --- | --- | --- | --- | --- | --- | --- | --- | --- | --- | --- | --- | --- |
| 1696 | 522 | **Latency Reductions** |  | 306d? | 2006-06-30 A | 2007-08-31 A | 100% | 2006-06-30 | 2007-08-31 | 306d? |  | GP | 7344h | 7344h | LATRED | Ericsson | Hakan.Persson@Ericsson.com | Rel-7 | Paolo |  |
| 1697 | 522.1 | Improved Ack/Nack reporting |  | 306d? | 2006-06-30 A | 2007-08-31 A | 100% | 2006-06-30 | 2007-08-31 | 306d? | finish no earlier than 2007-08-31 | G2 | 2448h | 2448h | LATRED-ACKNAR | Ericsson | Hakan.Persson@Ericsson.com | Rel-7 | Gert |  |
| 1698 | 522.2 | Reduced TTI |  | 306d? | 2006-06-30 A | 2007-08-31 A | 100% | 2006-06-30 | 2007-08-31 | 306d? | finish no earlier than 2007-08-31 | G2 | 2448h | 2448h | LATRED-REDTTI | Ericsson | Hakan.Persson@Ericsson.com | Rel-7 | Gert |  |
| 1699 | 523 | PS Handover between GERAN/UTRAN mode and GAN Mode |  | 166d? | 2006-06-30 A | 2007-02-16 A | 100% | 2006-06-30 | 2007-02-16 | 166d? | finish no earlier than 2007-02-16 | G2 | 1328h | 1328h | GUGAN | Ericsson | John.Diachina@Ericsson.com | Rel-7 | Gert |  |
| 1700 | 524 | **Higher Uplink performance for GERAN Evolution** |  | 1227d? | 2006-09-08 A | 2011-05-20 A | 100% | 2006-09-08 | 2011-05-20 | 1227d? |  | GP | 37184h | 37184h | HUGE | Nokia Siemens Networks, Ericsson | eddie.riddington@nokia.com, stefan.g.eriksson@ericsson.com | Rel-7 | Paolo |  |
| 1701 | 524.1 | Stage 2 for HUGE |  | 261d? | 2006-09-08 A | 2007-09-07 A | 100% | 2006-09-08 | 2007-09-07 | 261d? | finish no earlier than 2007-09-07 | G1 | 2088h | 2088h | HUGE-Stage2 | Nokia Siemens Networks, Ericsson | eddie.riddington@nokia.com, stefan.g.eriksson@ericsson.com | Rel-7 | Paolo |  |
| 1702 | 524.2 | Layer 1 Support for HUGE |  | 381d? | 2006-09-08 A | 2008-02-22 A | 100% | 2006-09-08 | 2008-02-22 | 381d? | finish no earlier than 2008-02-22 | G1 | 3048h | 3048h | HUGE-Layer1 | Nokia Siemens Networks, Ericsson | eddie.riddington@nokia.com, stefan.g.eriksson@ericsson.com | Rel-7 | Paolo |  |
| 1703 | 524.3 | Layer 2/3 Support for HUGE |  | 256d? | 2006-09-08 A | 2007-08-31 A | 100% | 2006-09-08 | 2007-08-31 | 256d? | finish no earlier than 2007-08-31 | G2 | 2048h | 2048h | HUGE-Layer23 | Nokia Siemens Networks, Ericsson | eddie.riddington@nokia.com, stefan.g.eriksson@ericsson.com | Rel-7 | Gert |  |
| 1704 | 524.4 | Performance requirements for HUGE |  | 516d? | 2006-09-08 A | 2008-08-29 A | 100% | 2006-09-08 | 2008-08-29 | 516d? | finish no earlier than 2008-08-29 | G1 | 4128h | 4128h | HUGE-Perfreq | Nokia Siemens Networks, Ericsson | eddie.riddington@nokia.com, stefan.g.eriksson@ericsson.com | Rel-7 | Paolo |  |
| 1705 | 524.5 | BTS Conformance Test for HUGE |  | 782d? | 2006-09-08 A | 2009-09-04 A | 100% | 2006-09-08 | 2009-09-04 | 782d? | finish no earlier than 2009-09-04 | G1 | 6248h | 6248h | HUGE-BTStest | Nokia Siemens Networks, Ericsson | eddie.riddington@nokia.com, stefan.g.eriksson@ericsson.com | Rel-7 | Paolo |  |
| 1706 | 524.6 | MS Conformance Test for HUGE |  | 1226d? | 2006-09-08 A | 2011-05-20 A | 100% | 2006-09-08 | 2011-05-20 | 1226d? | finish no earlier than 2011-05-20 | G3new | 9808h | 9808h | HUGE-Mstest | Nokia Siemens Networks, Ericsson | eddie.riddington@nokia.com, stefan.g.eriksson@ericsson.com | Rel-7 | Ingbert |  |
| 1707 | 525 | **REduced symbol Duration, Higher Order modulation and Turbo coding (RED HOT) for downlink** |  | 1177d? | 2006-11-17 A | 2011-05-20 A | 100% | 2006-11-17 | 2011-05-20 | 1177d? |  | GP | 28808h | 28808h | REDHOT | Ericsson, Nokia Siemens Networks, Marvell | stefan.g.eriksson@ericsson.com | Rel-7 | Paolo |  |
| 1708 | 525.1 | Stage 2 for REDHOT |  | 206d? | 2006-11-17 A | 2007-08-31 A | 100% | 2006-11-17 | 2007-08-31 | 206d? | finish no earlier than 2007-08-31 | G1 | 1648h | 1648h | REDHOT-Stage2 | Ericsson, Nokia Siemens Networks, Marvell | stefan.g.eriksson@ericsson.com | Rel-7 | Paolo |  |
| 1709 | 525.2 | Stage 3 for REDHOT |  | 391d? | 2006-11-17 A | 2008-05-16 A | 100% | 2006-11-17 | 2008-05-16 | 391d? | finish no earlier than 2008-05-16 | G1 | 3128h | 3128h | REDHOT-Stage3 | Ericsson, Nokia Siemens Networks, Marvell | stefan.g.eriksson@ericsson.com | Rel-7 | Paolo |  |
| 1710 | 525.3 | BTS Conformance Tests for REDHOT |  | 651d? | 2006-11-17 A | 2009-05-15 A | 100% | 2006-11-17 | 2009-05-15 | 651d? | finish no earlier than 2009-05-15 | G1 | 5208h | 5208h | REDHOT-BTStest | Ericsson, Nokia Siemens Networks, Marvell | stefan.g.eriksson@ericsson.com | Rel-7 | Paolo |  |
| 1711 | 525.4 | MS Conformance Tests for REDHOT |  | 1176d? | 2006-11-17 A | 2011-05-20 A | 100% | 2006-11-17 | 2011-05-20 | 1176d? | finish no earlier than 2011-05-20 | G3new | 9408h | 9408h | REDHOT-Mstest | Ericsson, Nokia Siemens Networks, Marvell | stefan.g.eriksson@ericsson.com | Rel-7 | Ingbert |  |
| 1712 | 526 | (Small) Technical Enhancements and Improvements for Rel-7 | milestone | 0d? | 2007-03-26 A | 2007-03-26 A | 100% | 2007-03-26 | 2007-03-26 | 0d? | start no earlier than 2007-03-26 | All |  |  | TEI7 |  |  | Rel-7 | All |  |
| 1713 | 527 | Test - (Small) Technical Enhancements and Improvements for Rel-7 |  | 389d? | 2006-06-02 A | 2007-11-28 A | 100% | 2006-06-02 | 2007-11-28 | 389d? | finish no earlier than 2010-06-04 | R5 | 3112h | 3112h | TEI7_Test |  |  | Rel-7 | Ingbert |  |
| 1714 | 528 | **Deleted - PS domain and IMS support for IMS Emergency sessions** |  | 63.69d? | 2006-06-23 A | 2006-09-21 A | 100% | 2006-06-23 | 2006-09-21 | 63.69d? |  | S2 |  |  | IMS-EMER | Nokia | curt.c.wong@nokia.com | Rel-7 | Maurice | SP-30 |
| 1715 | 528.1 | Deleted - IMS aspects to support IMS Emergency sessions | milestone | 0d? | 2006-06-23 A | 2006-09-21 A | 100% | 2006-06-23 | 2006-09-21 | 0d? | start no earlier than 2006-06-23 | S2 |  |  | IMS-EMER | Nokia | curt.c.wong@nokia.com | Rel-7 | Maurice | SP-30 |
| 1716 | 528.2 | Deleted - PS domain aspects to support IMS Emergency sessions | milestone | 0d? | 2006-06-23 A | 2006-09-21 A | 100% | 2006-06-23 | 2006-09-21 | 0d? | start no earlier than 2006-06-23 | S2 |  |  | IMS-EMER | Nokia | curt.c.wong@nokia.com | Rel-7 | Maurice | SP-30 |
| 1717 | 16.7 | **Deleted - IMS Local services** |  | 0d? | 2006-01-06 A | 2006-01-06 A | 100% | 2006-01-06 | 2006-01-06 | 0d? |  | S2 |  |  | IMSLocal |  |  | Rel-7 | Maurice | SP-28 |
| 1718 | 16.7.1 | Deleted - Stage 2 | milestone | 0d | 2006-01-06 A | 2006-01-06 A | 100% | 2006-01-06 | 2006-01-06 | 0d | start no earlier than 2006-01-06 | S2 |  |  | IMSLocal |  |  | Rel-7 | Maurice | SP-26 |
| 1719 | 529.2 | Deleted - Stage 3 for IMS Local services | milestone | 0d? | 2006-01-06 A | 2006-01-06 A | 100% | 2006-01-06 | 2006-01-06 | 0d? | finish no earlier than 2006-01-06 | C1 |  |  | IMSLocal | Lucent | Keith Drage (drage@alcatel-lucent.com) | Rel-7 | Frederic | SP-25 |
| 1720 | 530 | Deleted - IMS Phase 3 | milestone | 0d? | 2006-01-06 A | 2006-01-06 A | 100% | 2006-01-06 | 2006-01-06 | 0d? | start no earlier than 2006-01-06 | S2 |  |  |  |  |  | Rel-7 | Maurice | SP-25 |
| 1721 | 531 | Deleted - Improvements of Radio Interface | milestone | 0d? | 2004-09-15 A | 2004-09-15 A | 100% | 2004-09-15 | 2004-09-15 | 0d? | start no earlier than 2004-09-15 | RP |  |  | RInImp |  |  | Rel-7 | Issam | SP-24 |
| 1722 | 532 | Deleted: Generic User Profile Phase 2 | milestone | 0d | 2005-08-08 A | 2006-06-30 A | 100% | 2005-08-08 | 2006-06-30 | 0d |  | C4 |  |  |  |  |  | Rel-7 | Kimmo | SP-27 |
| 1723 | 30.4 | Deleted - Stage 3 - Common objects | milestone | 0d | 2005-08-08 A | 2006-06-30 A | 100% | 2005-08-08 | 2006-06-30 | 0d | finish no earlier than 2006-06-30 | C4 |  |  |  |  |  | Rel-7 | Kimmo | SP-27 |
| 1724 | 534 | Release 7 Studies |  | 841d? | 2004-06-28 A | 2007-09-17 A | 100% | 2004-06-28 | 2007-09-17 | 841d? |  | CP,GP,RP,SP | 6728h | 6728h |  |  |  | Rel-7 | All |  |
| 1725 | 535 | Study on Multimedia Telephony Capabilities for IMS |  | 276d? | 2005-07-11 A | 2006-07-31 A | 100% | 2005-07-11 | 2006-07-31 | 276d? |  | S1 | 2145.6h | 2145.6h | MITE | Ericsson | peter.bleckert@ericsson.com | Rel-7 | Alain |  |
| 1726 | 536 | Study on Behaviour of Multi system UEs |  | 384d? | 2004-06-28 A | 2005-12-15 A | 100% | 2004-06-28 | 2005-12-15 | 384d? | start no earlier than 2004-06-28 | S1 | 3072h | 3072h | BMSU | Qualcomm | dwilliams@qualcomm.com | Rel-7 | Alain |  |
| 1727 | 537 | Study on Combining CS calls and IMS sessions |  | 189d? | 2004-06-28 A | 2005-03-17 A | 100% | 2004-06-28 | 2005-03-17 | 189d? | start no earlier than 2004-06-28 | S1 | 1512h | 1512h | IRTSD-CS_IMS | TeliaSonera | robert.frank@teliasonera.com | Rel-7 | Alain |  |
| 1728 | 538 | Study on All-IP Network |  | 188d? | 2004-06-28 A | 2005-03-16 A | 100% | 2004-06-28 | 2005-03-16 | 188d? | start no earlier than 2004-06-28 | S1 | 1504h | 1504h | FS_AIPN | NTT DoCoMo | Shin-ichi Isobe (isobes@nttdocomo.co.jp) | Rel-7 | Alain |  |
| 1729 | 539 | Study on Videotelephony teleservice |  | 231d? | 2005-03-01 A | 2006-01-17 A | 100% | 2005-03-01 | 2006-01-17 | 231d? |  | S1 | 1848h | 1848h | VidTel | T-Mobile | michael.kurz@t-mobile.at | Rel-7 | Alain |  |
| 1730 | 540 | Study on Network Selection Principles |  | 193d? | 2005-03-15 A | 2005-12-08 A | 100% | 2005-03-15 | 2005-12-08 | 193d? |  | S1 | 1544h | 1544h | NetSel | O2 | chris.friel@O2.com | Rel-7 | Alain |  |
| 1731 | 541 | Study on Multimedia Priority Service |  | 851d? | 2003-03-28 A | 2006-06-30 A | 100% | 2003-03-28 | 2006-06-30 | 851d? | finish no earlier than 2005-12-16 | S1 | 6808h | 6808h | PRIOR-MM | Telcordia | James Garrahan (jgarraha@telcordia.com) | Rel-7 | Alain |  |
| 1732 | 542 | Study on Transferring of emergency Call data |  | 190d? | 2005-07-11 A | 2006-03-31 A | 100% | 2005-07-11 | 2006-03-31 | 190d? | finish no earlier than 2005-12-08 | S1 | 1520h | 1520h | eCALL | Motorola | jian.j.wu@motorola.com | Rel-7 | Alain |  |
| 1733 | 543 | Study on Enhancement of E2E QoS |  | 281.4d? | 2004-06-28 A | 2005-09-15 A | 100% | 2004-06-28 | 2005-09-15 | 281.4d? | finish no earlier than 2005-12-01 | S2 | 2251.2h | 2251.2h | QoS7 | Huawei | Robert Jaksa | Rel-7 | Maurice |  |
| 1734 | 544 | Study on SOAP/HTTP IRP Solution Sets |  | 330d? | 2005-09-02 A | 2006-12-07 A | 100% | 2005-09-02 | 2006-12-07 | 330d? | finish no earlier than 2006-12-07 | S5 | 2640h | 2640h | OAM7-NIM-XML | Nortel | Suzèle Lariven (lariven@nortel.com) | Rel-7 | Dionisio |  |
| 1735 | 545 | Study on Itf-N Implementation Conformance Statement (ICS) template |  | 400d? | 2005-09-02 A | 2007-03-15 A | 100% | 2005-09-02 | 2007-03-15 | 400d? | finish no earlier than 2007-03-15 | S5 | 3200h | 3200h | OAM7-NIM-ICS | China Mobile | Li Yewen (liyewen@chinamobile.com) | Rel-7 | Dionisio |  |
| 1736 | 546 | Study on IRP Information Model |  | 400d? | 2005-09-02 A | 2007-03-15 A | 100% | 2005-09-02 | 2007-03-15 | 400d? | finish no earlier than 2007-03-15 | S5 | 3200h | 3200h | OAM7-NIM-IM | Motorola | trevor.pirt@motorola.com | Rel-7 | Dionisio |  |
| 1737 | 547 | Study on Bandwidth Saving at Nb Interface with IP transport |  | 261d? | 2006-03-10 A | 2007-03-09 A | 100% | 2006-03-10 | 2007-03-09 | 261d? | finish no earlier than 2007-03-09 | C3 | 2088h | 2088h | BSNbIP | Siemens | Thomas.Belling@siemens.com | Rel-7 | Jiwan |  |
| 1738 | 548 | Study on Routeing of MT-SMS via the HPLMN |  | 301d? | 2005-10-07 A | 2006-12-01 A | 100% | 2005-10-07 | 2006-12-01 | 301d? | finish no earlier than 2006-12-01 | C4 | 2408h | 2408h | SMS7 | Vodafone | Nick.Russell@vodafone.com | Rel-7 | Kimmo |  |
| 1739 | 549 | Study on the TCAPsec Gateway concept |  | 96d? | 2005-10-28 A | 2006-03-10 A | 100% | 2005-10-28 | 2006-03-10 | 96d? | finish no earlier than 2006-03-10 | C4 | 768h | 768h | SEC7-TCAP | Siemens | Ulrich.wiehe@gksag.de | Rel-7 | Kimmo |  |
| 1740 | 550 | Study on using M2PA in 3GPP network |  | 318d? | 2006-03-22 A | 2007-06-08 A | 100% | 2006-03-22 | 2007-06-08 | 318d? | finish no earlier than 2007-06-08 | C4 | 2544h | 2544h | FS-M2PA | China Mobile | zhaoyuyi@chinamobile.com | Rel-7 | Kimmo |  |

Notes:
- 1696: GP#35 completed / Text3: 45.001, 45.002, 45.003, 45.005, 45.010, 43.055, 43.064, 44.060, 51.010-1, 51.021
- 1697: GP#35 completed / Text3: 45.001, 45.002, 45.003, 45.005, 45.010, 43.055, 43.064, 44.060, 51.010-1, 51.021
- 1698: GP#35 completed / Text3: 45.001, 45.002, 45.003, 45.005, 45.010, 43.055, 43.064, 44.060, 51.010-1, 51.021
- 1699: GP#33 completed / Text3: 43.318, 44.318, 43.129, 25.306, 24.008, 44.060, 25.331, 51.010
- 1700: -
- 1701: GP#35 completed / Text3: 43.055, 43.064
- 1702: GP#37 completed / Text3: 45.001, 45.002, 45.003, 45.004, 45.008
- 1703: GP#35 completed / Text3: 24.008, 44.018, 44.060
- 1704: GP#39 completed / Text3: 45.005
- 1705: GP#43 completed / Text3: 51.021
- 1706: GP#50 completed / Text3: 51.010
- 1707: GP#38 completed. SP#42 split core from testing specification work.
- 1708: GP#35 completed / Text3: 43.055, 43.064
- 1709: GP#38 completed / Text3: 24.008, 44.018, 44.060, 45.001, 45.002, 45.003, 45.004, 45.005, 45.008
- 1710: GP#42 completed / Text3: 51.021
- 1711: GP#50 completed / Text3: 51.010
- 1712: - / Text3: CP-070260
- 1713: -
- 1714: Approved at SP#29 / Text3: 23.867, 23.abc, 23.060, 23.002, 23.271
- 1715: Approved at SP#29 / Text3: 23.867, 23.abc, 23.060, 23.002, 23.271
- 1716: Approved at SP#29 / Text3: 23.867, 23.abc, 23.060, 23.002, 23.271
- 1717: - / Text3: 23.228
- 1718: DAB - Not yet required in SA2 as it exists in previous releases
- 1719: -
- 1720: -
- 1721: Stage 2 description of Interim conclusion
- 1722: Created at TSG#27 by A. Sultan because of the move to Rel-7 of "Common Objects".
- 1723: No progress in CN4#26. This have to be moved to Rel-7. It was deleted from WID / Text3: 24.241
- 1724: -
- 1725: Spin-off Feature UID_7038 (MTSI) / Text3: 22.973
- 1726: - / Text3: 22.936
- 1727: - / Text3: 22.979
- 1728: 07/08 Moved to Rel-7 as Study out of stopped Rel-8 Feature UID_31067 All-IP Network (AIPN) / Text3: 22.978
- 1729: - / Text3: 22.903
- 1730: Spin-off Feature Network selection enhancements (NSP-CR) UID_7041 / Text3: 22.811
- 1731: Spin-off Feature PRIOR UID_340044 / Text3: 22.953
- 1732: - / Text3: 22.967
- 1733: - / Text3: 23.802
- 1734: SP#34 completed / Text3: 32.809
- 1735: SP#35 completed / Text3: 32.812
- 1736: SP#35 completed / Text3: 32.810
- 1737: Moved to FS at CT32 (in line with slides) / Text3: 29.814
- 1738: Previously known as "Study of a SMS Centre for MT SMS" / Text3: 23.840
- 1739: TR 29.800 content moved to TS 29.204 under implementation WI UID_310005 TCAPsec Gateway / Text3: 29.800
- 1740: - / Text3: 29.801

| ID | WBS | Task | Type | Duration | Start | Finish | Complete | Baseline start | Baseline finish | Baseline duration | Constraint | Resources | Work | Actual work | Text1 | Text3 | Text4 | Text5 | Text6 | Text8 | Text11 | Text12 |
| --- | --- | --- | --- | --- | --- | --- | --- | --- | --- | --- | --- | --- | --- | --- | --- | --- | --- | --- | --- | --- | --- | --- |
| 1741 | 551 | **Study on Support of (G)MSC-S - (G)MSC-S Nc Interface based on the SIP-I protocol** |  | 350d? | 2006-05-15 A | 2007-09-14 A | 100% | 2006-05-15 | 2007-09-14 | 350d? |  | C4 | 7800h | 7800h | NcSIP | 29.802 | Vodafone | david.hutton@vodafone.com | Rel-7 | Kimmo |  |  |
| 1742 | 551.1 | CT4 aspects of NcSIP |  | 275d? | 2006-05-15 A | 2007-06-01 A | 100% | 2006-05-15 | 2007-06-01 | 275d? | finish no earlier than 2007-06-01 | C4 | 2200h | 2200h | NcSIP | 29.802 | Vodafone | david.hutton@vodafone.com | Rel-7 | Kimmo |  |  |
| 1743 | 551.2 | CT3 aspects of NcSIP |  | 350d? | 2006-05-15 A | 2007-09-14 A | 100% | 2006-05-15 | 2007-09-14 | 350d? | finish no earlier than 2007-09-14 | C3 | 2800h | 2800h | NcSIP | 29.802 | Ericsson | ragnar.huslende@ericsson.com | Rel-7 | Jiwan |  |  |
| 1744 | 552 | Study on Evolved UTRA and UTRAN |  | 458d? | 2004-12-15 A | 2006-09-15 A | 100% | 2004-12-15 | 2006-09-15 | 458d? | finish no earlier than 2006-09-15 | RP | 3664h | 3664h | RANFS-Evo | 25.912 | NTT DoCoMo | nakamurata@NTTDOCOMO.CO.JP | Rel-7 | Issam | RP-060472 |  |
| 1745 | 553 | Study on Performance Evaluation of the UE behaviour in high speed trains with speeds up to 350 kmph |  | 328d? | 2005-03-15 A | 2006-06-15 A | 100% | 2005-03-15 | 2006-06-15 | 328d? | finish no earlier than 2006-06-15 | R4 | 2624h | 2624h | RANFS-HSTrains | none | Vodafone | Mike.vogel@vodafone.com,tim.frost@vodafone.com | Rel-7 | Issam | RP-060412 |  |
| 1746 | 554 | Study on UTRA Tower Mounted Amplifier (FDD) |  | 195d? | 2005-06-15 A | 2006-03-14 A | 100% | 2005-06-15 | 2006-03-14 | 195d? | finish no earlier than 2006-03-15 | R4 | 1560h | 1560h | RANFS-TMA | 25.818 | Ericsson | Klas.Sjerling@ericsson.com | Rel-7 | Issam | RP-060035 |  |
| 1747 | 555 | Study on Continuous connectivity for packet data users |  | 132d? | 2005-03-15 A | 2005-09-14 A | 100% | 2005-03-15 | 2005-09-14 | 132d? | finish no earlier than 2005-09-15 | R1 | 1056h | 1056h | RANFS-cont-packet | none | Siemens | joerg.gustrau@siemens.com | Rel-7 | Patrick | RP-050427 |  |
| 1748 | 556 | Study on Improvement of the Multimedia Broadcast Multicast Service (MBMS) in UTRAN |  | 262d? | 2005-12-15 A | 2006-12-15 A | 100% | 2005-12-15 | 2006-12-15 | 262d? | finish no earlier than 2006-12-15 | R2 | 2096h | 2096h | RANFS-MBMSImp | 25.905 | LG Electronics | leego@lge.com | Rel-7 | Joern | RP-060692 |  |
| 1749 | 557 | Study on Performance Improvements in Small Cells using HSDPA/EDCH |  | 131d? | 2005-12-15 A | 2006-06-15 A | 100% | 2005-12-15 | 2006-06-15 | 131d? | finish no earlier than 2006-06-15 | R4 | 1048h | 1048h | SMALLCELLS | none | Cingular | Marc Grant | Rel-7 | Issam | RP-060263 |  |
| 1750 | 558 | Study on Further Improved Performance Requirements for UMTS/HSDPA UE (FDD) |  | 383d? | 2005-12-15 A | 2007-06-04 A | 100% | 2005-12-15 | 2007-06-04 | 383d? | finish no earlier than 2007-06-04 | R4 | 3064h | 3064h | RANFS-IC | 25.963 | Cingular | Marc Grant | Rel-7 | Issam | RP-070499 |  |
| 1751 | 559 | Study on Scope of future FDD HSPA Evolution |  | 394d? | 2006-03-15 A | 2007-09-17 A | 100% | 2006-03-15 | 2007-09-17 | 394d? | finish no earlier than 2007-09-17 | RP | 3152h | 3152h | RANFS-HSPAEvo | 25.999 | Cingular | Don Zelmer (dz1069@att.com) | Rel-7 | Issam | RP-070533 |  |
| 1752 | 560 | Study on Dynamically reconfiguring a FDD UE receiver to reduce power consumption when desired Quality of Service is met | milestone | 0d? | 2007-06-22 A | 2007-06-22 A | 100% | 2007-06-22 | 2007-06-22 | 0d? |  | R4 |  |  | FSUEPow | 25.906 | Nokia | Chris.callender@nokia.com, tiina.s.koskinen@nokia.com | Rel-7 | Issam | RP-070534 |  |
| 1753 | 561 | Study on Future GERAN Evolution |  | 486d? | 2005-04-08 A | 2007-02-16 A | 100% | 2005-04-08 | 2007-02-16 | 486d? | finish no earlier than 2007-02-16 | GP | 3888h | 3888h | FGE | 45.912 | Nokia | eddie.riddington@nokia.com | Rel-7 | Paolo |  |  |
| 1754 | 562 | Study on GAN Enhancements | milestone | 0d? | 2007-08-31 A | 2007-08-31 A | 100% | 2007-08-31 | 2007-08-31 | 0d? | start no earlier than 2007-08-31 | GP |  |  | EGAN | 43.902 | T-Mobile | janne.linkola@t-mobile.com | Rel-7 | Paolo |  |  |
| 1755 | 563 | Deleted - Study on IMS with real time services deployment |  | 316d? | 2004-06-28 A | 2005-09-12 A | 100% | 2004-06-28 | 2005-09-12 | 316d? |  | S1 | 2528h | 2528h | IRTSD |  |  |  | Rel-7 | Alain |  | SP-30 |
| 1756 | 564 | Deleted - Covered by SI - Personal Network (PN) and Personal Area Network (PAN) | milestone | 0d? | 2005-12-08 A | 2005-12-20 A | 100% | 2005-12-08 | 2005-12-20 | 0d? | start no earlier than 2005-12-08 | S1 |  |  | PNPAN |  | Vodafone | armin.toepfer@vodafone.com | Rel-7 | Alain |  | SP-30 |
| 1757 | 565 | Deleted - Study on Personal Network and Personal Area Network | milestone | 0d? | 2006-10-20 A | 2006-10-20 A | 100% | 2006-10-20 | 2006-10-20 | 0d? | finish no earlier than 2006-10-20 | S1 |  |  | PNPAN |  |  |  | Rel-7 | Alain |  | SP-31 |
| 1758 | 566 | Deleted - Covered by SI - Multimedia Telephony Capabilities for IMS | milestone | 0d? | 2005-12-08 A | 2005-12-20 A | 100% | 2005-12-08 | 2005-12-20 | 0d? | start no earlier than 2005-12-08 | S1 |  |  | MITE |  | Ericsson | peter.bleckert@ericsson.com | Rel-7 | Alain |  | SP-30 |
| 1759 | 567 | Deleted - Covered by SI - Transferring of emergency Call data | milestone | 0d? | 2005-12-08 A | 2005-12-08 A | 100% | 2005-12-08 | 2005-12-08 | 0d? | start no earlier than 2005-12-08 | S1 |  |  | eCALL |  | Motorola | steven.vardy@motorola.com | Rel-7 | Alain |  | SP-30 |
| 1760 | 568 | Deleted - Covered by SI - MBMS Enhancements | milestone | 0d? | 2005-12-08 A | 2005-12-08 A | 100% | 2005-12-08 | 2005-12-08 | 0d? | start no earlier than 2005-12-08 | S1 |  |  | MBMSE |  | China Mobile | liuhongyfw@chinamobile.com | Rel-7 | Alain |  | SP-30 |
| 1761 | 569 | Deleted - Study on Customised Alerting Tone (CAT) Requirements (was duplicated) | milestone | 0d? | 2006-06-30 A | 2006-06-30 A | 100% | 2006-06-30 | 2006-06-30 | 0d? | start no earlier than 2006-06-30 | S1 |  |  | CAT |  |  |  | Rel-7 | Alain |  | SP-31 |
| 1762 | 570 | Deleted - Study on LCS architecture for I-WLAN (covered by 32108) | milestone | 0d? | 2006-12-08 A | 2006-12-08 A | 100% | 2006-12-08 | 2006-12-08 | 0d? | start no earlier than 2006-12-08 | S2 |  |  | IMS-SE |  | LG Electronics | Donghee Shim dhshim@lge.com ; phede@lge.com | Rel-7 | Maurice |  | SP-33 |
| 1763 | 571 | Deleted - IMS security extensions (covered by UID33027) | milestone | 0d? | 2005-12-08 A | 2005-12-08 A | 100% | 2005-12-08 | 2005-12-08 | 0d? | start no earlier than 2005-12-08 | S3 |  |  | IMS-SE |  | Ericsson | Bengt.Sahlin@ericsson.com | Rel-7 | Dionisio |  | SP-30 |
| 1764 | 572 | **Deleted - Study on applicability of GALILEO for LCS** |  | 0d? | 2005-06-30 A | 2005-06-30 A | 100% | 2005-06-30 | 2005-06-30 | 0d? |  | S2 |  |  | Galileo |  |  |  | Rel-7 | Maurice |  | SP-25 |
| 1765 | 572.1 | Deleted - TR on Stage 2 | milestone | 0d? | 2005-06-30 A | 2005-06-30 A | 100% | 2005-06-30 | 2005-06-30 | 0d? | finish no earlier than 2005-06-30 | S2 |  |  | Galileo |  |  |  | Rel-7 | Maurice |  | SP-25 |
| 1766 | 572.2 | Deleted - GERAN review of the TR | milestone | 0d? | 2005-06-30 A | 2005-06-30 A | 100% | 2005-06-30 | 2005-06-30 | 0d? | start no earlier than 2005-06-30 | GP |  |  | Galileo |  |  |  | Rel-7 | Paolo |  | SP-26 |
| 1767 | 573 | Deleted - Study on Stage 2 (IMS services using CS bearers) |  | 316d? | 2004-06-28 A | 2005-09-12 A | 100% | 2004-06-28 | 2005-09-12 | 316d? | finish no earlier than 2005-09-12 | S2 | 2528h | 2528h | IRTSD-IMSCS | 23.899 | Nortel | Mark Watson | Rel-7 | Maurice |  | SP-30 |

Notes:
- 1741: -
- 1742: -
- 1743: -
- 1744: RP#33 (Sep 2006) completed. SR in RP-060472
- 1745: RP#32 (Jun 2006) completed. SR in RP-060412
- 1746: RP#31 (Mar 2006) completed. SR in RP-060035
- 1747: RP#29 (Sep 2006) completed. SR in RP-050427
- 1748: RP#34 (Dec 2006) completed. SR in RP-060692
- 1749: RP#32 (Jun 2006) closed (no progress). SR in RP-060263
- 1750: RP#36 (May 2007) completed. SR in RP-070499
- 1751: RP#37 (Sep 2007) completed. SR in RP-070533
- 1752: RP#37 (Sep 2007) completed. SR in RP-070534
- 1753: GP#33 completed
- 1754: GP#35 completed
- 1755: -
- 1756: -
- 1757: Moved from FS section Feb 06
- 1758: -
- 1759: -
- 1760: -
- 1761: Awaiting MCC SA3 input
- 1762: -
- 1763: -
- 1764: -
- 1765: -
- 1766: -
- 1767: SP-30: S2 has no intention for TR completion

| ID | WBS | Task | Type | Duration | Start | Finish | Complete | Baseline start | Baseline finish | Baseline duration | Constraint | Resources | Work | Actual work | Text1 | Text6 | Text8 | Text12 | Text3 | Text4 | Text5 | Text7 | Text10 |
| --- | --- | --- | --- | --- | --- | --- | --- | --- | --- | --- | --- | --- | --- | --- | --- | --- | --- | --- | --- | --- | --- | --- | --- |
| 1768 | 574 | **Deleted - VoIMS bearer related enhancements** |  | 0d? | 2006-07-21 A | 2006-07-21 A | 100% | 2006-07-21 | 2006-07-21 | 0d? |  | S2 |  |  | VoIMS | Rel-7 | Maurice | SP-32 |  |  |  |  |  |
| 1769 | 574.1 | Deleted - Study on enhancement of radio performance for VoIMS | milestone | 0d? | 2006-07-21 A | 2006-07-21 A | 100% | 2006-07-21 | 2006-07-21 | 0d? | start no earlier than 2006-07-21 | S2 |  |  | VoIMS | Rel-7 | Maurice | SP-32 | 23.807 | Nortel | Laurence Lautier (lautierl@nortel.com) |  |  |
| 1770 | 575 | Deleted - Study on IMS enhancements and optimizations for real time communication. |  | 430d? | 2005-10-10 A | 2007-06-01 A | 100% | 2005-10-10 | 2007-06-01 | 430d? | finish no earlier than 2007-06-01 | S2 | 3440h | 3440h | IMS-RT | Rel-7 | Maurice | SP-35 | 23.818 | Ericsson | stephen.terrill@ericsson.com |  |  |
| 1771 | 576 | Deleted - Study on Terminating Session handling |  | 255d? | 2006-01-09 A | 2006-12-29 A | 100% | 2006-01-09 | 2006-12-29 | 255d? | finish no earlier than 2006-12-29 | S2 | 2040h | 2040h | CSIterm | Rel-7 | Maurice | SP-32 | 23.819 | Samsung |  |  |  |
| 1772 | 577 | Deleted - Study on Transferring of emergency call data – in-band modem solution (moved to Rel-8) | milestone | 0d? | 2007-06-22 A | 2007-06-22 A | 100% | 2007-06-22 | 2007-06-22 | 0d? | start no earlier than 2007-06-22 | S4 |  |  | eCALLIBMS | Rel-7 | Paolo | SP-38 | 26.967 | Airbiquity | lhong@airbiquity.com |  |  |
| 1773 | 578 | Deleted - Study on IRP usage scenarios |  | 330d? | 2005-09-02 A | 2006-12-07 A | 100% | 2005-09-02 | 2006-12-07 | 330d? | finish no earlier than 2006-12-07 | S5 | 2640h | 2640h | OAM-Study | Rel-7 | Dionisio | SP-32 | 32.8xy | Lucent |  |  |  |
| 1774 | 579 | Deleted - Study on Interference Cancellation for UTRA FDD UE (covered by UID 20053) |  | 1d? | 2007-03-28 A | 2007-03-28 A | 100% | 2007-03-28 | 2007-03-28 | 1d? | start no earlier than 2007-03-28 | R4 | 8h | 8h | RANFS-InterfCanc | Rel-7 | Issam | SP-38 |  |  |  |  |  |
| 1775 | 580 | Deleted - Study on enhanced support of Video Telephony | milestone | 0d? | 2006-06-30 A | 2006-06-30 A | 100% | 2006-06-30 | 2006-06-30 | 0d? | start no earlier than 2006-06-30 | GP |  |  | VIDGER | Rel-7 | Paolo | SP-32 |  | Ericsson | stefan.g.eriksson@ericsson.com |  |  |
| 1776 | 581 | Release 6 Features |  | 915d? | 2002-06-28 A | 2005-12-30 A | 100% | 2002-06-28 | 2005-12-30 | 915d? |  | NP,GP, RP,SP,TP | 7320h | 7320h |  | Rel-6 | All |  |  |  |  |  |  |
| 1777 | 8 | **Rel-6 Improvements of Radio Interface** |  | 1645d? | 2000-08-14 A | 2006-12-01 A | 100% | 2000-08-14 | 2006-12-01 | 1645d? |  | RP | 55624h | 55624h | RInImp | Rel-6 |  |  |  |  |  |  |  |
| 1778 | 582.1 | Improved support of IMS Realtime Services using HSDPA/EDCH |  | 197d? | 2005-03-15 A | 2005-12-14 A | 100% | 2005-03-15 | 2005-12-14 | 197d? | finish no earlier than 2005-12-14 | R2 | 1576h | 1576h | RInImp-IMSRealTime | Rel-6 | Joern |  |  | Cingular | Don Zelmer (dz1069@att.com) |  |  |
| 1779 | 582.2 | Improving Receiver Performance Requirements for the FDD UE |  | 401d | 2002-03-08 A | 2003-09-19 A | 100% | 2002-03-08 | 2003-09-19 | 401d | start no earlier than 2002-03-08 | R4 | 3208h | 3208h | RInImp-UERecPerf | Rel-6 | Issam |  | 25.101 | Intel | shimon.moshavi@INTEL.COM |  |  |
| 1780 | 8.2 | **Base station classification** |  | 603d | 2000-08-14 A | 2002-12-04 A | 100% | 2000-08-14 | 2002-12-04 | 603d |  | R4 | 9648h | 9648h | RInImp-BSClass | Rel-6 | Issam |  |  |  |  |  |  |
| 1781 | 8.2.1 | FDD Base station classification |  | 603d | 2000-08-14 A | 2002-12-04 A | 100% | 2000-08-14 | 2002-12-04 | 603d | finish no earlier than 2002-12-04 | R4 | 4824h | 4824h | RInImp-BSClass-FDD | Rel-6 | Issam |  | 25.104, 25.141 | Nokia | antti.toskala@nokia.com |  |  |
| 1782 | 582.4 | UMTS-850 |  | 266d | 2002-12-06 A | 2003-12-12 A | 100% | 2002-12-06 | 2003-12-12 | 266d | finish no earlier than 2003-12-15 | R4 | 2128h | 2128h | RInImp-UMTS850 | Rel-6 | Issam |  | 25.101, 25.104, 25.133, 25.141, 25.307, 25.331, 25.942 | Cingular | Don Zelmer (dz1069@att.com) |  |  |
| 1783 | 582.5 | DS-CDMA introduction in the 800 MHz band |  | 196d | 2003-03-14 A | 2003-12-12 A | 100% | 2003-03-14 | 2003-12-12 | 196d | finish no earlier than 2003-12-15 | R4 | 1568h | 1568h | RInImp-UMTS800 | Rel-6 | Issam |  | 25.101, 25.104, 25.133, 25.141, 25.307, 25.331 | NTT DoCoMo | Takehiro Nakamura (nakamurata@nttdocomo.co.jp) |  |  |
| 1784 | 582.6 | UMTS 1.7/2.1 GHz | milestone | 0d? | 2003-03-14 A | 2003-03-14 A | 100% | 2003-03-14 | 2003-03-14 | 0d? |  | R4 |  |  | RInImp-UMTS1721 | Rel-6 | Issam |  | 25.101, 25.104, 25.133, 25.141, 25.307, 25.331 | Nokia | jussi.numminen@NOKIA.COM |  |  |
| 1785 | 582.7 | Conformance Test Aspects – UMTS 1.7/2.1 GHz Band |  | 191d? | 2006-03-10 A | 2006-12-01 A | 100% | 2006-03-10 | 2006-12-01 | 191d? | finish no earlier than 2006-12-01 | R5 | 1528h | 1528h | RInImp-UMTS1721_Test | Rel-6 | Ingbert |  | TS34.121, TS34.108 | Motorola | carolyn.taylor@motorola.com |  |  |
| 1786 | 582.8 | **Improved Receiver Performance Requirements for HSDPA** |  | 711d | 2003-09-19 A | 2006-06-09 A | 100% | 2003-09-19 | 2006-06-09 | 711d |  | R4,R5 | 22808h | 22808h | RInImp-HSPerf | Rel-6 | Issam |  |  | Nokia | jussi.numminen@NOKIA.COM |  |  |
| 1787 | 582.8.1 | Improved Minimum Performance Requirements for HSDPA UE categories 7 and 8 |  | 453d | 2004-09-15 A | 2006-06-09 A | 100% | 2004-09-15 | 2006-06-09 | 453d |  | R4 | 3624h | 3624h | RInImp-HSPerf-10code | Rel-6 | Issam |  | 25.101 | Nokia | jussi.numminen@nokia.com |  |  |
| 1788 | 582.8.2 | Testing of Improved Minimum Performance for HSDPA |  | 650d | 2003-09-19 A | 2006-03-16 A | 100% | 2003-09-19 | 2006-03-16 | 650d | finish no earlier than 2006-03-16 | R5 | 5200h | 5200h | RInImp-HSPerf-10Code_Test | Rel-6 | Ingbert |  | 34.108, 34.121, 34.122, 34.123-1, 34.123-2, 34.123-3 | Motorola | carolyn.taylor@motorola.com | TSG | 19/9/2003 |
| 1789 | 582.8.3 | Performance Requirements of Receive Diversity for HSDPA |  | 387d | 2003-12-15 A | 2005-06-07 A | 100% | 2003-12-15 | 2005-06-07 | 387d |  | R4 | 3096h | 3096h | RInImp-HSPerf-RxDiv | Rel-6 | Issam |  | 25.101 | NTT DoCoMo | Takehiro Nakamura (nakamurata@nttdocomo.co.jp) |  |  |
| 1790 | 582.8.4 | Testing of Performance of Receiver diversity for HSDPA |  | 650d | 2003-09-19 A | 2006-03-16 A | 100% | 2003-09-19 | 2006-03-16 | 650d | finish no earlier than 2006-03-16 | R5 | 5200h | 5200h | RInImp-HSPerf-RxDiv_Test | Rel-6 | Ingbert |  | 34.108, 34.121, 34.122, 34.123-1, 34.123-2, 34.123-3 | Motorola | carolyn.taylor@motorola.com | TSG | 19/9/2003 |
| 1791 | 583 | **Rel-6 RAN Feasibility Studies** |  | 1196d? | 2000-08-14 A | 2005-03-14 A | 100% | 2000-08-14 | 2005-03-14 | 1196d? |  | RP | 43048h | 43048h |  | Rel-6 |  |  |  |  |  |  |  |
| 1792 | 583.1 | FS of the improved access to UE measurement data for CRNC to support TDD RRM |  | 270d? | 2002-12-06 A | 2003-12-18 A | 100% | 2002-12-06 | 2003-12-18 | 270d? | finish no earlier than 2003-09-19 | R3 | 2160h | 2160h | RANimp-RRMopt-FSUEMsD | Rel-6 | Juha |  | 25.801, 25.423 | Interdigital | jim.miller@interdigital.com |  | SP-24 |
| 1793 | 583.2 | FS on Radio link performance enhancements |  | 1067d | 2000-08-14 A | 2004-09-14 A | 100% | 2000-08-14 | 2004-09-14 | 1067d | finish no earlier than 2004-09-14 | R1 | 8536h | 8536h | RInImp-Rlperf | Rel-6 | Patrick |  | 25.899 | Nokia | antti.toskala@nokia.com |  |  |
| 1794 | 583.3 | FS on Improvement of inter-frequency and inter-system measurements for 1.28 Mcps TDD |  | 461d | 2001-12-14 A | 2003-09-19 A | 100% | 2001-12-14 | 2003-09-19 | 461d | start no earlier than 2001-12-14 | R1 | 3688h | 3688h | RInImp-IfIsMLCR | Rel-6 | Patrick |  | 25.888 | Samsung | Li Xiao Qiang (xqli@samsung.co.kr) |  |  |
| 1795 | 583.4 | FS for the analysis of OFDM for UTRAN enhancement |  | 526d | 2002-06-10 A | 2004-06-14 A | 100% | 2002-06-10 | 2004-06-14 | 526d | start no earlier than 2002-06-10 | R1 | 4208h | 4208h | RInImp-FSOFDM | Rel-6 | Patrick |  | 25.892 | Nortel | Sarah Boumendil |  |  |
| 1796 | 583.5 | FS on Uplink Enhancements for Dedicated Transport Channels |  | 396d | 2002-09-06 A | 2004-03-12 A | 100% | 2002-09-06 | 2004-03-12 | 396d | finish no earlier than 2004-03-12 | R1 | 3168h | 3168h | RInImp-FSUpDTrCh | Rel-6 | Patrick |  | 25.896 | Nokia | Karri.Ranta-aho@nsn.com |  |  |
| 1797 | 583.6 | FS on Analysis on Higher Chip Rates for UTRA TDD evolutions |  | 528d | 2002-09-06 A | 2004-09-14 A | 100% | 2002-09-06 | 2004-09-14 | 528d | finish no earlier than 2004-09-14 | R1 | 4224h | 4224h | RInImp-FSVHCRTDD | Rel-6 | Patrick |  | 25.895 | IPWireless | mbeale@ipwireless.com |  |  |
| 1798 | 583.7 | FS on Low Output Powers for general purpose FDD BSs |  | 128d | 2003-06-13 A | 2004-03-12 A | 100% | 2003-06-13 | 2004-03-12 | 128d | finish no earlier than 2004-03-12 | R3 | 1024h | 1024h | RInImp-FSLoPw | Rel-6 | Juha |  | 25.807 | Telefónica | Ana Burgos (burgos_a@tsm.es) |  |  |
| 1799 | 583.8 | FS on Uplink enhancements for UTRA TDD |  | 462d | 2003-06-06 A | 2005-03-14 A | 100% | 2003-06-06 | 2005-03-14 | 462d | finish no earlier than 2005-03-14 | R1 | 3696h | 3696h | RInImp-FSUpEnhTDD | Rel-6 | Patrick |  | 25.804 | Interdigital | Marian.Rudolf@InterDigital.com |  |  |
| 1800 | 8.8 | FS on UE antenna efficiency test methods performance requirements (2) |  | 131d | 2002-03-08 A | 2002-09-06 A | 100% | 2002-03-08 | 2002-09-06 | 131d | finish no earlier than 2002-09-06 | R4 | 1048h | 1048h | RInImp-UEAnTM2 | Rel-6 | Issam |  |  | Allgon | Alf Ahlström (alf.ahlstrom@pwav.com) |  |  |
| 1801 | 9.4 | Deleted - FS on the evolution of the UTRAN architecture |  | 592d | 2002-09-09 A | 2004-12-14 A | 100% | 2002-09-09 | 2004-12-14 | 592d | finish no earlier than 2004-12-15 | R3 | 4736h | 4736h | RANimp-FSEvo | Rel-6 | Juha | RP-26 |  | Nokia | woonhee.hwang@nsn.com, Antti.Toskala@nokia.com |  |  |

Notes:
- 1768: Created by MCC to group all VoIMS related items, after consultation of chairs
- 1769: WID approved SP#28. SA2#52 stopped
- 1770: abandoned at 65%
- 1771: SP#32 Jun 2006 Study abandoned => spin-off Implementation work UID_320029
- 1772: SP-38 stopped
- 1773: -
- 1774: Deleted. Same as FS on Further Improved Performance Requirements for UMTS/HSDPA UE (FDD)
- 1775: FS CLOSED at G#28 (no input)
- 1776: -
- 1777: -
- 1778: -
- 1779: -
- 1780: -
- 1781: -
- 1782: Introduction of UMTS850 (Band V) in 25.307
- 1783: Introduction of UMTS800 in 25.307
- 1784: Introduction of UMTS1700/2100 (Band IV)
- 1785: -
- 1786: -
- 1787: Approved at RP#25 as RP-040375
- 1788: -
- 1789: -
- 1790: -
- 1791: -
- 1792: -
- 1793: Study finished at RP#25
- 1794: -
- 1795: -
- 1796: -
- 1797: Study finished at RP#25
- 1798: -
- 1799: -
- 1800: The RInImp-UEAnTM FS was re-opened at TSG RP#15 upon request from WG4
- 1801: Study Closed, work will continue within the FS on evolved UTRA and UTRAN

| ID | WBS | Task | Type | Duration | Start | Finish | Complete | Baseline start | Baseline finish | Baseline duration | Constraint | Deadline | Resources | Work | Actual work | Text1 | Text4 | Text5 | Text6 | Text3 | Text8 | Text7 | Text9 | Text10 | Text12 |
| --- | --- | --- | --- | --- | --- | --- | --- | --- | --- | --- | --- | --- | --- | --- | --- | --- | --- | --- | --- | --- | --- | --- | --- | --- | --- |
| 1802 | 584 | **FDD Enhanced Uplink** |  | 915d | 2004-03-15 A | 2007-09-14 A | 100% | 2004-03-15 | 2007-09-14 | 915d |  |  | RP | 23664h | 23664h | EDCH | Ericsson | Joakim Bergström | Rel-6 |  |  |  |  |  |  |
| 1803 | 584.1 | FDD Enhanced Uplink - Stage 2 |  | 197d | 2004-03-15 A | 2004-12-14 A | 100% | 2004-03-15 | 2004-12-14 | 197d | finish no earlier than 2004-12-14 |  | R2 | 1576h | 1576h | EDCH-Stage2 |  |  | Rel-6 | 25.309 | Joern |  |  |  |  |
| 1804 | 584.2 | FDD Enhanced Uplink - Physical Layer |  | 261d | 2004-03-15 A | 2005-03-14 A | 100% | 2004-03-15 | 2005-03-14 | 261d | finish no earlier than 2005-03-14 |  | R1 | 2088h | 2088h | EDCH-Phys | Nokia | Karri.Ranta-aho@nsn.com | Rel-6 | 25.211, 25.212, 25.213, 25.214, 25.215 | Patrick |  |  |  |  |
| 1805 | 584.3 | FDD Enhanced Uplink - Layer 2 and 3 Protocol Aspects |  | 261d | 2004-03-15 A | 2005-03-14 A | 100% | 2004-03-15 | 2005-03-14 | 261d | finish no earlier than 2005-03-14 |  | R2 | 2088h | 2088h | EDCH-L23 | Ericsson | Joakim Bergström | Rel-6 | 25.301, 25.302, 25.306, 25.321, 25.331 | Joern |  |  |  |  |
| 1806 | 584.4 | FDD Enhanced Uplink - UTRAN Iub/Iur Protocol Aspects |  | 261d | 2004-03-15 A | 2005-03-14 A | 100% | 2004-03-15 | 2005-03-14 | 261d | finish no earlier than 2005-03-14 |  | R3 | 2088h | 2088h | EDCH-IurIub | Nortel | Saso Stojanovski | Rel-6 | 25.401, 25.420, 25.423, 25.430, 25.433 | Juha |  |  |  |  |
| 1807 | 584.5 | FDD Enhanced Uplink - RF Radio Transmission/ Reception, System Performance Requirements and Conformance Testing |  | 74d | 2004-03-15 A | 2004-06-24 A | 100% | 2004-03-15 | 2004-06-24 | 74d |  |  | R4 | 592h | 592h | EDCH-RF | Ericsson | thomas.unshelm@ERICSSON.COM | Rel-6 | 25.101, 25.104, 25.133, 25.141 | Issam |  |  |  |  |
| 1808 | 584.6 | Conformance Test Aspects – FDD Enhanced Uplink |  | 596d | 2005-06-03 A | 2007-09-14 A | 100% | 2005-06-03 | 2007-09-14 | 596d | finish no earlier than 2007-09-14 | 2006-06-02 | R5 | 4768h | 4768h | EDCH_Test | Ericsson | Leif.Mattisson@ericsson.com | Rel-6 | 34.108, 34.109, 34.121, 34.123-1, 34.123-2, 34.123-3 | Ingbert | TSG | BB | Fri 03/06/05 |  |
| 1809 | 584.7 | FDD Enhanced Uplink - RF Radio Transmission/ Reception, System Performance Requirements and Conformance Testing |  | 393d | 2004-03-15 A | 2005-09-14 A | 100% | 2004-03-15 | 2005-09-14 | 393d | finish no earlier than 2005-09-15 |  | R4 | 3144h | 3144h | EDCH-RF | Ericsson | thomas.unshelm@ERICSSON.COM | Rel-6 | 25.101, 25.104, 25.133, 25.141 | Issam |  |  |  |  |
| 1810 | 585 | **Rel-6 RAN improvements** |  | 656d? | 2002-09-09 A | 2005-03-14 A | 100% | 2002-09-09 | 2005-03-14 | 656d? |  |  | RP,S5 | 19904h | 19904h | RANimp |  |  | Rel-6 |  |  |  |  |  |  |
| 1811 | 9.2 | **RAB support enhancement** |  | 522d? | 2003-03-14 A | 2005-03-14 A | 100% | 2003-03-14 | 2005-03-14 | 522d? |  |  | R2 | 9360h | 9360h | RANimp-RABSE | Nokia | Jussi Kähtävä (juha.mikola@nokia.com) | Rel-6 | 25.862 | Joern |  |  |  |  |
| 1812 | 585.1.1 | Optimization of downlink channelisation code utilisation |  | 262d | 2004-03-12 A | 2005-03-14 A | 100% | 2004-03-12 | 2005-03-14 | 262d | finish no earlier than 2005-03-14 |  | R1 | 2096h | 2096h | RANimp-RABSE-CodeOptFDD | Nortel | Sarah Boumendil | Rel-6 |  | Patrick |  |  |  |  |
| 1813 | 585.1.2 | optimization of channelisation code utilisation for 3.84 Mcps TDD |  | 261d | 2004-03-15 A | 2005-03-14 A | 100% | 2004-03-15 | 2005-03-14 | 261d | finish no earlier than 2005-03-15 |  | R1 | 2088h | 2088h | RANimp-RABSE-CodOptTDD | IPWireless | Nicholas Anderson | Rel-6 |  | Patrick |  |  |  |  |
| 1814 | 585.1.3 | HS-DPCCH ACK/NACK Enhancement |  | 65d? | 2004-09-15 A | 2004-12-14 A | 100% | 2004-09-15 | 2004-12-14 | 65d? | finish no earlier than 2004-12-15 |  | R1 | 520h | 520h | RANimp-RABSE-ACKNACK | Nokia | Jussi Kähtävä (juha.mikola@nokia.com) | Rel-6 | 25.212, 25.214, 24.331, 25.433 | Patrick |  |  |  |  |
| 1815 | 585.1.4 | Deleted - Iu enhancements for IMS support in RAN |  | 320d? | 2003-03-14 A | 2004-06-03 A | 100% | 2003-03-14 | 2004-06-03 | 320d? | start no earlier than 2003-03-14 |  | R3 | 2560h | 2560h | RANimp-RABSE-IuEnhIMS | Nortel | Philippe.Godin@nortelnetworks.com | Rel-6 |  | Juha |  |  |  | RP-24 |
| 1816 | 585.1.5 | Deleted - Improvement of RRM across RNS and RNS/BSS | milestone | 0d? | 2003-12-05 A | 2003-12-05 A | 100% | 2003-12-05 | 2003-12-05 | 0d? | finish no earlier than 2003-12-05 |  | R3 |  |  | RANimp-RRM1 | Nokia | antti.toskala@nokia.com | Rel-6 |  | Juha |  |  |  | RP-23 |
| 1817 | 9.1 | Beamforming Enhancements |  | 66d | 2003-09-19 A | 2003-12-19 A | 100% | 2003-09-19 | 2003-12-19 | 66d | finish no earlier than 2004-03-12 |  | R1 | 528h | 528h | RANimp-BFE | Nokia | Jussi Kähtävä (juha.mikola@nokia.com) | Rel-6 | 24.215, 25.423, 25.425, 25.433, 25.435 | Patrick |  |  |  |  |
| 1818 | 585.3 | **Rel6 RRM optimization for Iur and Iub** |  | 126d | 2003-09-19 A | 2004-03-12 A | 100% | 2003-09-19 | 2004-03-12 | 126d |  |  | R3 | 2016h | 2016h | RANimp-RRMopt | Ericsson | Gert-Jan.van.Lieshout@eln.ericsson.se | Rel-6 |  | Juha |  |  |  |  |
| 1819 | 585.3.1 | Improved access to UE measurement data for CRNC to support TDD RRM |  | 126d | 2003-09-19 A | 2004-03-12 A | 100% | 2003-09-19 | 2004-03-12 | 126d | finish no earlier than 2004-03-15 |  | R3 | 1008h | 1008h | RANimp-RRMopt-UEMsD | Interdigital | jim.miller@interdigital.com | Rel-6 | 25.423 | Juha |  |  |  | RP-22 |
| 1820 | 585.4 | **Remote Control of Electrical Tilting Antennas** |  | 395d? | 2003-03-14 A | 2004-09-16 A | 100% | 2003-03-14 | 2004-09-16 | 395d? |  |  | R3,S5 | 4304h | 4304h | RANimp-TiltAnt | Vodafone | Andreas.Hauser@vodafone.com | Rel-6 |  | Juha |  |  |  |  |
| 1821 | 585.4.1 | Tilting Antenna - RAN aspects |  | 393d? | 2003-03-14 A | 2004-09-14 A | 100% | 2003-03-14 | 2004-09-14 | 393d? | finish no earlier than 2004-09-14 |  | R3 | 3144h | 3144h | RANimp-TiltAnt | Vodafone | Andreas.Hauser@vodafone.com | Rel-6 | 25.460, 25.461, 25.462, 25.463 | Juha |  |  |  |  |
| 1822 | 585.4.2 | OAM&P impacts |  | 145d | 2004-02-27 A | 2004-09-16 A | 100% | 2004-02-27 | 2004-09-16 | 145d | finish no earlier than 2004-09-16 |  | S5 | 1160h | 1160h | RANimp-TiltAnt-OAM | Vodafone | Adrian.Neal@vodafone.com | Rel-6 | 32.804, 32.64x | Dionisio |  |  | SP-24 |  |
| 1823 | 585.5 | Network Assisted Cell Change (NACC) from UTRAN to GERAN - network-side aspects |  | 462d? | 2002-09-09 A | 2004-06-15 A | 100% | 2002-09-09 | 2004-06-15 | 462d? | finish no earlier than 2004-06-15 |  | R3 | 3696h | 3696h | RANimp-NACC | Vodafone | Brendan.McWilliams@gb.vodafone.co.uk | Rel-6 |  | Juha |  |  |  |  |
| 1824 | 12 | **Location Services enhancements 2** |  | 1024d? | 2001-01-15 A | 2004-12-16 A | 100% | 2001-01-15 | 2004-12-16 | 1024d? |  |  | S2,S5,N4,RP | 78152h | 78152h | LCS2 |  |  | Rel-6 | 23.271 | Maurice |  |  |  |  |
| 1825 | 12.1 | **Improvement on Le interface** |  | 653d? | 2002-06-17 A | 2004-12-15 A | 100% | 2002-06-17 | 2004-12-15 | 653d? |  |  | S2 | 9872h | 9872h | LCS2 |  |  | Rel-6 |  | Maurice |  |  |  |  |
| 1826 | 586.1.1 | Stage 2 |  | 331d? | 2002-06-17 A | 2003-09-22 A | 100% | 2002-06-17 | 2003-09-22 | 331d? | start no earlier than 2002-06-17 |  | S2 | 2648h | 2648h | LCS2 |  |  | Rel-6 |  | Maurice |  |  |  |  |
| 1827 | 586.1.2 | Stage 3 - impacts MLP (Mobile Location Protocol) |  | 250d? | 2004-01-01 A | 2004-12-15 A | 100% | 2004-01-01 | 2004-12-15 | 250d? | finish no earlier than 2004-12-15 |  | OMA | 2000h | 2000h | LCS2 |  | OMA-LIAISON@mail.openmobilealliance.org | Rel-6 |  |  |  |  |  |  |

Notes:
- 1802: -
- 1803: -
- 1804: -
- 1805: -
- 1806: -
- 1807: -
- 1808: -
- 1809: -
- 1810: Generic feature
- 1811: building block without particular end date
- 1812: -
- 1813: WIDS modified in RP#26, RP-040551
- 1814: Approved at RP#25 as RP-040390
- 1815: Closed RP#24 due to the lack of progress
- 1816: abandoned RP-23
- 1817: -
- 1818: -
- 1819: -
- 1820: -
- 1821: Finished at RP#25
- 1822: SP#25 09/2004 completed
- 1823: -
- 1824: -
- 1825: -
- 1826: -
- 1827: Updated according to SP-040232

| ID | WBS | Task | Type | Duration | Start | Finish | Complete | Baseline start | Baseline finish | Baseline duration | Constraint | Resources | Work | Actual work | Text1 | Text6 | Text8 | Text5 | Text4 | Text12 |
| --- | --- | --- | --- | --- | --- | --- | --- | --- | --- | --- | --- | --- | --- | --- | --- | --- | --- | --- | --- | --- |
| 1828 | 12.2 | **Enhanced support for anonymity and user privacy** |  | 638d? | 2002-07-08 A | 2004-12-15 A | 100% | 2002-07-08 | 2004-12-15 | 638d? |  | S2 | 9144h | 9144h | LCS2 | Rel-6 | Maurice |  |  |  |
| 1829 | 586.2.1 | Stage 2 |  | 255d? | 2002-07-08 A | 2003-06-27 A | 100% | 2002-07-08 | 2003-06-27 | 255d? | finish no earlier than 2003-06-27 | S2 | 2040h | 2040h | LCS2 | Rel-6 | Maurice |  |  |  |
| 1830 | 586.2.2 | Stage 3 - impacts MLP and RLP |  | 250d? | 2004-01-01 A | 2004-12-15 A | 100% | 2004-01-01 | 2004-12-15 | 250d? | finish no earlier than 2004-12-15 | OMA | 2000h | 2000h | LCS2 | Rel-6 |  | OMA-LIAISON@mail.openmobilealliance.org |  |  |
| 1831 | 12.3 | **Enhanced inter-GMLC interface** |  | 648d? | 2002-06-24 A | 2004-12-15 A | 100% | 2002-06-24 | 2004-12-15 | 648d? |  | S2 | 9704h | 9704h | LCS2 | Rel-6 | Maurice |  |  |  |
| 1832 | 586.3.1 | Stage 2 |  | 315d? | 2002-06-24 A | 2003-09-05 A | 100% | 2002-06-24 | 2003-09-05 | 315d? | finish no earlier than 2003-09-05 | S2 | 2520h | 2520h | LCS2 | Rel-6 | Maurice |  |  |  |
| 1833 | 586.3.2 | Stage 3 - definition of RLP and PCP |  | 250d? | 2004-01-01 A | 2004-12-15 A | 100% | 2004-01-01 | 2004-12-15 | 250d? | finish no earlier than 2004-12-15 | OMA | 2000h | 2000h | LCS2 | Rel-6 |  | OMA-LIAISON@mail.openmobilealliance.org |  |  |
| 1834 | 12.4 | **Location Services support for IMS public identities** |  | 473d? | 2003-02-24 A | 2004-12-15 A | 100% | 2003-02-24 | 2004-12-15 | 473d? |  | S2 | 7704h | 7704h | LCS2 | Rel-6 | Maurice |  |  |  |
| 1835 | 586.4.1 | Stage 2 |  | 240d? | 2003-02-24 A | 2004-01-23 A | 100% | 2003-02-24 | 2004-01-23 | 240d? | finish no earlier than 2004-01-23 | S2 | 1920h | 1920h | LCS2 | Rel-6 | Maurice |  |  |  |
| 1836 | 586.4.2 | Stage 3 - impacts MLP, RLP and PCP |  | 250d? | 2004-01-01 A | 2004-12-15 A | 100% | 2004-01-01 | 2004-12-15 | 250d? | finish no earlier than 2004-12-15 | OMA | 2000h | 2000h | LCS2 | Rel-6 |  | OMA-LIAISON@mail.openmobilealliance.org |  |  |
| 1837 | 12.5 | **New area event for location service triggering reports** |  | 663d? | 2002-06-03 A | 2004-12-15 A | 100% | 2002-06-03 | 2004-12-15 | 663d? |  | S2 | 11416h | 11416h | LCS2 | Rel-6 | Maurice |  |  |  |
| 1838 | 586.5.1 | Stage 2 |  | 280d? | 2002-06-03 A | 2003-06-27 A | 100% | 2002-06-03 | 2003-06-27 | 280d? | finish no earlier than 2003-06-27 | S2 | 2240h | 2240h | LCS2 | Rel-6 | Maurice |  |  |  |
| 1839 | 586.5.2 | Stage 3 for UE-CN signalling |  | 234d? | 2003-10-09 A | 2004-08-31 A | 100% | 2003-10-09 | 2004-08-31 | 234d? | start no earlier than 2003-10-09 | N4 | 1872h | 1872h | LCS2 | Rel-6 | Kimmo |  |  |  |
| 1840 | 586.5.3 | Stage 3 - impacts MLP, RLP and PCP |  | 250d? | 2004-01-01 A | 2004-12-15 A | 100% | 2004-01-01 | 2004-12-15 | 250d? | finish no earlier than 2004-12-15 | OMA | 2000h | 2000h | LCS2 | Rel-6 |  | OMA-LIAISON@mail.openmobilealliance.org |  |  |
| 1841 | 12.7 | **UE positioning** |  | 957d? | 2001-01-15 A | 2004-09-14 A | 100% | 2001-01-15 | 2004-09-14 | 957d? |  | RP | 18480h | 18480h | LCS2-UEpos | Rel-6 | Issam |  |  |  |
| 1842 | 12.8 | Open SMLC-SRNC Interface within the UTRAN to support UTRAN Rel4 positioning methods |  | 700d? | 2001-01-15 A | 2003-09-19 A | 100% | 2001-01-15 | 2003-09-19 | 700d? | finish no earlier than 2003-09-19 | R2 | 5600h | 5600h | LCS-Rel4Pos | Rel-6 | Joern | Meik.Kottkamp@siemens.com | Siemens |  |
| 1843 | 586.6.2 | A-GPS minimum performance specification |  | 333d? | 2003-06-06 A | 2004-09-14 A | 100% | 2003-06-06 | 2004-09-14 | 333d? | finish no earlier than 2004-09-14 | R4 | 2664h | 2664h | LCS-UEPos-AGPSPerf | Rel-6 | Issam | donglin.shen@attws.com | AT&T Wireless |  |
| 1844 | 12.7.2 | FS on Enhancements to OTDOA Positioning using advanced blanking methods |  | 320d | 2002-07-01 A | 2003-09-19 A | 100% | 2002-07-01 | 2003-09-19 | 320d | finish no earlier than 2003-09-19 | R2 | 2560h | 2560h | LCS2-UEpos-FSBlank | Rel-6 | Joern | david.bartlett@cursor-system.com | Cambridge Positioning Systems |  |
| 1845 | 586.6.4 | Deleted - UE positioning enhancements - other methods | milestone | 0d? | 2003-09-26 A | 2003-09-26 A | 100% | 2003-09-26 | 2003-09-26 | 0d? | finish no earlier than 2003-09-26 | R2 |  |  | LCS2-UEpos-enh | Rel-6 | Joern | Meik.Kottkamp@siemens.com | Siemens | RP-24 |
| 1846 | 586.7 | LCS charging |  | 455d? | 2003-03-21 A | 2004-12-16 A | 100% | 2003-03-21 | 2004-12-16 | 455d? | start no earlier than 2003-03-21 | S5 | 3640h | 3640h | LCS2-CH | Rel-6 | Dionisio | alain.bibas@orange-ft.com | France Telecom |  |
| 1847 | 14 | **Rel-6 Security enhancements** |  | 1018d? | 2001-01-03 A | 2004-11-26 A | 100% | 2001-01-03 | 2004-11-26 | 1018d? |  | S3 | 28824h | 28824h | SEC1 | Rel-6 | Dionisio | Peter.Howard@vodafone.com | Vodafone |  |
| 1848 | 14.1 | **Enhanced HE control of security (including positive authentication reporting)** |  | 712d | 2001-01-03 A | 2003-09-25 A | 100% | 2001-01-03 | 2003-09-25 | 712d |  | S3 | 14064h | 14064h | SEC1 | Rel-6 | Dionisio | Peter.Howard@vodafone.com | Vodafone |  |
| 1849 | 14.1.1 | Deleted - SEC1 Stage 2 (Enhanced HE control of security) |  | 378d | 2001-01-03 A | 2002-06-14 A | 100% | 2001-01-03 | 2002-06-14 | 378d | finish no earlier than 2002-06-14 | S3 | 3024h | 3024h | SEC1 | Rel-6 | Dionisio |  |  | SP-16 |
| 1850 | 14.1.3 | **Network domain security** |  | 334d | 2002-06-17 A | 2003-09-25 A | 100% | 2002-06-17 | 2003-09-25 | 334d |  | S3 | 5344h | 5344h | SEC1-NDS | Rel-6 | Dionisio | Geir-myrdahl.koien@telenor.com | Telenor |  |
| 1851 | 14.1.3.1 | IP network layer security (NDS/IP) |  | 334d | 2002-06-17 A | 2003-09-25 A | 100% | 2002-06-17 | 2003-09-25 | 334d | finish no earlier than 2003-09-25 | S3 | 2672h | 2672h | SEC1-NDS-IP | Rel-6 | Dionisio |  |  |  |
| 1852 | 587.2 | Network Domain Security; Authentication Framework (NDS/AF) |  | 521d? | 2002-02-15 A | 2004-02-13 A | 100% | 2002-02-15 | 2004-02-13 | 521d? | finish no earlier than 2004-02-13 | S3 | 4168h | 4168h | SEC1-NDS-AF | Rel-6 | Dionisio | tommi.viitanen@nokia.com | Nokia |  |
| 1853 | 587.3 | Key Management of group keys for Voice Group Call Services |  | 306d | 2003-09-26 A | 2004-11-26 A | 100% | 2003-09-26 | 2004-11-26 | 306d | finish no earlier than 2004-11-26 | S3 | 2448h | 2448h | SECGKYV | Rel-6 | Dionisio | benno.tietz@vodafone.com | Vodafone |  |

Notes:
- 1828: -
- 1829: -
- 1830: Updated according to SP-040232
- 1831: -
- 1832: -
- 1833: Updated according to SP-040232
- 1834: -
- 1835: -
- 1836: Updated according to SP-040232
- 1837: -
- 1838: -
- 1839: 31/10/2003 work has started. Current stage 3 fullfills the requirements of stage 2. ......
- 1840: Updated according to SP-040232
- 1841: -
- 1842: - / Text3: 25.305, 25.401, 25.450, 25.452, 25.453
- 1843: Finished at RP#25 / Text3: 25.171
- 1844: -
- 1845: building block without particular end date
- 1846: SP#26 12/2004 completed / Text3: 32.271
- 1847: Added BB UE authentication and rapporteur added.
- 1848: Added by SP-000575 without any dates. 18/10/00: Change of WI title, added hyperlink rapporteur new end date 03/01. New end date and correct Release to be decided S3#18
- 1849: New end date and correct Release to be decided S3#18. Marked as stopped 12/2008
- 1850: WID approved for Rel-6 at SP#17. Completed 2004-12
- 1851: Should be complete after SA3#27. Completed 2004-12 / Text3: 33.210
- 1852: WID approved SP#19. Work started after FS approved SP#18
- 1853: Approved TSG#21. Completed 2004-12 / Text3: 42.068, 43.068, 44.068, 42.069, 43.069, 44.069, 31.102, 24.008, 48.008, 42.009, 43.020

| ID | WBS | Task | Type | Duration | Start | Finish | Complete | Baseline start | Baseline finish | Baseline duration | Constraint | Resources | Work | Actual work | Text1 | Text3 | Text6 | Text8 | Text4 | Text5 | Text12 |
| --- | --- | --- | --- | --- | --- | --- | --- | --- | --- | --- | --- | --- | --- | --- | --- | --- | --- | --- | --- | --- | --- |
| 1854 | 16 | **IMS Phase 2** |  | 1840d? | 2000-08-28 A | 2007-09-14 A | 100% | 2000-08-28 | 2007-09-14 | 1840d? |  | S1,S2,S3,S5,NP,R5 | 136976h | 136976h | IMS2 | 23.228 | Rel-6 | Alain |  |  |  |
| 1855 | 588.1 | Enhancements to the Cx and Sh interfaces |  | 323d? | 2003-06-06 A | 2004-08-31 A | 100% | 2003-06-06 | 2004-08-31 | 323d? | finish no earlier than 2004-08-31 | N4 | 2584h | 2584h | IMS2-CCR |  | Rel-6 | Kimmo |  |  |  |
| 1856 | 588.2 | Conformance Test Aspects – IMS Call Control Rel-6 enhancements |  | 396d? | 2006-03-10 A | 2007-09-14 A | 100% | 2006-03-10 | 2007-09-14 | 396d? | finish no earlier than 2007-09-14 | R5 | 3168h | 3168h | IMS2_CCR_Test | 34.229-1, 34.229-2, 34.229-3, 34.108 | Rel-6 | Ingbert | Ericsson | Jacob.John@motorola.com, Leif.Mattisson@ericsson.com |  |
| 1857 | 16.12 | **IMS Group Management** |  | 715d? | 2002-03-14 A | 2004-12-08 A | 100% | 2002-03-14 | 2004-12-08 | 715d? |  | S1 | 12680h | 12680h | IMSGM |  | Rel-6 | Alain | Nokia | juha.kalliokulju@nokia.com |  |
| 1858 | 16.12.1 | Stage 1 - TS on IMS group management |  | 193d | 2002-03-14 A | 2002-12-09 A | 100% | 2002-03-14 | 2002-12-09 | 193d | finish no earlier than 2002-12-09 | S1 | 1544h | 1544h | IMSGM |  | Rel-6 | Alain | Nokia | juha.kalliokulju@nokia.com |  |
| 1859 | 588.3.2 | Stage 2 |  | 158d? | 2003-05-26 A | 2003-12-31 A | 100% | 2003-05-26 | 2003-12-31 | 158d? | finish no earlier than 2003-12-31 | S2 | 1264h | 1264h | IMSGM |  | Rel-6 | Maurice |  |  |  |
| 1860 | 588.3.3 | Stage 3 for IMS Group management (e.g. chat) |  | 519d? | 2002-12-13 A | 2004-12-08 A | 100% | 2002-12-13 | 2004-12-08 | 519d? | finish no earlier than 2004-12-08 | N1 | 4152h | 4152h | IMSGM |  | Rel-6 | Frederic | Lucent | Keith Drage (drage@alcatel-lucent.com) |  |
| 1861 | 588.4 | **IMS Conferencing** |  | 548d? | 2002-11-04 A | 2004-12-08 A | 100% | 2002-11-04 | 2004-12-08 | 548d? |  | N1 | 10960h | 10960h |  |  | Rel-6 | Frederic |  |  |  |
| 1862 | 588.4.1 | Stage 2 |  | 303d? | 2002-11-04 A | 2003-12-31 A | 100% | 2002-11-04 | 2003-12-31 | 303d? | finish no earlier than 2003-12-31 | S2 | 2424h | 2424h |  |  | Rel-6 | Maurice |  |  |  |
| 1863 | 588.4.2 | Stage 3 |  | 519d? | 2002-12-13 A | 2004-12-08 A | 100% | 2002-12-13 | 2004-12-08 | 519d? | finish no earlier than 2004-12-08 | N1 | 4152h | 4152h |  |  | Rel-6 | Frederic | Lucent | Keith Drage (drage@alcatel-lucent.com) |  |
| 1864 | 16.11 | **IMS Messaging** |  | 992d? | 2002-03-14 A | 2005-12-30 A | 100% | 2002-03-14 | 2005-12-30 | 992d? |  | S1 | 23912h | 23912h | IMSM |  | Rel-6 | Alain | Nokia | juha.kalliokulju@nokia.com |  |
| 1865 | 16.11.1 | TR on support of messaging in the IMS |  | 193d | 2002-03-14 A | 2002-12-09 A | 100% | 2002-03-14 | 2002-12-09 | 193d | finish no earlier than 2002-12-09 | S1 | 1544h | 1544h | IMSM-TR | new 22.940 | Rel-6 | Alain | Nokia | juha.kalliokulju@nokia.com |  |
| 1866 | 588.5.2 | Stage 1 22.340 |  | 23d? | 2002-11-11 A | 2002-12-11 A | 100% | 2002-11-11 | 2002-12-11 | 23d? | finish no earlier than 2002-12-11 | S1 | 184h | 184h | IMSM-TS | 22.340 | Rel-6 | Alain | Nokia | juha.kalliokulju@nokia.com |  |
| 1867 | 588.5.3 | CRs to 22.140 & 22.228 |  | 263d? | 2002-03-14 A | 2003-03-17 A | 100% | 2002-03-14 | 2003-03-17 | 263d? | finish no earlier than 2003-03-17 | S1 | 2104h | 2104h | IMSM-CR | 22.140,22.228 | Rel-6 | Alain | Nokia | juha.kalliokulju@nokia.com |  |
| 1868 | 16.11.3 | Stage 2 |  | 477d | 2002-11-04 A | 2004-08-31 A | 100% | 2002-11-04 | 2004-08-31 | 477d | finish no earlier than 2004-08-31 | S2 | 3816h | 3816h | IMSM |  | Rel-6 | Maurice |  |  |  |
| 1869 | 588.5.5 | Stage 3 for IMS Messaging |  | 519d? | 2002-12-13 A | 2004-12-08 A | 100% | 2002-12-13 | 2004-12-08 | 519d? | finish no earlier than 2004-12-08 | N1 | 4152h | 4152h | IMSM |  | Rel-6 | Frederic | Lucent | Keith Drage (drage@alcatel-lucent.com) |  |
| 1870 | 588.5.6 | SIP/SIMPLE Instant messaging |  | 522d? | 2004-01-01 A | 2005-12-30 A | 100% | 2004-01-01 | 2005-12-30 | 522d? | finish no earlier than 2005-06-30 | OMA | 4176h | 4176h |  |  | Rel-6 |  |  | OMA-LIAISON@mail.openmobilealliance.org |  |
| 1871 | 588.6 | **Additional SIP Capabilities support not covered by Rel-5** |  | 680d? | 2002-11-11 A | 2005-06-17 A | 100% | 2002-11-11 | 2005-06-17 | 680d? |  | N1 | 13392h | 13392h |  |  | Rel-6 | Frederic |  |  |  |
| 1872 | 588.6.1 | Stage 2 for add SIP cap (e.g. forking) |  | 335d? | 2002-11-11 A | 2004-02-20 A | 100% | 2002-11-11 | 2004-02-20 | 335d? | finish no earlier than 2004-02-20 | S2 | 2680h | 2680h |  |  | Rel-6 | Maurice |  |  |  |
| 1873 | 588.6.2 | Stage 3 for Additional SIP Capabilities |  | 454d? | 2002-12-13 A | 2004-09-08 A | 100% | 2002-12-13 | 2004-09-08 | 454d? | finish no earlier than 2004-09-08 | N1 | 3632h | 3632h |  |  | Rel-6 | Frederic | Lucent | Keith Drage (drage@alcatel-lucent.com) |  |
| 1874 | 588.6.3 | Procedured associated with IMS-ALG |  | 205d? | 2004-09-06 A | 2005-06-17 A | 100% | 2004-09-06 | 2005-06-17 | 205d? | start no earlier than 2004-09-06 | N1 | 1640h | 1640h |  |  | Rel-6 | Frederic |  |  |  |
| 1875 | 588.7 | Review additional SIP Capabilities against IMS |  | 454d? | 2002-12-13 A | 2004-09-08 A | 100% | 2002-12-13 | 2004-09-08 | 454d? | finish no earlier than 2004-09-08 | N1 | 3632h | 3632h |  |  | Rel-6 | Frederic | Lucent | Keith Drage (drage@alcatel-lucent.com) |  |
| 1876 | 16.5 | **Interworking between IMS and IP networks** |  | 1118d? | 2000-08-28 A | 2004-12-08 A | 100% | 2000-08-28 | 2004-12-08 | 1118d? |  | N3 | 31712h | 31712h | IMS-CCR-IWIP | 23.821, 29.061, 29.162 | Rel-6 | Gwiho | BT | nigel.holland@bt.com |  |
| 1877 | 16.5.1 | Interworking for 3GPP_SIP and IETF_SIP |  | 730d | 2000-08-28 A | 2003-06-13 A | 100% | 2000-08-28 | 2003-06-13 | 730d | finish no earlier than 2003-06-13 | N3 | 5840h | 5840h |  | New 29.962 | Rel-6 | Gwiho | Siemens | Thomas.Belling@nsn.com |  |
| 1878 | 16.5.2 | Interworking for IPv6 to IPv4 |  | 1118d | 2000-08-28 A | 2004-12-08 A | 100% | 2000-08-28 | 2004-12-08 | 1118d | finish no earlier than 2004-12-08 | N3 | 8944h | 8944h |  | 29.163 | Rel-6 | Gwiho |  |  |  |
| 1879 | 588.8.3 | Interworking for IPv6 to IPv4 (SIP / SDP aspects) |  | 87d? | 2004-05-11 A | 2004-09-08 A | 100% | 2004-05-11 | 2004-09-08 | 87d? | finish no earlier than 2004-09-08 | N1 | 696h | 696h |  |  | Rel-6 | Frederic |  |  |  |
| 1880 | 16.8.1 | stage 3 of interworking with non-IMS IP networks |  | 911d | 2001-03-14 A | 2004-09-08 A | 100% | 2001-03-14 | 2004-09-08 | 911d | finish no earlier than 2004-09-08 | N1 | 7288h | 7288h |  |  | Rel-6 | Frederic |  |  |  |
| 1881 | 16.6.1 | Interworking between IMS and CS networks |  | 929d? | 2000-08-28 A | 2004-03-18 A | 100% | 2000-08-28 | 2004-03-18 | 929d? | finish no earlier than 2004-03-18 | N3 | 7432h | 7432h | IMS-CCR-IWCS | 29.163, 29.061, 24.228, and new CN4 specification | Rel-6 | Gwiho | Vodafone | Brendan.McWilliams@gb.vodafone.co.uk |  |
| 1882 | 16.10 | Mn interface (IM-MGW to MGCF) enhancements (CN4 Part) |  | 418d | 2001-08-07 A | 2004-09-01 A | 100% | 2001-08-07 | 2004-09-01 | 418d | finish no earlier than 2004-09-01 | N4 | 3344h | 3344h | IMS-CCR-Mn |  | Rel-6 | Kimmo |  |  |  |
| 1883 | 588.11 | Study of subscriber and operators relationship in IMS and related ISIM requirements for Rel 6” |  | 20d? | 2002-11-15 A | 2002-12-12 A | 100% | 2002-11-15 | 2002-12-12 | 20d? | finish no earlier than 2002-12-12 | S1 | 160h | 160h |  |  | Rel-6 | Alain | Nokia | juha.kalliokulju@nokia.com |  |
| 1884 | 588.12 | Lawful Interception in the 3GPP Rel-6 architecture |  | 269d? | 2002-12-09 A | 2003-12-18 A | 100% | 2002-12-09 | 2003-12-18 | 269d? | finish no earlier than 2003-12-18 | S3 | 2152h | 2152h | SEC1-LI | 33.106, 33.107, 33.108 | Rel-6 | Dionisio | Reg TP | berthold.wilhelm@regtp.de |  |
| 1885 | 588.13 | IMS Subscription and access scenarios |  | 130d? | 2002-12-16 A | 2003-06-13 A | 100% | 2002-12-16 | 2003-06-13 | 130d? | start no earlier than 2002-12-16 | S1 | 1040h | 1040h |  | 22.800 | Rel-6 | Alain | TeliaSonera | FRANK, Robert |  |
| 1886 | 588.14 | IMS charging |  | 455d? | 2003-03-21 A | 2004-12-16 A | 100% | 2003-03-21 | 2004-12-16 | 455d? | finish no earlier than 2004-12-16 | S5 | 3640h | 3640h | IMS2-CH | 32.260 | Rel-6 | Dionisio | Ericsson | Patrik TEPPO |  |
| 1887 | 588.15 | IMS Management objects |  | 306d? | 2004-09-03 A | 2005-11-04 A | 100% | 2004-09-03 | 2005-11-04 | 306d? | finish no earlier than 2005-03-04 | N1 | 2448h | 2448h |  | 24.167 | Rel-6 | Frederic |  |  |  |
| 1888 | 588.16 | Deleted - Stage 2 of IMS Phase 2 | milestone | 0d? | 2003-09-19 A | 2003-09-19 A | 100% | 2003-09-19 | 2003-09-19 | 0d? | finish no earlier than 2003-09-19 | S2 |  |  | IMS2 |  | Rel-6 | Maurice |  |  | SP-21 |

Notes:
- 1854: Not yet available: verbally approved at SA15, actual WID to be provided at SA16 by Lucent
- 1855: Shared public user identities need to be solved. If email approval CR is accepted. Work 100% done....
- 1856: -
- 1857: -
- 1858: -
- 1859: -
- 1860: Depends on CN decision on CPCP in Rel-6. Complete, if unresolved IETF dependencies are dropped (-> LS to CN plenary)
- 1861: -
- 1862: -
- 1863: Depends on CN decision on IETF dependencies in Rel-6. Higher figure if CPCP is dropped (-> LS to CN plenary)
- 1864: -
- 1865: -
- 1866: -
- 1867: -
- 1868: -
- 1869: -
- 1870: Updated according to SP-040232
- 1871: -
- 1872: -
- 1873: -
- 1874: -
- 1875: -
- 1876: [DAB 14.02.02] - end date pushed back to March 2003
- 1877: [DAB - 20.08.03] - CN Part of TR Complete @ CN#20
- 1878: -
- 1879: -
- 1880: -
- 1881: [DAB - 25.05.04] - CN3 consider this work to be complete
- 1882: TISPAN issue is open
- 1883: -
- 1884: -
- 1885: -
- 1886: SP#26 12/2004 completed
- 1887: -
- 1888: -

| ID | WBS | Task | Type | Duration | Start | Finish | Complete | Baseline start | Baseline finish | Baseline duration | Constraint | Resources | Work | Actual work | Text1 | Text4 | Text5 | Text6 | Text8 | Text3 | Text10 | Text12 |
| --- | --- | --- | --- | --- | --- | --- | --- | --- | --- | --- | --- | --- | --- | --- | --- | --- | --- | --- | --- | --- | --- | --- |
| 1889 | 589 | **3GPP Enablers for services like Push to Talk over Cellular (PoC)** |  | 459d? | 2003-09-08 A | 2005-06-09 A | 100% | 2003-09-08 | 2005-06-09 | 459d? |  | S2,S4,S5 | 10696h | 10696h | PoC | Ericsson | Shabnam Sultana | Rel-6 | Maurice |  |  |  |
| 1890 | 589.1 | Feasibility Study |  | 322d? | 2003-09-08 A | 2004-11-30 A | 100% | 2003-09-08 | 2004-11-30 | 322d? | finish no earlier than 2004-11-30 | S2 | 2576h | 2576h | PoC | Ericsson | Shabnam Sultana | Rel-6 | Maurice | 23.979 | SP-24 |  |
| 1891 | 589.2 | Dependencies on OMA PoC |  | 303d? | 2004-01-01 A | 2005-02-28 A | 100% | 2004-01-01 | 2005-02-28 | 303d? | finish no earlier than 2004-12-30 | OMA | 2424h | 2424h | PoC |  | OMA-LIAISON@mail.openmobilealliance.org | Rel-6 |  |  | SP-24 |  |
| 1892 | 589.3 | Selection of one or more PoC codec(s) for PoC |  | 69d? | 2004-09-13 A | 2004-12-16 A | 100% | 2004-09-13 | 2004-12-16 | 69d? | start no earlier than 2004-09-13 | S4 | 552h | 552h | PoC |  |  | Rel-6 | Paolo | 26.235, 26.236 | SP-25 |  |
| 1893 | 589.4 | PoC charging |  | 184d? | 2004-09-27 A | 2005-06-09 A | 100% | 2004-09-27 | 2005-06-09 | 184d? | finish no earlier than 2005-06-09 | S5 | 1472h | 1472h | PoC-CH | Siemens | Gerald.Goermer@nsn.com | Rel-6 | Dionisio | 32.272 |  |  |
| 1894 | 590 | Study on Interworking aspects and migration scenarios for IPv4 based IMS Implementations |  | 210d? | 2003-09-08 A | 2004-06-25 A | 100% | 2003-09-08 | 2004-06-25 | 210d? | finish no earlier than 2004-06-25 | S2 | 1680h | 1680h | IPv4IMS | Siemens | Alexander Milinski | Rel-6 | Maurice | 23.981 |  |  |
| 1895 | 16.3 | **Interoperability and Commonality between IMS using different IP-connectivity Networks** |  | 325d? | 2002-09-16 A | 2003-12-12 A | 100% | 2002-09-16 | 2003-12-12 | 325d? |  | S2 | 9176h | 9176h | IMSCOOP |  |  | Rel-6 | Maurice | 23.864 |  |  |
| 1896 | 16.3.1 | Stage 2 for Interoperability |  | 272d | 2002-09-16 A | 2003-09-30 A | 100% | 2002-09-16 | 2003-09-30 | 272d | finish no earlier than 2003-09-30 | S2 | 2176h | 2176h | IMSCOOP | Nokia | balazs.bertenyi@nsn.com | Rel-6 | Maurice | 23.864 |  |  |
| 1897 | 591.2 | Stage 2 for commonality |  | 265d? | 2002-09-16 A | 2003-09-19 A | 100% | 2002-09-16 | 2003-09-19 | 265d? | start no earlier than 2002-09-16 | S2 | 2120h | 2120h | IMSCOOP | Nokia | balazs.bertenyi@nsn.com | Rel-6 | Maurice | 23.864 |  |  |
| 1898 | 16.3.2 | Stage 3 |  | 305d | 2002-10-14 A | 2003-12-12 A | 100% | 2002-10-14 | 2003-12-12 | 305d | finish no earlier than 2003-12-12 | N1 | 2440h | 2440h | IMSCOOP | Lucent | Keith Drage (drage@alcatel-lucent.com) | Rel-6 | Frederic |  |  |  |
| 1899 | 17 | **Support of Push Services** |  | 823d | 2001-01-03 A | 2004-02-27 A | 100% | 2001-01-03 | 2004-02-27 | 823d |  | S1 | 11390.6h | 11390.6h | PUSH | NTT Comware | Yoshinori Kitada | Rel-6 | Alain | 23.976 |  |  |
| 1900 | 17.1 | Stage 1 |  | 378d | 2001-01-03 A | 2002-06-14 A | 100% | 2001-01-03 | 2002-06-14 | 378d | finish no earlier than 2002-06-14 | S1 | 3024h | 3024h | PUSH |  |  | Rel-6 | Alain |  |  |  |
| 1901 | 17.3 | TR 23.976 on Push Architecture |  | 340d | 2002-11-11 A | 2004-02-27 A | 100% | 2002-11-11 | 2004-02-27 | 340d | finish no earlier than 2004-02-27 | S2 | 2720h | 2720h | PUSH | Research In Motion | Nick Alfano | Rel-6 | Maurice | 23.976 |  |  |
| 1902 | 18 | **Multimedia Messaging (MMS) enhancements** |  | 865d? | 2002-08-15 A | 2005-12-07 A | 100% | 2002-08-15 | 2005-12-07 | 865d? |  | T2,S1,S4,S5,OMA | 31936h | 31936h | MMS6 | Siemens | Josef.Laumen@SAL.SIEMENS.DE | Rel-6 | Kimmo |  |  |  |
| 1903 | 18.1 | **Definition of service requirements** |  | 286d? | 2002-11-15 A | 2003-12-19 A | 100% | 2002-11-15 | 2003-12-19 | 286d? |  | S1 | 4576h | 4576h | MMS6-SR |  |  | Rel-6 | Alain | 22.140 |  |  |
| 1904 | 593.1.1 | Definition of service requirements charging |  | 286d? | 2002-11-15 A | 2003-12-19 A | 100% | 2002-11-15 | 2003-12-19 | 286d? | finish no earlier than 2003-12-20 | S1 | 2288h | 2288h | MMS6-SR | Siemens | Josef.Laumen@SAL.SIEMENS.DE | Rel-6 | Alain | 22.140 |  |  |
| 1905 | 18.2 | Technical realization |  | 591d | 2002-09-06 A | 2004-12-10 A | 100% | 2002-09-06 | 2004-12-10 | 591d | finish no earlier than 2004-12-10 | T2 | 4728h | 4728h | MMS6 | Siemens | Josef.Laumen@SAL.SIEMENS.DE | Rel-6 | Kimmo | 23.140 |  |  |
| 1906 | 18.3 | OMA dependencies |  | 446d | 2003-08-15 A | 2005-04-29 A | 100% | 2003-08-15 | 2005-04-29 | 446d | finish no earlier than 2004-12-10 | OMA | 3568h | 3568h | MMS6 |  |  | Rel-6 | Kimmo | OMA specs |  |  |
| 1907 | 18.4 | MMS formats and codecs |  | 865d | 2002-08-15 A | 2005-12-07 A | 100% | 2002-08-15 | 2005-12-07 | 865d | finish no earlier than 2005-12-07 | S4 | 6920h | 6920h | MMS6-Codec | Nokia | roberto.castagno@nokia.com | Rel-6 | Paolo | 26.140, 26.936 |  |  |
| 1908 | 593.5 | Handling of private addressing schemes in MMS |  | 263d | 2003-12-10 A | 2004-12-10 A | 100% | 2003-12-10 | 2004-12-10 | 263d | finish no earlier than 2004-12-10 | T2 | 2104h | 2104h | MMS6 | T-Mobile | Steffen.Habermann@T-MOBILE.DE | Rel-6 | Kimmo | 23.140 |  |  |
| 1909 | 593.6 | MMS charging |  | 390d? | 2003-03-21 A | 2004-09-16 A | 100% | 2003-03-21 | 2004-09-16 | 390d? | start no earlier than 2003-03-21 | S5 | 3120h | 3120h | MMS6-CH |  |  | Rel-6 | Dionisio | 32.270 |  |  |
| 1910 | 593.7 | Deleted - FS Multiple MMS Relay/Server Architecture | milestone | 0d | 2004-12-10 A | 2004-12-10 A | 100% | 2004-12-10 | 2004-12-10 | 0d | finish no earlier than 2004-12-10 | T2 |  |  | MMS6 | Telefónica Móviles | Juan Gorospe (gorospe_j@tsm.es) | Rel-6 | Kimmo | probably Annex to 23.140 |  | TP-26 |
| 1911 | 19 | **Rel-6 MExE enhancements** |  | 326d | 2002-03-08 A | 2003-06-06 A | 100% | 2002-03-08 | 2003-06-06 | 326d |  | T2 | 7328h | 7328h | MEXE6 |  |  | Rel-6 | Kimmo |  |  |  |
| 1912 | 19.1 | MExE Rel-6 Improvements and Investigations |  | 264d | 2002-03-08 A | 2003-03-12 A | 100% | 2002-03-08 | 2003-03-12 | 264d | finish no earlier than 2003-03-12 | T2 | 2112h | 2112h | MEXE6-ENHANC | TTPCom | Lars Brenk ( (lsb_ttpcom@HOTMAIL.COM) | Rel-6 | Kimmo |  |  |  |
| 1913 | 19.2 | MExE Run-Time Independent Framework Feasibility Study |  | 326d | 2002-03-08 A | 2003-06-06 A | 100% | 2002-03-08 | 2003-06-06 | 326d | finish no earlier than 2003-06-06 | T2 | 2608h | 2608h | MEXE6-RTIF | Nokia Siemens Networks | balazs.bertenyi@nokia.com | Rel-6 | Kimmo | 22.857 |  |  |
| 1914 | 21 | Subscription Management |  | 650d | 2002-09-20 A | 2005-03-17 A | 100% | 2002-09-20 | 2005-03-17 | 650d | finish no earlier than 2005-03-17 | S5 | 5200h | 5200h | SuM | T-Mobile | istvan.aba@t-mobile.at | Rel-6 | Dionisio | 32.140/1, 32.171/2/5, 32.803 |  |  |

Notes:
- 1889: -
- 1890: -
- 1891: Updated according to SP-040232
- 1892: Completed
- 1893: SP#28 06/2005 completed
- 1894: -
- 1895: -
- 1896: No contributions assumed that no more will be done in 3GPP hence work may need to be done in 3GPP2
- 1897: -
- 1898: -
- 1899: Changed from FS to actual support of Push
- 1900: -
- 1901: -
- 1902: -
- 1903: -
- 1904: -
- 1905: -
- 1906: -
- 1907: -
- 1908: -
- 1909: SP#25 09/2004 completed
- 1910: originally it was intended to create a FS TR but most likely the work will become an Annex of 23.140
- 1911: -
- 1912: -
- 1913: -
- 1914: SP#27 03/2005 completed

| ID | WBS | Task | Duration | Start | Finish | Complete | Baseline start | Baseline finish | Baseline duration | Constraint | Resources | Work | Actual work | Text1 | Text4 | Text5 | Text6 | Text8 | Text3 |
| --- | --- | --- | --- | --- | --- | --- | --- | --- | --- | --- | --- | --- | --- | --- | --- | --- | --- | --- | --- |
| 1915 | 22 | **Presence Capability** | 1233d? | 2001-03-19 A | 2005-12-07 A | 100% | 2001-03-19 | 2005-12-07 | 1233d? |  | S1 | 37112h | 37112h | PRESNC | Motorola | Mark Cataldo | Rel-6 | Alain |  |
| 1916 | 22.1 | Stage 1 | 610d | 2001-03-19 A | 2003-07-18 A | 100% | 2001-03-19 | 2003-07-18 | 610d | finish no earlier than 2003-07-18 | S1 | 4880h | 4880h | PRESNC |  |  | Rel-6 | Alain | 22.141 |
| 1917 | 22.2 | Stage 2 | 268d | 2001-09-12 A | 2002-09-20 A | 100% | 2001-09-12 | 2002-09-20 | 268d | finish no earlier than 2002-09-20 | S2 | 2144h | 2144h | PRESNC | Nokia | balazs.bertenyi@nsn.com | Rel-6 | Maurice |  |
| 1918 | 22.3 | Stage 3 | 703d | 2002-04-01 A | 2004-12-08 A | 100% | 2002-04-01 | 2004-12-08 | 703d | finish no earlier than 2004-12-08 | N1 | 5624h | 5624h | PRESNC | Lucent | Keith Drage (drage@alcatel-lucent.com) | Rel-6 | Frederic |  |
| 1919 | 596.4 | Stage 3 (CN3 Part Pk interface) | 770d? | 2002-04-01 A | 2005-03-11 A | 100% | 2002-04-01 | 2005-03-11 | 770d? | finish no earlier than 2005-03-11 | N3 | 6160h | 6160h | PRESNC |  |  | Rel-6 | Gwiho |  |
| 1920 | 596.5 | Media Codecs and Formats for IMS Messaging and Presence | 650d? | 2003-06-12 A | 2005-12-07 A | 100% | 2003-06-12 | 2005-12-07 | 650d? | finish no earlier than 2005-12-07 | S4 | 5200h | 5200h | PRESNC-COFIMP | Nokia | harri.honko@nokia.com | Rel-6 | Paolo | 26.141, 26.936 |
| 1921 | 22.4 | Security issues | 79d | 2002-08-26 A | 2002-12-12 A | 100% | 2002-08-26 | 2002-12-12 | 79d | finish no earlier than 2002-12-12 | S3 | 632h | 632h | PRESNC |  |  | Rel-6 | Dionisio |  |
| 1922 | 596.7 | SIMPLE Presence | 326d? | 2004-01-01 A | 2005-03-31 A | 100% | 2004-01-01 | 2005-03-31 | 326d? | finish no earlier than 2004-12-30 | OMA | 2608h | 2608h | PRESNC |  | OMA-LIAISON@mail.openmobilealliance.org | Rel-6 |  |  |
| 1923 | 25 | **Enhanced A/Gb feasibility study** | 51d? | 2002-08-30 A | 2002-11-08 A | 100% | 2002-08-30 | 2002-11-08 | 51d? |  | GP | 3264h | 3264h | AGbEnFS | Vodafone | jose-luis.carrizo@vodafone.co.uk | Rel-6 | Paolo | None |
| 1924 | 25.1 | **Feasibility study on A/Gb enhancements** | 51d? | 2002-08-30 A | 2002-11-08 A | 100% | 2002-08-30 | 2002-11-08 | 51d? |  | G2 | 2856h | 2856h | AGbEnFS-FS | Vodafone | jose-luis.carrizo@vodafone.co.uk | Rel-6 | Gert | None |
| 1925 | 25.1.1 | Requirements for the support of conversational services | 51d | 2002-08-30 A | 2002-11-08 A | 100% | 2002-08-30 | 2002-11-08 | 51d | finish no earlier than 2002-11-08 | GP | 408h | 408h | AGbEnFS-FS |  |  | Rel-6 | Paolo | None |
| 1926 | 597.1.2 | Identification of the different building blocks for the provision of conversational services on the existing A/Gb protocol stack | 51d? | 2002-08-30 A | 2002-11-08 A | 100% | 2002-08-30 | 2002-11-08 | 51d? | finish no earlier than 2002-11-08 | GP | 408h | 408h | AGbEnFS-FS |  |  | Rel-6 | Paolo | None |
| 1927 | 597.1.3 | Outline of impact and feasibility of these building blocks and their different solutions | 51d? | 2002-08-30 A | 2002-11-08 A | 100% | 2002-08-30 | 2002-11-08 | 51d? | finish no earlier than 2002-11-08 | GP | 408h | 408h | AGbEnFS-FS |  |  | Rel-6 | Paolo | None |
| 1928 | 25.1.4 | Impact on 3GPP architecture and requirement to co-ordinatge with other TSGs (CN, SA) | 51d | 2002-08-30 A | 2002-11-08 A | 100% | 2002-08-30 | 2002-11-08 | 51d | finish no earlier than 2002-11-08 | GP | 408h | 408h | AGbEnFS-FS |  |  | Rel-6 | Paolo | None |
| 1929 | 25.1.5 | Standardisation effort | 51d | 2002-08-30 A | 2002-11-08 A | 100% | 2002-08-30 | 2002-11-08 | 51d | finish no earlier than 2002-11-08 | GP | 408h | 408h | AGbEnFS-FS |  |  | Rel-6 | Paolo | None |
| 1930 | 25.1.6 | Dependency to other features | 51d | 2002-08-30 A | 2002-11-08 A | 100% | 2002-08-30 | 2002-11-08 | 51d | finish no earlier than 2002-11-08 | GP | 408h | 408h | AGbEnFS-FS |  |  | Rel-6 | Paolo | None |
| 1931 | 26 | **Flexible Layer One for GERAN** | 1171d | 2000-01-03 A | 2004-06-25 A | 100% | 2000-01-03 | 2004-06-25 | 1171d |  | GP | 71551h | 71551h | FLOGER | Nokia | benoist.sebire@nokia.com | Rel-6 | Paolo |  |
| 1932 | 26.1 | **Realisation of a Flexible Layer One** | 1126d | 2000-01-03 A | 2004-04-23 A | 100% | 2000-01-03 | 2004-04-23 | 1126d |  | GP | 42816h | 42816h | FLOGER-Real | Nokia | benoist.sebire@nokia.com | Rel-6 | Paolo |  |
| 1933 | 26.1.1 | Technical Report | 471d | 2002-04-19 A | 2004-02-06 A | 100% | 2002-04-19 | 2004-02-06 | 471d | finish no earlier than 2004-02-06 | GP | 3768h | 3768h | FLOGER-Real |  |  | Rel-6 | Paolo |  |
| 1934 | 26.1.2 | Architecture in 45.001 and 43.051 | 526d | 2002-04-19 A | 2004-04-23 A | 100% | 2002-04-19 | 2004-04-23 | 526d | finish no earlier than 2004-04-23 | G1 | 4208h | 4208h | FLOGER-Real |  |  | Rel-6 | Paolo |  |
| 1935 | 26.1.3 | Multiplexing in 45.002 | 526d | 2002-04-19 A | 2004-04-23 A | 100% | 2002-04-19 | 2004-04-23 | 526d | finish no earlier than 2004-04-23 | G1 | 4208h | 4208h | FLOGER-Real |  |  | Rel-6 | Paolo |  |
| 1936 | 26.1.4 | Channel Coding in 45.003 | 526d | 2002-04-19 A | 2004-04-23 A | 100% | 2002-04-19 | 2004-04-23 | 526d | finish no earlier than 2004-04-23 | G1 | 4208h | 4208h | FLOGER-Real |  |  | Rel-6 | Paolo |  |
| 1937 | 26.1.5 | Performance Requirements in 45.005 | 1126d | 2000-01-03 A | 2004-04-23 A | 100% | 2000-01-03 | 2004-04-23 | 1126d | finish no earlier than 2004-04-23 | G1 | 9000h | 9000h | FLOGER-Real |  |  | Rel-6 | Paolo |  |
| 1938 | 26.1.6 | Radio subsystem link control in 45.008 | 526d | 2002-04-19 A | 2004-04-23 A | 100% | 2002-04-19 | 2004-04-23 | 526d | finish no earlier than 2004-04-23 | G1 | 4208h | 4208h | FLOGER-Real |  |  | Rel-6 | Paolo |  |
| 1939 | 26.1.7 | Requirements in 44.004 | 526d | 2002-04-19 A | 2004-04-23 A | 100% | 2002-04-19 | 2004-04-23 | 526d | finish no earlier than 2004-04-23 | G2 | 4208h | 4208h | FLOGER-Real |  |  | Rel-6 | Gert |  |

Notes:
- 1915: merged "Presence Service Enhancements" (UID31028, PRES1) to this feature as no answer was provided on why Presence and Presence Encmts had same target completion date
- 1916: -
- 1917: -
- 1918: Dependency to 2 IETF drafts, no known work at the moment
- 1919: No Contributions so far - only requires a little work
- 1920: -
- 1921: LSs handled in SA3. WID approved SP#17 Contribution at S3#25 & following e-mail discussion. Marked as closed 12/2008 (was marked 90% complete)
- 1922: Updated according to SP-040232
- 1923: -
- 1924: -
- 1925: -
- 1926: -
- 1927: -
- 1928: -
- 1929: -
- 1930: -
- 1931: -
- 1932: -
- 1933: -
- 1934: -
- 1935: -
- 1936: -
- 1937: -
- 1938: -
- 1939: -

| ID | WBS | Task | Type | Duration | Start | Finish | Complete | Baseline start | Baseline finish | Baseline duration | Constraint | Resources | Work | Actual work | Text1 | Text4 | Text5 | Text6 | Text8 | Text12 | Text3 |
| --- | --- | --- | --- | --- | --- | --- | --- | --- | --- | --- | --- | --- | --- | --- | --- | --- | --- | --- | --- | --- | --- |
| 1940 | 26.2 | **Signalling and protocol support for a Flexible Layer One** |  | 571d | 2002-04-19 A | 2004-06-25 A | 100% | 2002-04-19 | 2004-06-25 | 571d |  | G2 | 13704h | 13704h | FLOGER-SigPro | Nokia | benoist.sebire@nokia.com | Rel-6 | Gert |  |  |
| 1941 | 26.2.1 | Modifications to RLC/MAC in 44.060 and 44.160 |  | 571d | 2002-04-19 A | 2004-06-25 A | 100% | 2002-04-19 | 2004-06-25 | 571d | finish no earlier than 2004-06-25 | G2 | 4568h | 4568h | FLOGER-SigPro |  |  | Rel-6 | Gert |  |  |
| 1942 | 26.2.2 | Modifications to RRC in 44.118 and 44.018 |  | 571d | 2002-04-19 A | 2004-06-25 A | 100% | 2002-04-19 | 2004-06-25 | 571d | finish no earlier than 2004-06-25 | G2 | 4568h | 4568h | FLOGER-SigPro |  |  | Rel-6 | Gert |  |  |
| 1943 | 26.3 | **Security for a Flexible Layer One** |  | 356d | 2002-04-19 A | 2003-08-29 A | 100% | 2002-04-19 | 2003-08-29 | 356d |  | S3, G2 | 5663.03h | 5663.03h | FLOGER-SecFLO | Nokia | benoist.sebire@nokia.com | Rel-6 | Dionisio |  |  |
| 1944 | 26.3.1 | Ciphering in 44.160,44.118, 44.060 and 44.018 |  | 356d | 2002-04-19 A | 2003-08-29 A | 100% | 2002-04-19 | 2003-08-29 | 356d | finish no earlier than 2003-08-29 | S3, G2 | 2848h | 2848h | FLOGER-SecFLO |  |  | Rel-6 | Dionisio |  |  |
| 1945 | 26.4 | **Deleted - GERAN MS Conformance test for the Flexible Layer One - DELETE** |  | 0d | 2004-02-06 A | 2004-02-06 A | 100% | 2004-02-06 | 2004-02-06 | 0d |  | G4,G5 |  |  | FLOGER-Msconf | Nokia | benoist.sebire@nokia.com | Rel-6 | Paolo | GP-27 |  |
| 1946 | 26.4.1 | Deleted at TSG #27 - MS Test in 51.010 | milestone | 0d | 2004-02-06 A | 2004-02-06 A | 100% | 2004-02-06 | 2004-02-06 | 0d | finish no earlier than 2004-02-06 | G4,G5 |  |  | FLOGER-Msconf |  |  | Rel-6 | Paolo | GP-22 |  |
| 1947 | 26.5 | **Deleted - GERAN BTS Conformance test for the Flexible Layer One - DELETE** |  | 0d | 2004-02-06 A | 2004-02-06 A | 100% | 2004-02-06 | 2004-02-06 | 0d |  | G3new |  |  | FLOGER-BTSconf | Nokia | benoist.sebire@nokia.com | Rel-6 | Ingbert | GP-27 |  |
| 1948 | 26.5.1 | Deleted at TGS #27 - BTS Test in 51.021 - DELETE | milestone | 0d | 2004-02-06 A | 2004-02-06 A | 100% | 2004-02-06 | 2004-02-06 | 0d | finish no earlier than 2004-02-06 | G3new |  |  | FLOGER-BTSconf |  |  | Rel-6 | Ingbert | GP-22 |  |
| 1949 | 27 | Uplink TDOA feasibility study |  | 151d | 2001-11-30 A | 2002-06-28 A | 100% | 2001-11-30 | 2002-06-28 | 151d | finish no earlier than 2002-06-28 | GP | 1208h | 1208h | TDOAF | TruePosition | Bob Gross (rlgross@trueposition.com) | Rel-6 | Paolo |  | 45.811 |
| 1950 | 28 | **Multimedia Broadcast and Multicast Service** |  | 1781d? | 2001-05-11 A | 2008-03-07 A | 100% | 2001-05-11 | 2008-03-07 | 1781d? |  | S1,S2,S4,S5,RP,R5,GP | 158712h | 158712h | MBMS |  |  | Rel-6 | Alain |  |  |
| 1951 | 28.1 | Stage 1 |  | 232d | 2001-05-11 A | 2002-04-01 A | 100% | 2001-05-11 | 2002-04-01 | 232d | finish no earlier than 2002-04-01 | S1 | 1856h | 1856h | MBMS |  |  | Rel-6 | Alain |  | 22.146, 22.101 |
| 1952 | 28.2 | **Stage 2** |  | 648d | 2001-09-24 A | 2004-03-17 A | 100% | 2001-09-24 | 2004-03-17 | 648d |  | S2 | 10408h | 10408h | MBMS |  |  | Rel-6 | Maurice |  |  |
| 1953 | 28.2.1 | TR on Architectural Study |  | 240d | 2001-09-24 A | 2002-08-23 A | 100% | 2001-09-24 | 2002-08-23 | 240d | finish no earlier than 2002-08-23 | S2 | 1920h | 1920h | MBMS |  |  | Rel-6 | Maurice |  | 23.846 |
| 1954 | 28.2.2 | Stage 2 Specification Work |  | 413d | 2002-08-19 A | 2004-03-17 A | 100% | 2002-08-19 | 2004-03-17 | 413d | finish no earlier than 2004-03-17 | S2 | 3304h | 3304h | MBMS |  |  | Rel-6 | Maurice |  | 23.246 |
| 1955 | 28.3 | **Introduction of MBMS in RAN** |  | 967d? | 2002-01-01 A | 2005-09-14 A | 100% | 2002-01-01 | 2005-09-14 | 967d? |  | R2 | 15992h | 15992h | MBMS-RAN | Nokia | juho.pirskanen@nokia.com | Rel-6 | Joern |  | 25.346, 25.304, 25.321, 25.322, 25.323, 25.331 |
| 1956 | 600.3.1 | Introduction of MBMS in RAN (physical & upper layers, access network interfaces) |  | 771d? | 2002-01-01 A | 2004-12-14 A | 100% | 2002-01-01 | 2004-12-14 | 771d? | finish no earlier than 2004-12-14 | R2 | 6168h | 6168h | MBMS-RAN | Nokia | juho.pirskanen@nokia.com | Rel-6 | Joern |  | 25.346, 25.304, 25.321, 25.322, 25.323 |
| 1957 | 600.3.2 | UE Performance Requirements for MBMS |  | 261d? | 2004-09-15 A | 2005-09-14 A | 100% | 2004-09-15 | 2005-09-14 | 261d? | finish no earlier than 2005-09-15 | R4 | 2088h | 2088h | MBMS-RAN-RF | Ericsson | Torgny.Palenius@ericsson.com | Rel-6 | Issam |  | 25.101, 25.133 |
| 1958 | 28.4 | Support of the MBMS in CN protocols |  | 647d | 2002-06-18 A | 2004-12-08 A | 100% | 2002-06-18 | 2004-12-08 | 647d | finish no earlier than 2004-12-08 | N1 | 5176h | 5176h | MBMS |  |  | Rel-6 | Frederic |  |  |
| 1959 | 600.5 | Gmb interface for MBMS (CN3 part) |  | 334d | 2003-08-29 A | 2004-12-08 A | 100% | 2003-08-29 | 2004-12-08 | 334d | finish no earlier than 2004-12-08 | N3 | 2672h | 2672h | MBMS |  |  | Rel-6 | Gwiho |  | 29.061 |
| 1960 | 28.5 | Security Aspects of MBMS |  | 710d | 2002-07-01 A | 2005-03-18 A | 100% | 2002-07-01 | 2005-03-18 | 710d | finish no earlier than 2005-03-18 | S3 | 5680h | 5680h | MBMS |  | adrian.escott@three.co.uk | Rel-6 | Dionisio |  |  |
| 1961 | 28.6 | **Support of MBMS in GERAN** |  | 892d? | 2001-08-30 A | 2005-01-28 A | 100% | 2001-08-30 | 2005-01-28 | 892d? |  | GP | 71040h | 71040h | MBMS-GERAN |  |  | Rel-6 | Paolo |  |  |
| 1962 | 28.6.1 | Impact on the logical and physical channels |  | 631d | 2002-08-30 A | 2005-01-28 A | 100% | 2002-08-30 | 2005-01-28 | 631d | finish no earlier than 2005-01-28 | GP | 5048h | 5048h | MBMS-GERAN |  |  | Rel-6 | Paolo |  |  |
| 1963 | 28.6.4 | Re-synchronisation at cell change |  | 631d | 2002-08-30 A | 2005-01-28 A | 100% | 2002-08-30 | 2005-01-28 | 631d | finish no earlier than 2005-01-28 | G2 | 5048h | 5048h | MBMS-GERAN |  |  | Rel-6 | Gert |  |  |
| 1964 | 600.7.3 | Simultaneous support of MBMS services |  | 631d? | 2002-08-30 A | 2005-01-28 A | 100% | 2002-08-30 | 2005-01-28 | 631d? | finish no earlier than 2005-01-28 | GP | 5048h | 5048h | MBMS-GERAN |  |  | Rel-6 | Paolo |  |  |
| 1965 | 600.7.4 | Simultaneous support of MBMS and non-MBMS services |  | 892d? | 2001-08-30 A | 2005-01-28 A | 100% | 2001-08-30 | 2005-01-28 | 892d? | finish no earlier than 2005-01-28 | GP | 7136h | 7136h | MBMS-GERAN |  |  | Rel-6 | Paolo |  |  |
| 1966 | 600.7.5 | Resynchronisation at cell change |  | 892d? | 2001-08-30 A | 2005-01-28 A | 100% | 2001-08-30 | 2005-01-28 | 892d? | finish no earlier than 2005-01-28 | GP | 7136h | 7136h | MBMS-GERAN |  |  | Rel-6 | Paolo |  |  |
| 1967 | 28.6.5 | Decision making process between point-to-point or pont-to-multipoint configurations |  | 631d | 2002-08-30 A | 2005-01-28 A | 100% | 2002-08-30 | 2005-01-28 | 631d | finish no earlier than 2005-01-28 | GP | 5048h | 5048h | MBMS-GERAN |  |  | Rel-6 | Paolo |  |  |
| 1968 | 28.6.6 | MBMS channel allocations procedures to multiple MSs |  | 631d | 2002-08-30 A | 2005-01-28 A | 100% | 2002-08-30 | 2005-01-28 | 631d | finish no earlier than 2005-01-28 | GP | 5048h | 5048h | MBMS-GERAN |  |  | Rel-6 | Paolo |  |  |
| 1969 | 28.6.7 | Changes to the Gb interface |  | 631d | 2002-08-30 A | 2005-01-28 A | 100% | 2002-08-30 | 2005-01-28 | 631d | finish no earlier than 2005-01-28 | GP | 5048h | 5048h | MBMS-GERAN |  |  | Rel-6 | Paolo |  |  |
| 1970 | 28.6.8 | GERAN specific changes to the Iu-ps interface |  | 631d | 2002-08-30 A | 2005-01-28 A | 100% | 2002-08-30 | 2005-01-28 | 631d | finish no earlier than 2005-01-28 | GP | 5048h | 5048h | MBMS-GERAN |  |  | Rel-6 | Paolo |  |  |
| 1971 | 28.6.9 | Interaction between MBMS and Iu-flex |  | 631d | 2002-08-30 A | 2005-01-28 A | 100% | 2002-08-30 | 2005-01-28 | 631d | finish no earlier than 2005-01-28 | GP | 5048h | 5048h | MBMS-GERAN |  |  | Rel-6 | Paolo |  |  |
| 1972 | 28.6.10 | Security aspects |  | 631d | 2002-08-30 A | 2005-01-28 A | 100% | 2002-08-30 | 2005-01-28 | 631d | finish no earlier than 2005-01-28 | GP | 5048h | 5048h | MBMS-GERAN |  |  | Rel-6 | Paolo |  |  |
| 1973 | 600.7.12 | MBMS-GERAN - MS conformance tests |  | 786d? | 2002-01-25 A | 2005-01-28 A | 100% | 2002-01-25 | 2005-01-28 | 786d? | finish no earlier than 2005-01-28 | G3new | 6288h | 6288h | MBMS-GERAN |  |  | Rel-6 | Ingbert |  |  |
| 1974 | 600.7.13 | Deleted - MS conformance tests - G5 | milestone | 0d? | 2003-06-27 A | 2003-06-27 A | 100% | 2003-06-27 | 2003-06-27 | 0d? | start no earlier than 2003-06-27 | G5 |  |  | MBMS-GERAN |  |  | Rel-6 | Paolo | GP-19 |  |

Notes:
- 1940: -
- 1941: -
- 1942: -
- 1943: -
- 1944: -
- 1945: -
- 1946: -
- 1947: -
- 1948: -
- 1949: -
- 1950: Title renamed at SP#13
- 1951: This may or may not be a separate stage 1. In the meantime, CRs are proposed for 22.101
- 1952: -
- 1953: -
- 1954: -
- 1955: -
- 1956: Was "Introduction of MBMS in RAN" before RP#25. Created w/o WIDS after RAN approved the WT for RF aspects.Take WIDS from the parent BB
- 1957: Approved at RP#25 as RP-040370
- 1958: -
- 1959: -
- 1960: WID approved SP#17. 2004-12: Expected completion March 2005
- 1961: -
- 1962: -
- 1963: -
- 1964: -
- 1965: -
- 1966: -
- 1967: -
- 1968: -
- 1969: -
- 1970: -
- 1971: -
- 1972: -
- 1973: -
- 1974: -

| ID | WBS | Task | Type | Duration | Start | Finish | Complete | Baseline start | Baseline finish | Baseline duration | Constraint | Deadline | Resources | Work | Actual work | Text1 | Text6 | Text8 | Text4 | Text5 | Text10 | Text12 |
| --- | --- | --- | --- | --- | --- | --- | --- | --- | --- | --- | --- | --- | --- | --- | --- | --- | --- | --- | --- | --- | --- | --- |
| 1975 | 28.1 | **MBMS User Services** |  | 743d? | 2003-05-13 A | 2006-03-16 A | 100% | 2003-05-13 | 2006-03-16 | 743d? |  |  | S1 | 13576h | 13576h | MBMS | Rel-6 | Alain |  |  |  |  |
| 1976 | 28.1 | MBMS User Services Stage 1 |  | 233d | 2003-05-13 A | 2004-04-01 A | 100% | 2003-05-13 | 2004-04-01 | 233d | start no earlier than 2003-05-13 |  | S1 | 1864h | 1864h | MBMS | Rel-6 | Alain |  |  |  |  |
| 1977 | 600.8.2 | Definition of MBMS user services, media codecs, formats and transport/application protocols using MBMS |  | 721d? | 2003-06-12 A | 2006-03-16 A | 100% | 2003-06-12 | 2006-03-16 | 721d? | finish no earlier than 2006-03-16 |  | S4 | 5768h | 5768h | MBMS-TSMBMS | Rel-6 | Paolo | Nokia | igor.curcio@nokia.com |  |  |
| 1978 | 600.9 | MBMS charging |  | 108d? | 2005-01-11 A | 2005-06-09 A | 100% | 2005-01-11 | 2005-06-09 | 108d? | start no earlier than 2005-01-11 |  | S5 | 864h | 864h | MBMS-CH | Rel-6 | Dionisio |  |  |  |  |
| 1979 | 600.10 | **MBMS UE Conformance Testing** |  | 521d? | 2006-03-10 A | 2008-03-07 A | 100% | 2006-03-10 | 2008-03-07 | 521d? |  |  | R5,T1 | 17200h | 17200h | MBMS-UEConTest | Rel-6 | Ingbert |  |  |  |  |
| 1980 | 16.5.1 | RF/RRM Conformance Test Aspects – MBMS (FDD) |  | 461d | 2006-06-02 A | 2008-03-07 A | 100% | 2006-06-02 | 2008-03-07 | 461d | finish no earlier than 2008-03-07 | 2006-06-02 | R5,T1 | 3688h | 3688h | MBMS-RAN-RF_Test | Rel-6 | Ingbert | Ericsson | leif.mattisson@ericsson.com | Fri 11/03/05 |  |
| 1981 | 600.10.2 | Conformance Test Aspects - MBMS for 3.84 Mcps and 7.68 Mcps TDD |  | 318d? | 2006-09-20 A | 2007-12-07 A | 100% | 2006-09-20 | 2007-12-07 | 318d? | finish no earlier than 2007-12-07 |  | R5,T1 | 2544h | 2544h | MBMS-UEConTest_TDH | Rel-6 | Ingbert | IPWireless | Timothy Speight (tspeight@ipwireless.com) |  |  |
| 1982 | 600.10.3 | Signalling Conformance Test Aspects – MBMS for LCR TDD |  | 318d? | 2006-09-20 A | 2007-12-07 A | 100% | 2006-09-20 | 2007-12-07 | 318d? | finish no earlier than 2007-12-07 |  | R5,T1 | 2544h | 2544h | MBMS-UEConTest_SIGTDL | Rel-6 | Ingbert | DATANG | zhaojian@datangmobile.cn |  |  |
| 1983 | 600.10.4 | Conformance Test Aspects – MBMS |  | 396d? | 2006-03-10 A | 2007-09-14 A | 100% | 2006-03-10 | 2007-09-14 | 396d? | finish no earlier than 2007-09-14 |  | R5,T1 | 3168h | 3168h | MBMS_Test | Rel-6 | Ingbert | Qualcomm | Shubhang Vora (svora@qualcomm.com) |  |  |
| 1984 | 16.5.1 | Conformance Test Aspects - 1.28 Mcps TDD MBMS RF/RRM |  | 136d | 2007-06-01 A | 2007-12-07 A | 100% | 2007-06-01 | 2007-12-07 | 136d | finish no earlier than 2007-12-07 | 2006-06-02 | R5,T1 | 1088h | 1088h | MBMS-UEConTest_RFTDL | Rel-6 | Ingbert | Datang Mobile | chenxiaozhong@datangmobile.cn | Fri 11/03/05 |  |
| 1985 | 29 | **Speech Recognition and Speech Enabled Services** |  | 1105d? | 2001-10-08 A | 2005-12-30 A | 100% | 2001-10-08 | 2005-12-30 | 1105d? |  |  | S1 | 20176h | 20176h | SRSES | Rel-6 | Alain |  |  |  |  |
| 1986 | 29.1 | Speech Enabled Services Based on Distributed Speech Recognition (DSR) |  | 115d | 2001-10-08 A | 2002-03-15 A | 100% | 2001-10-08 | 2002-03-15 | 115d | finish no earlier than 2002-03-15 |  | S1 | 920h | 920h | DSR | Rel-6 | Alain | Qualcomm | Dwilliams@qualcomm.com |  |  |
| 1987 | 29.2 | TR on Architectural impacts |  | 212d | 2003-05-12 A | 2004-03-02 A | 100% | 2003-05-12 | 2004-03-02 | 212d | finish no earlier than 2004-03-02 |  | S2 | 1696h | 1696h | SRSES | Rel-6 | Maurice |  |  |  |  |
| 1988 | 601.3 | Codec Work to Support Speech Recognition Framework for Automated Voice Services |  | 568d? | 2002-10-15 A | 2004-12-16 A | 100% | 2002-10-15 | 2004-12-16 | 568d? | finish no earlier than 2004-12-16 |  | S4 | 4544h | 4544h | SRSES-Codec | Rel-6 | Paolo | Motorola | David Pearce (bdp003@motorola.com) |  |  |
| 1989 | 601.4 | Multimodal support |  | 522d? | 2004-01-01 A | 2005-12-30 A | 100% | 2004-01-01 | 2005-12-30 | 522d? | finish no earlier than 2005-06-30 |  | OMA | 4176h | 4176h | SRSES | Rel-6 | Paolo |  | OMA-LIAISON@mail.openmobilealliance.org | SP-24 |  |
| 1990 | 601.5 | Deleted - SES codec negotiation at Session Description Protocol (SDP) | milestone | 0d? | 2003-06-04 A | 2003-06-04 A | 100% | 2003-06-04 | 2003-06-04 | 0d? | start no earlier than 2003-06-04 |  | N1 |  |  | SRSES | Rel-6 | Frederic |  |  |  | NP-23 |
| 1991 | 30 | **Generic User Profile Rel-6** |  | 889d | 2001-10-08 A | 2005-03-03 A | 100% | 2001-10-08 | 2005-03-03 | 889d |  |  | S1 | 24295.8h | 24295.8h | GUP | Rel-6 | Alain |  |  |  |  |
| 1992 | 30.1 | Stage 1 - Requirements |  | 430d | 2001-10-08 A | 2003-05-30 A | 100% | 2001-10-08 | 2003-05-30 | 430d | finish no earlier than 2002-12-09 |  | S1 | 3440h | 3440h | GUP | Rel-6 | Alain | T-Mobile | kurt.bischinger@t-mobile.at |  |  |
| 1993 | 30.3 | Stage 2 - Architecture |  | 355d | 2002-01-28 A | 2003-06-06 A | 100% | 2002-01-28 | 2003-06-06 | 355d | finish no earlier than 2003-06-06 |  | S2 | 2840h | 2840h | GUP | Rel-6 | Maurice | Nokia | harri.o.koskinen@nokia.com |  |  |
| 1994 | 30.2 | Stage 2 - Data Description Method |  | 586d | 2002-12-05 A | 2005-03-03 A | 100% | 2002-12-05 | 2005-03-03 | 586d | finish no earlier than 2005-03-03 |  | N4 | 4688h | 4688h | GUP | Rel-6 | Kimmo | T-Mobile | kurt.bischinger@t-mobile.at |  |  |
| 1995 | 30.5 | Stage 3 - Network |  | 468.98d | 2003-05-19 A | 2005-03-03 A | 100% | 2003-05-19 | 2005-03-03 | 468.98d | finish no earlier than 2005-03-03 |  | N4 | 3751.83h | 3751.83h | GUP | Rel-6 | Kimmo |  |  |  |  |
| 1996 | 30.6 | Security Aspects |  | 308d | 2002-07-16 A | 2003-09-18 A | 100% | 2002-07-16 | 2003-09-18 | 308d | finish no earlier than 2003-09-18 |  | S3 | 2464h | 2464h | GUP | Rel-6 | Dionisio | Lucent | Owen, Bradley (bvowen@lucent.com) |  |  |
| 1997 | 31 | **Digital Rights Management** |  | 690d? | 2001-10-08 A | 2004-05-28 A | 100% | 2001-10-08 | 2004-05-28 | 690d? |  |  | S1 | 10152h | 10152h | DRM | Rel-6 | Alain |  |  |  |  |
| 1998 | 31.1 | Requirements |  | 179d | 2001-10-08 A | 2002-06-13 A | 100% | 2001-10-08 | 2002-06-13 | 179d | finish no earlier than 2002-06-13 |  | S1 | 1432h | 1432h | DRM | Rel-6 | Alain | Openwave | nicholas.wood@openwave.com |  |  |
| 1999 | 603.2 | Stage 2 |  | 107d? | 2004-01-01 A | 2004-05-28 A | 100% | 2004-01-01 | 2004-05-28 | 107d? | finish no earlier than 2004-05-28 |  | OMA | 856h | 856h | DRM | Rel-6 |  |  | OMA-LIAISON@mail.openmobilealliance.org | SP-24 |  |
| 2000 | 603.3 | Stage 3 |  | 107d? | 2004-01-01 A | 2004-05-28 A | 100% | 2004-01-01 | 2004-05-28 | 107d? | finish no earlier than 2004-05-28 |  | OMA | 856h | 856h | DRM | Rel-6 |  |  | OMA-LIAISON@mail.openmobilealliance.org | SP-24 |  |
| 2001 | 31.3 | Security |  | 186d | 2002-06-17 A | 2003-03-03 A | 100% | 2002-06-17 | 2003-03-03 | 186d | finish no earlier than 2003-03-03 |  | OMA | 1488h | 1488h | DRM | Rel-6 |  |  |  |  |  |
| 2002 | 603.5 | Deleted - Monitoring of Stages 2 and 3 progress (actual work to be done by OMA) | milestone | 0d? | 2003-03-21 A | 2003-03-21 A | 100% | 2003-03-21 | 2003-03-21 | 0d? | start no earlier than 2002-08-19 |  | S1 |  |  | DRM | Rel-6 | Alain |  |  |  | SP-19 |

Notes:
- 1975: - / Text3: 22.246
- 1976: - / Text3: 22.246
- 1977: TR26.946 tbc by March 06 / Text3: 26.346, 26.936, 26.946
- 1978: SP#28 06/2005 completed / Text3: 32.273
- 1979: BB place holder for a number of RAN5 Tasks. Moved in from the Stoyan/Testing WP / Text3: 34.108, 34.109, 34.121-1, 34.121-2, 34.122, 34.123-1, 34.123-2, 34.123-3
- 1980: TS 34.109 is under RAN2; RAN5 need to identify possible new requirements on UE test loop functionality to enable testing / Text3: 34.108, 34.109, 34.121-1, 34.121-2
- 1981: - / Text3: 34.108, 34.122, 34.123-1, 34.123-2, 34.123-3
- 1982: - / Text3: 34.108, 34.123-1, 34.123-2, 34.123-3
- 1983: - / Text3: 34.108, 34.123-1, 34.123-2, 34.123-3
- 1984: - / Text3: 34.108, 34.109, 34.122
- 1985: -
- 1986: - / Text3: 22.977, 22.941, 23.207, 22.243
- 1987: - / Text3: 23.877
- 1988: - / Text3: 26.235, 26.236, 26.243, 26.177, 26.943
- 1989: -
- 1990: Abandoned NP-23
- 1991: -
- 1992: - / Text3: 22.240, 22.228
- 1993: - / Text3: 23.240
- 1994: TR approved in CN#26 / Text3: 23.241
- 1995: - / Text3: 29.240
- 1996: WID approved SP#17. SA WG3 progress slow, depends on progress in other groups. / Text3: 33.102, 33.203, 33.210
- 1997: Foreseen start and completion dates introduced by MCC (no indication at all on the WID)
- 1998: -
- 1999: -
- 2000: -
- 2001: SA3 acknowledge role in WI at SA3#20. Active contribution S3#24, S3#25. S3 WID approved SP#17
- 2002: Replaced by UID 60005 and 60006

| ID | WBS | Task | Type | Duration | Start | Finish | Complete | Baseline start | Baseline finish | Baseline duration | Constraint | Deadline | Resources | Work | Actual work | Text1 | Text4 | Text5 | Text6 | Text8 | Text3 | Text10 |
| --- | --- | --- | --- | --- | --- | --- | --- | --- | --- | --- | --- | --- | --- | --- | --- | --- | --- | --- | --- | --- | --- | --- |
| 2003 | 32 | **WLAN-UMTS Interworking Rel-6** |  | 1495d? | 2000-01-03 A | 2005-09-22 A | 100% | 2000-01-03 | 2005-09-22 | 1495d? |  |  | S1 | 45472h | 45472h | WLAN | Telenor | frederic.paint@telenor.com | Rel-6 | Alain |  |  |
| 2004 | 32.1 | Technical Report |  | 901d? | 2000-01-03 A | 2003-06-13 A | 100% | 2000-01-03 | 2003-06-13 | 901d? | finish no earlier than 2003-06-13 |  | S1 | 7200h | 7200h | WLAN-TR | T-mobile | Mark.Younge@t-mobile.com | Rel-6 | Alain | 22.934 |  |
| 2005 | 604.2 | Stage 1 |  | 375d? | 2003-01-06 A | 2004-06-11 A | 100% | 2003-01-06 | 2004-06-11 | 375d? |  |  | S1 | 920h | 920h | WLAN-TS | Telenor | frederic.paint@telenor.com | Rel-6 | Alain | 22.101, 22.105 | SP-24 |
| 2006 | 32.2 | Architecture Definition for scenarii 2 and 3 |  | 571d | 2002-03-25 A | 2004-05-31 A | 100% | 2002-03-25 | 2004-05-31 | 571d | finish no earlier than 2004-05-31 |  | S2 | 4568h | 4568h | WLAN |  |  | Rel-6 | Maurice | 23.234 |  |
| 2007 | 32.3 | Security |  | 125d | 2002-09-30 A | 2003-03-21 A | 100% | 2002-09-30 | 2003-03-21 | 125d | finish no earlier than 2003-03-21 |  | S3 | 1000h | 1000h | WLAN | Ericsson | luis.lopez-soria@ece.ericsson.se | Rel-6 | Dionisio | 21.133, 33.106, 33.107, 33.108, 33.200, 33.203, 33.210 |  |
| 2008 | 604.5 | Stage 3 - CN4 aspects |  | 334d? | 2003-05-23 A | 2004-09-01 A | 100% | 2003-05-23 | 2004-09-01 | 334d? | finish no earlier than 2004-09-01 |  | N4 | 2672h | 2672h | WLAN-IW | Nokia | raquel.rodriguez@nokia.com | Rel-6 | Kimmo | 29.234, 29.061 |  |
| 2009 | 604.6 | Stage 3 - CN3 aspects (Wi Interface for Scenario 3) |  | 355d? | 2003-05-23 A | 2004-09-30 A | 100% | 2003-05-23 | 2004-09-30 | 355d? | start no earlier than 2003-05-23 |  | N3 | 2840h | 2840h | WLAN |  |  | Rel-6 | Gwiho | 29.161 | SP-24 |
| 2010 | 604.7 | Stage 3 for scenario 2 |  | 339d? | 2003-05-23 A | 2004-09-08 A | 100% | 2003-05-23 | 2004-09-08 | 339d? | finish no earlier than 2004-09-08 |  | N1 | 2712h | 2712h | WLAN |  |  | Rel-6 | Frederic |  |  |
| 2011 | 604.8 | Stage 3 for scenario 3 |  | 404d? | 2003-05-23 A | 2004-12-08 A | 100% | 2003-05-23 | 2004-12-08 | 404d? | finish no earlier than 2004-12-08 |  | N1 | 3232h | 3232h | WLAN |  |  | Rel-6 | Frederic |  | SP-24 |
| 2012 | 604.9 | WLAN charging |  | 655d? | 2003-03-21 A | 2005-09-22 A | 100% | 2003-03-21 | 2005-09-22 | 655d? | finish no earlier than 2005-09-22 |  | S5 | 5240h | 5240h | WLAN-CH | Nokia | Benni ALEXANDER | Rel-6 | Dionisio | 32.252 |  |
| 2013 | 604.10 | USIM enhancements for WLAN Interworking |  | 391d? | 2003-09-05 A | 2005-03-04 A | 100% | 2003-09-05 | 2005-03-04 | 391d? | finish no earlier than 2005-03-04 |  | T3 | 3128h | 3128h | WLAN | Axalto | Jabellan@axalto.com | Rel-6 | Xavier |  |  |
| 2014 | 33 | **Priority Service** |  | 347d? | 2002-05-30 A | 2003-09-26 A | 100% | 2002-05-30 | 2003-09-26 | 347d? |  |  | S1 | 6464h | 6464h | PRIOR1 | Telcordia | James Garrahan (jgarraha@telcordia.com) | Rel-6 | Alain |  |  |
| 2015 | 33.1 | Feasibility Study |  | 1d | 2002-06-14 A | 2002-06-14 A | 100% | 2002-06-14 | 2002-06-14 | 1d | finish no earlier than 2002-06-14 |  | S1 | 8h | 8h | PRIOR-FS | Telcordia | James Garrahan (jgarraha@telcordia.com) | Rel-6 | Alain | 22.950 |  |
| 2016 | 33.2 | Stage 1 - Requirements |  | 340d | 2002-05-30 A | 2003-09-17 A | 100% | 2002-05-30 | 2003-09-17 | 340d | finish no earlier than 2003-09-17 |  | S1 | 2720h | 2720h | PRIOR-SR | Telcordia | James Garrahan (jgarraha@telcordia.com) | Rel-6 | Alain |  |  |
| 2017 | 605.3 | Priority service implementation guide |  | 131d? | 2003-03-28 A | 2003-09-26 A | 100% | 2003-03-28 | 2003-09-26 | 131d? | finish no earlier than 2003-09-26 |  | S1 | 1048h | 1048h | PRIOR1 | Telcordia | James Garrahan (jgarraha@telcordia.com) | Rel-6 | Alain | 22.952 |  |
| 2018 | 34 | **Network Sharing** |  | 820d? | 2003-01-20 A | 2006-03-10 A | 100% | 2003-01-20 | 2006-03-10 | 820d? |  |  | S1,S2,N1,R2,R5 | 18696h | 18696h | NTShar | T-Mobile | michele.zarri@t-mobile.co.uk | Rel-6 | Alain |  |  |
| 2019 | 34.1 | Technical Report |  | 240d? | 2003-01-20 A | 2003-12-19 A | 100% | 2003-01-20 | 2003-12-19 | 240d? |  |  | S1 | 1920h | 1920h | NTShar-TR | T-Mobile | michele.zarri@t-mobile.co.uk | Rel-6 | Alain | 22.951 |  |
| 2020 | 606.2 | Stage 1 - CRs to implement Network Sharing |  | 240d? | 2003-01-20 A | 2003-12-19 A | 100% | 2003-01-20 | 2003-12-19 | 240d? | finish no earlier than 2003-12-19 |  | S1 | 1920h | 1920h | NTSharCR | T-Mobile | michele.zarri@t-mobile.co.uk | Rel-6 | Alain | 22.011, 22.101, 22.115, 22.129 |  |
| 2021 | 606.3 | Stage 2 |  | 372d? | 2003-02-27 A | 2004-07-30 A | 100% | 2003-02-27 | 2004-07-30 | 372d? | finish no earlier than 2004-07-30 |  | S2 | 2976h | 2976h | NTShar | T-Mobile | michele.zarri@t-mobile.co.uk | Rel-6 | Maurice | 23.002, 23.060, 23.221, 23.236, new 23.251 |  |
| 2022 | 606.4 | Network sharing - stage 3 |  | 404d? | 2003-05-23 A | 2004-12-08 A | 100% | 2003-05-23 | 2004-12-08 | 404d? | finish no earlier than 2004-12-08 |  | N1 | 3232h | 3232h | NTShar | T-Mobile | michele.zarri@t-mobile.co.uk | Rel-6 | Frederic | 23.008, 23.122, 24.007, 24.008, 29.018 |  |
| 2023 | 606.5 | Enhancement of the support of network sharing in the UTRAN | milestone | 0d | 2003-09-19 A | 2003-09-19 A | 100% | 2003-09-19 | 2003-09-19 | 0d |  |  | R2 |  |  | NTShar-UTRANEnh | TeliaSonera | Anders.Dahlen@TeliaSonera.com | Rel-6 | Joern | 25.401, 25.413, 25.331, 25.304 |  |
| 2024 | 16.5.1 | Conformance Test Aspects – Network Sharing |  | 261d | 2005-03-11 A | 2006-03-10 A | 100% | 2005-03-11 | 2006-03-10 | 261d | finish no earlier than 2006-03-10 | 2006-03-10 | R5 | 2088h | 2088h | NTShar-UTRANEnh_Test | TeliaSonera | Niklas.Wiren@TeliaSonera.com | Rel-6 | Ingbert | 34.108, 34.123-1, 34.123-2, 34.123-3 | Fri 11/03/05 |
| 2025 | 35 | **QoS Improvements** |  | 628d? | 2002-07-15 A | 2004-12-08 A | 100% | 2002-07-15 | 2004-12-08 | 628d? |  |  | S2,N3 | 13128h | 13128h | QoS1 | Nokia |  | Rel-6 | Maurice | 23.107, 23.207, 23.221 |  |
| 2026 | 35.1 | FS on Dynamic Policy control enhancements for end-to-end QoS |  | 465d | 2002-07-15 A | 2004-04-23 A | 100% | 2002-07-15 | 2004-04-23 | 465d | finish no earlier than 2004-04-23 |  | S2 | 3720h | 3720h | QoS1 | Nortel | Claire Mousset | Rel-6 | Maurice | 23.917 withdrawn (Contents all in 23.207) |  |
| 2027 | 607.2 | Definition of the Gq interface |  | 214d? | 2003-07-01 A | 2004-04-23 A | 100% | 2003-07-01 | 2004-04-23 | 214d? | finish no earlier than 2004-04-23 |  | S2 | 1712h | 1712h | QoS1 |  | Janne Rinne | Rel-6 | Maurice | 23.207 |  |
| 2028 | 607.3 | Gq interface specification for Dynamic Policy control enhancements – Stage 3 |  | 334d | 2003-08-29 A | 2004-12-08 A | 100% | 2003-08-29 | 2004-12-08 | 334d | finish no earlier than 2004-12-08 |  | N3 | 2672h | 2672h | QoS1 | Nokia | Anna.Sillanpaai@nokia.com | Rel-6 | Gwiho | 29.207, 29.208, 29.209 |  |

Notes:
- 2003: -
- 2004: -
- 2005: -
- 2006: -
- 2007: Active contribution S3#24, S3#25. WID approved SP#17
- 2008: WID approved at CN#19
- 2009: -
- 2010: -
- 2011: -
- 2012: SP#28: delayed 09/2005. WT also under SA5 BB 35017 Charging Management for Bearer level
- 2013: -
- 2014: -
- 2015: -
- 2016: -
- 2017: -
- 2018: -
- 2019: -
- 2020: -
- 2021: -
- 2022: -
- 2023: -
- 2024: -
- 2025: -
- 2026: -
- 2027: -
- 2028: [DAB - 25.05.04] - Delayed to Sept - possibly Dec 2004

| ID | WBS | Task | Type | Duration | Start | Finish | Complete | Baseline start | Baseline finish | Baseline duration | Constraint | Resources | Work | Actual work | Text1 | Text4 | Text5 | Text6 | Text8 | Text10 | Text12 |
| --- | --- | --- | --- | --- | --- | --- | --- | --- | --- | --- | --- | --- | --- | --- | --- | --- | --- | --- | --- | --- | --- |
| 2029 | 36 | **Subscriber certificates** |  | 728d? | 2002-02-25 A | 2004-12-08 A | 100% | 2002-02-25 | 2004-12-08 | 728d? |  | S3,S2,N1,N4,T3,OMA | 12888h | 12888h | SEC1-SC | Nokia | valtteri.niemi@nokia.com | Rel-6 | Dionisio |  |  |
| 2030 | 36.1 | Stage 1 |  | 144d | 2002-02-25 A | 2002-09-12 A | 100% | 2002-02-25 | 2002-09-12 | 144d | finish no earlier than 2002-09-12 | S3 | 1152h | 1152h | SEC1-SC | Nokia | valtteri.niemi@nokia.com | Rel-6 | Dionisio |  |  |
| 2031 | 36.2 | Architecture review |  | 24d | 2002-10-14 A | 2002-11-14 A | 100% | 2002-10-14 | 2002-11-14 | 24d | finish no earlier than 2002-11-14 | S2 | 192h | 192h | SEC1-SC | Nokia |  | Rel-6 | Maurice |  |  |
| 2032 | 608.3 | Stage 3 |  | 313d? | 2003-09-19 A | 2004-11-30 A | 100% | 2003-09-19 | 2004-11-30 | 313d? | finish no earlier than 2004-11-30 | N4,T3 | 2504h | 2504h | SEC1-SC | Nokia | Lauri Laitinen | Rel-6 | Kimmo |  |  |
| 2033 | 608.4 | Stage 3 Ua & Ub interfaces |  | 288d? | 2003-11-03 A | 2004-12-08 A | 100% | 2003-11-03 | 2004-12-08 | 288d? | finish no earlier than 2004-12-08 | N1 | 2304h | 2304h | SEC1-SC | Nokia |  | Rel-6 | Frederic |  |  |
| 2034 | 608.5 | OMA dependencies on Subscriber certificates |  | 114d? | 2004-01-01 A | 2004-06-08 A | 100% | 2004-01-01 | 2004-06-08 | 114d? | finish no earlier than 2004-06-08 | OMA | 912h | 912h | SEC1-SC | Nokia | OMA-LIAISON@mail.openmobilealliance.org | Rel-6 |  | SP-24 |  |
| 2035 | 609 | **Rel-6 OSA enhancements** |  | 616d? | 2002-10-31 A | 2005-03-10 A | 100% | 2002-10-31 | 2005-03-10 | 616d? |  | N5 | 22576h | 22576h | OSA3 | Alcatel | Chelo.Abarca@alcatel.fr | Rel-6 | Kimmo |  |  |
| 2036 | 609.1 | Scope of the Open Service Access Release 6 |  | 66d? | 2003-03-28 A | 2003-06-27 A | 100% | 2003-03-28 | 2003-06-27 | 66d? | finish no earlier than 2003-06-27 | S1 | 528h | 528h | OSA3 |  |  | Rel-6 | Alain |  |  |
| 2037 | 609.2 | OSA Stage 2 |  | 150d? | 2004-08-13 A | 2005-03-10 A | 100% | 2004-08-13 | 2005-03-10 | 150d? | finish no earlier than 2005-03-10 | N5 | 1200h | 1200h | OSA3 |  |  | Rel-6 | Kimmo |  |  |
| 2038 | 609.3 | Multi Media Messaging function |  | 487d? | 2002-10-31 A | 2004-09-10 A | 100% | 2002-10-31 | 2004-09-10 | 487d? | finish no earlier than 2004-09-10 | N5 | 3896h | 3896h | OSA3 |  |  | Rel-6 | Kimmo |  |  |
| 2039 | 609.4 | Policy management extensions |  | 292d? | 2002-10-31 A | 2003-12-12 A | 100% | 2002-10-31 | 2003-12-12 | 292d? | finish no earlier than 2003-12-12 | N5 | 2336h | 2336h | OSA3 |  |  | Rel-6 | Kimmo |  |  |
| 2040 | 609.5 | TS on Presence and Availability Management (from the PRESNC WI) |  | 367d? | 2002-10-31 A | 2004-03-26 A | 100% | 2002-10-31 | 2004-03-26 | 367d? | finish no earlier than 2004-03-26 | N5 | 2936h | 2936h | OSA3 |  |  | Rel-6 | Kimmo |  |  |
| 2041 | 609.6 | OSA interfaces at different levels of abstractions (Parlay X, Web services) |  | 305d? | 2003-07-14 A | 2004-09-10 A | 100% | 2003-07-14 | 2004-09-10 | 305d? | finish no earlier than 2004-09-10 | N5 | 2440h | 2440h | OSA3 |  |  | Rel-6 | Kimmo |  |  |
| 2042 | 609.7 | Introduction of migration support mechanism |  | 290d? | 2002-10-31 A | 2003-12-10 A | 100% | 2002-10-31 | 2003-12-10 | 290d? | finish no earlier than 2003-12-12 | N5 | 2320h | 2320h | OSA3 |  |  | Rel-6 | Kimmo |  |  |
| 2043 | 609.8 | Framework Function for Federation |  | 225d? | 2003-02-03 A | 2003-12-12 A | 100% | 2003-02-03 | 2003-12-12 | 225d? | finish no earlier than 2003-12-12 | N5 | 1800h | 1800h | OSA3 |  |  | Rel-6 | Kimmo |  |  |
| 2044 | 609.9 | OMA potential overlaps with 3GPP OSA Stage 3 (Web services) |  | 196d? | 2003-12-18 A | 2004-09-16 A | 100% | 2003-12-18 | 2004-09-16 | 196d? | start no earlier than 2003-12-18 | OMA | 1568h | 1568h | OSA3 |  |  | Rel-6 |  | SP-24 |  |
| 2045 | 609.10 | Deleted - TR on Presence and Availability Management (from the PRESNC WI) | milestone | 0d? | 2004-09-17 A | 2004-09-17 A | 100% | 2004-09-17 | 2004-09-17 | 0d? | start no earlier than 2004-09-17 | N5 |  |  | OSA3 |  |  | Rel-6 | Kimmo |  | NP-24 |
| 2046 | 39 | **Addition of frequency bands to GSM (TAPS)** |  | 676d | 2002-06-28 A | 2005-01-28 A | 100% | 2002-06-28 | 2005-01-28 | 676d |  | GP | 16640h | 16640h | TAPS | Nokia | Torben Themsen | Rel-6 | Paolo |  |  |
| 2047 | 39.1 | **Addition of frequency bands to GSM – Changes to core specs** |  | 26d | 2002-11-15 A | 2002-12-20 A | 100% | 2002-11-15 | 2002-12-20 | 26d |  | G1 | 416h | 416h | TAPS-Specs | Nokia | Torben Themsen | Rel-6 | Paolo |  |  |
| 2048 | 39.1.1 | Changes to core specs |  | 26d | 2002-11-15 A | 2002-12-20 A | 100% | 2002-11-15 | 2002-12-20 | 26d | finish no earlier than 2002-12-20 | G1 | 208h | 208h | TAPS-Specs | Nokia | Torben Themsen | Rel-6 | Paolo |  |  |
| 2049 | 39.2 | **Deleted - Addition of frequency bands to GSM – Changes for conformance tests** |  | 676d | 2002-06-28 A | 2005-01-28 A | 100% | 2002-06-28 | 2005-01-28 | 676d |  | G4 | 10816h | 10816h | TAPS-Conf | Nokia | Torben Themsen | Rel-6 | Paolo |  | GP-23 |
| 2050 | 39.2.1 | Deleted - 51.010-1 Add testing |  | 676d | 2002-06-28 A | 2005-01-28 A | 100% | 2002-06-28 | 2005-01-28 | 676d | finish no earlier than 2005-01-28 | G4 | 5408h | 5408h | TAPS-Conf | Nokia | Torben Themsen | Rel-6 | Paolo |  | GP-23 |
| 2051 | 40 | **Seamless support of streaming services in A/Gb mode** |  | 1426d? | 2000-01-03 A | 2005-06-17 A | 100% | 2000-01-03 | 2005-06-17 | 1426d? |  | GP | 53096h | 53096h | SSStrea | Vodafone | José Luis Carrizo Martínez | Rel-6 | Paolo |  |  |
| 2052 | 40.1 | **Identification of requirements for streaming** |  | 46d? | 2003-06-27 A | 2003-08-29 A | 100% | 2003-06-27 | 2003-08-29 | 46d? |  | G1 | 736h | 736h | SSStrea | Vodafone | José Luis Carrizo Martínez | Rel-6 | Paolo |  |  |
| 2053 | 611.1.1 | Requirements |  | 46d? | 2003-06-27 A | 2003-08-29 A | 100% | 2003-06-27 | 2003-08-29 | 46d? | finish no earlier than 2003-08-29 | G1 | 368h | 368h | SSStrea | Vodafone | José Luis Carrizo Martínez | Rel-6 | Paolo |  |  |

Notes:
- 2029: Approved at SP#14. May require BBs from CN1, CN4, SA5 and T3
- 2030: Contribution received S3#24, S3#25 / Text3: 33.220, 33.221, 33.222, 33.246, new TR 33.919
- 2031: -
- 2032: Finished in CN4#26 / Text3: 23.003, 23.008, 29.109, 29.230, T3 31.102, 31.103, 31.111
- 2033: - / Text3: 24.109
- 2034: Updated according to SP-040420
- 2035: CN#25: Updated WID NP-040351 replaces NP-040144. / Text3: 22.127, 23.198, 29.198, 29.199, 29.998
- 2036: -
- 2037: Inherited by CN5 from SA2 at TSG#25 Sep 2004. SA2's 23.127 (OSA/VHE Stage 2) replaced from Rel-6 onwards by a new CN5 TS 23.198 (Stage 2 OSA-only). / Text3: 23.198 OSA Stage 2-ONLY replaces 23.127 (OSA/VHE) from Rel-6 onwards
- 2038: - / Text3: 29.198-15
- 2039: - / Text3: 29.198, 29.998
- 2040: N5#26: Split WI into TS & TR. / Text3: 29.198-14
- 2041: - / Text3: 29.199
- 2042: - / Text3: 29.198, 29.998
- 2043: - / Text3: 29.198, 29.998
- 2044: TSG#25 Approved CN5 29.199 Parlay X Web services. Ongoing 3GPP/OMA co-ordination to avoid OMA producing conflicting/OVERLAPING specs (NP-040283/SP-040493).
- 2045: N5#26:TR Completion 09/04; consistent with CN1 delayed Rel-6 completion.
- 2046: -
- 2047: -
- 2048: -
- 2049: -
- 2050: -
- 2051: -
- 2052: -
- 2053: -

| ID | WBS | Task | Duration | Start | Finish | Complete | Baseline start | Baseline finish | Baseline duration | Constraint | Resources | Work | Actual work | Text1 | Text4 | Text5 | Text6 | Text8 | Text12 |
| --- | --- | --- | --- | --- | --- | --- | --- | --- | --- | --- | --- | --- | --- | --- | --- | --- | --- | --- | --- |
| 2054 | 40.2 | **Performance study of cell change mechanisms** | 956d? | 2000-01-03 A | 2003-08-29 A | 100% | 2000-01-03 | 2003-08-29 | 956d? |  | G1 | 30568h | 30568h | SSStrea | Vodafone | José Luis Carrizo Martínez | Rel-6 | Paolo |  |
| 2055 | 611.2.1 | Performance of NACC | 956d? | 2000-01-03 A | 2003-08-29 A | 100% | 2000-01-03 | 2003-08-29 | 956d? | finish no earlier than 2003-08-29 | G1 | 7640h | 7640h | SSStrea | Vodafone | José Luis Carrizo Martínez | Rel-6 | Paolo |  |
| 2056 | 611.2.2 | Performance of cell change in DTM for the PS domain | 956d? | 2000-01-03 A | 2003-08-29 A | 100% | 2000-01-03 | 2003-08-29 | 956d? | finish no earlier than 2003-08-29 | G1 | 7640h | 7640h | SSStrea | Vodafone | José Luis Carrizo Martínez | Rel-6 | Paolo |  |
| 2057 | 611.2.3 | Handover | 956d? | 2000-01-03 A | 2003-08-29 A | 100% | 2000-01-03 | 2003-08-29 | 956d? | finish no earlier than 2003-08-29 | G1 | 7640h | 7640h | SSStrea | Vodafone | José Luis Carrizo Martínez | Rel-6 | Paolo |  |
| 2058 | 40.3 | **Reduction of service interruption times and packet loss during mobility procedures** | 516d? | 2003-06-27 A | 2005-06-17 A | 100% | 2003-06-27 | 2005-06-17 | 516d? |  | G2 | 10800h | 10800h | SSStrea | Vodafone | José Luis Carrizo Martínez | Rel-6 | Gert |  |
| 2059 | 611.3.1 | optimizations of existing mechanisms/procedures | 106d? | 2003-06-27 A | 2003-11-21 A | 100% | 2003-06-27 | 2003-11-21 | 106d? | finish no earlier than 2003-11-21 | G2 | 848h | 848h | SSStrea | Vodafone | José Luis Carrizo Martínez | Rel-6 | Gert |  |
| 2060 | 611.3.2 | Inter-system NACC | 106d? | 2003-06-27 A | 2003-11-21 A | 100% | 2003-06-27 | 2003-11-21 | 106d? | finish no earlier than 2003-11-21 | G2 | 848h | 848h | SSStrea | Vodafone | José Luis Carrizo Martínez | Rel-6 | Gert |  |
| 2061 | 611.3.3 | PS Handover (within GERAN and between GERAN and UTRAN) | 516d? | 2003-06-27 A | 2005-06-17 A | 100% | 2003-06-27 | 2005-06-17 | 516d? | finish no earlier than 2003-11-21 | G2 | 4128h | 4128h | SSStrea | Vodafone | José Luis Carrizo Martínez | Rel-6 | Gert |  |
| 2062 | 611.3.4 | Dependency to other features | 106d? | 2003-06-27 A | 2003-11-21 A | 100% | 2003-06-27 | 2003-11-21 | 106d? | finish no earlier than 2003-11-21 | G2 | 848h | 848h | SSStrea | Vodafone | José Luis Carrizo Martínez | Rel-6 | Gert |  |
| 2063 | 40.5 | **Deleted - MS conformance testing** | 31d? | 2003-12-19 A | 2004-01-30 A | 100% | 2003-12-19 | 2004-01-30 | 31d? |  | G3new | 248h | 248h | SSStrea | Vodafone | José Luis Carrizo Martínez | Rel-6 | Ingbert | GP-27 |
| 2064 | 611.4.1 | Deleted - MS conformance tests | 31d? | 2003-12-19 A | 2004-01-30 A | 100% | 2003-12-19 | 2004-01-30 | 31d? | finish no earlier than 2004-01-30 | G4,G5 | 248h | 248h | SSStrea | Vodafone | José Luis Carrizo Martínez | Rel-6 | Ingbert | GP-27 |
| 2065 | 611.5 | GERAN A/Gb mode security enhancements | 612d? | 2002-09-26 A | 2005-01-28 A | 100% | 2002-09-26 | 2005-01-28 | 612d? | finish no earlier than 2005-01-28 | S3 | 4896h | 4896h | SSStrea | Vodafone | peter.howard@vodafone.com | Rel-6 | Dionisio |  |
| 2066 | 41 | Performance characterisation of default codecs for PS conversational multimedia application | 455d | 2002-09-13 A | 2004-06-10 A | 100% | 2002-09-13 | 2004-06-10 | 455d | finish no earlier than 2004-06-10 | S4 | 3640h | 3640h | CODCAR | Nokia | pasi.s.ojala@nokia.com | Rel-6 | Paolo |  |
| 2067 | 43 | Study on Privacy Capability | 83d | 2003-11-10 A | 2004-03-03 A | 100% | 2003-11-10 | 2004-03-03 | 83d | start no earlier than 2003-11-10 | S1 | 664h | 664h | PrivCap | Lucent | Michael Boote (mboote@alcatel-lucent.com) | Rel-6 | Alain |  |
| 2068 | 44 | **Rel-6 Operations, Administration, Maintenance and Provisioning (OAM&P)** | 652d? | 2002-09-12 A | 2005-03-11 A | 100% | 2002-09-12 | 2005-03-11 | 652d? |  | S5 | 30819.5h | 30819.5h | OAM | Motorola |  | Rel-6 | Dionisio |  |
| 2069 | 44.1 | Principles, high level Requirements and Architecture | 526d | 2002-09-12 A | 2004-09-16 A | 100% | 2002-09-12 | 2004-09-16 | 526d | finish no earlier than 2004-09-16 | S5 | 4208h | 4208h | OAM-AR | Motorola |  | Rel-6 | Dionisio |  |
| 2070 | 44.2 | Performance Management | 591d | 2002-09-12 A | 2004-12-16 A | 100% | 2002-09-12 | 2004-12-16 | 591d | finish no earlier than 2004-12-16 | S5 | 4728h | 4728h | OAM-PM | Nortel |  | Rel-6 | Dionisio |  |
| 2071 | 44.4 | Network Infrastructure Management | 591d | 2002-09-12 A | 2004-12-16 A | 100% | 2002-09-12 | 2004-12-16 | 591d | finish no earlier than 2004-12-16 | S5 | 4728h | 4728h | OAM-NIM | Ericsson | thomas.tovinger@ericsson.com | Rel-6 | Dionisio |  |
| 2072 | 44.5 | **Trace Management Rel-6** | 646d? | 2002-09-20 A | 2005-03-11 A | 100% | 2002-09-20 | 2005-03-11 | 646d? |  | S5 | 12061.9h | 12061.9h | OAM-Trace | Nokia | kari.t.ronka@nokia.com | Rel-6 | Dionisio |  |
| 2073 | 614.4.1 | Subscriber and UE trace management | 585d | 2002-09-20 A | 2004-12-16 A | 100% | 2002-09-20 | 2004-12-16 | 585d | finish no earlier than 2004-12-16 | S5 | 4680h | 4680h | OAM-Trace | Nokia | kari.t.ronka@nokia.com | Rel-6 | Dionisio |  |
| 2074 | 614.4.2 | Subscriber and equipment trace in UTRAN | 268d? | 2003-06-06 A | 2004-06-15 A | 100% | 2003-06-06 | 2004-06-15 | 268d? | finish no earlier than 2004-06-15 | R3 | 2144h | 2144h | OAM-Trace-RAN | Nortel | Yann Sehedi (sehedic@nortelnetworks.com) | Rel-6 | Juha |  |
| 2075 | 614.4.3 | Trace Management, Stage3 | 193.74d? | 2004-06-09 A | 2005-03-11 A | 100% | 2004-06-09 | 2005-03-11 | 193.74d? | finish no earlier than 2005-03-11 | N4 | 1549.92h | 1549.92h | OAM-Trace | Nokia | seppo.kauntola@nokia.com | Rel-6 | Kimmo |  |
| 2076 | 615 | **Rel-6 Charging Management** | 666d? | 2002-11-21 A | 2005-06-09 A | 100% | 2002-11-21 | 2005-06-09 | 666d? |  | S5 | 55320h | 55320h | CH | T-Mobile | karl-heinz.nenner@t-mobile.de | Rel-6 | Dionisio |  |
| 2077 | 615.1 | Charging architecture and principles | 390d? | 2003-03-21 A | 2004-09-16 A | 100% | 2003-03-21 | 2004-09-16 | 390d? | start no earlier than 2003-03-21 | S5 | 3120h | 3120h | CH |  |  | Rel-6 | Dionisio |  |
| 2078 | 615.2 | Charging Data Record (CDR) file format and transfer | 260d? | 2003-03-21 A | 2004-03-18 A | 100% | 2003-03-21 | 2004-03-18 | 260d? | start no earlier than 2003-03-21 | S5 | 2080h | 2080h | CH |  |  | Rel-6 | Dionisio |  |
| 2079 | 615.3 | CDR parameter description | 580d? | 2003-03-21 A | 2005-06-09 A | 100% | 2003-03-21 | 2005-06-09 | 580d? | finish no earlier than 2005-06-09 | S5 | 4640h | 4640h | CH |  |  | Rel-6 | Dionisio |  |
| 2080 | 615.4 | Diameter charging applications | 390d? | 2003-03-21 A | 2004-09-16 A | 100% | 2003-03-21 | 2004-09-16 | 390d? | start no earlier than 2003-03-21 | S5 | 3120h | 3120h | CH |  |  | Rel-6 | Dionisio |  |
| 2081 | 615.5 | Online Charging System (OCS) architecture study | 130d? | 2003-03-21 A | 2003-09-18 A | 100% | 2003-03-21 | 2003-09-18 | 130d? | start no earlier than 2003-03-21 | S5 | 1040h | 1040h | CH |  |  | Rel-6 | Dionisio |  |
| 2082 | 615.6 | OCS: Applications and interfaces | 455d? | 2003-03-21 A | 2004-12-16 A | 100% | 2003-03-21 | 2004-12-16 | 455d? | start no earlier than 2003-03-21 | S5 | 3640h | 3640h | CH |  |  | Rel-6 | Dionisio |  |

Notes:
- 2054: -
- 2055: -
- 2056: -
- 2057: -
- 2058: Completed at GERP#17
- 2059: -
- 2060: -
- 2061: -
- 2062: -
- 2063: Marked as stopped 10/2009
- 2064: Marked as stopped 10/2009
- 2065: Possible changes to 33.102 or new specification needed / Text3: 33.102
- 2066: - / Text3: 26.935
- 2067: - / Text3: 22.949
- 2068: SP#26: Updated WID SP-040766 was SP-020445. Completion delayed 12/04->03/05 due to OAM-Trace in CN1/4.
- 2069: SP#25 09/2004 completed / Text3: 32.101, 32.102
- 2070: SP#26 12/2004 completed / Text3: 32.401, 32.403, 52.402, 32.411, 32.412, 32.413, 32.432, 32.435, 32.436
- 2071: SP#26 12/2004 completed / Text3: 32.150/1/2, 32.805, 32.111-5, 32.313/4, 32.331/2/3/4/5, 32.341/2/3/4, 32.351/2/3/4, 32.361/2/3/4, 32.371/2/3/4, 32.804, 32.675, 32.690, 32.695, 32.71/2/3/4/5, 32.741/2/3/4/5
- 2072: SP#26 12/2004 SA5 completed 12/04. Signalling Based Trace Activation for IMS (SIP) moved to Rel-7. Reason: CN1 cannot complete 24.229 trace without IETF dependency => estimate 05/2005.
- 2073: SP#26 12/2004 completed / Text3: 32.421, 32.422, 32.423, 52.008
- 2074: - / Text3: 25.413, 25.420, 25.423
- 2075: - / Text3: 23.205, 29.232, 29.060, 29.002, 29.228
- 2076: SP#28 Target 09/2005 for WLAN Charging 32.252 / Text3: 32.2xy
- 2077: SP#25 09/2004 completed / Text3: 32.240
- 2078: SP#23 03/2004 completed / Text3: 32.297
- 2079: SP#28 06/2005 completed / Text3: 32.298
- 2080: SP#25 09/2004 completed / Text3: 32.299
- 2081: SP#21 09/2003 completed / Text3: 32.815
- 2082: SP#26 12/2004 completed / Text3: 32.296

| ID | WBS | Task | Duration | Start | Finish | Complete | Baseline start | Baseline finish | Baseline duration | Constraint | Resources | Work | Actual work | Text1 | Text4 | Text5 | Text6 | Text8 | Text10 | Text12 |
| --- | --- | --- | --- | --- | --- | --- | --- | --- | --- | --- | --- | --- | --- | --- | --- | --- | --- | --- | --- | --- |
| 2083 | 615.7 | **Charging Management for Bearer level** | 390d? | 2003-03-21 A | 2004-09-16 A | 100% | 2003-03-21 | 2004-09-16 | 390d? |  | S5 | 11440h | 11440h | CH-BC | Nokia | Benni ALEXANDER | Rel-6 | Dionisio |  |  |
| 2084 | 615.7.1 | CS domain charging | 260d? | 2003-03-21 A | 2004-03-18 A | 100% | 2003-03-21 | 2004-03-18 | 260d? | start no earlier than 2003-03-21 | S5 | 2080h | 2080h | CH |  |  | Rel-6 | Dionisio |  |  |
| 2085 | 615.7.2 | PS domain charging | 390d? | 2003-03-21 A | 2004-09-16 A | 100% | 2003-03-21 | 2004-09-16 | 390d? | start no earlier than 2003-03-21 | S5 | 3120h | 3120h | CH |  |  | Rel-6 | Dionisio |  |  |
| 2086 | 615.7.3 | CDR transfer | 390d? | 2003-03-21 A | 2004-09-16 A | 100% | 2003-03-21 | 2004-09-16 | 390d? | start no earlier than 2003-03-21 | S5 | 3120h | 3120h | CH |  |  | Rel-6 | Dionisio |  |  |
| 2087 | 615.8 | Charging Management for the IMS | 455d? | 2003-03-21 A | 2004-12-16 A | 100% | 2003-03-21 | 2004-12-16 | 455d? | finish no earlier than 2004-12-16 | S5 | 3640h | 3640h | IMS2-CH | Ericsson | Patrik TEPPO | Rel-6 | Dionisio |  |  |
| 2088 | 615.9 | Charging Management for the Service domain | 580d? | 2003-03-21 A | 2005-06-09 A | 100% | 2003-03-21 | 2005-06-09 | 580d? | finish no earlier than 2005-06-09 | S5 | 4640h | 4640h | CH | Siemens | Gerald.Goermer@nsn.com | Rel-6 | Dionisio |  |  |
| 2089 | 615.10 | **Overall architectural aspects of IP flow based bearer level charging** | 602d? | 2002-11-21 A | 2005-03-11 A | 100% | 2002-11-21 | 2005-03-11 | 602d? |  | S2 | 12632h | 12632h | CH-FBC |  |  | Rel-6 | Maurice |  |  |
| 2090 | 615.10.1 | Overall definition of FBC architecture | 334d? | 2002-11-21 A | 2004-03-02 A | 100% | 2002-11-21 | 2004-03-02 | 334d? | start no earlier than 2002-11-21 | S2 | 2672h | 2672h | CH-FBC |  |  | Rel-6 | Maurice | SP-24 |  |
| 2091 | 615.10.2 | Study on providing policy control with FBC | 130d? | 2004-02-02 A | 2004-07-30 A | 100% | 2004-02-02 | 2004-07-30 | 130d? | start no earlier than 2004-02-01 | S2 | 1040h | 1040h | CH-FBC |  |  | Rel-6 | Maurice | SP-24 |  |
| 2092 | 615.10.3 | Gx interface for flow based charging | 223d? | 2004-02-02 A | 2004-12-08 A | 100% | 2004-02-02 | 2004-12-08 | 223d? | start no earlier than 2004-02-01 | N3 | 1784h | 1784h | CH-FBC | Nokia | juha.a.rasanen@nokia.com | Rel-6 | Gwiho | SP-25 |  |
| 2093 | 615.10.4 | Rx interface for flow based charging | 290d? | 2004-02-02 A | 2005-03-11 A | 100% | 2004-02-02 | 2005-03-11 | 290d? | finish no earlier than 2005-03-11 | N3 | 2320h | 2320h | CH-FBC | Nortel | Javier Gonzalez Gallego | Rel-6 | Gwiho | SP-25 |  |
| 2094 | 13 | **Rel-6 UICC/USIM enhancements and interworking** | 1164d? | 2000-09-25 A | 2005-03-10 A | 100% | 2000-09-25 | 2005-03-10 | 1164d? |  | T3 | 43088h | 43088h | USAT1 |  |  | Rel-6 | Xavier |  |  |
| 2095 | 13.1 | **UICC API** | 777d | 2002-03-20 A | 2005-03-10 A | 100% | 2002-03-20 | 2005-03-10 | 777d |  | T3 | 15024h | 15024h | USAT1-API |  |  | Rel-6 | Xavier |  |  |
| 2096 | 13.1.1 | Java API Test specification | 59d | 2002-03-20 A | 2002-06-10 A | 100% | 2002-03-20 | 2002-06-10 | 59d | finish no earlier than 2002-09-20 | T3 | 472h | 472h | USAT1-API | Microelectrónica Española | Mario Pérez | Rel-6 | Xavier |  |  |
| 2097 | 616.1.2 | 2G/3G Java Card™ API based applet interworking | 255d | 2003-03-17 A | 2004-03-05 A | 100% | 2003-03-17 | 2004-03-05 | 255d | finish no earlier than 2004-02-19 | T3 | 2040h | 2040h | USAT1-API | Oberthur Card Systems | Stéphane Andrau | Rel-6 | Xavier |  |  |
| 2098 | 616.1.3 | (U)SIM API for Java Card Testing | 519d | 2003-03-17 A | 2005-03-10 A | 100% | 2003-03-17 | 2005-03-10 | 519d | finish no earlier than 2005-03-10 | T3 | 4152h | 4152h | USAT1-API | Axalto | Christophe Begassat (cbegassat@axalto.com) | Rel-6 | Xavier |  |  |
| 2099 | 13.1.2 | Deleted - Java API Test specification (TS 43.019 Rel-5) | 268d | 2002-05-30 A | 2003-06-09 A | 100% | 2002-05-30 | 2003-06-09 | 268d | finish no earlier than 2003-09-17 | T3 | 2144h | 2144h | USAT1-API | Microelectrónica Española | Mario Pérez | Rel-6 | Xavier |  | TP-20 |
| 2100 | 616.2 | **Rel-6 USIM toolkit enhancements** | 1160d? | 2000-09-25 A | 2005-03-04 A | 100% | 2000-09-25 | 2005-03-04 | 1160d? |  | T3 | 21848h | 21848h | USAT1-API-MULTOS | Aspects Software | Neil Livingston | Rel-6 | Xavier |  |  |
| 2101 | 616.2.1 | **C SIM API** | 525d | 2000-09-25 A | 2002-09-27 A | 100% | 2000-09-25 | 2002-09-27 | 525d |  | T3 | 9960h | 9960h | USAT1-API-MULTOS | Aspects Software | Neil Livingston | Rel-6 | Xavier |  |  |
| 2102 | 616.2.1.1 | Specification | 525d | 2000-09-25 A | 2002-09-27 A | 100% | 2000-09-25 | 2002-09-27 | 525d | finish no earlier than 2002-09-27 | T3 | 4200h | 4200h | USAT1-API-MULTOS | Aspects Software | Neil Livingston | Rel-6 | Xavier |  |  |
| 2103 | 616.2.1.2 | Test specification | 195d | 2001-01-01 A | 2001-09-28 A | 100% | 2001-01-01 | 2001-09-28 | 195d | finish no earlier than 2001-09-28 | T3 | 1560h | 1560h | USAT1-API-MULTOS | Aspects Software | Neil Livingston | Rel-6 | Xavier |  |  |
| 2104 | 616.2.2 | USIM application toolkit Conformance Test Specification for Mobile Equipments | 326d? | 2003-12-05 A | 2005-03-04 A | 100% | 2003-12-05 | 2005-03-04 | 326d? | start no earlier than 2003-12-05 | T3 | 2608h | 2608h | USAT1-API-MULTOS | Gemplus | Eric.laffont@gemplus.com | Rel-6 | Xavier |  |  |
| 2105 | 617 | **Packet Switched Streaming Services Rel-6** | 798d? | 2002-11-18 A | 2005-12-07 A | 100% | 2002-11-18 | 2005-12-07 | 798d? |  | S4,S1 | 13304h | 13304h | PSSrel6 | Ericsson | olle.franceschi@ericsson.com | Rel-6 | Paolo |  |  |
| 2106 | 617.1 | Stage 1 | 86d? | 2002-11-18 A | 2003-03-17 A | 100% | 2002-11-18 | 2003-03-17 | 86d? | finish no earlier than 2003-03-17 | S1 | 688h | 688h | PSSrel6 | Ericsson |  | Rel-6 | Alain |  |  |
| 2107 | 617.2 | Stage 3 | 779d? | 2002-12-13 A | 2005-12-07 A | 100% | 2002-12-13 | 2005-12-07 | 779d? | finish no earlier than 2005-12-07 | S4 | 6232h | 6232h | PSSrel6-Stage3 | Ericsson | olle.franceschi@ericsson.com | Rel-6 | Paolo |  |  |
| 2108 | 618 | AMR-WB extension for high audio quality | 779d | 2002-12-13 A | 2005-12-07 A | 100% | 2002-12-13 | 2005-12-07 | 779d | finish no earlier than 2005-12-07 | S4 | 6232h | 6232h | AMRWB+ | Nokia | janne.m.vainio@nokia.com | Rel-6 | Paolo |  |  |
| 2109 | 619 | Codec Enhancements for Packet Switched Conversational Multimedia Applications | 198d? | 2004-03-16 A | 2004-12-16 A | 100% | 2004-03-16 | 2004-12-16 | 198d? | finish no earlier than 2004-12-16 | S4 | 1584h | 1584h | CEPSCM | Nokia | miska.hannuksela@nokia.com | Rel-6 | Paolo |  |  |
| 2110 | 620 | 3G-324M Improvements | 198d? | 2004-03-16 A | 2004-12-16 A | 100% | 2004-03-16 | 2004-12-16 | 198d? | finish no earlier than 2004-12-16 | S4 | 1584h | 1584h | 3G-324MI | Ericsson | bo.burman@ericsson.com | Rel-6 | Paolo |  |  |
| 2111 | 621 | Single Antenna Receiver Interference Cancellation (SAIC) | 420.92d? | 2002-11-15 A | 2004-06-25 A | 100% | 2002-11-15 | 2004-06-25 | 420.92d? | finish no earlier than 2004-08-27 | GP,G1 | 3367.36h | 3367.36h | SAIC | Cingular | Marc Grant | Rel-6 | Paolo |  |  |

Notes:
- 2083: SP#28 Target 09/2005 for WLAN Charging 32.252
- 2084: SP#23 03/2004 completed / Text3: 32.250
- 2085: SP#25 09/2004 completed / Text3: 32.251
- 2086: SP#25 09/2004 completed / Text3: 32.295
- 2087: SP#26 12/2004 completed / Text3: 32.260
- 2088: SP#26: Updated WID SP-040778 was SP-030050. Target completion 06/2005. Consisting of MMS-CH, LCS-CH, WLAN-CH, POC-CH, MBMS-CH / Text3: 32.252, 32.270, 32.271, 32.272
- 2089: - / Text3: 23.125
- 2090: -
- 2091: -
- 2092: - / Text3: 29.210
- 2093: - / Text3: 29.209
- 2094: -
- 2095: 8/3/2001: test spec is based on R99 core spec, so deleted from Workplan
- 2096: -
- 2097: -
- 2098: - / Text3: 31.213
- 2099: MOVED to Rel-5 WP
- 2100: -
- 2101: - / Text3: 31.101, 31.102, 31.103, 31.111, 31.113, new 31.115, 31.116
- 2102: -
- 2103: -
- 2104: - / Text3: 31.124
- 2105: -
- 2106: 2nd resp SA4 / Text3: 22.233
- 2107: TR tbc by Sept. 05 / Text3: 26.233, 26.234, 26.244, 26.245, 26.246, 26.401, 26.402, 26.403, 26.404, 26.405, 26.406, 26.410, 26.411, 26.412, 26.273, 26.290, 26.304, 26.412, 26.274, 26.936
- 2108: TR tbc by Sept. 05 / Text3: 26.290, 26.304, 26.273, 26.274, 26.412, 26.936
- 2109: - / Text3: 26.235, 26.236
- 2110: - / Text3: 26.111, 26.911
- 2111: - / Text3: 45.903

| ID | WBS | Task | Type | Duration | Start | Finish | Complete | Baseline start | Baseline finish | Baseline duration | Constraint | Resources | Work | Actual work | Text1 | Text3 | Text4 | Text5 | Text6 | Text8 | Text12 |
| --- | --- | --- | --- | --- | --- | --- | --- | --- | --- | --- | --- | --- | --- | --- | --- | --- | --- | --- | --- | --- | --- |
| 2112 | 622 | **Enhancement of dialled service for CAMEL** |  | 199d | 2003-03-28 A | 2003-12-31 A | 100% | 2003-03-28 | 2003-12-31 | 199d |  | S1,N2,N4 | 3184h | 3184h | EDCAMEL | 22.078 | Samsung | craig.bishop@samsung.com | Rel-6 | Alain |  |
| 2113 | 622.1 | Stages 2 and 3 |  | 199d | 2003-03-28 A | 2003-12-31 A | 100% | 2003-03-28 | 2003-12-31 | 199d | finish no earlier than 2003-09-19 | N2,N4 | 1592h | 1592h | EDCAMEL | 23.008, 23.016, 23.018, 23.078, 29.002, 29.078 | Samsung | Richard Brook | Rel-6 | Kimmo |  |
| 2114 | 623 | Study on Bandwidth and resource savings in CS networks |  | 273d? | 2003-06-01 A | 2004-06-16 A | 100% | 2003-06-01 | 2004-06-16 | 273d? | finish no earlier than 2004-06-16 | S2 | 2184h | 2184h | BARS | 23.977 |  |  | Rel-6 | Maurice |  |
| 2115 | 624 | FS on (U)SIM Security Reuse by Peripheral Devices on Local Interfaces |  | 127d? | 2003-07-03 A | 2003-12-26 A | 100% | 2003-07-03 | 2003-12-26 | 127d? | finish no earlier than 2003-12-26 | S3 | 1016h | 1016h |  | 33.817 | Toshiba | Raziq Yaqub (ryaqub@tari.toshiba.com) | Rel-6 | Dionisio |  |
| 2116 | 625 | **Multiple TBF in A/Gb mode** |  | 736d? | 2002-04-05 A | 2005-01-28 A | 100% | 2002-04-05 | 2005-01-28 | 736d? |  | GP,G2 | 17600h | 17600h | MULTBF |  | Ericsson | gunnar.mildh@era.ericsson.se | Rel-6 | Paolo |  |
| 2117 | 625.1 | **Multiple TBF in A/Gb mode** |  | 366d? | 2002-04-05 A | 2003-08-29 A | 100% | 2002-04-05 | 2003-08-29 | 366d? |  | GP,G2 | 11712h | 11712h | MULTBF-Agbmode |  | Ericsson | gunnar.mildh@era.ericsson.se | Rel-6 | Paolo |  |
| 2118 | 625.1.1 | Multiple TBF Concept paper |  | 366d? | 2002-04-05 A | 2003-08-29 A | 100% | 2002-04-05 | 2003-08-29 | 366d? | finish no earlier than 2003-08-29 | GP,G2 | 2928h | 2928h | MULTBF-Agbmode |  |  |  | Rel-6 | Paolo |  |
| 2119 | 625.1.2 | Multiple TBF Stage 2 (43.064) CRs |  | 366d? | 2002-04-05 A | 2003-08-29 A | 100% | 2002-04-05 | 2003-08-29 | 366d? | finish no earlier than 2003-08-29 | GP,G2 | 2928h | 2928h | MULTBF-Agbmode |  |  |  | Rel-6 | Paolo |  |
| 2120 | 625.1.3 | Multiple TBF Stage 3 (44.060) CRs |  | 366d? | 2002-04-05 A | 2003-08-29 A | 100% | 2002-04-05 | 2003-08-29 | 366d? | finish no earlier than 2003-08-29 | GP,G2 | 2928h | 2928h | MULTBF-Agbmode |  |  |  | Rel-6 | Paolo |  |
| 2121 | 625.2 | Deleted - Multiple TBF in A/Gb mode – MS testing | milestone | 0d? | 2005-01-28 A | 2005-01-28 A | 100% | 2005-01-28 | 2005-01-28 | 0d? | start no earlier than 2005-01-28 | G3new |  |  | MULTBF-Testing |  | Ericsson | gunnar.mildh@era.ericsson.se | Rel-6 | Paolo | GP-27 |
| 2122 | 626 | **Alignment between the test-regimes for GERAN capable MS** |  | 526d? | 2003-08-29 A | 2005-09-02 A | 100% | 2003-08-29 | 2005-09-02 | 526d? |  | G3new | 4208h | 4208h | ALTERE |  | Ericsson | anthony.toubassi@sonyericsson.com | Rel-6 | Ingbert |  |
| 2123 | 626.1 | Determine the controversial test cases in the different test regimes and align them with 3GPP GERAN test specifications. Such test cases to be added to TS 51.010. |  | 526d? | 2003-08-29 A | 2005-09-02 A | 100% | 2003-08-29 | 2005-09-02 | 526d? | finish no earlier than 2005-09-02 | G3new | 4208h | 4208h | ALTERE-TC |  |  |  | Rel-6 | Ingbert |  |
| 2124 | 627 | Addition of U-TDOA in the CS domain |  | 111d? | 2003-11-21 A | 2004-04-23 A | 100% | 2003-11-21 | 2004-04-23 | 111d? | finish no earlier than 2004-04-23 | GP | 888h | 888h | UTDOACS |  | TruePosition | Bob Gross, Rhys Robinson (rlgross@trueposition.com) | Rel-6 | Paolo |  |
| 2125 | 628 | Addition of U-TDOA in the PS domain |  | 361d? | 2003-06-27 A | 2004-11-12 A | 100% | 2003-06-27 | 2004-11-12 | 361d? | finish no earlier than 2004-11-12 | GP | 2888h | 2888h | UTDOAPS |  | TruePosition | Bob Gross, Rhys Robinson (rlgross@trueposition.com) | Rel-6 | Paolo |  |
| 2126 | 629 | **Downlink Advanced Receiver Performance** |  | 466d? | 2003-11-21 A | 2005-09-02 A | 100% | 2003-11-21 | 2005-09-02 | 466d? |  | GP | 19160h | 19160h | DARP |  | Nokia | tommy.bysted@nokia.com | Rel-6 | Paolo |  |
| 2127 | 629.1 | DARP test scenarios |  | 201d? | 2003-11-21 A | 2004-08-27 A | 100% | 2003-11-21 | 2004-08-27 | 201d? | finish no earlier than 2004-08-27 | GP | 1608h | 1608h | DARP-TS |  | Nokia | tommy.bysted@nokia.com | Rel-6 | Paolo |  |
| 2128 | 629.2 | **DARP for GMSK modulated voice services** |  | 201d? | 2004-02-06 A | 2004-11-12 A | 100% | 2004-02-06 | 2004-11-12 | 201d? |  | GP | 4824h | 4824h | DARP-GMSK |  | Nokia | tommy.bysted@nokia.com | Rel-6 | Paolo |  |
| 2129 | 629.2.1 | Performance requirements in 45.005 |  | 201d? | 2004-02-06 A | 2004-11-12 A | 100% | 2004-02-06 | 2004-11-12 | 201d? | finish no earlier than 2004-11-12 | GP | 1608h | 1608h | DARP-GMSK-Perf |  |  |  | Rel-6 | Paolo |  |
| 2130 | 629.2.2 | Radio subsystem link control in 45.008 |  | 201d? | 2004-02-06 A | 2004-11-12 A | 100% | 2004-02-06 | 2004-11-12 | 201d? | finish no earlier than 2004-11-12 | GP | 1608h | 1608h | DARP-GMSK-LC |  |  |  | Rel-6 | Paolo |  |
| 2131 | 629.3 | **DARP for GPRS and EGPRS MCS1-MCS4** |  | 201d? | 2004-02-06 A | 2004-11-12 A | 100% | 2004-02-06 | 2004-11-12 | 201d? |  | GP | 4824h | 4824h | DARP-GPRSE |  | Nokia | tommy.bysted@nokia.com | Rel-6 | Paolo |  |
| 2132 | 629.3.1 | Performance requirements in 45.005 |  | 201d? | 2004-02-06 A | 2004-11-12 A | 100% | 2004-02-06 | 2004-11-12 | 201d? | finish no earlier than 2004-11-12 | GP | 1608h | 1608h | DARP-GPRSE-Perf |  |  |  | Rel-6 | Paolo |  |
| 2133 | 629.3.2 | Radio subsystem link control in 45.008 |  | 201d? | 2004-02-06 A | 2004-11-12 A | 100% | 2004-02-06 | 2004-11-12 | 201d? | finish no earlier than 2004-11-12 | GP | 1608h | 1608h | DARP-GPRSE-LC |  |  |  | Rel-6 | Paolo |  |
| 2134 | 629.4 | DARP Capability signalling |  | 256d? | 2003-11-21 A | 2004-11-12 A | 100% | 2003-11-21 | 2004-11-12 | 256d? | finish no earlier than 2004-11-12 | GP | 2048h | 2048h | DARP-CAPSIG |  | Nokia | tommy.bysted@nokia.com | Rel-6 | Paolo |  |
| 2135 | 629.5 | GERAN MS Conformance test for DARP |  | 266d? | 2004-08-27 A | 2005-09-02 A | 100% | 2004-08-27 | 2005-09-02 | 266d? | finish no earlier than 2005-06-24 | G3new | 2128h | 2128h | ARP-ConfTest |  | Nokia | tommy.bysted@nokia.com | Rel-6 | Ingbert |  |

Notes:
- 2112: -
- 2113: -
- 2114: -
- 2115: Approved TSG#20
- 2116: GP#17 Nov 2003 Moved from Rel-5 UID_50058 MULTBF (Only Multiple TBF Concept paper produced in Rel-5)
- 2117: -
- 2118: -
- 2119: -
- 2120: -
- 2121: -
- 2122: -
- 2123: -
- 2124: Completed, except for potential LMU performance specs
- 2125: -
- 2126: -
- 2127: -
- 2128: -
- 2129: -
- 2130: -
- 2131: -
- 2132: -
- 2133: -
- 2134: -
- 2135: -

| ID | WBS | Task | Type | Duration | Start | Finish | Complete | Baseline start | Baseline finish | Baseline duration | Constraint | Resources | Work | Actual work | Text1 | Text4 | Text5 | Text6 | Text8 | Text12 | Text3 | Text10 |
| --- | --- | --- | --- | --- | --- | --- | --- | --- | --- | --- | --- | --- | --- | --- | --- | --- | --- | --- | --- | --- | --- | --- |
| 2136 | 630 | **Reduction of PS service interruption in Dual Transfer Mode** |  | 416d? | 2003-11-21 A | 2005-06-24 A | 100% | 2003-11-21 | 2005-06-24 | 416d? |  | G2 | 8360h | 8360h | PSintDTM | Siemens | toby.proctor@roke.co.uk | Rel-6 | Gert |  |  |  |
| 2137 | 630.1 | Use case and requirement definition |  | 111d? | 2003-11-21 A | 2004-04-23 A | 100% | 2003-11-21 | 2004-04-23 | 111d? | finish no earlier than 2004-04-23 | G2 | 888h | 888h | PSintDTM-Req | Siemens | toby.proctor@roke.co.uk | Rel-6 | Gert |  |  |  |
| 2138 | 630.2 | Performance Study of Current Procedures |  | 111d? | 2003-11-21 A | 2004-04-23 A | 100% | 2003-11-21 | 2004-04-23 | 111d? | start no earlier than 2003-11-21 | G2 | 888h | 888h | PSintDTM-Perf | Siemens | toby.proctor@roke.co.uk | Rel-6 | Gert |  |  |  |
| 2139 | 630.3 | Reduction of service interruption times and packet loss during Dual Transfer Mode and mobility procedures |  | 146d? | 2004-04-23 A | 2004-11-12 A | 100% | 2004-04-23 | 2004-11-12 | 146d? | finish no earlier than 2004-11-12 | G2 | 1168h | 1168h | PSintDTM-Reduct | Siemens | toby.proctor@roke.co.uk | Rel-6 | Gert |  |  |  |
| 2140 | 630.4 | Deleted - MS Conformance testing - Reduction of PS service interruption in DTM |  | 261d? | 2004-06-25 A | 2005-06-24 A | 100% | 2004-06-25 | 2005-06-24 | 261d? | finish no earlier than 2005-06-24 | G3new | 2088h | 2088h | PSintDTM-ConfMS |  |  | Rel-6 | Ingbert | GP-25 |  |  |
| 2141 | 630.5 | Deleted - BTS Conformance testing - Reduction of PS service interruption in DTM | milestone | 0d? | 2005-06-24 A | 2005-06-24 A | 100% | 2005-06-24 | 2005-06-24 | 0d? | finish no earlier than 2005-06-24 | G3new |  |  | PSintDTM-ConfBTS |  |  | Rel-6 | Ingbert | GP-25 |  |  |
| 2142 | 631 | CAMEL prepay interworking with SCUDIF |  | 216.3d | 2003-12-08 A | 2004-10-05 A | 100% | 2003-12-08 | 2004-10-05 | 216.3d |  | N4,N3,S1 | 1730.4h | 1730.4h | SCCAMEL | Nokia | Keijo.Palviainen@Nokia.Com | Rel-6 | Kimmo |  | 22.078, 23.078, 29.078, 29.002, 23.172 |  |
| 2143 | 632 | **Circuit Switched Video and Voice Service Improvements** |  | 430d? | 2004-01-12 A | 2005-09-02 A | 100% | 2004-01-12 | 2005-09-02 | 430d? |  | S2,C1 | 9256h | 9256h | CS_VSS | Vodafone | John Watson | Rel-6 | Alain |  |  |  |
| 2144 | 632.1 | Deleted - Stage 1 - Requirements |  | 199d | 2004-01-12 A | 2004-10-14 A | 100% | 2004-01-12 | 2004-10-14 | 199d | finish no earlier than 2004-10-14 | S1 | 1592h | 1592h | CS_VSS | Vodafone | John Watson | Rel-6 | Alain | SP-26 | 22.101 |  |
| 2145 | 632.2 | Stage 2 Study on architecture alternatives |  | 244d? | 2004-01-12 A | 2004-12-16 A | 100% | 2004-01-12 | 2004-12-16 | 244d? | finish no earlier than 2004-08-13 | S2 | 1952h | 1952h | CS_VSS | Vodafone | Chris Pudney | Rel-6 | Maurice |  | 23.903 | SP-24 |
| 2146 | 632.3 | Deleted - Stage 2 description on Redial |  | 164d? | 2004-05-03 A | 2004-12-16 A | 100% | 2004-05-03 | 2004-12-16 | 164d? | finish no earlier than 2004-12-16 | S2 | 1312h | 1312h | CS_VSS | Vodafone | Chris Pudney | Rel-6 | Maurice | SP-26 |  | SP-24 |
| 2147 | 632.4 | Switching between voice and video call - Redial solution |  | 120d? | 2005-01-03 A | 2005-06-17 A | 100% | 2005-01-03 | 2005-06-17 | 120d? | start no earlier than 2005-01-03 | C1 | 960h | 960h | CS_VSS | Vodafone |  | Rel-6 | Frederic |  | 23.009, 24.008 |  |
| 2148 | 632.5 | Deleted - CS_VSS - GERAN2 Part | milestone | 0d | 2005-09-02 A | 2005-09-02 A | 100% | 2005-09-02 | 2005-09-02 | 0d | start no earlier than 2005-09-02 | G2 |  |  | CS_VSS | Vodafone |  | Rel-6 | Gert | GP-26 |  |  |
| 2149 | 632.6 | Deleted - CS_VSS - CN3 Part | milestone | 0d? | 2004-10-14 A | 2004-10-14 A | 100% | 2004-10-14 | 2004-10-14 | 0d? | start no earlier than 2004-10-14 | N3 |  |  | CS_VSS | Vodafone |  | Rel-6 | Gwiho | TP-26 |  |  |
| 2150 | 633 | Network Domain Security; MAP application layer security (NDS/MAPsec) |  | 127d? | 2004-07-06 A | 2004-12-29 A | 100% | 2004-07-06 | 2004-12-29 | 127d? | finish no earlier than 2003-12-26 | S3 | 1016h | 1016h | MAPSEC | Vodafone | Peter.Howard@vodafone.com | Rel-6 | Dionisio |  |  |  |
| 2151 | 634 | FS on Security for early IMS |  | 127d? | 2004-10-01 A | 2005-03-28 A | 100% | 2004-10-01 | 2005-03-28 | 127d? | finish no earlier than 2003-12-26 | S3 | 1016h | 1016h | SEC-IMS | Vodafone | Peter.Howard@vodafone.com | Rel-6 | Dionisio |  | 33.978 |  |
| 2152 | 635 | Reorganisation of CS Data Specifications |  | 14d? | 2004-11-19 A | 2004-12-08 A | 100% | 2004-11-19 | 2004-12-08 | 14d? | finish no earlier than 2004-12-24 | N3 | 112h | 112h | CS Data | Siemens | Thomas.Belling@nsn.com | Rel-6 | Gwiho |  | 23.910, 29.007, new 23.202 |  |
| 2153 | 636 | **Generic Access to A/Gb Interface (GAAI)** |  | 411d? | 2004-06-25 A | 2006-01-20 A | 100% | 2004-06-25 | 2006-01-20 | 411d? |  | GP | 9160h | 9160h | GAAI | Motorola |  | Rel-6 | Paolo |  |  |  |
| 2154 | 636.1 | FS on GAAI |  | 46d? | 2004-06-25 A | 2004-08-27 A | 100% | 2004-06-25 | 2004-08-27 | 46d? | finish no earlier than 2004-08-27 | GP | 368h | 368h | GAAG | Motorola |  | Rel-6 | Paolo |  | 43.901 |  |
| 2155 | 636.2 | GAAI – Stage 2 |  | 161d? | 2004-08-27 A | 2005-04-08 A | 100% | 2004-08-27 | 2005-04-08 | 161d? | finish no earlier than 2005-04-08 | GP | 1288h | 1288h | GAAI-Stage2 | Ericsson | jari.vikberg@ericsson.com | Rel-6 | Paolo |  | 43.318 |  |
| 2156 | 636.3 | GAAI – Stage 3 |  | 161d? | 2004-08-27 A | 2005-04-08 A | 100% | 2004-08-27 | 2005-04-08 | 161d? | finish no earlier than 2005-04-08 | GP | 1288h | 1288h | GAAI-Stage3 |  |  | Rel-6 | Paolo |  | 44.318 |  |
| 2157 | 636.4 | MS Conformance Test for GAAI |  | 366d? | 2004-08-27 A | 2006-01-20 A | 100% | 2004-08-27 | 2006-01-20 | 366d? | finish no earlier than 2006-01-20 | GP | 2928h | 2928h | GAAI-CT |  |  | Rel-6 | Ingbert |  |  |  |
| 2158 | 637 | **Support of PS Handover for GERAN A/Gb mode** |  | 473d? | 2003-11-03 A | 2005-08-24 A | 100% | 2003-11-03 | 2005-08-24 | 473d? |  | GP,G2 | 11352h | 11352h | SPSHAGB | Ericsson | gunnar.hedby@ericsson.com | Rel-6 | Paolo |  |  |  |
| 2159 | 637.1 | Stage 2 |  | 473d? | 2003-11-03 A | 2005-08-24 A | 100% | 2003-11-03 | 2005-08-24 | 473d? | finish no earlier than 2005-09-02 | GP,G2 | 3784h | 3784h | SPSHAGB-Stage2 | Ericsson | gunnar.hedby@ericsson.com | Rel-6 | Paolo |  | 43.129 |  |
| 2160 | 637.2 | PS handover |  | 473d? | 2003-11-03 A | 2005-08-24 A | 100% | 2003-11-03 | 2005-08-24 | 473d? | finish no earlier than 2005-09-02 | GP,G2 | 3784h | 3784h | SPSHAGB-PSHO | Ericsson | gunnar.hedby@ericsson.com | Rel-6 | Paolo |  |  |  |
| 2161 | 637.3 | Definition of radio resource management functionality |  | 473d? | 2003-11-03 A | 2005-08-24 A | 100% | 2003-11-03 | 2005-08-24 | 473d? | finish no earlier than 2005-09-02 | GP,G2 | 3784h | 3784h | SPSHAGB-RRM | Ericsson | gunnar.hedby@ericsson.com | Rel-6 | Paolo |  |  |  |
| 2162 | 638 | (Small) Technical Enhancements and Improvements for Rel-6 | milestone | 0d? | 2006-06-02 A | 2006-06-02 A | 100% | 2006-06-02 | 2006-06-02 | 0d? |  | All |  |  | TEI6 |  |  | Rel-6 | all |  |  |  |
| 2163 | 639 | Test - (Small) Technical Enhancements and Improvements for Rel-6 |  | 503d? | 2006-06-02 A | 2008-05-06 A | 100% | 2006-06-02 | 2008-05-06 | 503d? | start no earlier than 2006-06-02 | R5,T1 | 4024h | 4024h | TEI6_Test |  |  | Rel-6 | Ingbert |  | 34.108,34.121-1/2,34.122,34.123-1/2/3 |  |
| 2164 | 640 | Deleted - Study of Feature Interactions Requirements | milestone | 0d? | 2004-09-16 A | 2004-09-16 A | 100% | 2004-09-16 | 2004-09-16 | 0d? | finish no earlier than 2004-10-01 | S1 |  |  | FINTER |  |  | Rel-6 | Alain | SP-25 |  |  |
| 2165 | 641 | Deleted - Enhancements of VGCS in public networks for communication of public authority officials |  | 7d? | 2005-08-24 A | 2005-09-02 A | 100% | 2005-08-24 | 2005-09-02 | 7d? | start no earlier than 2005-08-24 | GP,G2 | 56h | 56h | EVGCS | Siemens | kenneth.isaacs@roke.co.uk | Rel-6 | Paolo | GP-26 | 44.018, 44.068, 48.008 |  |

Notes:
- 2136: -
- 2137: -
- 2138: -
- 2139: -
- 2140: -
- 2141: -
- 2142: -
- 2143: -
- 2144: -
- 2145: -
- 2146: -
- 2147: -
- 2148: -
- 2149: -
- 2150: Approved TSG#24. Marked as closed 12/2008 (was marked 20% complete)
- 2151: SP#24 approved WID. SP#27 completed. SP#46 TR 33.978 withdrawn from Rel-8 onwards
- 2152: Created at TSG#27 as 100 % complete
- 2153: -
- 2154: Feasibility Study
- 2155: -
- 2156: -
- 2157: Marked as closed 12/2008 (was marked 90% complete)
- 2158: Replaces SCSAGB- Originally Started Nov 2003 as GP-030443
- 2159: Replaces SCSAGB-Stage2
- 2160: Replaces SCSAGB-PSH
- 2161: Replaces SCSAGB-RRM
- 2162: "Joker" WI, to be used for a Rel 6 CR not related to any feature and with very limited impact on the system. Moved in from Stoyan/Testing WP
- 2163: "Joker" WI, to be used for small modifications applicable to Rel 4 conformance testing
- 2164: SP#25 stopped
- 2165: GP#26 moved to Rel-7 as UID_11045 Enhancements of VGCS in public networks for communication of public authority officials

| ID | WBS | Task | Type | Duration | Start | Finish | Complete | Baseline start | Baseline finish | Baseline duration | Constraint | Resources | Work | Actual work | Text1 | Text4 | Text5 | Text6 | Text8 | Text12 | Text3 | Text7 | Text10 |
| --- | --- | --- | --- | --- | --- | --- | --- | --- | --- | --- | --- | --- | --- | --- | --- | --- | --- | --- | --- | --- | --- | --- | --- |
| 2166 | 642 | **Deleted - Support of Conversational Services in A/Gb mode via the PS domain** |  | 64d? | 2003-11-21 A | 2004-02-19 A | 100% | 2003-11-21 | 2004-02-19 | 64d? |  | GP,N1 | 1024h | 1024h | SCSAGB | Ericsson | David Bladsjö (david.bladsjo@ericsson.com) | Rel-6 | Paolo | GP-18 |  |  |  |
| 2167 | 642.1 | Deleted - Creation of a TR | milestone | 0d? | 2003-11-21 A | 2003-11-21 A | 100% | 2003-11-21 | 2003-11-21 | 0d? | start no earlier than 2003-11-21 | GP |  |  | SCSAGB-TR | Ericsson | David Bladsjö (david.bladsjo@ericsson.com) | Rel-6 | Paolo | GP-17 |  |  |  |
| 2168 | 642.2 | Deleted - Stage 2 | milestone | 0d? | 2003-11-21 A | 2003-11-21 A | 100% | 2003-11-21 | 2003-11-21 | 0d? | finish no earlier than 2003-11-21 | GP |  |  | SCSAGB-Stage2 | Ericsson | David Bladsjö (david.bladsjo@ericsson.com) | Rel-6 | Paolo | GP-17 |  |  |  |
| 2169 | 642.3 | Deleted - Radio Channel Support | milestone | 0d? | 2003-11-21 A | 2003-11-21 A | 100% | 2003-11-21 | 2003-11-21 | 0d? | finish no earlier than 2003-11-21 | GP |  |  | SCSAGB-RCS | Ericsson | David Bladsjö (david.bladsjo@ericsson.com) | Rel-6 | Paolo | GP-17 |  |  |  |
| 2170 | 642.4 | Deleted - Definition of radio resource management functionality | milestone | 0d? | 2003-11-21 A | 2003-11-21 A | 100% | 2003-11-21 | 2003-11-21 | 0d? | finish no earlier than 2003-11-21 | GP |  |  | SCSAGB-RRM | Ericsson | David Bladsjö (david.bladsjo@ericsson.com) | Rel-6 | Paolo | GP-17 |  |  |  |
| 2171 | 642.5 | Deleted - replaced by 50561 - PS Handover |  | 64d | 2003-11-21 A | 2004-02-19 A | 100% | 2003-11-21 | 2004-02-19 | 64d | start no earlier than 2003-11-21 | GP,N1 | 512h | 512h | SCSAGB-PSH | Ericsson | David Bladsjö (david.bladsjo@ericsson.com) | Rel-6 | Paolo | GP-18 |  |  |  |
| 2172 | 642.6 | Deleted - Modifications to FLO | milestone | 0d? | 2003-11-21 A | 2003-11-21 A | 100% | 2003-11-21 | 2003-11-21 | 0d? | finish no earlier than 2003-11-21 | GP |  |  | SCSAGB-FLO | Ericsson | David Bladsjö (david.bladsjo@ericsson.com) | Rel-6 | Paolo | RP-29 |  |  |  |
| 2173 | 643 | Deleted - Rel-6 Evolutions of the transport in the UTRAN | milestone | 0d | 2003-12-31 A | 2003-12-31 A | 100% | 2003-12-31 | 2003-12-31 | 0d | start no earlier than 2003-12-31 | RP |  |  | ETRAN | Alcatel | Francois Courau | Rel-6 | Issam | RP-22 |  |  |  |
| 2174 | 644 | Release 5 Features |  | 325d? | 2001-03-30 A | 2002-06-28 A | 100% | 2001-03-30 | 2002-06-28 | 325d? |  | NP,GP, RP,SP,TP | 2600h | 2600h |  |  |  | Rel-5 | All |  |  |  |  |
| 2175 | 75 | IP transport in the UTRAN |  | 445d | 2000-07-17 A | 2002-03-29 A | 100% | 2000-07-17 | 2002-03-29 | 445d | finish no earlier than 2002-03-29 | R3 | 3560h | 3560h | ETRAN-IPtrans | Alcatel | Nicolas Drevon | Rel-5 | Juha |  |  |  |  |
| 2176 | 76 | FS on Usage of SUA |  | 205d | 2001-03-12 A | 2001-12-21 A | 100% | 2001-03-12 | 2001-12-21 | 205d | finish no earlier than 2001-12-21 | N4 | 1640h | 1640h | SS7IP |  |  | Rel-5 | Kimmo |  |  |  |  |
| 2177 | 77 | **High Speed Downlink Packet Access** |  | 1550d? | 2001-04-02 A | 2007-03-09 A | 100% | 2001-04-02 | 2007-03-09 | 1550d? |  | R2,R5 | 31488h | 31488h | HSDPA | Motorola | Ravi Kuchibhotla | Rel-5 | Joern |  |  |  |  |
| 2178 | 77.1 | Physical Layer |  | 257d | 2001-04-05 A | 2002-03-29 A | 100% | 2001-04-05 | 2002-03-29 | 257d | finish no earlier than 2002-03-29 | R1 | 2056h | 2056h | HSDPA-Phys | Motorola | Amitabha Ghosh (qa0047@email.mot.com) | Rel-5 | Patrick |  |  |  |  |
| 2179 | 77.2 | Layer 2 and 3 aspects |  | 257d | 2001-04-05 A | 2002-03-29 A | 100% | 2001-04-05 | 2002-03-29 | 257d | finish no earlier than 2002-03-29 | R2 | 2056h | 2056h | HSDPA-L23 | Motorola | Ravi Kuchibhotla | Rel-5 | Joern |  |  |  |  |
| 2180 | 77.3 | Iub/Iur protocol aspects |  | 260d | 2001-04-02 A | 2002-03-29 A | 100% | 2001-04-02 | 2002-03-29 | 260d | finish no earlier than 2002-03-29 | R3 | 2080h | 2080h | HSDPA-IubIur | Motorola | Mike Diesen | Rel-5 | Juha |  |  |  |  |
| 2181 | 77.4 | RF Radio Transmission/ Reception, System Performance Requirements and Conformance Testing |  | 565d | 2001-04-09 A | 2003-06-06 A | 100% | 2001-04-09 | 2003-06-06 | 565d | finish no earlier than 2003-06-06 | R4 | 4520h | 4520h | HSDPA-RF | Motorola | Howard Benn | Rel-5 | Issam |  |  |  |  |
| 2182 | 647.5 | Conformance Testing of HSDPA |  | 786d | 2003-09-19 A | 2006-09-22 A | 100% | 2003-09-19 | 2006-09-22 | 786d | finish no earlier than 2006-09-22 | R5 | 6288h | 6288h | HSDPA_Test | Motorola | carolyn.taylor@motorola.com | Rel-5 | Ingbert |  | 34.108, 34.121, 34.122, 34.123-1, 34.123-2, 34.123-3 | TSG | 19/9/2003 |
| 2183 | 647.6 | Conformance Testing of HCR TDD HSDPA |  | 261d? | 2006-03-10 A | 2007-03-09 A | 100% | 2006-03-10 | 2007-03-09 | 261d? | finish no earlier than 2007-03-09 | R5 | 2088h | 2088h | HSDPA_HCRTDD_Test | IPWireless | drichards@ipwireless.com | Rel-5 | Ingbert |  | 34.108, 34.122, 34.123-1, 34.123-2, 34.123-3 |  |  |
| 2184 | 78 | **Rel-5 Improvements of Radio Interface** |  | 535d | 2000-08-14 A | 2002-08-30 A | 100% | 2000-08-14 | 2002-08-30 | 535d |  | RP | 30376h | 30376h | RInImp |  |  | Rel-5 |  |  |  |  |  |
| 2185 | 78.1 | **Base station classification** |  | 480d | 2000-08-14 A | 2002-06-14 A | 100% | 2000-08-14 | 2002-06-14 | 480d |  | R4 | 9208h | 9208h | RInImp-BSClass | Nokia | antti.toskala@nokia.com | Rel-5 | Issam |  |  |  |  |
| 2186 | 78.1.1 | TDD Base station classification |  | 410d | 2000-08-14 A | 2002-03-08 A | 100% | 2000-08-14 | 2002-03-08 | 410d | finish no earlier than 2002-03-08 | R4 | 3280h | 3280h | RInImp-BSClass-TDD | Nokia | antti.toskala@nokia.com | Rel-5 | Issam |  |  |  |  |
| 2187 | 78.1.2 | Base Station Classification for 1.28 Mcps TDD option |  | 261d | 2001-06-15 A | 2002-06-14 A | 100% | 2001-06-15 | 2002-06-14 | 261d | finish no earlier than 2002-06-14 | R4 | 2088h | 2088h | RInImp-BSClass-LCRTDD | Siemens | Meik.Kottkamp@siemens.com | Rel-5 | Issam |  |  |  |  |
| 2188 | 78.2 | Enhancement on the DSCH hard split mode |  | 271d | 2001-03-16 A | 2002-03-29 A | 100% | 2001-03-16 | 2002-03-29 | 271d | finish no earlier than 2002-03-29 | R1 | 2168h | 2168h | RInImp-DSCHhsp | Samsung | Jaeyoel KIM | Rel-5 | Patrick |  |  |  |  |
| 2189 | 78.3 | Hybrid ARQ II/III |  | 355d | 2000-08-21 A | 2001-12-28 A | 100% | 2000-08-21 | 2001-12-28 | 355d | finish no earlier than 2001-12-28 | R2 | 2840h | 2840h | RInImp-HARQ | Siemens | armin.sitte@siemens.com | Rel-5 | Joern | RP-14 |  |  |  |
| 2190 | 78.4 | FS on USTS |  | 355d | 2000-08-14 A | 2001-12-21 A | 100% | 2000-08-14 | 2001-12-21 | 355d | finish no earlier than 2001-12-21 | R1 | 2840h | 2840h | RInImp-USTS | SK Telecom | D. Kim | Rel-5 | Patrick |  |  |  |  |
| 2191 | 78.5 | FS on UE antenna efficiency test method performance requirements |  | 255d | 2000-09-25 A | 2001-09-14 A | 100% | 2000-09-25 | 2001-09-14 | 255d | finish no earlier than 2001-09-14 | R4 | 2040h | 2040h | RInImp-UEAnTM | Allgon | O. Edvardsson | Rel-5 | Issam |  |  |  |  |
| 2192 | 78.6 | FS on the re-introduction of the downlink SIR measurement |  | 200d | 2001-03-12 A | 2001-12-14 A | 100% | 2001-03-12 | 2001-12-14 | 200d | finish no earlier than 2001-12-14 | R4 | 1600h | 1600h | RInImp-SIR | Ericsson | Torgny.Palenius@ericsson.com | Rel-5 | Issam |  |  |  |  |
| 2193 | 78.7 | FS on mitigating the effect of CPICH interference at the UE |  | 255d | 2001-03-19 A | 2002-03-08 A | 100% | 2001-03-19 | 2002-03-08 | 255d | finish no earlier than 2002-03-08 | R4 | 2040h | 2040h | RInImp-CPICH_Intf | Intel | shimon.moshavi@INTEL.COM | Rel-5 | Issam |  |  |  |  |

Notes:
- 2166: -
- 2167: -
- 2168: Started
- 2169: Not started
- 2170: Not started
- 2171: Started
- 2172: Not started
- 2173: Generic feature
- 2174: -
- 2175: -
- 2176: -
- 2177: -
- 2178: -
- 2179: -
- 2180: -
- 2181: -
- 2182: -
- 2183: -
- 2184: -
- 2185: -
- 2186: -
- 2187: -
- 2188: -
- 2189: Stopped at RP#14; work on this task was performed as part of High Speed Downlink Packet Access feature
- 2190: -
- 2191: -
- 2192: -
- 2193: -

| ID | WBS | Task | Duration | Start | Finish | Complete | Baseline start | Baseline finish | Baseline duration | Constraint | Deadline | Resources | Work | Actual work | Text6 | Text8 | Text12 | Text1 | Text4 | Text5 | Text3 | Text10 |
| --- | --- | --- | --- | --- | --- | --- | --- | --- | --- | --- | --- | --- | --- | --- | --- | --- | --- | --- | --- | --- | --- | --- |
| 2194 | 78.8 | **Deleted - Conformance Test Spec. improvements in Radio Interface** | 140d | 2002-02-18 A | 2002-08-30 A | 100% | 2002-02-18 | 2002-08-30 | 140d |  |  | T1 | 3360h | 3360h | Rel-5 | Ingbert | TP-17 |  |  |  |  |  |
| 2195 | 78.8.1 | Deleted - Testing improvement of inter-frequency and inter-system measurement | 140d | 2002-02-18 A | 2002-08-30 A | 100% | 2002-02-18 | 2002-08-30 | 140d | finish no earlier than 2002-08-30 |  | T1 | 1120h | 1120h | Rel-5 | Ingbert | TP-17 |  |  |  |  |  |
| 2196 | 78.8.2 | Deleted - Testing Hybrid ARQ II/III | 140d | 2002-02-18 A | 2002-08-30 A | 100% | 2002-02-18 | 2002-08-30 | 140d | finish no earlier than 2002-08-30 |  | T1 | 1120h | 1120h | Rel-5 | Ingbert | TP-17 |  |  |  |  |  |
| 2197 | 79 | **Rel-5 RAN improvements** | 1561d? | 2001-03-16 A | 2007-03-09 A | 100% | 2001-03-16 | 2007-03-09 | 1561d? |  |  | RP | 49424h | 49424h | Rel-5 |  |  | RANimp |  |  |  |  |
| 2198 | 79.1 | **RRM optimization for Iur and Iub** | 318d | 2001-03-16 A | 2002-06-04 A | 100% | 2001-03-16 | 2002-06-04 | 318d |  |  | R3 | 8904h | 8904h | Rel-5 | Juha |  | RANimp-RRMopt | Ericsson | Gert-Jan.van.Lieshout@eln.ericsson.se |  |  |
| 2199 | 79.1.1 | Iur common transport channel efficiency optimization | 271d | 2001-03-16 A | 2002-03-29 A | 100% | 2001-03-16 | 2002-03-29 | 271d | finish no earlier than 2002-03-29 |  | R3 | 2168h | 2168h | Rel-5 | Juha |  | RANimp-RRMopt-ctc | Ericsson | Shahrokh Amirijoo |  |  |
| 2200 | 79.1.2 | Iur neighbouring cell reporting efficiency optimization | 271d | 2001-03-16 A | 2002-03-29 A | 100% | 2001-03-16 | 2002-03-29 | 271d | finish no earlier than 2002-03-29 |  | R3 | 2168h | 2168h | Rel-5 | Juha |  | RANimp-RRMopt-ncr | Ericsson | Shahrokh Amirijoo |  |  |
| 2201 | 79.1.3 | FS Introduction of direct transport bearers between SRNC and Node-B | 253d | 2001-06-15 A | 2002-06-04 A | 100% | 2001-06-15 | 2002-06-04 | 253d | finish no earlier than 2002-06-28 |  | R3 | 2024h | 2024h | Rel-5 | Juha |  | RAN-imp-RRMopt-DTB | Ericsson | Risto Sepponen |  |  |
| 2202 | 79.2 | RL Timing Adjustment | 271d | 2001-03-16 A | 2002-03-29 A | 100% | 2001-03-16 | 2002-03-29 | 271d | finish no earlier than 2002-03-29 |  | R3 | 2168h | 2168h | Rel-5 | Juha |  | RANimp-RLTA | Ericsson | Elena Voltolina |  |  |
| 2203 | 79.3 | Separation of resource reservation and radio link activation | 271d | 2001-03-16 A | 2002-03-29 A | 100% | 2001-03-16 | 2002-03-29 | 271d | finish no earlier than 2002-03-29 |  | R3 | 2168h | 2168h | Rel-5 | Juha |  | RANimp-SepRR | Ericsson | Gert-Jan.van.Lieshout@eln.ericsson.se |  |  |
| 2204 | 79.4 | FS SRNS Relocation Procedure Enhancement | 318d | 2001-06-15 A | 2002-09-03 A | 100% | 2001-06-15 | 2002-09-03 | 318d | finish no earlier than 2002-09-06 |  | R3 | 2544h | 2544h | Rel-5 | Juha |  | RANimp-SRNS | Nokia | Olivier Guyot |  |  |
| 2205 | 79.5 | FS Improvement of Radio Resource Management across RNS and RNS/PSS | 201d | 2001-03-16 A | 2001-12-21 A | 100% | 2001-03-16 | 2001-12-21 | 201d | finish no earlier than 2001-12-21 |  | R3 | 1608h | 1608h | Rel-5 | Juha |  | RANimp-ImpRRM | Nokia | antti.toskala@nokia.com |  |  |
| 2206 | 79.6 | Re-arrangements of Iub transport bearers | 271d | 2001-03-16 A | 2002-03-29 A | 100% | 2001-03-16 | 2002-03-29 | 271d | finish no earlier than 2002-03-29 |  | R3 | 2168h | 2168h | Rel-5 | Juha |  | RANimp-TTPS | Nokia | antti.toskala@nokia.com |  |  |
| 2207 | 79.7 | RAB support enhancement for Rel-5 | 325d | 2001-04-02 A | 2002-06-28 A | 100% | 2001-04-02 | 2002-06-28 | 325d |  |  | R2 | 2600h | 2600h | Rel-5 | Joern |  | RANimp-RABSE5 | Nokia | Juha Mikola |  |  |
| 2208 | 16.5.1 | Testing of ROHC performance | 391d | 2005-09-09 A | 2007-03-09 A | 100% | 2005-09-09 | 2007-03-09 | 391d | finish no earlier than 2007-03-09 | 2006-06-02 | R5 | 3128h | 3128h | Rel-5 | Ingbert |  | RANimp-RABSE5_Test | Nokia | jarkko.hellsten@nokia.com | 34.108, 34.123-1, 34.123-2, 34.123-3 | Fri 11/03/05 |
| 2209 | 79.8 | Beamforming requirements for UE | 61d | 2001-09-21 A | 2001-12-14 A | 100% | 2001-09-21 | 2001-12-14 | 61d | finish no earlier than 2001-12-14 |  | R1 | 488h | 488h | Rel-5 | Patrick |  | RANimp-BFR-UE | Nokia | Jussi Kähtävä (juha.mikola@nokia.com) |  |  |
| 2210 | 79.9 | Support of Site Selection Diversity Transmission in UTRAN | 123d | 2001-12-14 A | 2002-06-04 A | 100% | 2001-12-14 | 2002-06-04 | 123d | finish no earlier than 2002-06-04 |  | R1 | 984h | 984h | Rel-5 | Patrick |  | RANimp-SSDT | NEC |  |  |  |
| 2211 | 79.10 | Node B Synchronisation for 1.28 Mcps TDD | 271d | 2001-03-16 A | 2002-03-29 A | 100% | 2001-03-16 | 2002-03-29 | 271d | finish no earlier than 2002-03-29 |  | R1 | 2168h | 2168h | Rel-5 | Patrick |  | RANimp-NBSLCR | CATT | Jinling HU |  |  |
| 2212 | 79.12 | **Deleted - Conformance Test Aspects - RAN Improvements** | 565d? | 2002-01-01 A | 2004-03-01 A | 100% | 2002-01-01 | 2004-03-01 | 565d? |  |  | T1 | 8008h | 8008h | Rel-5 | Ingbert | TP-23 |  |  |  | 0% |  |
| 2213 | 79.12.1 | Deleted - Testing Radio access bearer support enhancements | 175d | 2002-01-01 A | 2002-09-02 A | 100% | 2002-01-01 | 2002-09-02 | 175d | finish no earlier than 2002-09-02 |  | T1 | 1400h | 1400h | Rel-5 | Ingbert | TP-17 |  |  |  |  |  |
| 2214 | 649.12.2 | Deleted - General changes to TS34.121 and TS34.122 corresponding to release 5 | 261d? | 2003-03-03 A | 2004-03-01 A | 100% | 2003-03-03 | 2004-03-01 | 261d? | finish no earlier than 2004-03-01 |  | T1 | 2088h | 2088h | Rel-5 | Ingbert | TP-23 | RANimp-test |  |  | 34.108, 34.121, 34.122 |  |
| 2215 | 80 | UTRAN Sharing in Connected Mode | 197d | 2001-12-03 A | 2002-09-03 A | 100% | 2001-12-03 | 2002-09-03 | 197d | finish no earlier than 2002-09-06 |  | R3 | 1576h | 1576h | Rel-5 | Juha |  | NETSHARE | Ericsson | Martin Israelsson |  |  |
| 2216 | 81 | **Provisioning of IP-based multimedia services** | 1806d | 2000-01-03 A | 2006-12-01 A | 100% | 2000-01-03 | 2006-12-01 | 1806d |  |  | S1,S2,S5,R5 | 205676h | 205676h | Rel-5 | Alain |  | IMS | Openwave | Mark Cataldo |  |  |
| 2217 | 81.1 | **Call control and roaming to support IMS in UMTS** | 1806d | 2000-01-03 A | 2006-12-01 A | 100% | 2000-01-03 | 2006-12-01 | 1806d |  |  | S2,R5 | 95312h | 95312h | Rel-5 | Maurice |  | IMS-CCR | Lucent | Liz Daniel |  |  |
| 2218 | 81.1.1 | Stage 1 | 215d | 2000-02-21 A | 2000-12-15 A | 100% | 2000-02-21 | 2000-12-15 | 215d | finish no earlier than 2000-09-21 |  | S1 | 1720h | 1720h | Rel-5 | Alain |  | IMS-CCR | Motorola | Mark Cataldo | 22.228 |  |
| 2219 | 81.1.2 | Stage 2 (Architecture and Main flows) | 246d | 2000-04-14 A | 2001-03-23 A | 100% | 2000-04-14 | 2001-03-23 | 246d | finish no earlier than 2001-03-23 |  | S2 | 1968h | 1968h | Rel-5 | Maurice |  | IMS-CCR | Lucent | Liz Daniel | 23.228 |  |
| 2220 | 81.1.3 | Impact on MM/CC/SM | 400d | 2000-08-28 A | 2002-03-08 A | 100% | 2000-08-28 | 2002-03-08 | 400d | finish no earlier than 2002-03-08 |  | N1 | 3200h | 3200h | Rel-5 | Frederic |  | IMS-CCR-IWMM | Lucent | Keith Drage (drage@alcatel-lucent.com) |  |  |

Notes:
- 2194: Marked as stopped 12/2008
- 2195: Marked as stopped 12/2008
- 2196: Marked as stopped 12/2008
- 2197: -
- 2198: -
- 2199: -
- 2200: -
- 2201: FS was closed and introduction of WI not agreed at RAN #16
- 2202: -
- 2203: -
- 2204: -
- 2205: FS was closed and WI was introduced at RAN #14
- 2206: -
- 2207: RFC 3095 context relocation
- 2208: -
- 2209: -
- 2210: RP-020356
- 2211: -
- 2212: Marked as stopped 12/2008
- 2213: Marked as stopped 12/2008
- 2214: Marked as stopped 12/2008
- 2215: Formerly 'Shared Network support in connected mode', renamed at RAN #16.
- 2216: -
- 2217: -
- 2218: Issues include e.g.: Roaming requirements, Requirements on supplementary services, Interworking requirements
- 2219: Issues include e.g.: Mobile IP, RAB selection principles, Optimized VoIP bearer mechanisms, SIP multimedia protocol
- 2220: Per 26/2-02: This is understood to be the PCO & TFT CRs which CN1 provides to TSGN #15 for approval. If this is correct understanding, then the task is 100 % complete.

| ID | WBS | Task | Duration | Start | Finish | Complete | Baseline start | Baseline finish | Baseline duration | Constraint | Deadline | Resources | Work | Actual work | Text1 | Text3 | Text4 | Text5 | Text6 | Text8 | Text10 |
| --- | --- | --- | --- | --- | --- | --- | --- | --- | --- | --- | --- | --- | --- | --- | --- | --- | --- | --- | --- | --- | --- |
| 2221 | 81.1.4 | **SIP Call Control protocol for the IMS** | 385d | 2000-10-02 A | 2002-03-22 A | 100% | 2000-10-02 | 2002-03-22 | 385d |  |  | N1 | 12320h | 12320h | IMS-CCR | 24.228, 24.229, 23.218 | Lucent | Keith Drage (drage@alcatel-lucent.com) | Rel-5 | Frederic |  |
| 2222 | 81.1.4.1 | IMS signalling flows | 385d | 2000-10-02 A | 2002-03-22 A | 100% | 2000-10-02 | 2002-03-22 | 385d | finish no earlier than 2002-03-22 |  | N1 | 3080h | 3080h | IMS-CCR | 24.228 |  |  | Rel-5 | Frederic |  |
| 2223 | 81.1.4.2 | IMS stage 3 | 385d | 2000-10-02 A | 2002-03-22 A | 100% | 2000-10-02 | 2002-03-22 | 385d | finish no earlier than 2002-03-22 |  | N1 | 3080h | 3080h | IMS-CCR | 24.229 |  |  | Rel-5 | Frederic |  |
| 2224 | 81.1.4.3 | IMS Session Handling; stage 2 | 385d | 2000-10-02 A | 2002-03-22 A | 100% | 2000-10-02 | 2002-03-22 | 385d | finish no earlier than 2002-03-22 |  | N1 | 3080h | 3080h | IMS-CCR | 23.218 |  |  | Rel-5 | Frederic |  |
| 2225 | 16.5.1 | Conformance Test Aspects – IMS Call Control | 451d | 2005-03-11 A | 2006-12-01 A | 100% | 2005-03-11 | 2006-12-01 | 451d |  | 2006-06-02 | R5 | 3608h | 3608h | IMS-CCR_Test | 34.108, 34.229-1, 34.229-2, 34.229-3 | Motorola | Jacob.John@motorola.com | Rel-5 | Ingbert | Fri 11/03/05 |
| 2226 | 81.1.4.4 | **Main IETF dependencies** | 641d | 2000-01-03 A | 2002-06-14 A | 100% | 2000-01-03 | 2002-06-14 | 641d |  |  | NP | 58048h | 58048h | IMS |  |  |  | Rel-5 | Kimmo |  |
| 2227 | 81.1.4.4.1 | IETF: RFC 3261 (Session Initiation Protocol) | 346d | 2000-11-24 A | 2002-03-22 A | 100% | 2000-11-24 | 2002-03-22 | 346d | finish no earlier than 2002-03-22 |  | N1 | 2768h | 2768h | IMS |  |  |  | Rel-5 | Frederic |  |
| 2228 | 81.1.4.4.2 | IETF: RFC 3262 (Reliability of provisional responses) | 346d | 2000-11-24 A | 2002-03-22 A | 100% | 2000-11-24 | 2002-03-22 | 346d | finish no earlier than 2002-03-22 |  | N1 | 2768h | 2768h | IMS |  |  |  | Rel-5 | Frederic |  |
| 2229 | 81.1.4.4.3 | IETF: RFC 3312 (Without COMET)(Integration of resource management and SIP) | 382d | 2000-11-24 A | 2002-05-13 A | 100% | 2000-11-24 | 2002-05-13 | 382d | finish no earlier than 2002-05-13 |  | N1 | 3056h | 3056h | IMS |  |  |  | Rel-5 | Frederic |  |
| 2230 | 81.1.4.4.4 | IETF: RFC 3323 (SIP extensions for caller identity and privacy) | 382d | 2000-11-24 A | 2002-05-13 A | 100% | 2000-11-24 | 2002-05-13 | 382d | finish no earlier than 2002-05-13 |  | N1 | 3056h | 3056h | IMS |  |  |  | Rel-5 | Frederic |  |
| 2231 | 81.1.4.4.5 | IETF: RFC 3313 (SIP extensions for media authorization) | 382d | 2000-11-24 A | 2002-05-13 A | 100% | 2000-11-24 | 2002-05-13 | 382d | finish no earlier than 2002-05-13 |  | N1 | 3056h | 3056h | IMS |  |  |  | Rel-5 | Frederic |  |
| 2232 | 81.1.4.4.6 | IETF: RFC 3265 (specific event notification) | 346d | 2000-11-24 A | 2002-03-22 A | 100% | 2000-11-24 | 2002-03-22 | 346d | finish no earlier than 2002-03-22 |  | N1 | 2768h | 2768h | IMS |  |  |  | Rel-5 | Frederic |  |
| 2233 | 81.1.4.4.7 | IETF: RFC editor Queue (refer method) | 401d | 2000-11-24 A | 2002-06-07 A | 100% | 2000-11-24 | 2002-06-07 | 401d | finish no earlier than 2002-06-07 |  | N1 | 3208h | 3208h | IMS |  |  |  | Rel-5 | Frederic |  |
| 2234 | 81.1.4.4.8 | IETF: RFC editor Queue (DHCP options for SIP servers) | 382d | 2000-11-24 A | 2002-05-13 A | 100% | 2000-11-24 | 2002-05-13 | 382d | finish no earlier than 2002-05-13 |  | N1 | 3056h | 3056h | IMS |  |  |  | Rel-5 | Frederic |  |
| 2235 | 81.1.4.4.10 | IETF: RFC 3267 (AMR and AMR WB RTP and SDP) | 346d | 2000-11-24 A | 2002-03-22 A | 100% | 2000-11-24 | 2002-03-22 | 346d | finish no earlier than 2002-03-22 |  | N1 | 2768h | 2768h | IMS |  |  |  | Rel-5 | Frederic |  |
| 2236 | 81.1.4.4.11 | IETF: RFC 3266 (IPv6 support within SDP) | 581d | 2000-01-03 A | 2002-03-22 A | 100% | 2000-01-03 | 2002-03-22 | 581d | finish no earlier than 2002-03-22 |  | N1 | 4640h | 4640h | IMS |  |  |  | Rel-5 | Frederic |  |
| 2237 | 81.1.4.4.12 | IETF: RFC 3311 (The Update method) | 382d | 2000-11-24 A | 2002-05-13 A | 100% | 2000-11-24 | 2002-05-13 | 382d | finish no earlier than 2002-05-13 |  | N1 | 3056h | 3056h | IMS |  |  |  | Rel-5 | Frederic |  |
| 2238 | 81.1.4.4.13 | IETF: RFC 3324 (Network Asserted Identity) | 382d | 2000-11-24 A | 2002-05-13 A | 100% | 2000-11-24 | 2002-05-13 | 382d | finish no earlier than 2002-05-13 |  | N1 | 3056h | 3056h | IMS |  |  |  | Rel-5 | Frederic |  |
| 2239 | 81.1.4.4.14 | IETF: RFC editor Queue (Various 3GPP Private Extensions) | 382d | 2000-11-24 A | 2002-05-13 A | 100% | 2000-11-24 | 2002-05-13 | 382d | finish no earlier than 2002-05-13 |  | N1 | 3056h | 3056h | IMS |  |  |  | Rel-5 | Frederic |  |
| 2240 | 81.1.4.5 | **Addressing** | 380d | 2000-10-09 A | 2002-03-22 A | 100% | 2000-10-09 | 2002-03-22 | 380d |  |  | S2 | 7744h | 7744h | IMS |  |  |  | Rel-5 | Maurice |  |
| 2241 | 81.1.4.5.1 | Architectural issues | 235d | 2000-10-09 A | 2001-08-31 A | 100% | 2000-10-09 | 2001-08-31 | 235d | finish no earlier than 2001-03-16 |  | S2 | 1880h | 1880h | IMS |  |  |  | Rel-5 | Maurice |  |
| 2242 | 81.1.4.5.2 | Impact on HSS | 353d | 2000-11-15 A | 2002-03-22 A | 100% | 2000-11-15 | 2002-03-22 | 353d | finish no earlier than 2002-03-22 |  | N4 | 2824h | 2824h | IMS |  |  |  | Rel-5 | Kimmo |  |
| 2243 | 81.1.4.6 | **Service Examples (Work stopped)** | 304d | 2001-04-17 A | 2002-06-14 A | 100% | 2001-04-17 | 2002-06-14 | 304d |  |  | S1 | 4864h | 4864h | IMS-Sex | 22.928 | Motorola | Mark Cataldo | Rel-5 | Alain |  |
| 2244 | 81.1.4.6.1 | IMS Framework Report (work stopped) | 304d | 2001-04-17 A | 2002-06-14 A | 100% | 2001-04-17 | 2002-06-14 | 304d | finish no earlier than 2002-06-14 |  | S1 | 2432h | 2432h | IMS-FrWk | 22.941 | SBC | Randolph Wohlert (rwohlert@tri.sbc.com) | Rel-5 | Alain |  |

Notes:
- 2221: TSGN_10 approved the change:CN1 - SA2 SIP joint meeting spotted one more place for improvement: work tasks with ID 1998 and 1278 are actually subtasks under of single CN1 WT. One WI has been approved for the CN1 WT with title "SIP Call Control protocol
- 2222: 24.228
- 2223: 24.229
- 2224: 23.218
- 2225: -
- 2226: -
- 2227: -
- 2228: -
- 2229: -
- 2230: -
- 2231: -
- 2232: -
- 2233: -
- 2234: -
- 2235: -
- 2236: -
- 2237: -
- 2238: -
- 2239: -
- 2240: -
- 2241: -
- 2242: Covered by 29.228 & 29228
- 2243: -
- 2244: -

| ID | WBS | Task | Duration | Start | Finish | Complete | Baseline start | Baseline finish | Baseline duration | Constraint | Resources | Work | Actual work | Text1 | Text4 | Text5 | Text6 | Text8 | Text3 |
| --- | --- | --- | --- | --- | --- | --- | --- | --- | --- | --- | --- | --- | --- | --- | --- | --- | --- | --- | --- |
| 2245 | 81.2 | **Access Security for IMS** | 190d | 2001-10-08 A | 2002-06-28 A | 100% | 2001-10-08 | 2002-06-28 | 190d |  | S3 | 4120h | 4120h | IMS-ASEC | Ericsson | krister.boman@emw.ericsson.se | Rel-5 | Dionisio |  |
| 2246 | 81.2.2 | IMS impacts on UICC (ISIM application) | 185d | 2001-10-08 A | 2002-06-21 A | 100% | 2001-10-08 | 2002-06-21 | 185d | finish no earlier than 2002-06-21 | T3 | 1480h | 1480h |  | Vodafone | Jeremy Norris | Rel-5 | Xavier |  |
| 2247 | 81.2.3 | SIP extensions for Integrity protection | 140d | 2001-12-17 A | 2002-06-28 A | 100% | 2001-12-17 | 2002-06-28 | 140d | finish no earlier than 2002-06-28 | N1 | 1120h | 1120h |  |  |  | Rel-5 | Frederic |  |
| 2248 | 81.3 | Security Aspects of Requirement for Network Configuration Independence | 130d | 2001-07-02 A | 2001-12-28 A | 100% | 2001-07-02 | 2001-12-28 | 130d | finish no earlier than 2001-12-28 | S3 | 1040h | 1040h | SEC1-NCI | AT&T Wireless | hugh.shieh@attws.com | Rel-5 | Dionisio |  |
| 2249 | 81.4 | Lawful interception | 410d | 2000-09-04 A | 2002-03-29 A | 100% | 2000-09-04 | 2002-03-29 | 410d | finish no earlier than 2002-03-29 | S3 | 3280h | 3280h | IMS-LI | Reg TP | berthold.wilhelm@regtp.de | Rel-5 | Dionisio | 33.106, 33.107, new 33.108 |
| 2250 | 81.5 | Charging and OAM&P for IMS | 383d | 2000-12-25 A | 2002-06-12 A | 100% | 2000-12-25 | 2002-06-12 | 383d | finish no earlier than 2002-06-12 | S5 | 3064h | 3064h | IMS-OAM | VoiceStream, Motorola |  | Rel-5 | Dionisio | 32-series |
| 2251 | 81.6 | **Multimedia codecs and protocols for conversational PS services** | 568d | 2000-07-26 A | 2002-09-27 A | 100% | 2000-07-26 | 2002-09-27 | 568d |  | S4 | 15640h | 15640h | IMS-CODEC | Toshiba, Nokia | B. Aronson (Toshiba), pasi.s.ojala@nokia.com | Rel-5 | Paolo | 26.235, 26.236 |
| 2252 | 81.6.1 | Codecs | 427d | 2000-07-26 A | 2002-03-14 A | 100% | 2000-07-26 | 2002-03-14 | 427d | finish no earlier than 2001-03-21 | S4 | 3416h | 3416h |  |  |  | Rel-5 | Paolo | 26.235, 26.236 |
| 2253 | 81.6.2 | Transport protocols | 1d | 2002-03-12 A | 2002-03-12 A | 100% | 2002-03-12 | 2002-03-12 | 1d | finish no earlier than 2002-03-12 | S4 | 8h | 8h | IMS-CODEC | Nokia | P. Ojala | Rel-5 | Paolo | 26.236 |
| 2254 | 81.6.4 | recommendation for QoS parameter values for various media types | 195d | 2001-12-31 A | 2002-09-27 A | 100% | 2001-12-31 | 2002-09-27 | 195d | finish no earlier than 2002-09-27 | S4 | 1560h | 1560h |  |  |  | Rel-5 | Paolo |  |
| 2255 | 81.6.5 | IETF: RFC 3310 (HTTP Digest Authentication using AKA) | 382d | 2000-11-24 A | 2002-05-13 A | 100% | 2000-11-24 | 2002-05-13 | 382d | finish no earlier than 2002-05-13 | N1 | 3056h | 3056h |  |  |  | Rel-5 | Frederic |  |
| 2256 | 81.6.6 | IETF: RFC 3329 (Security mechanism agreement for SIP connections) | 382d | 2000-11-24 A | 2002-05-13 A | 100% | 2000-11-24 | 2002-05-13 | 382d | finish no earlier than 2002-05-13 | N1 | 3056h | 3056h |  |  |  | Rel-5 | Frederic |  |
| 2257 | 81.7 | **SIP message compression** | 185d | 2001-09-24 A | 2002-06-07 A | 100% | 2001-09-24 | 2002-06-07 | 185d |  | S2 | 3128h | 3128h |  |  |  | Rel-5 | Maurice |  |
| 2258 | 81.7.1 | Stage 2 | 25d | 2001-09-24 A | 2001-10-26 A | 100% | 2001-09-24 | 2001-10-26 | 25d | finish no earlier than 2001-10-26 | S2 | 200h | 200h |  |  |  | Rel-5 | Maurice |  |
| 2259 | 81.7.2 | Compression signalling | 181d | 2001-09-28 A | 2002-06-07 A | 100% | 2001-09-28 | 2002-06-07 | 181d | finish no earlier than 2002-06-07 | N1 | 1448h | 1448h |  |  |  | Rel-5 | Frederic |  |
| 2260 | 81.8 | **Stage 3 description of IMS interfaces** | 383d | 2001-03-14 A | 2002-08-30 A | 100% | 2001-03-14 | 2002-08-30 | 383d |  | NP | 29531.6h | 29531.6h |  |  |  | Rel-5 | Kimmo |  |
| 2261 | 81.8.1 | Cx interface (HSS to CSCF) | 135.95d | 2001-03-14 A | 2002-06-07 A | 100% | 2001-03-14 | 2002-06-07 | 135.95d | finish no earlier than 2002-06-07 | N4 | 1087.58h | 1087.58h |  |  |  | Rel-5 | Kimmo |  |
| 2262 | 81.8.2 | Mp interface (MRFC - MRFP) enhancements | 258d | 2001-03-14 A | 2002-03-08 A | 100% | 2001-03-14 | 2002-03-08 | 258d | finish no earlier than 2002-06-07 | N4 | 2064h | 2064h |  |  |  | Rel-5 | Kimmo |  |
| 2263 | 81.8.3 | Mw interface (CSCF to P-CSCF) | 323d | 2001-03-14 A | 2002-06-07 A | 100% | 2001-03-14 | 2002-06-07 | 323d | finish no earlier than 2002-06-07 | N1 | 2584h | 2584h |  |  |  | Rel-5 | Frederic |  |
| 2264 | 81.8.4 | Mr interface (CSCF to MRF) | 273d | 2001-03-14 A | 2002-03-29 A | 100% | 2001-03-14 | 2002-03-29 | 273d | finish no earlier than 2002-03-29 | N1 | 2184h | 2184h |  |  |  | Rel-5 | Frederic |  |
| 2265 | 81.8.5 | Dx interface (I-CSCF to SLF) | 323d | 2001-03-14 A | 2002-06-07 A | 100% | 2001-03-14 | 2002-06-07 | 323d | finish no earlier than 2002-06-07 | N4 | 2584h | 2584h |  |  |  | Rel-5 | Kimmo |  |
| 2266 | 81.8.6 | Go interface (GGSN to PCF) | 323d | 2001-03-14 A | 2002-06-07 A | 100% | 2001-03-14 | 2002-06-07 | 323d | finish no earlier than 2002-06-07 | N3 | 2584h | 2584h |  |  |  | Rel-5 | Gwiho |  |
| 2267 | 81.8.7 | ISC (IMS Service Control) Interface | 323d | 2001-03-14 A | 2002-06-07 A | 100% | 2001-03-14 | 2002-06-07 | 323d | finish no earlier than 2002-06-07 | N1 | 2584h | 2584h |  |  |  | Rel-5 | Frederic |  |
| 2268 | 81.8.8 | Sh interface (HSS to AS) | 82d | 2002-02-14 A | 2002-06-07 A | 100% | 2002-02-14 | 2002-06-07 | 82d | finish no earlier than 2002-06-07 | N4 | 656h | 656h |  |  |  | Rel-5 | Kimmo |  |
| 2269 | 81.8.9 | Si interface (HSS to IM-SSF) | 162.5d | 2002-01-16 A | 2002-08-30 A | 100% | 2002-01-16 | 2002-08-30 | 162.5d | finish no earlier than 2002-06-07 | N4 | 1300h | 1300h |  |  |  | Rel-5 | Kimmo |  |
| 2270 | 81.8.10 | Gm interface (UE to CSCF) | 323d | 2001-03-14 A | 2002-06-07 A | 100% | 2001-03-14 | 2002-06-07 | 323d | finish no earlier than 2002-06-07 | N1 | 2584h | 2584h |  |  |  | Rel-5 | Frederic |  |
| 2271 | 81.8.11 | Mi interface (CSCF to BGCF) | 323d | 2001-03-14 A | 2002-06-07 A | 100% | 2001-03-14 | 2002-06-07 | 323d | finish no earlier than 2002-06-07 | N1 | 2584h | 2584h |  |  |  | Rel-5 | Frederic |  |
| 2272 | 81.8.12 | Mj interface (BGCF to MGCF) | 323d | 2001-03-14 A | 2002-06-07 A | 100% | 2001-03-14 | 2002-06-07 | 323d | finish no earlier than 2002-06-07 | N1 | 2584h | 2584h |  |  |  | Rel-5 | Frederic |  |
| 2273 | 81.8.13 | Mk interface (BGCF to BGCF) | 323d | 2001-03-14 A | 2002-06-07 A | 100% | 2001-03-14 | 2002-06-07 | 323d | finish no earlier than 2002-06-07 | N1 | 2584h | 2584h |  |  |  | Rel-5 | Frederic |  |
| 2274 | 81.9 | Support of VHE/OSA by entities and protocols of the IMS (e.g. CSCF) | 186d | 2001-09-21 A | 2002-06-07 A | 100% | 2001-09-21 | 2002-06-07 | 186d | finish no earlier than 2002-06-07 | N5 | 1488h | 1488h | IMS-ONOSA | Ericsson | Ard.Jan.Moerdijk@eln.ericsson.se | Rel-5 | Kimmo | 29.198, 29.998 |

Notes:
- 2245: TS33.203 will be presented for info at SP#14 and is scheduled for approval at SP#15. Dependencies on IETF exist. Approved SP#15
- 2246: -
- 2247: Per 26/2-02: CN1 is not aware of any requirements and is not doing anything on this task.
- 2248: Incorporated into IMS access security TS (33.203) which will be presented for info at SP#14 and is scheduled for approval at SP#15.Editors notes removed SP#16&17
- 2249: SA#17 completed
- 2250: -
- 2251: -
- 2252: -
- 2253: -
- 2254: -
- 2255: -
- 2256: -
- 2257: -
- 2258: -
- 2259: -
- 2260: -
- 2261: -
- 2262: [DAB 08-03-02] - No work required in CN4
- 2263: -
- 2264: -
- 2265: CN4#11 30/11/01: No inputs received in CN4 / 14/02/02 Completed(introduced in 29.228)
- 2266: [DAB - 23/05/03] - 100 % complete
- 2267: -
- 2268: CN4#11 30/11/01: No inputs received in CN4 / CN4#12bis 14/02/02: WID approved / 17th May 100% complete. 3GPP TS 29.329 will be sent for approval in CN#16
- 2269: SA16: Part of Rel5 only if completed in September 02. Marked as closed 12/2008 (was marked 72% complete)
- 2270: -
- 2271: -
- 2272: -
- 2273: -
- 2274: -

| ID | WBS | Task | Duration | Start | Finish | Predecessors | Complete | Baseline start | Baseline finish | Baseline duration | Constraint | Resources | Work | Actual work | Text1 | Text4 | Text5 | Text6 | Text8 | Text12 | Text3 |
| --- | --- | --- | --- | --- | --- | --- | --- | --- | --- | --- | --- | --- | --- | --- | --- | --- | --- | --- | --- | --- | --- |
| 2275 | 81.10 | **CAMEL control of IMS services** | 365d | 2001-04-16 A | 2002-09-06 A |  | 100% | 2001-04-16 | 2002-09-06 | 365d |  | N2 | 9952h | 9952h | IMS-CAMEL | Lucent | Angelica Remoquillo | Rel-5 | Kimmo |  |  |
| 2276 | 81.10.1 | Stage2 work 'general' | 365d | 2001-04-16 A | 2002-09-06 A |  | 100% | 2001-04-16 | 2002-09-06 | 365d | finish no earlier than 2002-09-06 | N2 | 2920h | 2920h |  |  |  | Rel-5 | Kimmo |  |  |
| 2277 | 81.10.2 | Stage3 work 'CAP' | 175d | 2002-01-07 A | 2002-09-06 A |  | 100% | 2002-01-07 | 2002-09-06 | 175d | finish no earlier than 2002-09-06 | N2 | 1400h | 1400h |  |  |  | Rel-5 | Kimmo |  |  |
| 2278 | 81.10.3 | Stage2 work 'Si interface' | 175d | 2002-01-07 A | 2002-09-06 A |  | 100% | 2002-01-07 | 2002-09-06 | 175d | finish no earlier than 2002-09-06 | N2 | 1400h | 1400h |  |  |  | Rel-5 | Kimmo |  |  |
| 2279 | 81.10.4 | Stage3 work 'Si interface' | 82d | 2002-02-14 A | 2002-06-07 A |  | 100% | 2002-02-14 | 2002-06-07 | 82d | finish no earlier than 2002-06-07 | N4 | 656h | 656h |  |  |  | Rel-5 | Kimmo |  |  |
| 2280 | 81.10.5 | Deleted - SDM issues for CAMEL control of IMS | 82d | 2002-02-14 A | 2002-06-07 A |  | 100% | 2002-02-14 | 2002-06-07 | 82d | finish no earlier than 2002-06-07 | N4 | 656h | 656h |  |  |  | Rel-5 | Kimmo | NP-17 |  |
| 2281 | 81.11 | Pre-pay/real-time charging in IMS | 196d | 2001-06-15 A | 2002-03-15 A |  | 100% | 2001-06-15 | 2002-03-15 | 196d | finish no earlier than 2002-03-15 | S1 | 1568h | 1568h |  |  |  | Rel-5 | Alain |  |  |
| 2282 | 81.12 | **Charging** | 289d | 2001-08-06 A | 2002-09-12 A |  | 100% | 2001-08-06 | 2002-09-12 | 289d |  | S2,S5 | 6632h | 6632h | OAM-CH | T-Mobile | karl-heinz.nenner@t-mobile.de | Rel-5 | Dionisio |  | 32.225 |
| 2283 | 81.12.1 | Charging Implications of IMS architecture | 75d | 2001-08-06 A | 2001-11-16 A |  | 100% | 2001-08-06 | 2001-11-16 | 75d | finish no earlier than 2001-11-16 | S2 | 600h | 600h |  |  |  | Rel-5 | Maurice |  |  |
| 2284 | 81.12.2 | Charging management for IMS (off-line & on-line) | 214d | 2001-11-19 A | 2002-09-12 A | 2283 | 100% | 2001-11-19 | 2002-09-12 | 214d | finish no earlier than 2002-09-12 | S5 | 1712h | 1712h | OAM-CH |  |  | Rel-5 | Dionisio |  | 32.225 |
| 2285 | 86.1.6.10 | Billing, accounting and call detail record aspects | 251d | 2001-09-27 A | 2002-09-12 A |  | 100% | 2001-09-27 | 2002-09-12 | 251d | finish no earlier than 2002-09-12 | S5 | 2008h | 2008h | OAM-CH | T-Mobile | Karl-Heinz.Nenner@T-MOBILE.DE | Rel-5 | Dionisio |  | 32.225 |
| 2286 | 81.13 | **Other IETF dependencies** | 401d | 2000-11-24 A | 2002-06-07 A |  | 100% | 2000-11-24 | 2002-06-07 | 401d |  | NP | 9624h | 9624h |  |  |  | Rel-5 |  |  |  |
| 2287 | 81.13.1 | IETF: draft-ietf-aaa-diameter - should be CN4 | 401d | 2000-11-24 A | 2002-06-07 A |  | 100% | 2000-11-24 | 2002-06-07 | 401d | finish no earlier than 2002-06-07 | NP | 3208h | 3208h |  |  |  | Rel-5 |  |  |  |
| 2288 | 81.13.2 | IETF: draft-johansson-aaa-diameter-mm-app - should be CN4 | 401d | 2000-11-24 A | 2002-06-07 A |  | 100% | 2000-11-24 | 2002-06-07 | 401d | finish no earlier than 2002-06-07 | NP | 3208h | 3208h |  |  |  | Rel-5 |  |  |  |
| 2289 | 81.15 | Conformance Test Aspects - Provisioning of IMS | 205d | 2002-03-18 A | 2002-12-27 A |  | 100% | 2002-03-18 | 2002-12-27 | 205d | finish no earlier than 2002-12-27 | T1 | 1640h | 1640h | IMS-TEST |  |  | Rel-5 | Ingbert |  |  |
| 2290 | 81.16 | Testing of support for IMS - prose | 270d | 2002-09-18 A | 2003-09-30 A |  | 100% | 2002-09-18 | 2003-09-30 | 270d | finish no earlier than 2003-09-30 | T1 | 2160h | 2160h |  | Anritsu | dan.fox@eu.anritsu.com | Rel-5 | Ingbert |  | 34.108, 34.123 |
| 2291 | 81.17 | Testing of support for IMS - TTCN | 381d | 2002-09-18 A | 2004-03-03 A |  | 100% | 2002-09-18 | 2004-03-03 | 381d | finish no earlier than 2004-03-03 | T1 | 3048h | 3048h |  | Anritsu | dan.fox@eu.anritsu.com | Rel-5 | Ingbert |  | 34.108, 34.123 |
| 2292 | 82 | **Extended Transparent End-to-End PS Streaming Service** | 313d? | 2002-01-03 A | 2003-03-17 A |  | 100% | 2002-01-03 | 2003-03-17 | 313d? |  | S4 | 6224h | 6224h | PSS-E | Ericsson | olle.franceschi@ericsson.com | Rel-5 | Paolo |  | 26.233, 26.234 |
| 2293 | 82.1 | **Stage 1** | 86d? | 2002-11-18 A | 2003-03-17 A |  | 100% | 2002-11-18 | 2003-03-17 | 86d? |  | S1 | 1376h | 1376h |  | Vodafone | stephen.wolak@vodafone.com | Rel-5 | Alain |  | 22.233 |
| 2294 | 652.1.1 | Interaction with other services | 86d? | 2002-11-18 A | 2003-03-17 A |  | 100% | 2002-11-18 | 2003-03-17 | 86d? | finish no earlier than 2003-03-17 | S1 | 688h | 688h |  | Vodafone | stephen.wolak@vodafone.com | Rel-5 | Alain |  | 22.233 |
| 2295 | 82.2 | Stage 2 (version Rel5 of TS 26.234) | 51d | 2002-01-03 A | 2002-03-14 A |  | 100% | 2002-01-03 | 2002-03-14 | 51d | finish no earlier than 2002-03-26 | S4 | 408h | 408h |  |  |  | Rel-5 | Paolo |  | 26.234 |
| 2296 | 82.3 | RTP usage model | 242d | 2002-01-03 A | 2002-12-06 A |  | 100% | 2002-01-03 | 2002-12-06 | 242d | finish no earlier than 2002-12-06 | S4 | 1936h | 1936h |  |  |  | Rel-5 | Paolo |  | 26.937 |
| 2297 | 83 | **Rel-5 OSA enhancements** | 955d | 1999-04-27 A | 2002-12-20 A |  | 100% | 1999-04-27 | 2002-12-20 | 955d |  | S1 | 62480h | 62480h | OSA1 | Siemens | Joerg Swetina (joerg.swetina@nw.neclab.eu) | Rel-5 | Alain |  | 22.127, 23.127, 29.198-x, 29.998-x |
| 2298 | 83.1 | General Stage 2 for Rel5 | 194d | 2001-09-11 A | 2002-06-07 A |  | 100% | 2001-09-11 | 2002-06-07 | 194d |  | S2 | 1232h | 1232h |  |  |  | Rel-5 | Maurice |  |  |

Notes:
- 2275: -
- 2276: DAB 12.12.01 split into cn4 and cn2 parts
- 2277: DAB 12.12.01 split into cn4 and cn2 parts
- 2278: DAB 12.12.01 split into cn4 and cn2 parts
- 2279: [DAB 08-03-02] - UID 12004 is MASTER of UID 14998 / 17 May need to be recearch possible impact on 23.008 & 23.016, changes to 29.002 are done.
- 2280: Marked as stopped 12/2008
- 2281: Marked as closed 12/2008 (was marked 60% complete)
- 2282: -
- 2283: -
- 2284: -
- 2285: -
- 2286: Was introduced at SP#13 by Ileana Leuca (exact position in the WP and related WG have to be defined)
- 2287: Marked as closed 12/2008 (was marked 90% complete)
- 2288: Marked as closed 12/2008 (was marked 50% complete)
- 2289: The task is a BB, individual work items were considered but are constrained by lack of supporting companies. Marked as stopped 12/2008
- 2290: Marked as stopped 12/2008
- 2291: Marked as stopped 12/2008
- 2292: -
- 2293: 2nd resp SA4
- 2294: 2nd resp SA4. Marked as closed 12/2008 (was marked 65% complete)
- 2295: 2nd resp SA2
- 2296: Marked as closed 12/2008 (was marked 90% complete)
- 2297: -
- 2298: Marked as closed 12/2008 (was marked 47% complete)

| ID | WBS | Task | Duration | Start | Finish | Predecessors | Complete | Baseline start | Baseline finish | Baseline duration | Constraint | Resources | Work | Actual work | Text1 | Text6 | Text8 | Text3 | Text4 | Text5 |
| --- | --- | --- | --- | --- | --- | --- | --- | --- | --- | --- | --- | --- | --- | --- | --- | --- | --- | --- | --- | --- |
| 2299 | 83.2 | **OSA APIs for Multimedia Call Control** | 499d | 2000-07-11 A | 2002-06-07 A |  | 100% | 2000-07-11 | 2002-06-07 | 499d |  | S2 | 5960h | 5960h | OSA1-CSCF | Rel-5 | Maurice |  |  |  |
| 2300 | 83.2.1 | Stage 1 | 438d | 2000-07-11 A | 2002-03-14 A |  | 100% | 2000-07-11 | 2002-03-14 | 438d | finish no earlier than 2002-03-14 | S1 | 3504h | 3504h |  | Rel-5 | Alain | 22.127 | Siemens | Manfred.leitgeb@siemens.at |
| 2301 | 83.2.2 | Multimedia Call Control - Stages 2 and 3 | 194d | 2001-09-11 A | 2002-06-07 A |  | 100% | 2001-09-11 | 2002-06-07 | 194d | finish no earlier than 2002-06-07 | N5 | 1552h | 1552h |  | Rel-5 | Kimmo | 29.198-04 |  |  |
| 2302 | 83.3 | Generic user interaction - Stage 3 | 194d | 2001-09-11 A | 2002-06-07 A |  | 100% | 2001-09-11 | 2002-06-07 | 194d | finish no earlier than 2002-06-07 | N5 | 1552h | 1552h |  | Rel-5 | Kimmo | 29.198-05 |  |  |
| 2303 | 83.4 | Charging - Stage 3 | 194d | 2001-09-11 A | 2002-06-07 A |  | 100% | 2001-09-11 | 2002-06-07 | 194d | finish no earlier than 2002-06-07 | N5 | 1552h | 1552h |  | Rel-5 | Kimmo | 29.198-12 |  |  |
| 2304 | 83.5 | Call Control Service Mapping; Multiparty Call Control SIP - Stage 3 | 194d | 2001-09-11 A | 2002-06-07 A |  | 100% | 2001-09-11 | 2002-06-07 | 194d | finish no earlier than 2002-06-07 | N5 | 1552h | 1552h |  | Rel-5 | Kimmo | 29.998-04-4 |  |  |
| 2305 | 83.6 | WSDL APIs for SOAP/HTTP - Stage 3 | 455d | 2000-09-11 A | 2002-06-07 A |  | 100% | 2000-09-11 | 2002-06-07 | 455d | finish no earlier than 2002-06-07 | N5 | 3640h | 3640h |  | Rel-5 | Kimmo | 29.198, 29.998 |  |  |
| 2306 | 83.7 | **OSA security** | 639d | 2000-07-11 A | 2002-12-20 A |  | 100% | 2000-07-11 | 2002-12-20 | 639d |  | S3 | 15000h | 15000h | OSA1-SEC | Rel-5 | Dionisio |  | BT | colin.blanchard@bt.com |
| 2307 | 83.7.1 | Stage 1 | 349d | 2000-07-11 A | 2001-11-09 A |  | 100% | 2000-07-11 | 2001-11-09 | 349d | finish no earlier than 2001-11-09 | S1 | 2792h | 2792h |  | Rel-5 | Alain | 22.127 | Siemens | Manfred.leitgeb@siemens.at |
| 2308 | 83.7.2 | Stage 3 | 430d | 2000-10-23 A | 2002-06-14 A |  | 100% | 2000-10-23 | 2002-06-14 | 430d | finish no earlier than 2002-06-14 | S3 | 3440h | 3440h |  | Rel-5 | Dionisio |  |  |  |
| 2309 | 83.7.3 | security related SCF(s) definition | 186d | 2001-09-21 A | 2002-06-07 A |  | 100% | 2001-09-21 | 2002-06-07 | 186d | finish no earlier than 2002-06-07 | N5 | 1488h | 1488h |  | Rel-5 | Kimmo | 29.198, 29.998 | Ericsson | Ard.Jan.Moerdijk@eln.ericsson.se |
| 2310 | 83.7.4 | changes required from supporting platforms, e.g. gsmSCF, HLR | 69d | 2000-09-11 A | 2000-12-14 A |  | 100% | 2000-09-11 | 2000-12-14 | 69d | finish no earlier than 2000-12-14 | S3 | 552h | 552h |  | Rel-5 | Dionisio |  |  |  |
| 2311 | 653.7.5 | Security (moved from Rel-6) | 202d | 2002-03-14 A | 2002-12-20 A |  | 100% | 2002-03-14 | 2002-12-20 | 202d | finish no earlier than 2002-12-20 | S3 | 1616h | 1616h |  | Rel-5 | Dionisio |  |  |  |
| 2312 | 83.8 | **Interactions OSA - e-commerce** | 815d | 1999-04-27 A | 2002-06-07 A |  | 100% | 1999-04-27 | 2002-06-07 | 815d |  | S2 | 6152h | 6152h | OSA1-ECOM | Rel-5 | Maurice |  |  |  |
| 2313 | 83.8.1 | Stage 1 | 439d | 1999-04-27 A | 2000-12-28 A |  | 100% | 1999-04-27 | 2000-12-28 | 439d | finish no earlier than 2000-12-28 | S1 | 3504h | 3504h |  | Rel-5 | Alain | 22.127 | Siemens | Joerg Swetina (joerg.swetina@nw.neclab.eu) |
| 2314 | 83.8.2 | Stages 2 and 3 | 186d | 2001-09-21 A | 2002-06-07 A |  | 100% | 2001-09-21 | 2002-06-07 | 186d | finish no earlier than 2002-06-07 | N5 | 1488h | 1488h |  | Rel-5 | Kimmo | 29.198, 29.998 | Ericsson | Ard.Jan.Moerdijk@eln.ericsson.se |
| 2315 | 83.9 | Policy Management - Stage 3 | 194d | 2001-09-11 A | 2002-06-07 A |  | 100% | 2001-09-11 | 2002-06-07 | 194d | finish no earlier than 2002-06-07 | N5 | 1552h | 1552h |  | Rel-5 | Kimmo | 29.198-13 |  |  |
| 2316 | 83.10 | Presence and Availability Management (PAM) - Stage 3 | 194d | 2001-09-11 A | 2002-06-07 A |  | 100% | 2001-09-11 | 2002-06-07 | 194d | finish no earlier than 2002-06-07 | N5 | 1552h | 1552h |  | Rel-5 | Kimmo | 29.198-14 |  |  |
| 2317 | 83.11 | **CHECK STATUS - LCS - OSA interfaces** | 455d | 2000-09-11 A | 2002-06-07 A |  | 100% | 2000-09-11 | 2002-06-07 | 455d |  | S1 | 5656h | 5656h | OSA1-LCSI | Rel-5 | Alain |  | Siemens | Joerg Swetina (joerg.swetina@nw.neclab.eu) |
| 2318 | 83.11.1 | Stage 1 | 65d | 2000-09-11 A | 2000-12-08 A |  | 100% | 2000-09-11 | 2000-12-08 | 65d | finish no earlier than 2000-12-08 | S1 | 520h | 520h |  | Rel-5 | Alain | 22.127 | Siemens | Joerg Swetina (joerg.swetina@nw.neclab.eu) |
| 2319 | 83.11.2 | Stage 2 | 1d | 2000-12-11 A | 2000-12-11 A | 2318 | 100% | 2000-12-11 | 2000-12-11 | 1d | finish no earlier than 2000-12-11 | S2 | 8h | 8h |  | Rel-5 | Maurice | 23.127 | Ericsson | Christophe GOURRAUD |
| 2320 | 83.11.3 | Stage 3 | 186d | 2001-09-21 A | 2002-06-07 A | 2319 | 100% | 2001-09-21 | 2002-06-07 | 186d | finish no earlier than 2002-06-07 | N5 | 1488h | 1488h |  | Rel-5 | Kimmo | 29.198, 29.998 | Ericsson | Ard.Jan.Moerdijk@eln.ericsson.se |
| 2321 | 653.12 | Access to User Profile | 145d | 2001-06-01 A | 2001-12-20 A |  | 100% | 2001-06-01 | 2001-12-20 | 145d | finish no earlier than 2001-12-20 | S1 | 1160h | 1160h | OSA2-UP | Rel-5 | Alain |  |  |  |
| 2322 | 653.13 | **Retrieval of Terminal capabilities** | 634d | 2000-07-11 A | 2002-12-13 A |  | 100% | 2000-07-11 | 2002-12-13 | 634d |  | S2 | 10808h | 10808h | OSA2-TC | Rel-5 | Maurice |  |  |  |
| 2323 | 653.13.1 | Stage 1 | 132d | 2000-07-11 A | 2001-01-10 A |  | 100% | 2000-07-11 | 2001-01-10 | 132d | finish no earlier than 2001-01-10 | S1 | 1056h | 1056h |  | Rel-5 | Alain | 22.127 | Siemens | Joerg Swetina (joerg.swetina@nw.neclab.eu) |
| 2324 | 653.13.2 | Stages 2 and 3 | 321d | 2001-09-21 A | 2002-12-13 A | 2323 | 100% | 2001-09-21 | 2002-12-13 | 321d | finish no earlier than 2002-12-13 | N5 | 2568h | 2568h |  | Rel-5 | Kimmo | 29.198, 29.998 | Ericsson | Ard.Jan.Moerdijk@eln.ericsson.se |
| 2325 | 653.13.3 | Provisioning of the terminal capabilities | 445d | 2001-04-02 A | 2002-12-13 A |  | 100% | 2001-04-02 | 2002-12-13 | 445d | finish no earlier than 2002-12-13 | T2 | 3560h | 3560h |  | Rel-5 |  | 23.057 |  |  |

Notes:
- 2299: For Rel5 even if completed by March
- 2300: -
- 2301: -
- 2302: -
- 2303: -
- 2304: -
- 2305: -
- 2306: CR to correct security specifications in 29.198 scheduled for approval at CN#15
- 2307: -
- 2308: Marked as closed 12/2008 (was marked 80% complete)
- 2309: -
- 2310: -
- 2311: Contribution at S3#25
- 2312: -
- 2313: Marked as closed 12/2008 (was marked 95% complete)
- 2314: -
- 2315: -
- 2316: -
- 2317: az: CN#13 - changed to Rel5
- 2318: -
- 2319: az 24/05/01: Rel4 completion 90->100%.
- 2320: -
- 2321: -
- 2322: -
- 2323: -
- 2324: -
- 2325: According to T2 SWG1 M. Cataldo this is automatically supported by the MExE support of UAProf therefore 100% complete

| ID | WBS | Task | Duration | Start | Finish | Predecessors | Complete | Baseline start | Baseline finish | Baseline duration | Constraint | Resources | Work | Actual work | Text1 | Text4 | Text5 | Text6 | Text8 | Text3 |
| --- | --- | --- | --- | --- | --- | --- | --- | --- | --- | --- | --- | --- | --- | --- | --- | --- | --- | --- | --- | --- |
| 2326 | 84 | **CAMEL phase 4** | 625d | 2000-04-17 A | 2002-09-06 A |  | 100% | 2000-04-17 | 2002-09-06 | 625d |  | S1 | 41104h | 41104h | CAMEL4 | Nokia | keijo.palviainen@nokia.com | Rel-5 | Alain |  |
| 2327 | 84.1 | Service requirements | 565d | 2000-04-17 A | 2002-06-14 A |  | 100% | 2000-04-17 | 2002-06-14 | 565d | finish no earlier than 2002-06-14 | S1 | 4520h | 4520h |  |  |  | Rel-5 | Alain |  |
| 2328 | 84.2 | Call Party Handling | 500d | 2000-07-10 A | 2002-06-07 A |  | 100% | 2000-07-10 | 2002-06-07 | 500d | finish no earlier than 2002-06-07 | N2 | 4000h | 4000h | CAMEL4-CPH |  |  | Rel-5 | Kimmo |  |
| 2329 | 84.3 | Mid call procedure for MO and MT calls | 495d | 2000-07-17 A | 2002-06-07 A |  | 100% | 2000-07-17 | 2002-06-07 | 495d | finish no earlier than 2002-06-07 | N2 | 3960h | 3960h | CAMEL4-MCP |  |  | Rel-5 | Kimmo |  |
| 2330 | 84.4 | Interactions with Optimal Routing | 430d | 2000-07-17 A | 2002-03-08 A |  | 100% | 2000-07-17 | 2002-03-08 | 430d | finish no earlier than 2002-03-08 | N2 | 3440h | 3440h | CAMEL4-IOR |  |  | Rel-5 | Kimmo |  |
| 2331 | 84.5 | Inclusion of flexible tone injection | 430d | 2000-07-17 A | 2002-03-08 A |  | 100% | 2000-07-17 | 2002-03-08 | 430d | finish no earlier than 2002-03-08 | N2 | 3440h | 3440h | CAMEL4-IFTI |  |  | Rel-5 | Kimmo |  |
| 2332 | 84.6 | CSE control over MT SMS | 430d | 2000-07-17 A | 2002-03-08 A |  | 100% | 2000-07-17 | 2002-03-08 | 430d | finish no earlier than 2002-03-08 | N2 | 3440h | 3440h | CAMEL4-CCSMS |  |  | Rel-5 | Kimmo |  |
| 2333 | 84.7 | Notification of GPRS mobility management to CSE | 331d | 2001-03-02 A | 2002-06-07 A |  | 100% | 2001-03-02 | 2002-06-07 | 331d | finish no earlier than 2002-06-07 | N2 | 2648h | 2648h | CAMEL4-NMM |  |  | Rel-5 | Kimmo |  |
| 2334 | 84.8 | Provision of location information of called subscriber | 266d | 2001-03-02 A | 2002-03-08 A |  | 100% | 2001-03-02 | 2002-03-08 | 266d | finish no earlier than 2002-03-08 | N2 | 2128h | 2128h | CAMEL4-LOCB |  |  | Rel-5 | Kimmo |  |
| 2335 | 84.9 | Inclusion of ODB data in the CSE_HLR interface | 175d | 2001-07-09 A | 2002-03-08 A |  | 100% | 2001-07-09 | 2002-03-08 | 175d | finish no earlier than 2002-03-08 | N2 | 1400h | 1400h | CAMEL4-ODB |  |  | Rel-5 | Kimmo |  |
| 2336 | 84.10 | Location information during an ongoing call (Handover DP) | 280d | 2001-05-14 A | 2002-06-07 A |  | 100% | 2001-05-14 | 2002-06-07 | 280d | finish no earlier than 2002-06-07 | N2 | 2240h | 2240h | CAMEL4-HODP |  |  | Rel-5 | Kimmo |  |
| 2337 | 84.11 | GPRS Any Time Interrogation | 240d | 2001-07-09 A | 2002-06-07 A |  | 100% | 2001-07-09 | 2002-06-07 | 240d | finish no earlier than 2002-06-07 | N2 | 1920h | 1920h | CAMEL4-ATI |  |  | Rel-5 | Kimmo |  |
| 2338 | 84.12 | Transfer of IMEI (with SW version) to CSE | 240d | 2001-07-09 A | 2002-06-07 A |  | 100% | 2001-07-09 | 2002-06-07 | 240d | finish no earlier than 2002-06-07 | N2 | 1920h | 1920h | CAMEL4-ATI |  |  | Rel-5 | Kimmo |  |
| 2339 | 84.13 | Handling of partial implementations of CAMEL4 | 131d | 2002-03-08 A | 2002-09-06 A |  | 100% | 2002-03-08 | 2002-09-06 | 131d | finish no earlier than 2002-06-07 | N2 | 1048h | 1048h | CAMEL4-SUB |  |  | Rel-5 | Kimmo |  |
| 2340 | 85 | **Rel-5 MExE enhancements** | 250d | 2001-03-26 A | 2002-03-08 A |  | 100% | 2001-03-26 | 2002-03-08 | 250d |  | T2 | 2880h | 2880h | MEXE5 |  |  | Rel-5 | Kimmo |  |
| 2341 | 85.1 | MExE Rel-5 Improvements and Investigations | 110d | 2001-03-26 A | 2002-03-08 A |  | 100% | 2001-03-26 | 2002-03-08 | 110d | finish no earlier than 2001-12-17 | T2 | 880h | 880h | MEXE5-ENHANC | Motorola | Mark Cataldo | Rel-5 | Kimmo | 22.057, 23.057 |
| 2342 | 86 | **Wideband Telephony Service - AMR** | 1036d | 2000-01-01 A | 2003-12-19 A |  | 100% | 2000-01-01 | 2003-12-19 | 1036d |  | S4 | 81496h | 81496h | AMRWB | Siemens | Imre.Varga@mch.siemens.de | Rel-5 | Paolo |  |
| 2343 | 86.1 | **Specification** | 636d | 2000-01-01 A | 2002-06-07 A |  | 100% | 2000-01-01 | 2002-06-07 | 636d |  | S4 | 19984h | 19984h |  |  |  | Rel-5 | Paolo |  |
| 2344 | 86.1.1 | Stage 1 | 125d | 2001-10-01 A | 2002-03-22 A |  | 100% | 2001-10-01 | 2002-03-22 | 125d | finish no earlier than 2002-03-22 | S1 | 1000h | 1000h |  |  |  | Rel-5 | Alain |  |
| 2345 | 86.1.2 | **Stage 2** | 77d | 2000-01-03 A | 2000-04-17 A |  | 100% | 2000-01-03 | 2000-04-17 | 77d |  | S4 | 1232h | 1232h |  |  |  | Rel-5 | Paolo |  |
| 2346 | 86.1.2.1 | Design Constraints | 27d | 2000-01-03 A | 2000-02-07 A |  | 100% | 2000-01-03 | 2000-02-07 | 27d |  | S4 [96.3%] | 208h | 208h |  |  |  | Rel-5 | Paolo |  |
| 2347 | 86.1.2.2 | General Description | 51d | 2000-02-07 A | 2000-04-17 A | 2346 | 100% | 2000-02-07 | 2000-04-17 | 51d | start no earlier than 2000-09-25 | S4 | 408h | 408h |  |  |  | Rel-5 | Paolo |  |
| 2348 | 86.1.3 | Feasibility Study | 26d | 2000-04-28 A | 2000-06-02 A | 2347 | 100% | 2000-04-28 | 2000-06-02 | 26d | finish no earlier than 2000-06-02 | S4 | 208h | 208h |  |  |  | Rel-5 | Paolo | 26.901 |
| 2349 | 86.1.4 | N1 Aspects | 66d | 2001-09-21 A | 2001-12-21 A |  | 100% | 2001-09-21 | 2001-12-21 | 66d | finish no earlier than 2001-12-21 | N1 | 528h | 528h |  |  |  | Rel-5 | Frederic |  |
| 2350 | 86.1.5 | N4 work | 83d | 2002-02-13 A | 2002-06-07 A |  | 100% | 2002-02-13 | 2002-06-07 | 83d | finish no earlier than 2002-06-07 | N4 | 664h | 664h |  |  |  | Rel-5 | Kimmo |  |

Notes:
- 2326: -
- 2327: -
- 2328: -
- 2329: -
- 2330: -
- 2331: -
- 2332: -
- 2333: -
- 2334: -
- 2335: Added on May 29, 2001
- 2336: -
- 2337: -
- 2338: -
- 2339: stage2 and stage3 CRs for approval at CN#17
- 2340: -
- 2341: -
- 2342: -
- 2343: -
- 2344: -
- 2345: -
- 2346: -
- 2347: -
- 2348: S4,TD SP-000024: TR 26.901 v.4.0.0
- 2349: Some of N1 tasks: Indication of supported codecs by the MS, Bearer cap negociation, codec indication to MS... / One common set of codec negotiation procedures will be specified as in ID1657.
- 2350: CN4#11 30/11/01: No inputs to CN4 at this meeting / 14/02/02 work started 50% reached / 17 May work is done 100%

| ID | WBS | Task | Duration | Start | Finish | Predecessors | Complete | Baseline start | Baseline finish | Baseline duration | Constraint | Resources | Work | Actual work | Text6 | Text8 | Text1 | Text3 | Text12 | Text4 | Text5 |
| --- | --- | --- | --- | --- | --- | --- | --- | --- | --- | --- | --- | --- | --- | --- | --- | --- | --- | --- | --- | --- | --- |
| 2351 | 86.1.6 | **Codec issues** | 636d | 2000-01-03 A | 2002-06-07 A |  | 100% | 2000-01-03 | 2002-06-07 | 636d |  | S4 | 9496h | 9496h | Rel-5 | Paolo |  |  |  |  |  |
| 2352 | 86.1.6.1 | Codec qualification | 86d | 2000-02-02 A | 2000-05-31 A |  | 100% | 2000-02-02 | 2000-05-31 | 86d | finish no earlier than 2000-05-31 | S4 | 688h | 688h | Rel-5 | Paolo |  |  |  |  |  |
| 2353 | 86.1.6.2 | Codec selection tests | 102d | 2000-06-01 A | 2000-10-20 A | 2352 | 100% | 2000-06-01 | 2000-10-20 | 102d | finish no earlier than 2000-10-20 | S4 | 816h | 816h | Rel-5 | Paolo |  |  |  |  |  |
| 2354 | 86.1.6.3 | Codec selection | 5d | 2000-10-23 A | 2000-10-27 A | 2353 | 100% | 2000-10-23 | 2000-10-27 | 5d | finish no earlier than 2000-10-27 | S4 | 40h | 40h | Rel-5 | Paolo |  |  |  |  |  |
| 2355 | 86.1.6.4 | TFO AMR-WB | 63d | 2001-12-18 A | 2002-03-14 A |  | 100% | 2001-12-18 | 2002-03-14 | 63d | finish no earlier than 2002-03-14 | S4 | 504h | 504h | Rel-5 | Paolo | AMRWB-TFO |  |  |  |  |
| 2356 | 86.1.6.5 | Other codec issues (verif., characterization) | 441d | 2000-09-29 A | 2002-06-07 A |  | 100% | 2000-09-29 | 2002-06-07 | 441d | finish no earlier than 2002-06-07 | S4 | 3528h | 3528h | Rel-5 | Paolo |  | 26.976 |  |  |  |
| 2357 | 86.1.6.6 | AMR-WB and narrrowband interworking | 121d | 2001-09-27 A | 2002-03-14 A |  | 100% | 2001-09-27 | 2002-03-14 | 121d | finish no earlier than 2002-03-14 | S4 | 968h | 968h | Rel-5 | Paolo | AMRWB-IWG |  |  |  |  |
| 2358 | 86.1.6.7 | Interworking with fixed broadband networks | 121d | 2001-09-27 A | 2002-03-14 A |  | 100% | 2001-09-27 | 2002-03-14 | 121d | finish no earlier than 2002-03-14 | S4 | 968h | 968h | Rel-5 | Paolo |  |  |  |  |  |
| 2359 | 86.1.6.8 | Tones and announcements | 121d | 2001-09-27 A | 2002-03-14 A |  | 100% | 2001-09-27 | 2002-03-14 | 121d | finish no earlier than 2002-03-14 | S4 | 968h | 968h | Rel-5 | Paolo |  |  |  |  |  |
| 2360 | 86.1.6.9 | Deleted - WB Conferencing and WB Voice Group calls | 1d | 2000-01-03 A | 2000-01-03 A |  | 100% | 2000-01-03 | 2000-01-03 | 1d | finish no earlier than 2000-01-03 | S1 | 8h | 8h | Rel-5 | Alain |  |  | SP-07 |  |  |
| 2361 | 86.1.8 | **Conformance tests (CRs to 34 series)** | 74d | 2000-01-01 A | 2000-04-12 A |  | 100% | 2000-01-01 | 2000-04-12 | 74d |  | T1 | 1768h | 1768h | Rel-5 | Ingbert |  |  |  |  |  |
| 2362 | 86.1.8.1 | **Terminal Acoustic Characteristics** | 74d | 2000-01-01 A | 2000-04-12 A |  | 100% | 2000-01-01 | 2000-04-12 | 74d |  | S4 | 1176h | 1176h | Rel-5 | Paolo |  |  |  |  |  |
| 2363 | 86.1.8.1.1 | Definition | 22d | 2000-01-01 A | 2000-01-31 A |  | 100% | 2000-01-01 | 2000-01-31 | 22d | finish no earlier than 2000-01-28 | S4 [95.5%] | 168h | 168h | Rel-5 | Paolo |  | 26.131 |  |  |  |
| 2364 | 86.1.8.1.2 | Test specification | 52d | 2000-02-01 A | 2000-04-12 A | 2363 | 100% | 2000-02-01 | 2000-04-12 | 52d | finish no earlier than 2000-03-13 | S4 | 416h | 416h | Rel-5 | Paolo |  | 26.132 |  |  |  |
| 2365 | 86.2 | Floating-point ANSI-C code for the AMR-WB speech codec | 123d | 2001-09-25 A | 2002-03-14 A |  | 100% | 2001-09-25 | 2002-03-14 | 123d | finish no earlier than 2002-03-14 | S4 | 984h | 984h | Rel-5 | Paolo | AMRWB-FP | 26.204 |  | Nokia | janne.m.vainio@nokia.com |
| 2366 | 86.3 | **Support of AMR-WB in GERAN: GMSK and 8PSK WB FR / HR** | 651d | 2000-01-03 A | 2002-06-28 A |  | 100% | 2000-01-03 | 2002-06-28 | 651d |  | GP | 23488h | 23488h | Rel-5 | Paolo | GAMRWB |  |  |  |  |
| 2367 | 86.3.1 | Channel coding in 45.003 | 591d | 2000-01-03 A | 2002-04-05 A |  | 100% | 2000-01-03 | 2002-04-05 | 591d |  | GP | 4720h | 4720h | Rel-5 | Paolo |  |  |  |  |  |
| 2368 | 86.3.2 | Signalling for the A interface | 391d | 2000-01-03 A | 2001-06-29 A |  | 100% | 2000-01-03 | 2001-06-29 | 391d | finish no earlier than 2001-06-29 | GP | 3120h | 3120h | Rel-5 | Paolo |  |  |  |  |  |
| 2369 | 86.3.3 | Signalling for Iu | 651d | 2000-01-03 A | 2002-06-28 A |  | 100% | 2000-01-03 | 2002-06-28 | 651d | finish no earlier than 2002-06-28 | GP | 5200h | 5200h | Rel-5 | Paolo |  |  |  |  |  |
| 2370 | 86.3.4 | Receiver performance in TS 45.005 | 325d | 2001-04-02 A | 2002-06-28 A |  | 100% | 2001-04-02 | 2002-06-28 | 325d | finish no earlier than 2002-06-28 | GP | 2600h | 2600h | Rel-5 | Paolo |  |  |  |  |  |
| 2371 | 86.3.5 | Link Adaptation in 45.009 | 330d | 2001-03-26 A | 2002-06-28 A |  | 100% | 2001-03-26 | 2002-06-28 | 330d | finish no earlier than 2002-06-28 | GP | 2640h | 2640h | Rel-5 | Paolo |  |  |  |  |  |
| 2372 | 86.4 | **Deleted - GERAN MS conformance test for AMR-WB** | 1036d | 2000-01-03 A | 2003-12-19 A |  | 100% | 2000-01-03 | 2003-12-19 | 1036d |  | GP | 16568h | 16568h | Rel-5 | Paolo |  |  |  |  |  |
| 2373 | 86.4.1 | Deleted - MS test for AMR-WB | 1036d | 2000-01-03 A | 2003-12-19 A |  | 100% | 2000-01-03 | 2003-12-19 | 1036d | finish no earlier than 2003-12-19 | GP | 8280h | 8280h | Rel-5 | Paolo |  |  | GP-17 |  |  |
| 2374 | 86.5 | **GERAN BTS conformance test for AMR-WB** | 762d | 2000-01-03 A | 2002-12-02 A |  | 100% | 2000-01-03 | 2002-12-02 | 762d |  | GP | 12184h | 12184h | Rel-5 | Paolo |  |  |  |  |  |
| 2375 | 86.5.1 | BTS test | 762d | 2000-01-03 A | 2002-12-02 A |  | 100% | 2000-01-03 | 2002-12-02 | 762d | finish no earlier than 2002-12-02 | GP | 6088h | 6088h | Rel-5 | Paolo |  |  |  |  |  |

Notes:
- 2351: -
- 2352: -
- 2353: -
- 2354: -
- 2355: -
- 2356: ANSI C-Code , Test Sequences, Speech Transcoding Functions, Error Concealment of lost frames, Source Controlled Bit-Rate Operation, Voice Activity Detector, Frame Structure
- 2357: -
- 2358: -
- 2359: -
- 2360: -
- 2361: -
- 2362: -
- 2363: -
- 2364: -
- 2365: -
- 2366: -
- 2367: 50098 -> 50298
- 2368: -
- 2369: -
- 2370: -
- 2371: -
- 2372: Not started 02/2003. Marked as stopped 12/2008
- 2373: Marked as stopped 12/2008
- 2374: -
- 2375: -

| ID | WBS | Task | Duration | Start | Finish | Complete | Baseline start | Baseline finish | Baseline duration | Constraint | Resources | Work | Actual work | Text1 | Text6 | Text8 | Text3 | Text4 | Text5 |
| --- | --- | --- | --- | --- | --- | --- | --- | --- | --- | --- | --- | --- | --- | --- | --- | --- | --- | --- | --- |
| 2376 | 11 | **Terminal interfaces** | 223d | 2001-05-14 A | 2002-03-20 A | 100% | 2001-05-14 | 2002-03-20 | 223d |  | T2 | 3568h | 3568h | TI | Rel-5 | Kimmo |  |  |  |
| 2377 | 87 | Terminal local model enhancements | 223d | 2001-05-14 A | 2002-03-20 A | 100% | 2001-05-14 | 2002-03-20 | 223d | finish no earlier than 2002-03-20 | T2 | 1784h | 1784h | TLM5 | Rel-5 |  | 23.227 |  |  |
| 2378 | 88 | **Rel-5 Location Services enhancements** | 845d | 2000-04-03 A | 2003-06-27 A | 100% | 2000-04-03 | 2003-06-27 | 845d |  | S2,S5 | 86804h | 86804h | LCS1 | Rel-5 | Maurice |  | Nokia | Jan Kall |
| 2379 | 88.1 | **UE positioning** | 315d | 2001-01-15 A | 2002-03-29 A | 100% | 2001-01-15 | 2002-03-29 | 315d |  | RP | 5560h | 5560h | LCS1-UEpos | Rel-5 | Issam |  |  |  |
| 2380 | 88.1.1 | UE positioning enhancements for 1.28 Mcps TDD | 255d | 2001-04-09 A | 2002-03-29 A | 100% | 2001-04-09 | 2002-03-29 | 255d | finish no earlier than 2002-03-29 | R2 | 2040h | 2040h | LCS-128Pos | Rel-5 | Joern |  | CATT | Xiaohua Mei |
| 2381 | 88.1.2 | Open SMLC-SRNC Interface within the UTRAN to support A-GPS Positioning | 195d | 2001-01-15 A | 2001-10-12 A | 100% | 2001-01-15 | 2001-10-12 | 195d |  | R2 | 1560h | 1560h | LCS-INTF | Rel-5 | Joern |  | Qualcomm | Kirk Burroughs |
| 2382 | 88.2 | **Event based and Periodic LCS** | 535d | 2000-05-22 A | 2002-06-07 A | 100% | 2000-05-22 | 2002-06-07 | 535d |  | S1 | 6288h | 6288h | LCS1-EBP | Rel-5 | Alain |  |  |  |
| 2383 | 88.2.1 | Stage 1 | 130d | 2000-05-22 A | 2000-11-17 A | 100% | 2000-05-22 | 2000-11-17 | 130d | finish no earlier than 2000-07-21 | S1 | 1040h | 1040h |  | Rel-5 | Alain | 22.071 | Pacific Bell Wireless | Randolph Wohlert (rwohlert@tri.sbc.com) |
| 2384 | 88.2.2 | Stage 2 specification | 60d | 2000-11-06 A | 2001-01-26 A | 100% | 2000-11-06 | 2001-01-26 | 60d | finish no earlier than 2001-01-26 | S2 | 480h | 480h |  | Rel-5 | Maurice |  |  |  |
| 2385 | 88.2.3 | Impact on MAP | 61d | 2002-03-15 A | 2002-06-07 A | 100% | 2002-03-15 | 2002-06-07 | 61d | finish no earlier than 2002-06-07 | N4 | 488h | 488h |  | Rel-5 | Kimmo |  |  |  |
| 2386 | 88.3 | **Location Services for GERAN in A/Gb Mode** | 485d | 2000-04-03 A | 2002-02-08 A | 100% | 2000-04-03 | 2002-02-08 | 485d |  | GP | 14760h | 14760h | LCS-GERAN | Rel-5 | Paolo |  |  |  |
| 2387 | 88.3.1 | GERAN LCS Stage 2 (first release) | 485d | 2000-04-03 A | 2002-02-08 A | 100% | 2000-04-03 | 2002-02-08 | 485d | finish no earlier than 2002-02-08 | GP,S2,G1,G2 | 3880h | 3880h |  | Rel-5 | Paolo |  |  |  |
| 2388 | 88.3.2 | Gb interface support for LCS | 370d | 2000-04-03 A | 2001-08-31 A | 100% | 2000-04-03 | 2001-08-31 | 370d | finish no earlier than 2001-08-31 | GP | 2960h | 2960h |  | Rel-5 | Paolo |  |  |  |
| 2389 | 88.3.3 | L3 protocol support for LCS | 305d | 2000-04-03 A | 2001-06-01 A | 100% | 2000-04-03 | 2001-06-01 | 305d | finish no earlier than 2001-06-01 | GP | 2440h | 2440h |  | Rel-5 | Paolo |  |  |  |
| 2390 | 88.3.4 | Stage 3 specifications | 305d | 2000-04-03 A | 2001-06-01 A | 100% | 2000-04-03 | 2001-06-01 | 305d | finish no earlier than 2001-06-01 | GP | 2440h | 2440h |  | Rel-5 | Paolo |  |  |  |
| 2391 | 88.4 | **Location Services for GERAN in Iu Mode** | 585d | 2000-04-03 A | 2002-06-28 A | 100% | 2000-04-03 | 2002-06-28 | 585d |  | S2,G1,G2,R2,R3 | 20996h | 20996h |  | Rel-5 | Paolo |  |  |  |
| 2392 | 88.4.1 | GERAN LCS Stage 2 | 585d | 2000-04-03 A | 2002-06-28 A | 100% | 2000-04-03 | 2002-06-28 | 585d | finish no earlier than 2002-06-28 | S2,G1,G2 | 4680h | 4680h |  | Rel-5 | Paolo |  |  |  |
| 2393 | 88.4.2 | Iu-ps interface support for LCS | 585d | 2000-04-03 A | 2002-06-28 A | 100% | 2000-04-03 | 2002-06-28 | 585d | finish no earlier than 2002-06-28 | R2,R3 | 4680h | 4680h |  | Rel-5 | Paolo |  |  |  |
| 2394 | 88.4.3 | Iu-cs interface support for LCS | 585d | 2000-04-03 A | 2002-06-28 A | 100% | 2000-04-03 | 2002-06-28 | 585d | finish no earlier than 2002-06-28 | R2,R3 | 4680h | 4680h |  | Rel-5 | Paolo |  |  |  |
| 2395 | 88.4.4 | Iur-g interface support for LCS | 62.5d | 2002-01-23 A | 2002-04-19 A | 100% | 2002-01-23 | 2002-04-19 | 62.5d | finish no earlier than 2002-04-19 | G1,G2 | 500h | 500h |  | Rel-5 | Paolo |  |  |  |
| 2396 | 88.4.5 | RRC protocol support for LCS | 75d | 2001-08-20 A | 2001-11-30 A | 100% | 2001-08-20 | 2001-11-30 | 75d | finish no earlier than 2001-11-30 | G1,G2,R2,R3 | 600h | 600h |  | Rel-5 | Paolo |  |  |  |
| 2397 | 88.4.6 | Additional impacts on Broadcast of LCS data on packet channels | 77.5d | 2001-08-20 A | 2001-12-05 A | 100% | 2001-08-20 | 2001-12-05 | 77.5d | finish no earlier than 2001-12-05 | G1,G2,R2,R3 | 620h | 620h |  | Rel-5 | Paolo |  |  |  |
| 2398 | 88.4.7 | Stage 3 specifications | 69.5d | 2002-03-25 A | 2002-06-28 A | 100% | 2002-03-25 | 2002-06-28 | 69.5d | finish no earlier than 2002-06-28 | G1,G2,R2,R3 | 556h | 556h |  | Rel-5 | Paolo |  |  |  |
| 2399 | 88.5 | **GERAN MS Conformance test for LCS** | 280d | 2002-06-03 A | 2003-06-27 A | 100% | 2002-06-03 | 2003-06-27 | 280d |  | GP | 6720h | 6720h | LCS-GERAN-MSconf | Rel-5 | Paolo |  |  |  |
| 2400 | 88.5.1 | Develop LCS MS test case work plan (Release 98/99/4) | 280d | 2002-06-03 A | 2003-06-27 A | 100% | 2002-06-03 | 2003-06-27 | 280d | finish no earlier than 2003-06-27 | G4,G5 | 2240h | 2240h |  | Rel-5 | Paolo |  |  |  |
| 2401 | 88.5.2 | Develop LCS MS test cases | 280d | 2002-06-03 A | 2003-06-27 A | 100% | 2002-06-03 | 2003-06-27 | 280d | finish no earlier than 2003-06-27 | G4,G5 | 2240h | 2240h |  | Rel-5 | Paolo |  |  |  |

Notes:
- 2376: -
- 2377: -
- 2378: -
- 2379: -
- 2380: -
- 2381: Finished at RP#13
- 2382: -
- 2383: Evaluate Event based and Periodic LCS to be included in R00, corresponding Stage 1 description
- 2384: Marked as closed 12/2008 (was marked 51% complete)
- 2385: Possible impact on UTRAN of LCS quality level request / 17 May No stage 2 for event-based & periodic LCS. Work 100% completefor current stage 2
- 2386: -
- 2387: -
- 2388: -
- 2389: -
- 2390: -
- 2391: -
- 2392: -
- 2393: -
- 2394: -
- 2395: FFS
- 2396: -
- 2397: -
- 2398: -
- 2399: -
- 2400: Marked as closed 12/2008 (was marked 60% complete)
- 2401: Marked as closed 12/2008 (was marked 60% complete)

| ID | WBS | Task | Duration | Start | Finish | Predecessors | Complete | Baseline start | Baseline finish | Baseline duration | Constraint | Resources | Work | Actual work | Text1 | Text6 | Text8 | Text12 | Text3 | Text4 | Text5 |
| --- | --- | --- | --- | --- | --- | --- | --- | --- | --- | --- | --- | --- | --- | --- | --- | --- | --- | --- | --- | --- | --- |
| 2402 | 88.6 | **Deleted - GERAN BTS Conformance test for LCS** | 280d | 2002-06-03 A | 2003-06-27 A |  | 100% | 2002-06-03 | 2003-06-27 | 280d |  | GP | 6720h | 6720h | LCS-GERAN-BTSconf | Rel-5 | Paolo | GP-15 |  |  |  |
| 2403 | 88.6.1 | Deleted - Develop LCS BTS test case work plan (Release 98/99/4) | 280d | 2002-06-03 A | 2003-06-27 A |  | 100% | 2002-06-03 | 2003-06-27 | 280d | finish no earlier than 2003-06-27 | G4,G5 | 2240h | 2240h |  | Rel-5 | Paolo | GP-15 |  |  |  |
| 2404 | 88.6.2 | Deleted - Develop LCS BTS test cases | 280d | 2002-06-03 A | 2003-06-27 A |  | 100% | 2002-06-03 | 2003-06-27 | 280d | finish no earlier than 2003-06-27 | G4,G5 | 2240h | 2240h |  | Rel-5 | Paolo | GP-15 |  |  |  |
| 2405 | 88.7 | LCS interoperation stage 2 aspects | 480d | 2000-08-28 A | 2002-06-28 A |  | 100% | 2000-08-28 | 2002-06-28 | 480d |  | S2 | 3840h | 3840h |  | Rel-5 | Maurice |  |  |  |  |
| 2406 | 88.8 | **LCS interoperability aspects to GERAN** | 480d | 2000-08-28 A | 2002-06-28 A |  | 100% | 2000-08-28 | 2002-06-28 | 480d |  | GP,S5 | 7680h | 7680h | LCS-GERAN | Rel-5 | Paolo |  |  |  |  |
| 2407 | 88.8.1 | Co-ordinated development of GSM LCS Phase 2 and UMTS LCS, S2 and GERAN | 480d | 2000-08-28 A | 2002-06-28 A |  | 100% | 2000-08-28 | 2002-06-28 | 480d | finish no earlier than 2002-06-28 | GP,S2,S5,R2,R3,G2,G1 | 3840h | 3840h | LCS-GERAN | Rel-5 | Paolo |  |  |  |  |
| 2408 | 88.9 | FS on LCS support in the IMS | 90d | 2001-02-12 A | 2002-01-18 A |  | 100% | 2001-02-12 | 2002-01-18 | 90d | start no earlier than 2001-02-12 | S1 | 720h | 720h |  | Rel-5 | Alain |  |  |  |  |
| 2409 | 88.10 | Charging and OAM&P for LCS enhancements | 201d | 2001-09-21 A | 2002-06-28 A |  | 100% | 2001-09-21 | 2002-06-28 | 201d | finish no earlier than 2002-06-28 | S5 | 1608h | 1608h | LCS1-OAM | Rel-5 | Dionisio |  | 32-series | VoiceStream, Motorola |  |
| 2410 | 88.11 | New security aspects of LCS (not identified) | 446d | 2000-04-14 A | 2001-12-28 A |  | 100% | 2000-04-14 | 2001-12-28 | 446d | finish no earlier than 2001-12-28 | S3 | 3568h | 3568h | LCS1-SEC | Rel-5 | Dionisio |  |  | Nokia | valtteri.niemi@nokia.com |
| 2411 | 88.12 | Specification for the Le Interface | 45d | 2002-01-14 A | 2002-03-15 A |  | 100% | 2002-01-14 | 2002-03-15 | 45d | start no earlier than 2002-01-14 | S2 | 360h | 360h | LCS1-Le | Rel-5 | Maurice |  |  |  |  |
| 2412 | 88.13 | Deleted - CHECK STATUS - Inter-GMLC interface | 153d | 2002-05-30 A | 2002-12-30 A |  | 100% | 2002-05-30 | 2002-12-30 | 153d | finish no earlier than 2002-12-30 | S2 | 1224h | 1224h |  | Rel-5 | Maurice | SP-10 |  |  |  |
| 2413 | 89 | **Rel-5 Security enhancements** | 615d | 2000-02-21 A | 2002-06-28 A |  | 100% | 2000-02-21 | 2002-06-28 | 615d |  | S3 | 29974.9h | 29974.9h |  | Rel-5 | Dionisio |  |  | Vodafone | Peter.Howard@vodafone.com |
| 2414 | 89.1 | **Network domain security** | 615d | 2000-02-21 A | 2002-06-28 A |  | 100% | 2000-02-21 | 2002-06-28 | 615d |  | S3 | 25054.9h | 25054.9h | SEC1-NDS | Rel-5 | Dionisio |  |  | Telenor | Geir-myrdahl.koien@telenor.com |
| 2415 | 89.1.1 | **Deleted -Control plane protection in core network (e.g., GTP, CAP, MAP/IP, provided by IPsec)** | 541d | 2000-05-12 A | 2002-06-07 A |  | 100% | 2000-05-12 | 2002-06-07 | 541d |  | S3 | 7118.9h | 7118.9h |  | Rel-5 | Dionisio | SP-16 |  |  |  |
| 2416 | 89.1.1.1 | Deleted - Main aspects | 290d | 2000-05-12 A | 2001-06-21 A |  | 100% | 2000-05-12 | 2001-06-21 | 290d | finish no earlier than 2001-06-21 | S3 | 2320h | 2320h |  | Rel-5 | Dionisio | SP-12 |  |  |  |
| 2417 | 89.1.1.2 | Deleted -Integration of GTP signalling security architecture | 191d | 2001-09-14 A | 2002-06-07 A |  | 100% | 2001-09-14 | 2002-06-07 | 191d | finish no earlier than 2002-06-07 | N4 | 1528h | 1528h |  | Rel-5 | Kimmo | NP-16 |  |  |  |
| 2418 | 89.1.2 | **Deleted -User plane protection in core network (e.g., provided by IPsec)** | 615d | 2000-02-21 A | 2002-06-28 A |  | 100% | 2000-02-21 | 2002-06-28 | 615d |  | S3 | 9360h | 9360h |  | Rel-5 | Dionisio | SP-16 |  |  |  |
| 2419 | 89.1.2.1 | Deleted -Main aspects | 349d | 2000-02-21 A | 2001-06-21 A |  | 100% | 2000-02-21 | 2001-06-21 | 349d | finish no earlier than 2001-06-21 | S3 | 2792h | 2792h |  | Rel-5 | Dionisio | SP-12 |  |  |  |
| 2420 | 89.1.2.2 | Deleted -Integration of GTP signalling security architecture | 206d | 2001-09-14 A | 2002-06-28 A |  | 100% | 2001-09-14 | 2002-06-28 | 206d | finish no earlier than 2002-06-28 | N4 | 1648h | 1648h |  | Rel-5 | Kimmo | NP-16 |  |  |  |
| 2421 | 89.1.3 | IP network layer security (NDS/IP) | 457d | 2000-06-15 A | 2002-03-15 A |  | 100% | 2000-06-15 | 2002-03-15 | 457d | finish no earlier than 2002-03-15 | S3 | 3656h | 3656h | SEC1-NDS-IP | Rel-5 | Dionisio |  | 33.210 | Telenor | Geir-myrdahl.koien@telenor.com |
| 2422 | 90 | **Intra Domain Connection of RAN Nodes to Multiple CN Nodes** | 455d | 2000-10-02 A | 2002-06-28 A |  | 100% | 2000-10-02 | 2002-06-28 | 455d |  | S2 | 15136h | 15136h | IUFLEX | Rel-5 | Alain |  | 23.236 | Ericsson | stephen.terrill@ericsson.com |
| 2423 | 90.1 | Overall System Architecture | 188d | 2001-01-03 A | 2001-09-21 A |  | 100% | 2001-01-03 | 2001-09-21 | 188d | finish no earlier than 2001-06-01 | S2 | 1504h | 1504h |  | Rel-5 | Maurice |  |  |  |  |
| 2424 | 90.2 | Stage 3: RAN node selecting CN node | 130d | 2001-09-24 A | 2002-03-22 A | 2423 | 100% | 2001-09-24 | 2002-03-22 | 130d | finish no earlier than 2002-03-22 | R3 | 1040h | 1040h |  | Rel-5 | Juha |  |  | Vodafone | Brendan.McWilliams@gb.vodafone.co.uk |
| 2425 | 90.3 | N1 work | 205d | 2001-09-17 A | 2002-06-28 A |  | 100% | 2001-09-17 | 2002-06-28 | 205d | start no earlier than 2001-09-17 | N1 | 1640h | 1640h |  | Rel-5 | Frederic |  | 24.008 and check 29.018 |  |  |
| 2426 | 90.4 | N4 work | 375d | 2000-10-02 A | 2002-03-08 A |  | 100% | 2000-10-02 | 2002-03-08 | 375d | finish no earlier than 2002-03-15 | N4 | 3000h | 3000h |  | Rel-5 | Kimmo |  |  |  |  |

Notes:
- 2402: Not started 02/3003. Marked as stopped 12/2008
- 2403: Marked as stopped 12/2008
- 2404: Marked as stopped 12/2008
- 2405: Marked as closed 12/2008 (was marked 17% complete)
- 2406: -
- 2407: -
- 2408: Marked as closed 12/2008 (was marked 75% complete)
- 2409: -
- 2410: 14/09/00: WI may need to be split to improve on this date. S3#17 15% complete. No progress since S3#17
- 2411: -
- 2412: Marked as stopped 12/2008
- 2413: Added BB UE authentication and rapporteur added. TO BE DELETED
- 2414: S3#17: All due in Rel5. (WI Update at S3#18). Replaced by NDS-IP and NDS-MAP. TO BE DELETED OR MOVED TO HISTORY FILE
- 2415: Marked as stopped 12/2008
- 2416: TO BE DELETED. Marked as stopped 12/2008
- 2417: Waiting for input from SA3!.... Marked as stopped 12/2008
- 2418: TO BE DELETED. Marked as stopped 12/2008
- 2419: -
- 2420: 14/02/2002 requirements are not clear/not received...Marked as closed 12/2008 (was marked 95 complete)
- 2421: 2002/12: All IPsec RFCs are stable STD Track RFCs. WID updated SP#17
- 2422: No clear indication on the end date. Put to Rel5 by AS.
- 2423: -
- 2424: Not identified
- 2425: -
- 2426: DAB 12.12.01 - % complete to 66% / 14/02/02 Work completed

| ID | WBS | Task | Duration | Start | Finish | Complete | Baseline start | Baseline finish | Baseline duration | Constraint | Resources | Work | Actual work | Text1 | Text4 | Text5 | Text6 | Text8 | Text12 | Text3 |
| --- | --- | --- | --- | --- | --- | --- | --- | --- | --- | --- | --- | --- | --- | --- | --- | --- | --- | --- | --- | --- |
| 2427 | 90.5 | **GERAN work for Intra Domain Connection of RAN Nodes to Multiple CN Nodes** | 101d | 2002-02-08 A | 2002-06-28 A | 100% | 2002-02-08 | 2002-06-28 | 101d |  | GP | 4848h | 4848h | IDCRAN-GERAN | Ericsson | ingemar.backlund@era.ericsson.se | Rel-5 | Paolo |  |  |
| 2428 | 90.5.1 | Stage 2 (changes to ) | 101d | 2002-02-08 A | 2002-06-28 A | 100% | 2002-02-08 | 2002-06-28 | 101d | finish no earlier than 2002-06-28 | G1 | 808h | 808h |  |  |  | Rel-5 | Paolo |  |  |
| 2429 | 90.5.2 | 43.051 Introduction of support for IDNNS in GERAN Iu mode | 101d | 2002-02-08 A | 2002-06-28 A | 100% | 2002-02-08 | 2002-06-28 | 101d | finish no earlier than 2002-06-28 | G1 | 808h | 808h |  |  |  | Rel-5 | Paolo |  |  |
| 2430 | 90.5.3 | Stage 3 (changes to ) | 101d | 2002-02-08 A | 2002-06-28 A | 100% | 2002-02-08 | 2002-06-28 | 101d | finish no earlier than 2002-06-28 | G2 | 808h | 808h |  |  |  | Rel-5 | Gert |  |  |
| 2431 | 90.5.4 | 48.016 Use of Gb interface concepts when a network applies IDNNS | 101d | 2002-02-08 A | 2002-06-28 A | 100% | 2002-02-08 | 2002-06-28 | 101d | finish no earlier than 2002-06-28 | G2 | 808h | 808h |  |  |  | Rel-5 | Gert |  |  |
| 2432 | 90.5.5 | 48.018 Include MSC/VLR identity in CS IMSI paging | 101d | 2002-02-08 A | 2002-06-28 A | 100% | 2002-02-08 | 2002-06-28 | 101d | finish no earlier than 2002-06-28 | G2 | 808h | 808h |  |  |  | Rel-5 | Gert |  |  |
| 2433 | 91 | **Deleted - GERAN improvements 3 (new transport layer on interface A)** | 446d | 2001-04-06 A | 2002-12-20 A | 100% | 2001-04-06 | 2002-12-20 | 446d |  | GP | 14272h | 14272h | GEIMP3 |  |  | Rel-5 | Paolo |  |  |
| 2434 | 91.1 | **Deleted - Evolution of the transport for A** | 446d | 2001-04-06 A | 2002-12-20 A | 100% | 2001-04-06 | 2002-12-20 | 446d |  | GP | 10704h | 10704h | GEIMP3-EtA |  |  | Rel-5 | Paolo | GP-12 |  |
| 2435 | 91.1.1 | Deleted - Definition of a new A/Ater interface Transport Layer option based on the Iu Interface Transport Layer | 446d | 2001-04-06 A | 2002-12-20 A | 100% | 2001-04-06 | 2002-12-20 | 446d | finish no earlier than 2002-12-20 | GP | 3568h | 3568h |  |  |  | Rel-5 | Paolo | GP-12 |  |
| 2436 | 91.1.2 | Deleted - Adaptation of the Layer 3 BSSMAP procedures as required | 446d | 2001-04-06 A | 2002-12-20 A | 100% | 2001-04-06 | 2002-12-20 | 446d | finish no earlier than 2002-12-20 | GP | 3568h | 3568h |  |  |  | Rel-5 | Paolo | GP-12 |  |
| 2437 | 92 | **Rel-5 Charging Management & Operations, Administration, Maintenance and Provisioning (OAM&P)** | 264d | 2001-09-10 A | 2002-09-12 A | 100% | 2001-09-10 | 2002-09-12 | 264d |  | S5 | 9976h | 9976h | OAM | VoiceStream, Motorola |  | Rel-5 | Dionisio |  |  |
| 2438 | 92.1 | Rel5 Principles, high level Requirements and Architecture | 205d | 2001-09-17 A | 2002-06-28 A | 100% | 2001-09-17 | 2002-06-28 | 205d | finish no earlier than 2002-06-28 | S5 | 1640h | 1640h | OAM-AR/PR | Motorola |  | Rel-5 | Dionisio |  | 32.101, 32.102 |
| 2439 | 92.2 | Rel5 Performance Management | 259d | 2001-09-17 A | 2002-09-12 A | 100% | 2001-09-17 | 2002-09-12 | 259d | finish no earlier than 2002-09-12 | S5 | 2072h | 2072h | OAM-PM | Nortel |  | Rel-5 | Dionisio |  | 32.4xy, 52.402 |
| 2440 | 92.3 | Rel5 Charging Management | 264d | 2001-09-10 A | 2002-09-12 A | 100% | 2001-09-10 | 2002-09-12 | 264d | finish no earlier than 2002-09-12 | S5 | 2112h | 2112h | OAM-CH | T-Mobile | Karl-Heinz.Nenner@T-MOBILE.DE | Rel-5 | Dionisio |  | 32.200, 32.205, 32.215, 32.225, 32.235 |
| 2441 | 92.4 | Rel5 Network Infrastructure Management | 255d | 2001-09-21 A | 2002-09-12 A | 100% | 2001-09-21 | 2002-09-12 | 255d | finish no earlier than 2002-09-12 | S5 | 2040h | 2040h | OAM-NIM | Ericsson | thomas.tovinger@ericsson.com | Rel-5 | Dionisio |  | 32.6xy, 32.3xy |
| 2442 | 93 | **GERAN enhancements for streaming services 1 (RLC enhancements)** | 430d | 2000-11-06 A | 2002-06-28 A | 100% | 2000-11-06 | 2002-06-28 | 430d |  | GP | 8944h | 8944h |  |  |  | Rel-5 | Paolo |  |  |
| 2443 | 93.1 | Concept | 258d | 2000-11-06 A | 2001-10-31 A | 100% | 2000-11-06 | 2001-10-31 | 258d | finish no earlier than 2001-10-31 | GP | 2064h | 2064h |  |  |  | Rel-5 | Paolo |  |  |
| 2444 | 93.2 | RLC protocol enhancement (SDU Discard) | 430d | 2000-11-06 A | 2002-06-28 A | 100% | 2000-11-06 | 2002-06-28 | 430d | finish no earlier than 2002-06-28 | GP | 3440h | 3440h |  |  |  | Rel-5 | Paolo |  |  |
| 2445 | 94 | **GERAN enhancements for streaming services 2 (usage of ECSD)** | 430d | 2000-11-06 A | 2002-06-28 A | 100% | 2000-11-06 | 2002-06-28 | 430d |  | GP | 19840h | 19840h |  | Ericsson | Frank Muller | Rel-5 | Paolo |  |  |
| 2446 | 94.1 | Usage of ECSD Concept | 380d | 2000-11-06 A | 2002-04-19 A | 100% | 2000-11-06 | 2002-04-19 | 380d | finish no earlier than 2002-04-19 | GP | 3040h | 3040h |  |  |  | Rel-5 | Paolo |  |  |
| 2447 | 94.2 | Stage 2 | 380d | 2000-11-06 A | 2002-04-19 A | 100% | 2000-11-06 | 2002-04-19 | 380d | finish no earlier than 2002-04-19 | GP | 3040h | 3040h |  |  |  | Rel-5 | Paolo |  |  |
| 2448 | 94.3 | Stage 3 | 430d | 2000-11-06 A | 2002-06-28 A | 100% | 2000-11-06 | 2002-06-28 | 430d | finish no earlier than 2002-06-28 | GP | 3440h | 3440h |  |  |  | Rel-5 | Paolo |  |  |
| 2449 | 94.4 | RLC PDU formats | 430d | 2000-11-06 A | 2002-06-28 A | 100% | 2000-11-06 | 2002-06-28 | 430d | finish no earlier than 2002-06-28 | GP | 3440h | 3440h |  |  |  | Rel-5 | Paolo |  |  |
| 2450 | 94.5 | MAC header | 430d | 2000-11-06 A | 2002-06-28 A | 100% | 2000-11-06 | 2002-06-28 | 430d | finish no earlier than 2002-06-28 | GP | 3440h | 3440h |  |  |  | Rel-5 | Paolo |  |  |

Notes:
- 2427: Accept changes Gb over IP
- 2428: -
- 2429: -
- 2430: -
- 2431: Closed, accept changes for Gb over IP
- 2432: -
- 2433: Terminated - not standardized. Marked as stopped 12/2008
- 2434: TERMINATED - NOT STANDARDIZED. Marked as stopped 12/2008
- 2435: TERMINATED - NOT STANDARDIZED. Marked as stopped 12/2008
- 2436: TERMINATED - NOT STANDARDIZED. Marked as stopped 12/2008
- 2437: -
- 2438: -
- 2439: -
- 2440: -
- 2441: -
- 2442: -
- 2443: -
- 2444: -
- 2445: AWS, Nokia, Ericsson, Nortel, Siemens, Motorola, Vodafone
- 2446: -
- 2447: -
- 2448: -
- 2449: -
- 2450: -

| ID | WBS | Task | Duration | Start | Finish | Predecessors | Complete | Baseline start | Baseline finish | Baseline duration | Constraint | Resources | Work | Actual work | Text1 | Text4 | Text5 | Text6 | Text8 |
| --- | --- | --- | --- | --- | --- | --- | --- | --- | --- | --- | --- | --- | --- | --- | --- | --- | --- | --- | --- |
| 2451 | 95 | **GERAN/UTRAN interface evolution 1 (evolution of Iu PS)** | 476d | 2000-09-01 A | 2002-06-28 A |  | 100% | 2000-09-01 | 2002-06-28 | 476d |  | GP,R3 | 10688h | 10688h | GERUEV1 | SBC | Marc Grant | Rel-5 | Paolo |
| 2452 | 95.1 | **Evolution of Iu ps** | 476d | 2000-09-01 A | 2002-06-28 A |  | 100% | 2000-09-01 | 2002-06-28 | 476d |  | GP,R3 | 7248h | 7248h | GERUEV1-IuPS |  |  | Rel-5 | Paolo |
| 2453 | 95.1.1 | Identification of GERAN requirements on Iu ps | 326d | 2000-09-01 A | 2001-11-30 A |  | 100% | 2000-09-01 | 2001-11-30 | 326d | finish no earlier than 2001-11-30 | GP,R3 | 2608h | 2608h |  |  |  | Rel-5 | Paolo |
| 2454 | 95.1.2 | Update of specifications | 150d | 2001-12-03 A | 2002-06-28 A | 2453 | 100% | 2001-12-03 | 2002-06-28 | 150d | finish no earlier than 2002-06-28 | GP,R3 | 1200h | 1200h |  |  |  | Rel-5 | Paolo |
| 2455 | 96 | **GERAN/UTRAN interface evolution 2 (evolution of Iu CS)** | 476d | 2000-09-01 A | 2002-06-28 A |  | 100% | 2000-09-01 | 2002-06-28 | 476d |  | GP,R3 | 12816h | 12816h | GERUEV2 |  |  | Rel-5 | Paolo |
| 2456 | 96.1 | **Evolution of Iu cs** | 476d | 2000-09-01 A | 2002-06-28 A |  | 100% | 2000-09-01 | 2002-06-28 | 476d |  | GP,R3 | 10016h | 10016h | GERUEV2-IuCS | Lucent | Krishna Balachandran | Rel-5 | Paolo |
| 2457 | 96.1.1 | Identification of GERAN requirements on Iu cs | 426d | 2000-09-01 A | 2002-06-24 A |  | 100% | 2000-09-01 | 2002-06-24 | 426d | finish no earlier than 2002-04-19 | GP,R3 | 3408h | 3408h |  |  |  | Rel-5 | Paolo |
| 2458 | 96.1.2 | Update of specifications | 476d | 2000-09-01 A | 2002-06-28 A |  | 100% | 2000-09-01 | 2002-06-28 | 476d | finish no earlier than 2002-06-28 | GP,R3 | 3808h | 3808h |  |  |  | Rel-5 | Paolo |
| 2459 | 97 | **End to End QoS for PS Domain including IMS** | 480d | 2000-08-28 A | 2002-06-28 A |  | 100% | 2000-08-28 | 2002-06-28 | 480d |  | S2 | 9856h | 9856h | E2EQoS | Ericsson | Johnson.oyama@era.ericcson.se | Rel-5 | Maurice |
| 2460 | 97.1 | E2E QoSConcept and Architecture | 178d | 2001-01-03 A | 2001-09-07 A |  | 100% | 2001-01-03 | 2001-09-07 | 178d | finish no earlier than 2001-09-07 | S2 | 1424h | 1424h |  |  |  | Rel-5 | Maurice |
| 2461 | 97.2 | E2E QoS interworking | 465d | 2000-08-28 A | 2002-06-07 A |  | 100% | 2000-08-28 | 2002-06-07 | 465d | finish no earlier than 2002-06-07 | N3 | 3720h | 3720h | E2EQoS-IW | Lucent | Daisuke Yokota (yokota@lucent.com) | Rel-5 | Gwiho |
| 2462 | 97.3 | QoS Management (Provisioning and Monitoring) | 201d | 2001-09-21 A | 2002-06-28 A |  | 100% | 2001-09-21 | 2002-06-28 | 201d | finish no earlier than 2002-06-28 | S5 | 1608h | 1608h | E2EQoS-OAM | VoiceStream, Motorola |  | Rel-5 | Dionisio |
| 2463 | 98 | **Messaging enhancements Rel-5** | 467d | 2001-06-15 A | 2003-03-31 A |  | 100% | 2001-06-15 | 2003-03-31 | 467d |  | T2 | 19000h | 19000h | MESS5 |  |  | Rel-5 | Kimmo |
| 2464 | 98.1 | **Multimedia Messaging (MMS) enhancements** | 467d | 2001-06-15 A | 2003-03-31 A |  | 100% | 2001-06-15 | 2003-03-31 | 467d |  | T2 | 11688h | 11688h | MESS5-MMS | Siemens | Josef.Laumen@SAL.SIEMENS.DE | Rel-5 | Alain |
| 2465 | 98.1.1 | Definition of service requirements | 196d | 2001-06-15 A | 2002-03-15 A |  | 100% | 2001-06-15 | 2002-03-15 | 196d | finish no earlier than 2002-03-15 | S1 | 1568h | 1568h | MESS5-SR | Siemens | Josef.Laumen@SAL.SIEMENS.DE | Rel-5 | Alain |
| 2466 | 98.1.2 | Technical realization | 256d | 2001-06-15 A | 2002-06-07 A |  | 100% | 2001-06-15 | 2002-06-07 | 256d | finish no earlier than 2002-06-07 | T2 | 2048h | 2048h |  | Siemens | Josef.Laumen@SAL.SIEMENS.DE | Rel-5 |  |
| 2467 | 98.1.3 | WAP Forum dependency: MM1 stage 3 | 467d | 2001-06-15 A | 2003-03-31 A |  | 100% | 2001-06-15 | 2003-03-31 | 467d | finish no earlier than 2003-03-31 | T2 | 3736h | 3736h |  |  |  | Rel-5 |  |
| 2468 | 98.1.4 | MMS formats and codecs | 75d | 2001-12-03 A | 2002-03-15 A |  | 100% | 2001-12-03 | 2002-03-15 | 75d | finish no earlier than 2002-03-15 | S4 | 600h | 600h |  |  |  | Rel-5 | Paolo |
| 2469 | 98.2 | **Enhanced Messaging Service (EMS) enhancements** | 191d | 2001-06-15 A | 2002-03-08 A |  | 100% | 2001-06-15 | 2002-03-08 | 191d |  | T2 | 3584h | 3584h | MESS5-EMS | Ericsson | Alan.Baldwin@EML.ERICSSON.SE | Rel-5 | Kimmo |
| 2470 | 98.2.1 | Definition of service requirements | 66d | 2001-06-15 A | 2001-09-14 A |  | 100% | 2001-06-15 | 2001-09-14 | 66d | finish no earlier than 2001-09-14 | S1 | 528h | 528h |  | Ericsson | Alan.Baldwin@EML.ERICSSON.SE | Rel-5 | Alain |
| 2471 | 98.2.2 | Technical realization | 191d | 2001-06-15 A | 2002-03-08 A |  | 100% | 2001-06-15 | 2002-03-08 | 191d | finish no earlier than 2002-03-08 | T2 | 1528h | 1528h |  | Ericsson | Alan.Baldwin@EML.ERICSSON.SE | Rel-5 | Kimmo |
| 2472 | 99 | **GERAN Inter BSC NACC improvements over the Gb Interface** | 215d | 2001-09-03 A | 2002-06-28 A |  | 100% | 2001-09-03 | 2002-06-28 | 215d |  | GP | 8200h | 8200h | GERNACC |  |  | Rel-5 | Paolo |
| 2473 | 99.1 | **Modification of core network protocols for GERAN Inter BSC NACC over Gb Interface** | 165d | 2001-09-03 A | 2002-04-19 A |  | 100% | 2001-09-03 | 2002-04-19 | 165d |  | N4,S2 | 4064h | 4064h | GERNACC-Cnmod |  |  | Rel-5 | Kimmo |
| 2474 | 99.1.1 | Stage 2 - Concept | 43d | 2001-09-03 A | 2001-10-31 A |  | 100% | 2001-09-03 | 2001-10-31 | 43d | finish no earlier than 2001-10-31 | N4,S2 | 344h | 344h |  |  |  | Rel-5 | Kimmo |
| 2475 | 99.1.2 | Stage 2 - 23.060 change - Definition of Inter BSC NACC | 165d | 2001-09-03 A | 2002-04-19 A |  | 100% | 2001-09-03 | 2002-04-19 | 165d | finish no earlier than 2002-04-19 | N4,S2 | 1320h | 1320h |  |  |  | Rel-5 | Kimmo |
| 2476 | 99.1.3 | Stage 3 (changes to TS 29.060) | 135d | 2001-09-03 A | 2002-03-08 A |  | 100% | 2001-09-03 | 2002-03-08 | 135d | finish no earlier than 2002-03-08 | N4 | 1080h | 1080h |  |  |  | Rel-5 | Kimmo |

Notes:
- 2451: SBC, Motorola, Nokia, Ericsson, Nortel
- 2452: -
- 2453: -
- 2454: -
- 2455: -
- 2456: Lucent, Ericsson, AWS, Nortel
- 2457: -
- 2458: -
- 2459: -
- 2460: - / Text3: 23.207
- 2461: [DAB - 30/07/02] - % complete to 95% (if we exclude Diffserv). Marked as closed 12/2008 (was marked 95% complete) / Text3: 29.208, 29.207, 27.060, 29.061, 24.008, 24.228, , 24.229, 29.060, 29.163
- 2462: - / Text3: 32-series
- 2463: support of UAProf, so this in my opinion is 100% complete
- 2464: -
- 2465: - / Text3: 22.140
- 2466: stage 3 MM7 is missing / Text3: 23.140
- 2467: Marked as closed 12/2008 (was marked 80% complete)
- 2468: - / Text3: 26.140
- 2469: - / Text3: 23.040
- 2470: -
- 2471: - / Text3: 23.040
- 2472: -
- 2473: -
- 2474: -
- 2475: -
- 2476: IP 30/11/01: Input awaited from GERAN2 to CN4 / 17 May Work complete 100%

| ID | WBS | Task | Duration | Start | Finish | Complete | Baseline start | Baseline finish | Baseline duration | Constraint | Resources | Work | Actual work | Text1 | Text6 | Text8 | Text12 | Text3 | Text4 | Text5 |
| --- | --- | --- | --- | --- | --- | --- | --- | --- | --- | --- | --- | --- | --- | --- | --- | --- | --- | --- | --- | --- |
| 2477 | 99.2 | **Modification of Gb protocols for GERAN Inter BSC NACC over Gb Interface** | 151d | 2001-11-30 A | 2002-06-28 A | 100% | 2001-11-30 | 2002-06-28 | 151d |  | GP | 2416h | 2416h | GERNACC-Gbmod | Rel-5 | Paolo |  |  |  |  |
| 2478 | 99.2.1 | Stage 3 (changes to TS 48.018) | 151d | 2001-11-30 A | 2002-06-28 A | 100% | 2001-11-30 | 2002-06-28 | 151d | finish no earlier than 2002-06-28 | GP | 1208h | 1208h |  | Rel-5 | Paolo |  |  |  |  |
| 2479 | 100 | **Enhanced Power Control** | 540d | 2001-11-26 A | 2003-12-19 A | 100% | 2001-11-26 | 2003-12-19 | 540d |  | GP | 12840h | 12840h | EPC | Rel-5 | Paolo |  |  |  |  |
| 2480 | 100.1 | Realization of Enhanced power control and signalling support | 5d | 2001-11-26 A | 2001-11-30 A | 100% | 2001-11-26 | 2001-11-30 | 5d | finish no earlier than 2001-11-30 | GP | 40h | 40h |  | Rel-5 | Paolo |  |  |  |  |
| 2481 | 100.2 | Deleted - GERAN MS Conformance test for Enhanced Power Control | 530d | 2001-12-10 A | 2003-12-19 A | 100% | 2001-12-10 | 2003-12-19 | 530d | finish no earlier than 2003-12-19 | GP | 4240h | 4240h |  | Rel-5 | Paolo | GP-17 |  |  |  |
| 2482 | 100.3 | Deleted - GERAN BTS Conformance test for Enhanced Power Control | 530d | 2001-12-10 A | 2003-12-19 A | 100% | 2001-12-10 | 2003-12-19 | 530d | finish no earlier than 2003-12-19 | GP | 4240h | 4240h |  | Rel-5 | Paolo | GP-17 |  |  |  |
| 2483 | 101 | **8PSK AMR HR** | 530d | 2001-12-10 A | 2003-12-19 A | 100% | 2001-12-10 | 2003-12-19 | 530d |  | GP | 21080h | 21080h | 8PSK-AH | Rel-5 | Paolo |  |  |  |  |
| 2484 | 101.1 | **Definition of channel coding, performance requirements and signalling support** | 145d | 2001-12-10 A | 2002-06-28 A | 100% | 2001-12-10 | 2002-06-28 | 145d |  | GP | 10440h | 10440h |  | Rel-5 | Paolo |  |  |  |  |
| 2485 | 101.1.1 | Concept | 145d | 2001-12-10 A | 2002-06-28 A | 100% | 2001-12-10 | 2002-06-28 | 145d | finish no earlier than 2002-06-28 | GP | 1160h | 1160h |  | Rel-5 | Paolo |  |  |  |  |
| 2486 | 101.1.2 | Changes to 44.018 | 145d | 2001-12-10 A | 2002-06-28 A | 100% | 2001-12-10 | 2002-06-28 | 145d | finish no earlier than 2002-06-28 | G2 | 1160h | 1160h |  | Rel-5 | Gert |  |  |  |  |
| 2487 | 101.1.3 | Changes to 45.001 | 145d | 2001-12-10 A | 2002-06-28 A | 100% | 2001-12-10 | 2002-06-28 | 145d | finish no earlier than 2002-06-28 | G1 | 1160h | 1160h |  | Rel-5 | Paolo |  |  |  |  |
| 2488 | 101.1.4 | Changes to 45.002 | 145d | 2001-12-10 A | 2002-06-28 A | 100% | 2001-12-10 | 2002-06-28 | 145d | finish no earlier than 2002-06-28 | G1 | 1160h | 1160h |  | Rel-5 | Paolo |  |  |  |  |
| 2489 | 101.1.5 | Changes to 45.003 | 145d | 2001-12-10 A | 2002-06-28 A | 100% | 2001-12-10 | 2002-06-28 | 145d | finish no earlier than 2002-06-28 | G1 | 1160h | 1160h |  | Rel-5 | Paolo |  |  |  |  |
| 2490 | 101.1.6 | Changes to 45.005 | 145d | 2001-12-10 A | 2002-06-28 A | 100% | 2001-12-10 | 2002-06-28 | 145d | finish no earlier than 2002-06-28 | G1 | 1160h | 1160h |  | Rel-5 | Paolo |  |  |  |  |
| 2491 | 101.1.7 | Changes to 24.008 | 145d | 2001-12-10 A | 2002-06-28 A | 100% | 2001-12-10 | 2002-06-28 | 145d | finish no earlier than 2002-06-28 | G2 | 1160h | 1160h |  | Rel-5 | Gert |  |  |  |  |
| 2492 | 101.1.8 | Changes to 48.058 | 145d | 2001-12-10 A | 2002-06-28 A | 100% | 2001-12-10 | 2002-06-28 | 145d | finish no earlier than 2002-06-28 | G2 | 1160h | 1160h |  | Rel-5 | Gert |  |  |  |  |
| 2493 | 101.2 | Deleted - GERAN MS Conformance test for 8PSK HR | 530d | 2001-12-10 A | 2003-12-19 A | 100% | 2001-12-10 | 2003-12-19 | 530d | finish no earlier than 2003-12-19 | GP | 4240h | 4240h |  | Rel-5 | Paolo | GP-17 |  |  |  |
| 2494 | 101.3 | GERAN BTS Conformance test for 8PSK HR | 270d | 2001-12-10 A | 2002-12-20 A | 100% | 2001-12-10 | 2002-12-20 | 270d | finish no earlier than 2002-12-20 | GP | 2160h | 2160h |  | Rel-5 | Paolo |  |  |  |  |
| 2495 | 102 | Service Change and UDI Fallback | 175d | 2001-10-08 A | 2002-06-07 A | 100% | 2001-10-08 | 2002-06-07 | 175d | finish no earlier than 2002-06-07 | N3 | 1400h | 1400h | SCUDIF | Rel-5 | Gwiho |  | 29.007, 27.001, 24.008 | Ericsson | Rune.Werner.Wiik@ericsson.no |
| 2496 | 103 | **Rel-5 USIM toolkit enhancements** | 865d | 2000-06-05 A | 2003-09-26 A | 100% | 2000-06-05 | 2003-09-26 | 865d |  | T3 | 24352h | 24352h | USAT1-Interpr | Rel-5 | Xavier |  |  | G & D | Michael Meyer |
| 2497 | 103.1 | Deleted - Test specification for USIM toolkit security mechanisms | 349d | 2002-05-28 A | 2003-09-26 A | 100% | 2002-05-28 | 2003-09-26 | 349d | finish no earlier than 2003-09-26 | T3 | 2792h | 2792h |  | Rel-5 | Xavier | TP-21 |  | Gemplus | Sophie Viallet |
| 2498 | 103.2 | **Protocol Standardisation of a SIM Toolkit Interpreter** | 688d | 2000-06-05 A | 2003-01-22 A | 100% | 2000-06-05 | 2003-01-22 | 688d |  | T3 | 12512h | 12512h | USAT1-Interpr | Rel-5 | Xavier |  | 27.103 | G & D | Michael Meyer |
| 2499 | 103.2.1 | Stage 1 | 205d | 2000-06-05 A | 2001-03-16 A | 100% | 2000-06-05 | 2001-03-16 | 205d | finish no earlier than 2001-03-16 | T3 | 1640h | 1640h | USAT1-Interpr | Rel-5 | Xavier |  |  |  |  |
| 2500 | 103.2.2 | Stage 2 and 3 | 308d | 2001-01-03 A | 2002-03-08 A | 100% | 2001-01-03 | 2002-03-08 | 308d | finish no earlier than 2002-03-08 | T3 | 2464h | 2464h | USAT1-Interpr | Rel-5 | Xavier |  |  |  |  |
| 2501 | 103.2.3 | Test specification | 363d | 2001-09-03 A | 2003-01-22 A | 100% | 2001-09-03 | 2003-01-22 | 363d | finish no earlier than 2003-01-22 | T3 | 2904h | 2904h | USAT1-Interpr | Rel-5 | Xavier |  |  | Gemplus | Gérald MAUNIER |

Notes:
- 2477: -
- 2478: -
- 2479: -
- 2480: Completed 11/2001
- 2481: Not started. Marked as stopped 12/2008
- 2482: Not started. Marked as stopped 12/2008
- 2483: Completed for Rel-5
- 2484: -
- 2485: -
- 2486: -
- 2487: -
- 2488: -
- 2489: -
- 2490: -
- 2491: -
- 2492: -
- 2493: Marked as stopped 12/2008
- 2494: -
- 2495: -
- 2496: -
- 2497: Marked as stopped 12/2008
- 2498: 28/5/2001: T3-19 proposed that since the stage 2 and 3 will not be presented to TP-12 for approval as expected, the WI will be moved to rel-5, with completion expected at TP-13.
- 2499: 5/10/2001: Stage one comepeted at TP-12.
- 2500: 5/10/2001: TS 31.112 and 31.113 approved at TP-13. TS 31.114 to be presented to TP-14.
- 2501: 5/10/2001: Work started on test specification. Marked as closed 12/2008 (was marked 12% complete)

| ID | WBS | Task | Type | Duration | Start | Finish | Complete | Baseline start | Baseline finish | Baseline duration | Constraint | Resources | Work | Actual work | Text1 | Text4 | Text5 | Text6 | Text8 | Text12 |
| --- | --- | --- | --- | --- | --- | --- | --- | --- | --- | --- | --- | --- | --- | --- | --- | --- | --- | --- | --- | --- |
| 2502 | 103.4 | **(U)SIM API** |  | 133d | 2002-03-20 A | 2002-09-20 A | 100% | 2002-03-20 | 2002-09-20 | 133d |  | T3 | 2128h | 2128h | USAT1-API | Microelectrónica Española | Mario Pérez | Rel-5 | Xavier |  |
| 2503 | 103.4.1 | Java API Test specification |  | 133d | 2002-03-20 A | 2002-09-20 A | 100% | 2002-03-20 | 2002-09-20 | 133d | finish no earlier than 2002-09-20 | T3 | 1064h | 1064h | USAT1-API | Microelectrónica Española | Mario Pérez | Rel-5 | Xavier |  |
| 2504 | 104 | (Small) Technical Enhancements and Improvements for Rel-5 | milestone | 0d? | 2000-01-03 A | 2000-01-03 A | 100% | 2000-01-03 | 2000-01-03 | 0d? |  | All |  |  | TEI5 |  |  | Rel-5 | all |  |
| 2505 | 675 | Test - (Small) Technical Enhancements and Improvements for Rel-5 |  | 2349d? | 2000-01-03 A | 2008-12-31 A | 100% | 2000-01-03 | 2008-12-31 | 2349d? | finish no earlier than 2008-12-31 | R5,T1 | 18792h | 18792h | TEI5_Test |  |  | Rel-5 | Ingbert |  |
| 2506 | 105 | Technical Report on UE Functionality Split |  | 87d | 2000-01-03 A | 2000-05-01 A | 100% | 2000-01-03 | 2000-05-01 | 87d |  | S1 [98.9%] | 688h | 688h | UESPLIT | Motorola | jian.j.wu@motorola.com | Rel-5 | Alain |  |
| 2507 | 106 | **User Equipment Management** |  | 267d | 2001-06-21 A | 2002-06-28 A | 100% | 2001-06-21 | 2002-06-28 | 267d |  | S5 | 3752h | 3752h | UEM | Vodafone | john.mudge@vf.vodafone.co.uk | Rel-5 | Dionisio |  |
| 2508 | 106.1 | FS on User Equipment (UE) Management |  | 267d | 2001-06-21 A | 2002-06-28 A | 100% | 2001-06-21 | 2002-06-28 | 267d | finish no earlier than 2002-06-28 | S5 | 2136h | 2136h | OAM-UEM | Vodafone | john.mudge@vf.vodafone.co.uk | Rel-5 | Dionisio |  |
| 2509 | 107 | **Flow control supporting an MS with multiple data flows with different QoS over the Gb interface** |  | 50d | 2002-06-24 A | 2002-08-30 A | 100% | 2002-06-24 | 2002-08-30 | 50d |  | GP | 1288h | 1288h | FlowCon | Ericsson | ingemar.backlund@era.ericsson.se | Rel-5 | Paolo |  |
| 2510 | 107.1 | **Update of stage 2 specifications** |  | 50d | 2002-06-24 A | 2002-08-30 A | 100% | 2002-06-24 | 2002-08-30 | 50d |  | GP | 808h | 808h |  |  |  | Rel-5 | Paolo |  |
| 2511 | 107.1.1 | Concept document 23.060 (changes to) |  | 46d | 2002-06-28 A | 2002-08-30 A | 100% | 2002-06-28 | 2002-08-30 | 46d | finish no earlier than 2002-08-30 | S2 | 368h | 368h |  |  |  | Rel-5 | Maurice |  |
| 2512 | 107.1.2 | Flow Control |  | 5d | 2002-06-24 A | 2002-06-28 A | 100% | 2002-06-24 | 2002-06-28 | 5d | finish no earlier than 2002-06-28 | GP | 40h | 40h |  |  |  | Rel-5 | Paolo |  |
| 2513 | 107.2 | **Modification of BSSGP protocol** |  | 5d | 2002-06-24 A | 2002-06-28 A | 100% | 2002-06-24 | 2002-06-28 | 5d |  | GP | 80h | 80h |  | Ericsson | ingemar.backlund@era.ericsson.se | Rel-5 | Paolo |  |
| 2514 | 107.2.1 | Stage 3 (changes to 48.018) |  | 5d | 2002-06-24 A | 2002-06-28 A | 100% | 2002-06-24 | 2002-06-28 | 5d | finish no earlier than 2002-06-28 | G2 | 40h | 40h |  |  |  | Rel-5 | Gert |  |
| 2515 | 108 | **Deleted - Multiple TBF in A/Gb mode - Phase 1** |  | 421d | 2002-04-19 A | 2003-11-28 A | 100% | 2002-04-19 | 2003-11-28 | 421d |  | GP | 17480h | 17480h | MULTBF | Ericsson | gunnar.mildh@era.ericsson.se | Rel-5 | Paolo | GP-17 |
| 2516 | 108.1 | **Deleted - Multiple TBF in A/Gb mode - Phase 1** |  | 351d | 2002-04-19 A | 2003-08-22 A | 100% | 2002-04-19 | 2003-08-22 | 351d |  | GP | 8112h | 8112h | MULTBF-Agbmode |  |  | Rel-5 | Paolo | GP-17 |
| 2517 | 108.1.1 | Deleted - Multiple TBF Concept paper |  | 351d | 2002-04-19 A | 2003-08-22 A | 100% | 2002-04-19 | 2003-08-22 | 351d | finish no earlier than 2003-08-22 | GP | 2808h | 2808h | MULTBF-Agbmode |  |  | Rel-5 | Paolo | GP-17 |
| 2518 | 108.1.2 | Deleted - Multiple TBF Stage 2 (43.064) CRs |  | 156d | 2002-04-19 A | 2002-11-22 A | 100% | 2002-04-19 | 2002-11-22 | 156d | finish no earlier than 2002-11-22 | G1 | 1248h | 1248h | MULTBF-Agbmode |  |  | Rel-5 | Paolo | GP-12 |
| 2519 | 108.1.3 | Deleted - Multiple TBF Stage 3 (44.060) CRs |  | 156d | 2002-04-19 A | 2002-11-22 A | 100% | 2002-04-19 | 2002-11-22 | 156d | finish no earlier than 2002-11-22 | G2 | 1248h | 1248h | MULTBF-Agbmode |  |  | Rel-5 | Gert | GP-12 |
| 2520 | 108.2 | **Deleted - Multiple TBF in A/Gb mode – MS testing** |  | 375d | 2002-06-24 A | 2003-11-28 A | 100% | 2002-06-24 | 2003-11-28 | 375d |  | GP | 6000h | 6000h |  | Ericsson | ingemar.backlund@era.ericsson.se | Rel-5 | Paolo | GP-17 |
| 2521 | 108.2.1 | Deleted - MS conformance tests |  | 375d | 2002-06-24 A | 2003-11-28 A | 100% | 2002-06-24 | 2003-11-28 | 375d | finish no earlier than 2003-11-28 | G4 | 3000h | 3000h |  |  |  | Rel-5 | Paolo | GP-17 |
| 2522 | 109 | **Alignment of 3G functional split and Iu** |  | 922d | 2000-06-08 A | 2003-12-19 A | 100% | 2000-06-08 | 2003-12-19 | 922d |  | GP | 126664h | 126664h | GER3GAL | Ericsson | Frank Muller | Rel-5 | Paolo |  |
| 2523 | 109.1 | **GERAN user / control plane** |  | 540d | 2000-08-07 A | 2002-08-30 A | 100% | 2000-08-07 | 2002-08-30 | 540d |  | GP | 36232h | 36232h | GER3GAL-GUCOPL | Ericsson | Frank Muller | Rel-5 | Paolo |  |
| 2524 | 109.1.1 | **Alignment with UMTS bearer concept** |  | 540d | 2000-08-07 A | 2002-08-30 A | 100% | 2000-08-07 | 2002-08-30 | 540d |  | GP | 24952h | 24952h |  |  |  | Rel-5 | Paolo |  |
| 2525 | 109.1.1.1 | Enhanced power control |  | 1d | 2001-08-31 A | 2001-08-31 A | 100% | 2001-08-31 | 2001-08-31 | 1d | finish no earlier than 2001-08-31 | GP | 8h | 8h |  |  |  | Rel-5 | Paolo |  |
| 2526 | 109.1.1.2 | Stage 2 |  | 235d | 2000-08-07 A | 2001-06-29 A | 100% | 2000-08-07 | 2001-06-29 | 235d | finish no earlier than 2001-06-29 | GP | 1880h | 1880h |  |  |  | Rel-5 | Paolo |  |
| 2527 | 109.1.1.3 | Adoption of the UTRAN PDCP |  | 295d | 2000-11-06 A | 2001-12-21 A | 100% | 2000-11-06 | 2001-12-21 | 295d | finish no earlier than 2001-12-21 | GP | 2360h | 2360h |  |  |  | Rel-5 | Paolo |  |
| 2528 | 109.1.1.4 | Development of RLC / MAC |  | 261d | 2001-08-31 A | 2002-08-30 A | 100% | 2001-08-31 | 2002-08-30 | 261d | finish no earlier than 2002-08-30 | GP | 2088h | 2088h |  |  |  | Rel-5 | Paolo |  |
| 2529 | 109.1.1.5 | Development of GERAN RRC |  | 266d | 2001-06-22 A | 2002-06-28 A | 100% | 2001-06-22 | 2002-06-28 | 266d | finish no earlier than 2002-06-28 | GP | 2128h | 2128h |  |  |  | Rel-5 | Paolo |  |
| 2530 | 109.1.1.6 | Ciphering and integrity protection concept paper |  | 166d | 2001-08-31 A | 2002-04-19 A | 100% | 2001-08-31 | 2002-04-19 | 166d | finish no earlier than 2002-04-19 | GP | 1328h | 1328h |  |  |  | Rel-5 | Paolo |  |
| 2531 | 109.1.1.7 | Multiple TBF or equivalent Concept paper |  | 116d | 2001-08-31 A | 2002-02-08 A | 100% | 2001-08-31 | 2002-02-08 | 116d | finish no earlier than 2002-02-08 | GP | 928h | 928h |  |  |  | Rel-5 | Paolo |  |
| 2532 | 109.1.1.8 | Paging concept |  | 166d | 2001-08-31 A | 2002-04-19 A | 100% | 2001-08-31 | 2002-04-19 | 166d | finish no earlier than 2002-04-19 | GP | 1328h | 1328h |  |  |  | Rel-5 | Paolo |  |
| 2533 | 109.1.1.9 | Dedicated Physical subchannels, includes traffic and control channels |  | 66d | 2001-08-31 A | 2001-11-30 A | 100% | 2001-08-31 | 2001-11-30 | 66d | finish no earlier than 2001-11-30 | GP | 528h | 528h |  |  |  | Rel-5 | Paolo |  |
| 2534 | 109.1.1.10 | Iu support and broadcast concept |  | 166d | 2001-08-31 A | 2002-04-19 A | 100% | 2001-08-31 | 2002-04-19 | 166d | finish no earlier than 2002-04-19 | GP | 1328h | 1328h |  |  |  | Rel-5 | Paolo |  |
| 2535 | 109.1.1.11 | Impact of using RLC instead of LAPDm concept |  | 116d | 2001-08-31 A | 2002-02-08 A | 100% | 2001-08-31 | 2002-02-08 | 116d | finish no earlier than 2002-02-08 | GP | 928h | 928h |  |  |  | Rel-5 | Paolo |  |
| 2536 | 109.1.1.12 | Contention resolution, mobile station identity, and access concept |  | 66d | 2001-08-31 A | 2001-11-30 A | 100% | 2001-08-31 | 2001-11-30 | 66d | finish no earlier than 2001-11-30 | GP | 528h | 528h |  |  |  | Rel-5 | Paolo |  |
| 2537 | 109.1.1.13 | PDCP concept |  | 166d | 2001-08-31 A | 2002-04-19 A | 100% | 2001-08-31 | 2002-04-19 | 166d | finish no earlier than 2002-04-19 | GP | 1328h | 1328h |  |  |  | Rel-5 | Paolo |  |
| 2538 | 109.1.1.14 | Downlink delayed TBF release |  | 261d | 2001-08-31 A | 2002-08-30 A | 100% | 2001-08-31 | 2002-08-30 | 261d | finish no earlier than 2002-08-30 | GP | 2088h | 2088h |  |  |  | Rel-5 | Paolo |  |
| 2539 | 109.1.1.15 | Add transparent RLC Concept |  | 116d | 2001-08-31 A | 2002-02-08 A | 100% | 2001-08-31 | 2002-02-08 | 116d | finish no earlier than 2002-02-08 | GP | 928h | 928h |  |  |  | Rel-5 | Paolo |  |
| 2540 | 109.1.1.16 | Handover concept |  | 116d | 2001-08-31 A | 2002-02-08 A | 100% | 2001-08-31 | 2002-02-08 | 116d | finish no earlier than 2002-02-08 | GP | 928h | 928h |  |  |  | Rel-5 | Paolo |  |

Notes:
- 2502: 8/3/2001: test spec is based on R99 core spec, so deleted from Workplan
- 2503: -
- 2504: "Joker" WI, to be used for a Rel 5 CR not related to any feature and with very limited impact on the system
- 2505: "Joker" WI, to be used for small modifications applicable to Rel 5 conformance testing. Moved in from Stoyan/testing WP. / Text3: 34.108, 34.109, 34.121-1, 34.121-2, 34.122, 34.123-1, 34.123-2, 34.123-3, 34.171, 34.229-1, 34.229-2, 34.229-3
- 2506: - / Text3: new TR 22.944
- 2507: - / Text3: 32.802
- 2508: - / Text3: 32.802
- 2509: 50101 -> 50201
- 2510: 50102 -> 50202
- 2511: -
- 2512: 50103 -> 50203
- 2513: -
- 2514: -
- 2515: GP#17 Nov 2003 Moved to Rel-6 as UID_50600 MULTBF (Only Multiple TBF Concept paper produced in Rel-5)
- 2516: Marked as closed 12/2008 (was marked 26% complete)
- 2517: Marked as closed 12/2008 (was marked 50% complete)
- 2518: Marked as stopped 12/2008
- 2519: Marked as stopped 12/2008
- 2520: 08/08: duplicate UID_50106=-> 50206. Marked as stopped 12/2008
- 2521: Not started. Marked as stopped 12/2008
- 2522: AWS, Nokia, Ericsson, Nortel, Siemens, Vodafone
- 2523: AWS, Nokia, Ericsson, Nortel, Siemens, Vodafone
- 2524: -
- 2525: -
- 2526: -
- 2527: Responsible is GERAN; RAN WG2 help may be needed.
- 2528: -
- 2529: -
- 2530: -
- 2531: -
- 2532: -
- 2533: -
- 2534: -
- 2535: -
- 2536: -
- 2537: -
- 2538: -
- 2539: -
- 2540: -

| ID | WBS | Task | Duration | Start | Finish | Complete | Baseline start | Baseline finish | Baseline duration | Constraint | Resources | Work | Actual work | Text6 | Text8 | Text1 | Text4 | Text5 |
| --- | --- | --- | --- | --- | --- | --- | --- | --- | --- | --- | --- | --- | --- | --- | --- | --- | --- | --- |
| 2541 | 109.1.2 | **Physical layer alignment with UMTS bearer concept** | 280d | 2000-11-06 A | 2001-11-30 A | 100% | 2000-11-06 | 2001-11-30 | 280d |  | GP | 6960h | 6960h | Rel-5 | Paolo |  |  |  |
| 2542 | 109.1.2.1 | PDTCH/TCH in 45.003 | 155d | 2000-11-06 A | 2001-06-08 A | 100% | 2000-11-06 | 2001-06-08 | 155d | finish no earlier than 2001-06-08 | GP | 1240h | 1240h | Rel-5 | Paolo |  |  |  |
| 2543 | 109.1.2.2 | Control channels in 45.003 | 155d | 2000-11-06 A | 2001-06-08 A | 100% | 2000-11-06 | 2001-06-08 | 155d | finish no earlier than 2001-06-08 | GP | 1240h | 1240h | Rel-5 | Paolo |  |  |  |
| 2544 | 109.1.2.3 | Receiver performance in 45.005 for PDTCH/TCH and control channels | 280d | 2000-11-06 A | 2001-11-30 A | 100% | 2000-11-06 | 2001-11-30 | 280d | finish no earlier than 2001-11-30 | GP | 2240h | 2240h | Rel-5 | Paolo |  |  |  |
| 2545 | 109.2 | **Iu rg interface** | 430d | 2000-11-06 A | 2002-06-28 A | 100% | 2000-11-06 | 2002-06-28 | 430d |  | GP,RP | 39560h | 39560h | Rel-5 | Paolo | GER3GAL-Iurg | Ericsson | Frank Muller |
| 2546 | 109.2.1 | **Inter BSS interface** | 430d | 2000-11-06 A | 2002-06-28 A | 100% | 2000-11-06 | 2002-06-28 | 430d |  | GP,RP | 20640h | 20640h | Rel-5 | Paolo |  |  |  |
| 2547 | 109.2.1.1 | Identification of requirements | 430d | 2000-11-06 A | 2002-06-28 A | 100% | 2000-11-06 | 2002-06-28 | 430d | finish no earlier than 2002-06-28 | GP | 3440h | 3440h | Rel-5 | Paolo |  |  |  |
| 2548 | 109.2.1.2 | Stage 2 | 430d | 2000-11-06 A | 2002-06-28 A | 100% | 2000-11-06 | 2002-06-28 | 430d | finish no earlier than 2002-06-28 | GP | 3440h | 3440h | Rel-5 | Paolo |  |  |  |
| 2549 | 109.2.1.3 | Adoption of relevant parts from Iur | 430d | 2000-11-06 A | 2002-06-28 A | 100% | 2000-11-06 | 2002-06-28 | 430d | finish no earlier than 2002-06-28 | GP | 3440h | 3440h | Rel-5 | Paolo |  |  |  |
| 2550 | 109.2.1.4 | Complementation with GERAN specifics | 430d | 2000-11-06 A | 2002-06-28 A | 100% | 2000-11-06 | 2002-06-28 | 430d | finish no earlier than 2002-06-28 | GP | 3440h | 3440h | Rel-5 | Paolo |  |  |  |
| 2551 | 109.2.1.5 | Stage 3 | 430d | 2000-11-06 A | 2002-06-28 A | 100% | 2000-11-06 | 2002-06-28 | 430d | finish no earlier than 2002-06-28 | GP | 3440h | 3440h | Rel-5 | Paolo |  |  |  |
| 2552 | 109.2.2 | **Inter BSS-RNS interface** | 430d | 2000-11-06 A | 2002-06-28 A | 100% | 2000-11-06 | 2002-06-28 | 430d |  | GP,RP | 15480h | 15480h | Rel-5 | Paolo |  |  |  |
| 2553 | 109.2.2.1 | Identification of requirements | 430d | 2000-11-06 A | 2002-06-28 A | 100% | 2000-11-06 | 2002-06-28 | 430d | start no earlier than 2000-11-06 | GP,R3 | 3440h | 3440h | Rel-5 | Paolo |  |  |  |
| 2554 | 109.2.2.2 | Stage 2 | 430d | 2000-11-06 A | 2002-06-28 A | 100% | 2000-11-06 | 2002-06-28 | 430d | finish no earlier than 2002-06-28 | GP,R3 | 3440h | 3440h | Rel-5 | Paolo |  |  |  |
| 2555 | 109.2.2.3 | Adoption of relevant parts from Iur | 430d | 2000-11-06 A | 2002-06-28 A | 100% | 2000-11-06 | 2002-06-28 | 430d | finish no earlier than 2002-06-28 | GP,R3 | 3440h | 3440h | Rel-5 | Paolo |  |  |  |
| 2556 | 109.2.2.4 | Complementation with GERAN specifics | 107.5d | 2002-01-30 A | 2002-06-28 A | 100% | 2002-01-30 | 2002-06-28 | 107.5d | finish no earlier than 2002-06-28 | GP,R3 | 860h | 860h | Rel-5 | Paolo |  |  |  |
| 2557 | 109.2.2.5 | Stage 3 | 107.5d | 2002-01-30 A | 2002-06-28 A | 100% | 2002-01-30 | 2002-06-28 | 107.5d | finish no earlier than 2002-06-28 | GP,R3 | 860h | 860h | Rel-5 | Paolo |  |  |  |
| 2558 | 109.3 | **Voice over GERAN PS and CS concept** | 430d | 2000-11-06 A | 2002-06-28 A | 100% | 2000-11-06 | 2002-06-28 | 430d |  | GP,R3 | 18520h | 18520h | Rel-5 | Paolo |  |  |  |
| 2559 | 109.3.1 | Architecture for A, Iu cs and Iu ps | 430d | 2000-11-06 A | 2002-06-28 A | 100% | 2000-11-06 | 2002-06-28 | 430d | finish no earlier than 2002-06-28 | GP,R3 | 3440h | 3440h | Rel-5 | Paolo |  |  |  |
| 2560 | 109.3.2 | Transcoder position/operation | 115d | 2000-11-06 A | 2001-04-13 A | 100% | 2000-11-06 | 2001-04-13 | 115d | finish no earlier than 2001-04-13 | GP | 920h | 920h | Rel-5 | Paolo |  |  |  |
| 2561 | 109.3.3 | Handover | 430d | 2000-11-06 A | 2002-06-28 A | 100% | 2000-11-06 | 2002-06-28 | 430d | finish no earlier than 2002-06-28 | GP,R3 | 3440h | 3440h | Rel-5 | Paolo |  |  |  |
| 2562 | 109.3.4 | RTP payload | 430d | 2000-11-06 A | 2002-06-28 A | 100% | 2000-11-06 | 2002-06-28 | 430d | finish no earlier than 2002-06-28 | GP,R3 | 3440h | 3440h | Rel-5 | Paolo |  |  |  |
| 2563 | 109.3.5 | Codec renegotiation concept | 365d | 2000-11-06 A | 2002-03-29 A | 100% | 2000-11-06 | 2002-03-29 | 365d | finish no earlier than 2002-03-29 | GP,R3 | 2920h | 2920h | Rel-5 | Paolo |  |  |  |
| 2564 | 109.3.6 | LA | 115d | 2000-11-06 A | 2001-04-13 A | 100% | 2000-11-06 | 2001-04-13 | 115d | finish no earlier than 2001-04-13 | GP | 920h | 920h | Rel-5 | Paolo |  |  |  |

Notes:
- 2541: -
- 2542: -
- 2543: -
- 2544: -
- 2545: AWS, Nokia, Ericsson, Nortel, Siemens, Vodafone
- 2546: -
- 2547: -
- 2548: -
- 2549: -
- 2550: -
- 2551: -
- 2552: -
- 2553: -
- 2554: -
- 2555: -
- 2556: -
- 2557: -
- 2558: -
- 2559: -
- 2560: -
- 2561: -
- 2562: -
- 2563: -
- 2564: -

| ID | WBS | Task | Duration | Start | Finish | Complete | Baseline start | Baseline finish | Baseline duration | Constraint | Resources | Work | Actual work | Text6 | Text8 | Text12 | Text1 | Text4 | Text5 |
| --- | --- | --- | --- | --- | --- | --- | --- | --- | --- | --- | --- | --- | --- | --- | --- | --- | --- | --- | --- |
| 2565 | 109.4 | **Deleted - GERAN MS Conformance test for GERAN interface evolution** | 660d | 2001-06-11 A | 2003-12-19 A | 100% | 2001-06-11 | 2003-12-19 | 660d |  | GP | 10560h | 10560h | Rel-5 | Paolo | GP-17 |  |  |  |
| 2566 | 109.4.1 | Deleted - MS test | 660d | 2001-06-11 A | 2003-12-19 A | 100% | 2001-06-11 | 2003-12-19 | 660d | finish no earlier than 2003-12-19 | GP | 5280h | 5280h | Rel-5 | Paolo | GP-17 |  |  |  |
| 2567 | 109.5 | **GERAN BSS Conformance test for GERAN interface evolution** | 922d | 2000-06-08 A | 2003-12-19 A | 100% | 2000-06-08 | 2003-12-19 | 922d |  | GP | 14752h | 14752h | Rel-5 | Paolo |  |  |  |  |
| 2568 | 109.5.1 | Deleted - BSS test | 922d | 2000-06-08 A | 2003-12-19 A | 100% | 2000-06-08 | 2003-12-19 | 922d | finish no earlier than 2003-12-19 | GP | 7376h | 7376h | Rel-5 | Paolo | GP-17 |  |  |  |
| 2569 | 110 | **GERAN support for IMS** | 690d | 2000-05-01 A | 2002-12-20 A | 100% | 2000-05-01 | 2002-12-20 | 690d |  | GP | 39198.4h | 39198.4h | Rel-5 | Paolo |  | GERIMS | Nokia | Shkumbin Hamiti |
| 2570 | 110.1 | **GERAN Header adaptation** | 690d | 2000-05-01 A | 2002-12-20 A | 100% | 2000-05-01 | 2002-12-20 | 690d |  | GP,S2,RP | 12302.8h | 12302.8h | Rel-5 | Paolo |  | GERIMS-HEADAPT | Nokia | Shkumbin Hamiti |
| 2571 | 110.1.1 | Definition of compression and removal modes for PDCP protocol | 15.05d | 2000-05-01 A | 2000-06-09 A | 100% | 2000-05-01 | 2000-06-09 | 15.05d | finish no earlier than 2000-09-01 | GP,S2,RP | 120.4h | 120.4h | Rel-5 | Paolo |  |  |  |  |
| 2572 | 110.1.2 | Conceptual description in stage 2 | 393d | 2000-05-01 A | 2001-10-31 A | 100% | 2000-05-01 | 2001-10-31 | 393d | finish no earlier than 2001-10-31 | GP,S2,RP | 3144h | 3144h | Rel-5 | Paolo |  |  |  |  |
| 2573 | 110.1.3 | Necessary changes on stage 3 regarding header removal | 439.8d | 2000-11-06 A | 2002-12-20 A | 100% | 2000-11-06 | 2002-12-20 | 439.8d | finish no earlier than 2002-12-20 | GP,S2,RP | 3518.4h | 3518.4h | Rel-5 | Paolo |  |  |  |  |
| 2574 | 110.2 | **Deleted - GERAN Radio access bearer design for IMS** | 430d | 2000-11-06 A | 2002-06-28 A | 100% | 2000-11-06 | 2002-06-28 | 430d |  | GP,S2,RP | 9287.6h | 9287.6h | Rel-5 | Paolo | GP-10 | GERIMS-RABDES | Nokia | Shkumbin Hamiti |
| 2575 | 110.2.1 | **Deleted - MuM control signalling for conversational multimedia services** | 430d | 2000-11-06 A | 2002-06-28 A | 100% | 2000-11-06 | 2002-06-28 | 430d |  | GP,S2,RP | 5847.6h | 5847.6h | Rel-5 | Paolo | GP-10 |  |  |  |
| 2576 | 110.2.1.1 | Deleted - Identification of requirements | 330d | 2000-11-06 A | 2002-02-08 A | 100% | 2000-11-06 | 2002-02-08 | 330d | finish no earlier than 2002-02-08 | GP,S2,RP | 2640h | 2640h | Rel-5 | Paolo | GP-08 |  |  |  |
| 2577 | 110.2.1.2 | Deleted - Necessary modifications due to SIP | 40d | 2002-05-06 A | 2002-06-28 A | 100% | 2002-05-06 | 2002-06-28 | 40d | finish no earlier than 2002-06-28 | GP,S2,RP | 320h | 320h | Rel-5 | Paolo | GP-10 |  |  |  |
| 2578 | 110.3 | **Deleted - GERAN MS Conformance test for support of IMS** | 400d | 2001-06-11 A | 2002-12-20 A | 100% | 2001-06-11 | 2002-12-20 | 400d |  | GP | 6400h | 6400h | Rel-5 | Paolo | GP-12 | GERIMS-MSconf | Nokia | Shkumbin Hamiti |
| 2579 | 110.3.1 | Deleted - MS test | 400d | 2001-06-11 A | 2002-12-20 A | 100% | 2001-06-11 | 2002-12-20 | 400d | finish no earlier than 2002-12-20 | G4 | 3200h | 3200h | Rel-5 | Paolo | GP-12 |  |  |  |
| 2580 | 110.4 | **Deleted - GERAN BTS Conformance test for support of IMS** | 400d | 2001-06-11 A | 2002-12-20 A | 100% | 2001-06-11 | 2002-12-20 | 400d |  | GP | 6400h | 6400h | Rel-5 | Paolo | GP-12 | GERIMS-BTSconf | Nokia | Shkumbin Hamiti |
| 2581 | 110.4.1 | Deleted - BTS test | 400d | 2001-06-11 A | 2002-12-20 A | 100% | 2001-06-11 | 2002-12-20 | 400d | finish no earlier than 2002-12-20 | G3new | 3200h | 3200h | Rel-5 | Ingbert | GP-12 |  |  |  |
| 2582 | 682 | MS Conformance Testing of Dual Transfer Mode | 65d? | 2002-11-11 A | 2003-02-07 A | 100% | 2002-11-11 | 2003-02-07 | 65d? | finish no earlier than 2003-02-07 | G4,G5 | 520h | 520h | Rel-5 | Paolo |  | MSCTDTM | Vodafone | Dave Fox |
| 2583 | 683 | **Handling of early UEs** | 911d? | 2000-01-03 A | 2003-06-27 A | 100% | 2000-01-03 | 2003-06-27 | 911d? |  | S2 | 4488h | 4488h | Rel-5 | Maurice |  | LATE_UE |  |  |
| 2584 | 683.1 | Feasibility Study | 50d? | 2002-10-07 A | 2002-12-13 A | 100% | 2002-10-07 | 2002-12-13 | 50d? | finish no earlier than 2002-12-13 | S2 | 400h | 400h | Rel-5 | Maurice |  |  |  |  |
| 2585 | 683.2 | Stage 2 | 125d? | 2003-01-06 A | 2003-06-27 A | 100% | 2003-01-06 | 2003-06-27 | 125d? | start no earlier than 2003-01-06 | S2 | 1000h | 1000h | Rel-5 | Maurice |  |  |  |  |
| 2586 | 683.3 | FS for the Early Mobile Handling in UTRAN | 195d | 2002-09-09 A | 2003-06-06 A | 100% | 2002-09-09 | 2003-06-06 | 195d | finish no earlier than 2003-06-06 | R2 | 1560h | 1560h | Rel-5 | Joern |  | FSEarlyUE | Vodafone | alan.law@vodafone.com |
| 2587 | 683.4 | Note: Stage 3 RAN part not shown | 1d | 2000-01-03 A | 2000-01-03 A | 100% | 2000-01-03 | 2000-01-03 | 1d |  | RP | 8h | 8h | Rel-5 |  |  |  |  |  |
| 2588 | 684 | Release 4 Features | 326d? | 2000-01-03 A | 2001-03-30 A | 100% | 2000-01-03 | 2001-03-30 | 326d? |  | NP,GP, RP,SP,TP | 2608h | 2608h | Rel-4 | All |  |  |  |  |

Notes:
- 2565: Not started. Marked as stopped 12/2008
- 2566: Not started. Marked as stopped 12/2008
- 2567: Not started. Marked as stopped 12/2008
- 2568: Not started. Marked as stopped 12/2008
- 2569: AWS, Nokia, Ericsson, Nortel, Siemens, Motorola
- 2570: AWS, Nokia, Ericsson, Nortel, Siemens, Motorola
- 2571: -
- 2572: -
- 2573: -
- 2574: TERMINATED - NOT STANDARDIZED. Marked as stopped 12/2008
- 2575: TERMINATED - NOT STANDARDIZED. Marked as stopped 12/2008
- 2576: TERMINATED - NOT STANDARDIZED
- 2577: TERMINATED - NOT STANDARDIZED
- 2578: TERMINATED - NOT STANDARDIZED. Marked as stopped 12/2008
- 2579: TERMINATED - NOT STANDARDIZED. Marked as stopped 12/2008
- 2580: TERMINATED - NOT STANDARDIZED. Marked as stopped 12/2008
- 2581: TERMINATED - NOT STANDARDIZED. Marked as stopped 12/2008
- 2582: Needed to complete DTM (R99)
- 2583: -
- 2584: -
- 2585: -
- 2586: -
- 2587: -
- 2588: -

| ID | WBS | Task | Duration | Start | Finish | Predecessors | Complete | Baseline start | Baseline finish | Baseline duration | Constraint | Resources | Work | Actual work | Text1 | Text6 | Text8 | Text3 | Text12 | Text4 | Text5 |
| --- | --- | --- | --- | --- | --- | --- | --- | --- | --- | --- | --- | --- | --- | --- | --- | --- | --- | --- | --- | --- | --- |
| 2589 | 15 | **Miscellaneous UE Conformance Testing Activities** | 958d | 2001-04-02 A | 2004-12-01 A |  | 100% | 2001-04-02 | 2004-12-01 | 958d |  | T1 | 36360h | 36360h | MISTST1 | Rel-4 | Ingbert |  |  |  |  |
| 2590 | 15.1 | Optimization of Test Time, RF Aspects (FDD) | 508d | 2001-09-24 A | 2003-09-03 A |  | 100% | 2001-09-24 | 2003-09-03 | 508d | finish no earlier than 2003-09-03 | T1 | 4064h | 4064h | MISTST1-OpFDD | Rel-4 | Ingbert | 34.121 |  |  |  |
| 2591 | 15.2 | Optimization of Test Time, RF Aspects (TDD) | 508d | 2001-09-24 A | 2003-09-03 A |  | 100% | 2001-09-24 | 2003-09-03 | 508d | finish no earlier than 2003-09-03 | T1 | 4064h | 4064h | MISTST1-OpTDD | Rel-4 | Ingbert | 34.122 |  |  |  |
| 2592 | 15.3 | Extensions to R99 Test cases | 139.4w | 2001-04-02 A | 2003-12-02 A |  | 100% | 2001-04-02 | 2003-12-02 | 139.4w | finish no earlier than 2003-12-02 | T1 | 5576h | 5576h | MISTST1-Ext | Rel-4 | Ingbert | 34.123 p 1,2 |  |  |  |
| 2593 | 15.4 | Extension to R99 Test cases - TTCN | 439d | 2002-06-28 A | 2004-03-03 A |  | 100% | 2002-06-28 | 2004-03-03 | 439d | finish no earlier than 2004-03-03 | T1 | 3512h | 3512h |  | Rel-4 | Ingbert |  |  |  |  |
| 2594 | 15.5 | Creation of R99 TCs for TDD - prose | 719d | 2001-10-01 A | 2004-07-01 A |  | 100% | 2001-10-01 | 2004-07-01 | 719d | finish no earlier than 2004-07-01 | T1 | 5752h | 5752h | MISTST1-TDD | Rel-4 | Ingbert | 34.123-1 |  |  |  |
| 2595 | 15.6 | Deleted - Creation of R99 TCs for TDD - TTCN | 587d | 2002-09-03 A | 2004-12-01 A |  | 100% | 2002-09-03 | 2004-12-01 | 587d | finish no earlier than 2004-12-01 | T1 | 4696h | 4696h |  | Rel-4 | Ingbert |  | TP-26 |  |  |
| 2596 | 15.7 | Deleted - Review all other work items for impact on new or exiting 34 series specs. | 25.8w | 2002-07-02 A | 2002-12-27 A |  | 100% | 2002-07-02 | 2002-12-27 | 25.8w | finish no earlier than 2002-12-27 | T1 | 1032h | 1032h | MISTST1 | Rel-4 | Ingbert | 34.121,122,123,125 | TP-18 |  |  |
| 2597 | 46 | **Facsimile** | 89d | 2000-02-22 A | 2000-06-23 A |  | 100% | 2000-02-22 | 2000-06-23 | 89d |  | S1 | 4376h | 4376h | FAX | Rel-4 | Alain |  |  |  |  |
| 2598 | 46.1 | **Real Time Fax** | 89d | 2000-02-22 A | 2000-06-23 A |  | 100% | 2000-02-22 | 2000-06-23 | 89d |  | S2 | 3664h | 3664h | FAX-RT | Rel-4 | Maurice |  |  |  |  |
| 2599 | 46.1.1 | Terminal capabilities, AT commands | 89d | 2000-02-22 A | 2000-06-23 A |  | 100% | 2000-02-22 | 2000-06-23 | 89d | finish no earlier than 2000-06-23 | T2 | 712h | 712h |  | Rel-4 |  | 21.904, 27.007 |  |  |  |
| 2600 | 46.1.2 | Signalling aspects (e.g. ICM) | 89d | 2000-02-22 A | 2000-06-23 A |  | 100% | 2000-02-22 | 2000-06-23 | 89d | start no earlier than 2000-02-22 | N1 | 712h | 712h |  | Rel-4 | Frederic |  |  |  |  |
| 2601 | 46.1.3 | Service provision | 89d | 2000-02-22 A | 2000-06-23 A |  | 100% | 2000-02-22 | 2000-06-23 | 89d | finish no earlier than 2000-06-23 | N3 | 712h | 712h |  | Rel-4 | Gwiho | 23.146 |  |  |  |
| 2602 | 46.1.4 | Review whether service/stage 1 aspects need to be aligned | 51d | 2000-04-14 A | 2000-06-23 A |  | 100% | 2000-04-14 | 2000-06-23 | 51d | finish no earlier than 2000-12-14 | S1 | 408h | 408h |  | Rel-4 | Alain |  |  |  |  |
| 2603 | 46.1.5 | Review whether architecture/stage 2 aspects need to be aligned | 51d | 2000-04-14 A | 2000-06-23 A |  | 100% | 2000-04-14 | 2000-06-23 | 51d | finish no earlier than 2000-12-14 | S2 | 408h | 408h |  | Rel-4 | Maurice |  |  |  |  |
| 2604 | 47 | Transparent End-to-End PS mobile streaming application | 253d | 2000-04-03 A | 2001-03-21 A |  | 100% | 2000-04-03 | 2001-03-21 | 253d | finish no earlier than 2000-12-29 | S4 | 2024h | 2024h | PSTREAM | Rel-4 | Paolo | 26.233, 26.234 |  |  |  |
| 2605 | 48 | **Multimedia Messaging** | 277d | 2000-02-22 A | 2001-03-14 A |  | 100% | 2000-02-22 | 2001-03-14 | 277d |  | T2,S1 | 9992h | 9992h | MMS | Rel-4 | Kimmo | 22.140, 23.140 |  | Siemens | Josef.Laumen@SAL.SIEMENS.DE |
| 2606 | 48.1 | Definition of service requirements | 72d | 2000-02-22 A | 2000-05-31 A |  | 100% | 2000-02-22 | 2000-05-31 | 72d | start no earlier than 2000-02-22 | S1 | 576h | 576h | MMS | Rel-4 | Alain |  |  |  |  |
| 2607 | 48.2 | Review of definition of service requirements | 205d | 2000-06-01 A | 2001-03-14 A | 2606 | 100% | 2000-06-01 | 2001-03-14 | 205d | finish no earlier than 2000-09-08 | T2 | 1640h | 1640h | MMS | Rel-4 | Kimmo | 22.140, 23.140 |  | Siemens |  |
| 2608 | 48.3 | **Technical Realisation** | 243d | 2000-04-10 A | 2001-03-14 A |  | 100% | 2000-04-10 | 2001-03-14 | 243d |  | T2 | 7776h | 7776h | MMS | Rel-4 | Kimmo | 22.140, 23.140 |  | Siemens | Josef.Laumen@SAL.SIEMENS.DE |
| 2609 | 48.3.1 | Review of definition of reference Achitecture model | 243d | 2000-04-10 A | 2001-03-14 A |  | 100% | 2000-04-10 | 2001-03-14 | 243d | finish no earlier than 2001-03-14 | T2 | 1944h | 1944h | MMS | Rel-4 | Kimmo | 22.140, 23.140 |  | Siemens | Josef.Laumen@SAL.SIEMENS.DE |
| 2610 | 48.3.2 | Fulfill Requirements of Stage 1 | 243d | 2000-04-10 A | 2001-03-14 A |  | 100% | 2000-04-10 | 2001-03-14 | 243d | finish no earlier than 2001-03-14 | T2 | 1944h | 1944h | MMS | Rel-4 | Kimmo | 22.140, 23.140 |  | Siemens | Josef.Laumen@SAL.SIEMENS.DE |
| 2611 | 48.3.3 | Definition of MMS primitives in Stage 2 | 243d | 2000-04-10 A | 2001-03-14 A |  | 100% | 2000-04-10 | 2001-03-14 | 243d | finish no earlier than 2001-03-14 | T2 | 1944h | 1944h | MMS | Rel-4 | Kimmo | 22.140, 23.140 |  | Siemens | Josef.Laumen@SAL.SIEMENS.DE |
| 2612 | 49 | **Transcoder-Free Operation** | 326d | 2000-01-03 A | 2001-03-30 A |  | 100% | 2000-01-03 | 2001-03-30 | 326d |  | N4,S2,N1 | 10448h | 10448h | TrFO | Rel-4 | Kimmo |  |  |  |  |
| 2613 | 49.1 | **Out-of-Band Transcoder Control solution** | 326d | 2000-01-03 A | 2001-03-30 A |  | 100% | 2000-01-03 | 2001-03-30 | 326d |  | N4 | 8448h | 8448h | TrFO-OoBTC | Rel-4 | Kimmo |  |  | NEC | Toshiyuki Tamura (tamurato@aj.jp.nec.com) |
| 2614 | 49.1.1 | implementation in UTRAN | 145d | 2000-09-11 A | 2001-03-30 A |  | 100% | 2000-09-11 | 2001-03-30 | 145d | finish no earlier than 2001-03-30 | R3 | 1160h | 1160h | TrFO-OoBTC-UTRAN | Rel-4 | Juha | 25.401, 25.410, 25.413, 25.415, 23.153 |  | Siemens | Alexander Vesely |
| 2615 | 49.1.2 | Impact on architecture, Principles and Terminology | 211d | 2000-01-03 A | 2000-10-20 A |  | 100% | 2000-01-03 | 2000-10-20 | 211d | finish no earlier than 2000-10-20 | S2 | 1680h | 1680h | TrFO-OoBTC | Rel-4 | Maurice |  |  |  |  |
| 2616 | 49.1.3 | Codec Negotiation between UE and MSC | 125d | 2000-08-14 A | 2001-02-02 A |  | 100% | 2000-08-14 | 2001-02-02 | 125d | finish no earlier than 2001-02-02 | N1 | 1000h | 1000h | TrFO-OoBTC | Rel-4 | Frederic | 24.008, 23.009, 23.108, (29.002) |  | Motorola | Andrew Howell |
| 2617 | 49.1.4 | Codec Negotiation inter MSC | 125d | 2000-07-03 A | 2000-12-22 A |  | 100% | 2000-07-03 | 2000-12-22 | 125d | finish no earlier than 2000-12-22 | N4 | 1000h | 1000h | TrFO-OoBTC | Rel-4 | Kimmo |  |  |  |  |
| 2618 | 49.1.5 | Bearer establishment inter MSC | 125d | 2000-07-03 A | 2000-12-22 A |  | 100% | 2000-07-03 | 2000-12-22 | 125d | finish no earlier than 2000-12-22 | N4 | 1000h | 1000h | TrFO-OoBTC | Rel-4 | Kimmo | 23.153 |  |  |  |

Notes:
- 2589: -
- 2590: It is believed that the current R99 test spec. can be optimised for faster overall test times. Marked as stopped 12/2008 (was 70% complete)
- 2591: It is believed that the current R99 test spec. can be optimised for faster overall test times
- 2592: Further test coverage of the R99 specification to cover supplementry services. Marked as stopped 12/2008 (was 70% complete)
- 2593: Marked as closed 12/2008 (was marked 50% complete)
- 2594: Marked as closed 12/2008 (was marked 50% complete)
- 2595: Marked as stopped 12/2008
- 2596: Marked as stopped 12/2008
- 2597: -
- 2598: postponed from R99 to R00, SP-000169
- 2599: -
- 2600: -
- 2601: -
- 2602: -
- 2603: -
- 2604: -
- 2605: -
- 2606: -
- 2607: -
- 2608: -
- 2609: -
- 2610: e.g. minimum set of media formats, media format conversion, personalization of MMS.
- 2611: -
- 2612: Lead given to CN4 from CN / [DAB 28/11/00]
- 2613: -
- 2614: moved according to NP-000575
- 2615: e.g. study cascading TrFO/TFO/TrFO
- 2616: the link to NP-000085has been deleted because refering to a R99 status sheet / One common set of codec negotiation procedures will be specified as in ID1656.
- 2617: Bearer establishment inter MSC. TS 23.153 R99 part complete. capabilities moved to annex + list of open issues
- 2618: Bearer establishment inter MSC. TS 23.153 R99 part complete. capabilities moved to annex. / See NP-000127 / Open issues: / Handling of Conference Calls; / Handling of Multi Party Supplementary Services; / Handling of Handover UMTS to GSM; / Handling of Sending a ...

| ID | WBS | Task | Duration | Start | Finish | Complete | Baseline start | Baseline finish | Baseline duration | Constraint | Resources | Work | Actual work | Text1 | Text6 | Text8 | Text4 | Text5 |
| --- | --- | --- | --- | --- | --- | --- | --- | --- | --- | --- | --- | --- | --- | --- | --- | --- | --- | --- |
| 2619 | 49.2 | **Speech Transcoder: Location and Control at the UMTS Core Network Border** | 125d | 2000-04-10 A | 2000-09-29 A | 100% | 2000-04-10 | 2000-09-29 | 125d |  | S2 | 2000h | 2000h | TrFO-STLC | Rel-4 | Maurice |  |  |
| 2620 | 49.2.1 | Transcoder at Edge | 125d | 2000-04-10 A | 2000-09-29 A | 100% | 2000-04-10 | 2000-09-29 | 125d | finish no earlier than 2000-09-29 | NP | 1000h | 1000h | TrFO-STLC | Rel-4 | Kimmo |  |  |
| 2621 | 50 | **GERAN improvements 1 (Gb over IP)** | 225d | 2000-05-09 A | 2001-03-19 A | 100% | 2000-05-09 | 2001-03-19 | 225d |  | GP | 6472h | 6472h | GEIMP1 | Rel-4 | Paolo |  |  |
| 2622 | 50.1 | **Gb over IP (Ip-fication of Gb)** | 225d | 2000-05-09 A | 2001-03-19 A | 100% | 2000-05-09 | 2001-03-19 | 225d |  | GP | 4672h | 4672h | GbIP | Rel-4 | Paolo |  |  |
| 2623 | 50.1.1 | Concept of Gb over IP (Ip-fication of Gb) | 134d | 2000-05-09 A | 2000-11-10 A | 100% | 2000-05-09 | 2000-11-10 | 134d |  | GP | 1072h | 1072h |  | Rel-4 | Paolo |  |  |
| 2624 | 50.1.2 | Changes to 08.16, 08.18 | 225d | 2000-05-09 A | 2001-03-19 A | 100% | 2000-05-09 | 2001-03-19 | 225d |  | GP | 1800h | 1800h |  | Rel-4 | Paolo |  |  |
| 2625 | 51 | **GERAN improvements 2 (NACC)** | 677d | 2000-11-06 A | 2003-06-10 A | 100% | 2000-11-06 | 2003-06-10 | 677d |  | GP | 19224h | 19224h | GEIMP2 | Rel-4 | Paolo |  |  |
| 2626 | 51.1 | **Gb enhancements** | 155d | 2000-11-06 A | 2001-06-08 A | 100% | 2000-11-06 | 2001-06-08 | 155d |  | GP | 7440h | 7440h | Gben | Rel-4 | Paolo |  |  |
| 2627 | 51.1.1 | **Intra BSC NACC (Network Assisted Cell Change)** | 155d | 2000-11-06 A | 2001-06-08 A | 100% | 2000-11-06 | 2001-06-08 | 155d |  | GP | 6200h | 6200h |  | Rel-4 | Paolo |  |  |
| 2628 | 51.1.1.1 | Concept | 155d | 2000-11-06 A | 2001-06-08 A | 100% | 2000-11-06 | 2001-06-08 | 155d | finish no earlier than 2001-06-08 | GP | 1240h | 1240h |  | Rel-4 | Paolo |  |  |
| 2629 | 51.1.1.2 | Changes in 03.64 | 155d | 2000-11-06 A | 2001-06-08 A | 100% | 2000-11-06 | 2001-06-08 | 155d | finish no earlier than 2001-06-08 | GP | 1240h | 1240h |  | Rel-4 | Paolo |  |  |
| 2630 | 51.1.1.3 | Changes in 04.60 | 155d | 2000-11-06 A | 2001-06-08 A | 100% | 2000-11-06 | 2001-06-08 | 155d | finish no earlier than 2001-06-08 | GP | 1240h | 1240h |  | Rel-4 | Paolo |  |  |
| 2631 | 51.1.1.4 | Changes in 44.008 | 155d | 2000-11-06 A | 2001-06-08 A | 100% | 2000-11-06 | 2001-06-08 | 155d | finish no earlier than 2001-06-08 | GP | 1240h | 1240h |  | Rel-4 | Paolo |  |  |
| 2632 | 51.3 | **MS conformance test for Intra BSC NACC** | 398d | 2001-11-30 A | 2003-06-10 A | 100% | 2001-11-30 | 2003-06-10 | 398d |  | GP | 6368h | 6368h | GEIMP2-Msconf | Rel-4 | Paolo |  |  |
| 2633 | 51.3.1 | Changes in 51.010 | 398d | 2001-11-30 A | 2003-06-10 A | 100% | 2001-11-30 | 2003-06-10 | 398d | finish no earlier than 2003-12-19 | G5,G4 | 3184h | 3184h |  | Rel-4 | Paolo |  |  |
| 2634 | 52 | **GERAN improvements 4 (Delayed TBF)** | 105d | 2001-01-15 A | 2001-06-08 A | 100% | 2001-01-15 | 2001-06-08 | 105d |  | GP | 3960h | 3960h | GEIMP4 | Rel-4 | Paolo |  |  |
| 2635 | 52.1 | **Gb enhancements 2** | 105d | 2001-01-15 A | 2001-06-08 A | 100% | 2001-01-15 | 2001-06-08 | 105d |  | GP | 3120h | 3120h | GEIMP4-Gben2 | Rel-4 | Paolo |  |  |
| 2636 | 52.1.1 | stage 2 | 105d | 2001-01-15 A | 2001-06-08 A | 100% | 2001-01-15 | 2001-06-08 | 105d | finish no earlier than 2001-06-08 | GP | 840h | 840h |  | Rel-4 | Paolo |  |  |
| 2637 | 52.1.2 | **Stage 3 (changes in 44.060)** | 60d | 2001-01-15 A | 2001-04-06 A | 100% | 2001-01-15 | 2001-04-06 | 60d |  | G2 | 1440h | 1440h |  | Rel-4 | Gert |  |  |
| 2638 | 52.1.2.1 | Definition of enhanced countdown procedure | 60d | 2001-01-15 A | 2001-04-06 A | 100% | 2001-01-15 | 2001-04-06 | 60d | finish no earlier than 2001-04-06 | G2 | 480h | 480h |  | Rel-4 | Gert |  |  |
| 2639 | 52.1.2.2 | Definition of enhanced TBF release procedure | 60d | 2001-01-15 A | 2001-04-06 A | 100% | 2001-01-15 | 2001-04-06 | 60d | finish no earlier than 2001-04-06 | G2 | 480h | 480h |  | Rel-4 | Gert |  |  |
| 2640 | 52.1.2.3 | Definition of USF=FREE type polling mechanism on PDCH | 60d | 2001-01-15 A | 2001-04-06 A | 100% | 2001-01-15 | 2001-04-06 | 60d | finish no earlier than 2001-04-06 | G2 | 480h | 480h |  | Rel-4 | Gert |  |  |
| 2641 | 53 | **Low Chip Rate TDD option** | 880d | 2000-07-19 A | 2003-12-02 A | 100% | 2000-07-19 | 2003-12-02 | 880d |  | R1 | 27488h | 27488h | LCRTDD | Rel-4 | Patrick | CWTS | G. Yang |
| 2642 | 53.1 | Physical layer | 183d | 2000-07-19 A | 2001-03-30 A | 100% | 2000-07-19 | 2001-03-30 | 183d | finish no earlier than 2001-03-30 | R1 | 1464h | 1464h | LCRTDD-Phys | Rel-4 | Patrick | CWTS | G. Yang |
| 2643 | 53.2 | Layer 2 and layer 3 protocol aspects | 183d | 2000-07-19 A | 2001-03-30 A | 100% | 2000-07-19 | 2001-03-30 | 183d | finish no earlier than 2001-03-30 | R2 | 1464h | 1464h | LCRTDD-L23 | Rel-4 | Joern | CWTS | Y. Liu |
| 2644 | 53.3 | RF radio transmission/reception, system performance requirements and conformance testing | 165d | 2000-08-14 A | 2001-03-30 A | 100% | 2000-08-14 | 2001-03-30 | 165d | finish no earlier than 2001-03-30 | R4 | 1320h | 1320h | LCRTDD-RF | Rel-4 | Issam | CWTS | D. Zhang |
| 2645 | 53.4 | UE radio access capability | 165d | 2000-08-14 A | 2001-03-30 A | 100% | 2000-08-14 | 2001-03-30 | 165d | finish no earlier than 2001-03-30 | R2 | 1320h | 1320h | LCRTDD-UErac | Rel-4 | Joern | CWTS | Y. Liu |
| 2646 | 53.5 | Iub/Iur protocol aspects | 165d | 2000-08-14 A | 2001-03-30 A | 100% | 2000-08-14 | 2001-03-30 | 165d | finish no earlier than 2001-03-30 | R3 | 1320h | 1320h | LCRTDD-IubIur | Rel-4 | Juha | CWTS | Y. Liu |

Notes:
- 2619: WI description and Tdoc S2-99352 / Speech Transcoder: Location and Control at the UMTS Core Network Border
- 2620: WI description and Tdoc S2-99352...
- 2621: -
- 2622: -
- 2623: -
- 2624: -
- 2625: -
- 2626: -
- 2627: -
- 2628: -
- 2629: -
- 2630: -
- 2631: -
- 2632: -
- 2633: az 05/08: duplicated UID_50099 => 50299. Marked as closed 12/2008 (was marked 50% complete)
- 2634: -
- 2635: -
- 2636: -
- 2637: -
- 2638: -
- 2639: -
- 2640: -
- 2641: -
- 2642: -
- 2643: -
- 2644: -
- 2645: -
- 2646: -

| ID | WBS | Task | Duration | Start | Finish | Predecessors | Complete | Baseline start | Baseline finish | Baseline duration | Constraint | Resources | Work | Actual work | Text6 | Text8 | Text3 | Text12 | Text1 | Text4 | Text5 |
| --- | --- | --- | --- | --- | --- | --- | --- | --- | --- | --- | --- | --- | --- | --- | --- | --- | --- | --- | --- | --- | --- |
| 2647 | 53.6 | **Low chiprate TDD interworking with GERAN** | 101d | 2000-09-01 A | 2001-01-19 A | 2646 | 100% | 2000-09-01 | 2001-01-19 | 101d |  | GP | 1616h | 1616h | Rel-4 | Paolo |  |  |  |  |  |
| 2648 | 53.6.1 | Handover and Cell Selection / Reselection to UTRA 1.28 Mcps TDD | 101d | 2000-09-01 A | 2001-01-19 A |  | 100% | 2000-09-01 | 2001-01-19 | 101d | finish no earlier than 2001-01-19 | GP | 808h | 808h | Rel-4 | Paolo |  |  |  |  |  |
| 2649 | 53.8 | **Conformance Test Aspects - Low Chip Rate TDD** | 577d | 2001-09-17 A | 2003-12-02 A | 2647 | 100% | 2001-09-17 | 2003-12-02 | 577d |  | T1 | 12088h | 12088h | Rel-4 | Ingbert |  |  |  |  |  |
| 2650 | 53.8.1 | Testing Layer 2 and layer 3 protocol aspects | 468d | 2001-09-17 A | 2003-07-02 A |  | 100% | 2001-09-17 | 2003-07-02 | 468d | finish no earlier than 2003-07-02 | T1 | 3744h | 3744h | Rel-4 | Ingbert | 34.123-1, 34.123-2 |  |  |  |  |
| 2651 | 53.8.2 | Deleted - Testing Layer 2 and layer 3 protocol aspects - TTCN | 261d | 2002-12-03 A | 2003-12-02 A |  | 100% | 2002-12-03 | 2003-12-02 | 261d | finish no earlier than 2003-12-02 | T1 | 2088h | 2088h | Rel-4 | Ingbert | 34.123-3 | TP-22 |  |  |  |
| 2652 | 53.8.3 | Testing RF Radio Transmission and Reception | 205d | 2001-09-17 A | 2002-06-28 A |  | 100% | 2001-09-17 | 2002-06-28 | 205d | finish no earlier than 2002-06-28 | T1 | 1640h | 1640h | Rel-4 | Ingbert |  |  |  |  |  |
| 2653 | 54 | **Enable bearer independent CS architecture** | 566d | 2000-01-03 A | 2002-03-01 A |  | 100% | 2000-01-03 | 2002-03-01 | 566d |  | S2 | 20192h | 20192h | Rel-4 | Maurice |  |  | CSSPLIT | Siemens | Alexander Milinski |
| 2654 | 54.1 | **Enable bearer-independent call control** | 425d | 2000-01-03 A | 2001-08-16 A |  | 100% | 2000-01-03 | 2001-08-16 | 425d |  | N4 | 12344h | 12344h | Rel-4 | Kimmo |  |  |  | Ericsson | Heinz-Peter.Keutmann@eed.ericsson.se |
| 2655 | 54.1.1 | Architecture and Stage 2 description | 181d | 2000-01-03 A | 2000-09-08 A |  | 100% | 2000-01-03 | 2000-09-08 | 181d | finish no earlier than 2000-09-08 | S2 [99.4%] | 1440h | 1440h | Rel-4 | Maurice | 23.002 |  |  |  |  |
| 2656 | 54.1.2 | Standardisation of protocols (control & user planes) over Nb interface | 64d | 2001-01-02 A | 2001-03-30 A |  | 100% | 2001-01-02 | 2001-03-30 | 64d | finish no earlier than 2001-03-30 | N3 | 512h | 512h | Rel-4 | Gwiho |  |  |  |  |  |
| 2657 | 54.1.3 | Standardisation of protocols over reference points between MSC server and Gateway MSC server | 130d | 2000-09-25 A | 2001-03-23 A |  | 100% | 2000-09-25 | 2001-03-23 | 130d | finish no earlier than 2001-03-23 | N4 | 1040h | 1040h | Rel-4 | Kimmo |  |  |  |  |  |
| 2658 | 54.1.4 | Standardisation of detailed stage 2 description | 180d | 2000-07-17 A | 2001-03-23 A |  | 100% | 2000-07-17 | 2001-03-23 | 180d | finish no earlier than 2001-03-23 | N4 | 1440h | 1440h | Rel-4 | Kimmo |  |  |  |  |  |
| 2659 | 54.1.5 | **Bearer control between MSC server and MGW** | 250d | 2000-09-01 A | 2001-08-16 A |  | 100% | 2000-09-01 | 2001-08-16 | 250d |  | N4 | 4512h | 4512h | Rel-4 | Kimmo |  |  |  |  |  |
| 2660 | 54.1.5.1 | stage 3 - protocol issues | 250d | 2000-09-01 A | 2001-08-16 A |  | 100% | 2000-09-01 | 2001-08-16 | 250d | finish no earlier than 2001-08-16 | N4 | 2000h | 2000h | Rel-4 | Kimmo |  |  |  |  |  |
| 2661 | 54.1.5.2 | stage 3 - parameter value issues | 64d | 2001-01-02 A | 2001-03-30 A |  | 100% | 2001-01-02 | 2001-03-30 | 64d | finish no earlier than 2001-03-30 | N3 | 512h | 512h | Rel-4 | Gwiho |  |  |  |  |  |
| 2662 | 54.2 | Lawful interception | 155d | 2000-08-21 A | 2001-03-23 A |  | 100% | 2000-08-21 | 2001-03-23 | 155d | finish no earlier than 2001-03-23 | S3 | 1240h | 1240h | Rel-4 | Dionisio |  |  |  |  |  |
| 2663 | 54.4 | Deleted - Conformance Test Aspects - Enable bearer independent CS architecture | 260d | 2001-03-05 A | 2002-03-01 A |  | 100% | 2001-03-05 | 2002-03-01 | 260d |  | T1 | 2080h | 2080h | Rel-4 | Ingbert |  | TP-15 | CSSPLIT-TEST |  |  |
| 2664 | 55 | **MExE enhancements Rel-4** | 511d | 2000-01-03 A | 2001-12-14 A |  | 100% | 2000-01-03 | 2001-12-14 | 511d |  | T2 | 19032h | 19032h | Rel-4 | Kimmo |  |  | MEXE |  |  |
| 2665 | 55.1 | **MExE Security Analysis Activity** | 474d | 2000-02-22 A | 2001-12-14 A |  | 100% | 2000-02-22 | 2001-12-14 | 474d |  | S3 | 8464h | 8464h | Rel-4 | Dionisio |  |  | MEXE-SEC | BT | colin.blanchard@bt.com |
| 2666 | 55.1.1 | Stage 3 | 370d | 2000-07-17 A | 2001-12-14 A |  | 100% | 2000-07-17 | 2001-12-14 | 370d | finish no earlier than 2001-12-14 | S3 | 2960h | 2960h | Rel-4 | Dionisio |  |  | MEXE1-SEC |  |  |
| 2667 | 55.1.2 | Terminal aspects | 214d | 2000-02-22 A | 2000-12-15 A |  | 100% | 2000-02-22 | 2000-12-15 | 214d | finish no earlier than 2000-12-15 | T2 | 1712h | 1712h | Rel-4 |  |  |  |  |  |  |
| 2668 | 55.2 | **MExE Rel4 Improvements and Investigations** | 251d | 2000-01-03 A | 2000-12-15 A |  | 100% | 2000-01-03 | 2000-12-15 | 251d |  | T2 | 6480h | 6480h | Rel-4 | Kimmo | 22.057, 23.057 |  | MEXE-ENHANC | Motorola | Mark Cataldo |
| 2669 | 55.2.1 | 3rd MExE classmark | 251d | 2000-01-03 A | 2000-12-15 A |  | 100% | 2000-01-03 | 2000-12-15 | 251d | finish no earlier than 2000-12-15 | T2 | 2000h | 2000h | Rel-4 | Kimmo | 22.057, 23.057 |  |  | Motorola | Mark Cataldo |
| 2670 | 55.2.2 | FS on Secure download mechanism and capabilities to support SDR concepts | 225d | 2000-02-07 A | 2000-12-15 A |  | 100% | 2000-02-07 | 2000-12-15 | 225d | finish no earlier than 2000-12-15 | T2 | 1800h | 1800h | Rel-4 | Kimmo | 22.057, 23.057 |  |  | Motorola | Mark Cataldo |
| 2671 | 55.2.3 | FS on Support of MP3/MPEG4 content | 225d | 2000-02-07 A | 2000-12-15 A |  | 100% | 2000-02-07 | 2000-12-15 | 225d | finish no earlier than 2000-12-15 | T2 | 1800h | 1800h | Rel-4 | Kimmo | 22.057, 23.057 |  |  | Motorola | Mark Cataldo |

Notes:
- 2647: -
- 2648: -
- 2649: -
- 2650: Marked as closed 12/2008 (was marked 60% complete)
- 2651: Marked as stopped 12/2008
- 2652: duration set to 6 months (was 0), finish date set
- 2653: -
- 2654: DAB 12.12.01 should be 100% hence closed
- 2655: R00 stage 2 at least 80 % complete in TSGS #8 21.-23.6.2000
- 2656: -
- 2657: -
- 2658: -
- 2659: -
- 2660: -
- 2661: -
- 2662: Requirements capture: S3#14 (Aug 00), Feature specification: S3#15 (Sep 00), Definition of architecture. Should be included in general LI work mentioned above.
- 2663: Marked as stopped 12/2008
- 2664: -
- 2665: Presentation to S3 of threats and countermeasures analysis: S3#15, Feature specification: S3#16. S3#18: WID updated
- 2666: Analysis undertaken by T2. No additional analysis needed for Rel-4
- 2667: -
- 2668: -
- 2669: Additional features for MExE R2000
- 2670: -
- 2671: -

| ID | WBS | Task | Duration | Start | Finish | Complete | Baseline start | Baseline finish | Baseline duration | Constraint | Resources | Work | Actual work | Text1 | Text6 | Text8 | Text3 | Text4 | Text5 |
| --- | --- | --- | --- | --- | --- | --- | --- | --- | --- | --- | --- | --- | --- | --- | --- | --- | --- | --- | --- |
| 2672 | 56 | **Tandem Free aspects for 3G and between 2G and 3G systems** | 344d | 2000-02-22 A | 2001-06-15 A | 100% | 2000-02-22 | 2001-06-15 | 344d |  | S4 | 9696h | 9696h | TFO | Rel-4 | Paolo |  |  |  |
| 2673 | 56.1 | **Tandem Free AMR** | 344d | 2000-02-22 A | 2001-06-15 A | 100% | 2000-02-22 | 2001-06-15 | 344d |  | S4 | 6944h | 6944h | TFO-AMR | Rel-4 | Paolo |  |  |  |
| 2674 | 56.1.1 | Specification | 284d | 2000-02-22 A | 2001-03-23 A | 100% | 2000-02-22 | 2001-03-23 | 284d | start no earlier than 2000-02-22 | S4 | 2272h | 2272h |  | Rel-4 | Paolo | 28.062 |  |  |
| 2675 | 56.1.2 | **Impact on:** | 115d | 2001-01-08 A | 2001-06-15 A | 100% | 2001-01-08 | 2001-06-15 | 115d |  | NP | 1920h | 1920h |  | Rel-4 | Kimmo |  |  |  |
| 2676 | 56.1.2.1 | CN | 60d | 2001-03-26 A | 2001-06-15 A | 100% | 2001-03-26 | 2001-06-15 | 60d | finish no earlier than 2001-06-15 | NP | 480h | 480h |  | Rel-4 | Kimmo |  |  |  |
| 2677 | 56.1.2.2 | GERAN | 65d | 2001-01-08 A | 2001-04-06 A | 100% | 2001-01-08 | 2001-04-06 | 65d | finish no earlier than 2001-04-06 | GP | 520h | 520h |  | Rel-4 | Paolo |  |  |  |
| 2678 | 57 | **Advanced Speech Call Items enhancements_REL-4** | 334d | 2000-12-03 A | 2002-03-14 A | 100% | 2000-12-03 | 2002-03-14 | 334d |  | N1 | 5925.6h | 5925.6h | ASCI | Rel-4 | Frederic |  | Nortel | sonia.garapaty@nortelnetworks.com |
| 2679 | 57.1 | Stage 2 | 326.7d | 2000-12-03 A | 2002-03-14 A | 100% | 2000-12-03 | 2002-03-14 | 326.7d | finish no earlier than 2002-03-14 | N4 | 2613.6h | 2613.6h |  | Rel-4 | Kimmo | 23.067, 24.067 | Sagem | Vivien Perlic |
| 2680 | 57.2 | Stages 2 and 3 on A interface | 80d | 2000-12-03 A | 2001-03-23 A | 100% | 2000-12-03 | 2001-03-23 | 80d | finish no earlier than 2001-03-23 | N1 | 640h | 640h |  | Rel-4 | Frederic | 44.068, 44.069, 24.008 | Nortel | sonia.garapaty@nortelnetworks.com |
| 2681 | 58 | **700 MHz spectrum support** | 776d | 2000-01-03 A | 2002-12-20 A | 100% | 2000-01-03 | 2002-12-20 | 776d |  | GP | 25016h | 25016h | 700SS | Rel-4 | Paolo |  |  |  |
| 2682 | 58.1 | **GERAN support for the 700 MHz band** | 276d | 2000-01-03 A | 2001-01-19 A | 100% | 2000-01-03 | 2001-01-19 | 276d |  | GP | 8808h | 8808h |  | Rel-4 | Paolo |  |  |  |
| 2683 | 58.1.1 | Signalling support | 276d | 2000-01-03 A | 2001-01-19 A | 100% | 2000-01-03 | 2001-01-19 | 276d | finish no earlier than 2001-01-19 | GP | 2200h | 2200h |  | Rel-4 | Paolo |  |  |  |
| 2684 | 58.1.2 | Physical layer definitions | 276d | 2000-01-03 A | 2001-01-19 A | 100% | 2000-01-03 | 2001-01-19 | 276d | finish no earlier than 2001-01-19 | GP | 2200h | 2200h |  | Rel-4 | Paolo |  |  |  |
| 2685 | 58.1.3 | Receiver performance and RF budget | 276d | 2000-01-03 A | 2001-01-19 A | 100% | 2000-01-03 | 2001-01-19 | 276d | finish no earlier than 2001-01-19 | GP | 2200h | 2200h |  | Rel-4 | Paolo |  |  |  |
| 2686 | 58.2 | **GERAN MS Conformance test for 700 MHz band** | 175d | 2001-04-02 A | 2001-11-30 A | 100% | 2001-04-02 | 2001-11-30 | 175d |  | GP | 2800h | 2800h |  | Rel-4 | Paolo |  |  |  |
| 2687 | 58.2.1 | MS test | 175d | 2001-04-02 A | 2001-11-30 A | 100% | 2001-04-02 | 2001-11-30 | 175d | finish no earlier than 2001-11-30 | GP | 1400h | 1400h |  | Rel-4 | Paolo |  |  |  |
| 2688 | 58.3 | **GERAN BTS Conformance test for 700 MHz band** | 450d | 2001-04-02 A | 2002-12-20 A | 100% | 2001-04-02 | 2002-12-20 | 450d |  | GP | 7200h | 7200h |  | Rel-4 | Paolo |  |  |  |
| 2689 | 58.3.1 | BTS test | 450d | 2001-04-02 A | 2002-12-20 A | 100% | 2001-04-02 | 2002-12-20 | 450d | finish no earlier than 2002-12-20 | GP | 3600h | 3600h |  | Rel-4 | Paolo |  |  |  |
| 2690 | 59 | Operator Determined Barring for Packet Oriented Services | 208d | 2000-06-01 A | 2001-03-19 A | 100% | 2000-06-01 | 2001-03-19 | 208d | finish no earlier than 2001-03-19 | NP | 1664h | 1664h | ODB | Rel-4 | Kimmo |  | NEC | Toshiyuki Tamura (tamurato@aj.jp.nec.com) |
| 2691 | 60 | **UMTS QoS Architecture for PS Domain** | 759d | 2000-01-03 A | 2002-11-27 A | 100% | 2000-01-03 | 2002-11-27 | 759d |  | S2,S5,R3,GP | 35600h | 35600h | QoSPS | Rel-4 | Maurice |  | Ericsson | Ina.widegren@era.ericsson.se |
| 2692 | 60.1 | Architecture | 153d | 2000-06-05 A | 2001-01-03 A | 100% | 2000-06-05 | 2001-01-03 | 153d | finish no earlier than 2001-01-03 | S2 | 1224h | 1224h |  | Rel-4 | Maurice | 23.107 |  |  |
| 2693 | 60.2 | Charging and OAM&P for QoS Management | 201d | 2001-09-21 A | 2002-06-28 A | 100% | 2001-09-21 | 2002-06-28 | 201d | finish no earlier than 2002-06-28 | S5 | 1608h | 1608h | QoSPS-OAM | Rel-4 | Dionisio | 32-series | VoiceStream, Motorola |  |
| 2694 | 60.3 | **RAB Quality of Service (re)Negotiation over Iu** | 155d | 2000-08-21 A | 2001-03-23 A | 100% | 2000-08-21 | 2001-03-23 | 155d |  | R3 | 3648h | 3648h | QoSPS-MAPEND-RABQoS | Rel-4 | Juha | 25.413 | Ericsson | anders.molander@ericsson.com |
| 2695 | 60.3.1 | RAB Quality of Service Negotiation over Iu | 155d | 2000-08-21 A | 2001-03-23 A | 100% | 2000-08-21 | 2001-03-23 | 155d | finish no earlier than 2001-03-23 | R3 | 1240h | 1240h | QoSPS-MAPEND-RABQoS-Negot | Rel-4 | Juha |  | Ericsson | anders.molander@ericsson.com |
| 2696 | 60.3.2 | RAB Quality of Service Negotiation over Iu during relocation | 16d | 2001-03-02 A | 2001-03-23 A | 100% | 2001-03-02 | 2001-03-23 | 16d | start no earlier than 2001-03-02 | R3 | 128h | 128h | QoSPS-MAPEND-RABQoS-NegotReloc | Rel-4 | Juha |  |  |  |
| 2697 | 60.3.3 | RAB Quality of Service Re-Negotiation over Iu | 130d | 2000-09-25 A | 2001-03-23 A | 100% | 2000-09-25 | 2001-03-23 | 130d | finish no earlier than 2001-03-23 | R3 | 1040h | 1040h | QoSPS-MAPEND-RABQoS-ReNegot | Rel-4 | Juha |  | Motorola | S. Irwin |

Notes:
- 2672: RAN and CN to verify no problems for GSM terminals roaming in 3G R99
- 2673: RAN and CN to verify UMTS_AMR_2 support
- 2674: -
- 2675: "Implementation" changed to "Impact on:" by A. Sultan (for better wording)
- 2676: RAN and CN to verify UMTS_AMR_2 support
- 2677: End date Modified from June to March to have it in Rel4
- 2678: Approved at CN#10
- 2679: CN4#11 30/11/02: no inputs received in CN4
- 2680: -
- 2681: -
- 2682: -
- 2683: -
- 2684: -
- 2685: -
- 2686: -
- 2687: -
- 2688: -
- 2689: -
- 2690: Completed WI missing from the P-plan Added for tracking
- 2691: -
- 2692: -
- 2693: -
- 2694: -
- 2695: -
- 2696: -
- 2697: -

| ID | WBS | Task | Duration | Start | Finish | Complete | Baseline start | Baseline finish | Baseline duration | Constraint | Resources | Work | Actual work | Text1 | Text6 | Text8 | Text12 | Text4 | Text5 | Text3 |
| --- | --- | --- | --- | --- | --- | --- | --- | --- | --- | --- | --- | --- | --- | --- | --- | --- | --- | --- | --- | --- |
| 2698 | 60.4 | **GERAN QoS Aspects - Handovers: maintenance of real-time QoS while moving between cells in the PLMN including inter-SGSN and SRNS relocation or possibly other mechanisms** | 501d | 2000-01-03 A | 2001-11-30 A | 100% | 2000-01-03 | 2001-11-30 | 501d |  | GP | 14456h | 14456h | GERQoS | Rel-4 | Paolo |  |  |  |  |
| 2699 | 60.4.1 | **Handover Concept for the PS domain** | 501d | 2000-01-03 A | 2001-11-30 A | 100% | 2000-01-03 | 2001-11-30 | 501d |  | GP | 10448h | 10448h |  | Rel-4 | Paolo |  |  |  |  |
| 2700 | 60.4.1.1 | Stable RT handover report 25.936 including header removal | 14d | 2000-01-03 A | 2000-01-19 A | 100% | 2000-01-03 | 2000-01-19 | 14d | start no earlier than 2000-01-03 | GP [92.9%] | 104h | 104h |  | Rel-4 | Paolo |  |  |  |  |
| 2701 | 60.4.1.2 | Update of stage 2 | 293d | 2000-01-03 A | 2001-02-13 A | 100% | 2000-01-03 | 2001-02-13 | 293d | finish no earlier than 2001-02-13 | GP | 2336h | 2336h |  | Rel-4 | Paolo |  |  |  |  |
| 2702 | 60.4.1.3 | Update of relevant stage 3 specs -> RRC | 501d | 2000-01-03 A | 2001-11-30 A | 100% | 2000-01-03 | 2001-11-30 | 501d | finish no earlier than 2001-11-30 | G2 | 4000h | 4000h |  | Rel-4 | Gert |  |  |  |  |
| 2703 | 60.5 | **Deleted - GERAN MS Conformance test for inter-system and intra-system Packet data real-time Handover** | 324d | 2001-08-31 A | 2002-11-27 A | 100% | 2001-08-31 | 2002-11-27 | 324d |  | G4,R3 | 12960h | 12960h | GERQoS-Mstest | Rel-4 | Paolo | GP-12 |  |  |  |
| 2704 | 60.5.1 | **Deleted - Handover for the PS domain** | 324d | 2001-08-31 A | 2002-11-27 A | 100% | 2001-08-31 | 2002-11-27 | 324d |  | G4,R3 | 10368h | 10368h |  | Rel-4 | Paolo | GP-12 |  |  |  |
| 2705 | 60.5.1.1 | Deleted - Stable RT handover report 25.936 including header removal | 324d | 2001-08-31 A | 2002-11-27 A | 100% | 2001-08-31 | 2002-11-27 | 324d | finish no earlier than 2002-11-27 | G4,R3 | 2592h | 2592h |  | Rel-4 | Paolo | GP-12 |  |  |  |
| 2706 | 60.5.1.2 | Deleted - Update of stage 2 | 324d | 2001-08-31 A | 2002-11-27 A | 100% | 2001-08-31 | 2002-11-27 | 324d | finish no earlier than 2002-11-27 | G4,R3 | 2592h | 2592h |  | Rel-4 | Paolo | GP-12 |  |  |  |
| 2707 | 60.5.1.3 | Deleted - Update of relevant stage 3 specs | 324d | 2001-08-31 A | 2002-11-27 A | 100% | 2001-08-31 | 2002-11-27 | 324d | finish no earlier than 2002-11-27 | G4,R3 | 2592h | 2592h |  | Rel-4 | Paolo | GP-12 |  |  |  |
| 2708 | 60.6 | PS-domain handover for real-time services | 155d | 2000-08-28 A | 2001-03-30 A | 100% | 2000-08-28 | 2001-03-30 | 155d | finish no earlier than 2001-03-30 | R3 | 1240h | 1240h | QoSPS-PSdoRTS | Rel-4 | Juha |  | Nokia | atte.lansisalmi@nokia.com |  |
| 2709 | 60.7 | Deleted - RAB QoS Renegotiation at Relocation | 58d | 2001-01-03 A | 2001-03-23 A | 100% | 2001-01-03 | 2001-03-23 | 58d | finish no earlier than 2001-03-23 | R3 | 464h | 464h |  | Rel-4 | Juha | RP-11 |  |  | 25.851, 25.946 |
| 2710 | 61 | (Small) Technical Enhancements and Improvements for Rel-4 | 326d? | 2000-01-03 A | 2001-03-30 A | 100% | 2000-01-03 | 2001-03-30 | 326d? |  | All | 2608h | 2608h | TEI4 | Rel-4 | all |  |  |  |  |
| 2711 | 702 | Test - (Small) Technical Enhancements and Improvements for Rel-4 | 326d? | 2000-01-03 A | 2001-03-30 A | 100% | 2000-01-03 | 2001-03-30 | 326d? | finish no earlier than 2008-12-31 | R5,T1 | 2608h | 2608h | TEI4_Test | Rel-4 | Ingbert |  |  |  |  |
| 2712 | 62 | **Rel-4 Evolutions of the transport in the UTRAN** | 525d | 2000-08-21 A | 2002-08-23 A | 100% | 2000-08-21 | 2002-08-23 | 525d |  | RP | 8600h | 8600h | ETRAN | Rel-4 | Issam |  | Alcatel | Francois Courau |  |
| 2713 | 62.1 | QoS optimization for AAL2 connections over Iub and Iur interfaces | 160d | 2000-08-21 A | 2001-03-30 A | 100% | 2000-08-21 | 2001-03-30 | 160d | finish no earlier than 2001-03-30 | R3 | 1280h | 1280h | ETRAN-QoSAAL2 | Rel-4 | Juha |  | Japan Telecom | T. Yoshimura |  |
| 2714 | 62.2 | Transport bearer modification procedure on Iub, Iur, and Iu | 130d | 2000-10-02 A | 2001-03-30 A | 100% | 2000-10-02 | 2001-03-30 | 130d | finish no earlier than 2001-03-30 | R3 | 1040h | 1040h | ETRAN-MigrMod | Rel-4 | Juha |  | Japan Telecom | T. Yoshimura |  |
| 2715 | 62.3 | **Deleted - Conformance Test Aspects of Rel-4 evolutions of the transport in UTRAN** | 130d | 2002-02-25 A | 2002-08-23 A | 100% | 2002-02-25 | 2002-08-23 | 130d |  | T1 | 2080h | 2080h |  | Rel-4 | Ingbert | TP-17 |  |  |  |
| 2716 | 62.3.1 | Deleted - Testing RAB support enhancements | 130d | 2002-02-25 A | 2002-08-23 A | 100% | 2002-02-25 | 2002-08-23 | 130d | finish no earlier than 2002-08-23 | T1 | 1040h | 1040h | CT-RABS? | Rel-4 | Ingbert | TP-17 |  |  | 34.108, 34. 121, 34.122, 34.123 p 1,2, 34.123 pt 3 |
| 2717 | 63 | **Rel-4 Evolutions of the transport in the CN** | 215d | 2000-05-29 A | 2001-03-23 A | 100% | 2000-05-29 | 2001-03-23 | 215d |  | N4,N1,N2,S2 | 7968h | 7968h | CNTRSP | Rel-4 | Kimmo |  |  |  |  |
| 2718 | 63.1 | **IP Transport of CN protocols (e.g., CAP, MAP)** | 77d | 2000-12-07 A | 2001-03-23 A | 100% | 2000-12-07 | 2001-03-23 | 77d |  | N4 | 2808h | 2808h | SS7IP | Rel-4 | Kimmo |  |  |  |  |
| 2719 | 63.1.1 | **Stage 3** | 77d | 2000-12-07 A | 2001-03-23 A | 100% | 2000-12-07 | 2001-03-23 | 77d |  | N4 | 2192h | 2192h |  | Rel-4 | Kimmo |  |  |  |  |
| 2720 | 63.1.1.1 | CAP | 77d | 2000-12-07 A | 2001-03-23 A | 100% | 2000-12-07 | 2001-03-23 | 77d | finish no earlier than 2001-03-23 | N2 | 616h | 616h |  | Rel-4 | Kimmo |  |  |  |  |
| 2721 | 63.1.1.2 | MAP | 77d | 2000-12-07 A | 2001-03-23 A | 100% | 2000-12-07 | 2001-03-23 | 77d | finish no earlier than 2001-03-23 | N4 | 616h | 616h |  | Rel-4 | Kimmo |  |  |  |  |
| 2722 | 63.1.1.3 | BSSAP+ | 43d | 2001-01-15 A | 2001-03-14 A | 100% | 2001-01-15 | 2001-03-14 | 43d | finish no earlier than 2001-03-14 | N1 | 344h | 344h | SS7IP-BSSAP+ | Rel-4 | Frederic |  |  |  |  |

Notes:
- 2698: -
- 2699: -
- 2700: -
- 2701: -
- 2702: -
- 2703: Still exist? To be clarified by GERAN4/5. Marked as stopped 12/2008
- 2704: Marked as stopped 12/2008
- 2705: Marked as stopped 12/2008
- 2706: Marked as stopped 12/2008
- 2707: Marked as stopped 12/2008
- 2708: -
- 2709: Marked as stopped 12/2008
- 2710: "Joker" WI, to be used for a Rel 4 CR not related to any feature and with very limited impact on the system
- 2711: "Joker" WI, to be used for small modifications applicable to Rel 4 conformance testing. Moved in from the Stoyan/Testing WP
- 2712: -
- 2713: -
- 2714: -
- 2715: Marked as stopped 12/2008
- 2716: Marked as stopped 12/2008
- 2717: -
- 2718: -
- 2719: -
- 2720: -
- 2721: -
- 2722: -

| ID | WBS | Task | Duration | Start | Finish | Complete | Baseline start | Baseline finish | Baseline duration | Constraint | Resources | Work | Actual work | Text4 | Text5 | Text6 | Text8 | Text1 | Text3 | Text12 |
| --- | --- | --- | --- | --- | --- | --- | --- | --- | --- | --- | --- | --- | --- | --- | --- | --- | --- | --- | --- | --- |
| 2723 | 63.2 | **FS on Transport and control separation in the PS CN domain** | 215d | 2000-05-29 A | 2001-03-23 A | 100% | 2000-05-29 | 2001-03-23 | 215d |  | S2 | 3440h | 3440h | Ericsson | Juan-Antonio.Ibanez@eed.ericsson.se | Rel-4 | Maurice |  |  |  |
| 2724 | 63.2.1 | Architectural impacts | 215d | 2000-05-29 A | 2001-03-23 A | 100% | 2000-05-29 | 2001-03-23 | 215d | finish no earlier than 2001-03-23 | S2 | 1720h | 1720h |  |  | Rel-4 | Maurice |  |  |  |
| 2725 | 64 | **Rel-4 Improvements of Radio Interface** | 700d | 2000-07-10 A | 2003-03-14 A | 100% | 2000-07-10 | 2003-03-14 | 700d |  | RP | 28624h | 28624h |  |  | Rel-4 |  | RInImp |  |  |
| 2726 | 64.1 | UTRA repeater specification (master) | 183d | 2000-07-10 A | 2001-03-21 A | 100% | 2000-07-10 | 2001-03-21 | 183d | finish no earlier than 2001-03-21 | R4 | 1464h | 1464h | Mikom, Allgon | T. Kummetz, Mikom; Alf Ahlström, Allgon | Rel-4 | Issam | RInImp-REP |  |  |
| 2727 | 64.2 | DSCH power control improvement in soft handover | 140d | 2000-09-11 A | 2001-03-23 A | 100% | 2000-09-11 | 2001-03-23 | 140d | finish no earlier than 2001-03-23 | R1 | 1120h | 1120h | Nokia | antti.toskala@nokia.com | Rel-4 | Patrick | RInImp-DSCHsho |  |  |
| 2728 | 64.3 | UMTS 1800 | 320d | 2000-09-25 A | 2001-12-14 A | 100% | 2000-09-25 | 2001-12-14 | 320d | finish no earlier than 2001-12-14 | R4 | 2560h | 2560h | Motorola | Howard Benn | Rel-4 | Issam | RInImp-UMTS18 |  |  |
| 2729 | 64.4 | UMTS 1900 | 195d | 2001-03-19 A | 2001-12-14 A | 100% | 2001-03-19 | 2001-12-14 | 195d | finish no earlier than 2001-12-14 | R4 | 1560h | 1560h | Motorola | Howard Benn | Rel-4 | Issam | RInImp-UMTS19 | 25.101 |  |
| 2730 | 64.5 | FS on High Speed downlink packet access | 155d | 2000-08-21 A | 2001-03-23 A | 100% | 2000-08-21 | 2001-03-23 | 155d | finish no earlier than 2001-03-23 | R2 | 1240h | 1240h | Motorola | Amitabha Ghosh (qa0047@email.mot.com) | Rel-4 | Joern | RInImp-HSDPA |  |  |
| 2731 | 64.6 | Deleted - FS on improved common DL channel for Cell-FACH state | 340d | 2000-09-11 A | 2001-12-28 A | 100% | 2000-09-11 | 2001-12-28 | 340d | finish no earlier than 2001-12-28 | R2 | 2720h | 2720h | GBT | J. Kwak | Rel-4 | Joern | RInImp-DLCFACH |  | RP-14 |
| 2732 | 64.7 | **Conformance Test Spec. Rel-4 improvements in Radio Interface** | 375d | 2001-10-08 A | 2003-03-14 A | 100% | 2001-10-08 | 2003-03-14 | 375d |  | T1 | 12360h | 12360h |  |  | Rel-4 | Ingbert |  |  |  |
| 2733 | 64.7.1 | Deleted - Testing Improved usage of downlink resource in FDD for CCTrCHs of dedicated type | 140d | 2002-02-18 A | 2002-08-30 A | 100% | 2002-02-18 | 2002-08-30 | 140d | finish no earlier than 2002-08-30 | T1 | 1120h | 1120h |  |  | Rel-4 | Ingbert |  |  | TP-17 |
| 2734 | 64.7.2 | Deleted - Testing Terminal Power saving features | 140d | 2002-02-18 A | 2002-08-30 A | 100% | 2002-02-18 | 2002-08-30 | 140d | finish no earlier than 2002-08-30 | T1 | 1120h | 1120h |  |  | Rel-4 | Ingbert |  |  | TP-17 |
| 2735 | 64.7.3 | Deleted - Testing DSCH power control improvement in soft handover | 140d | 2002-02-18 A | 2002-08-30 A | 100% | 2002-02-18 | 2002-08-30 | 140d | finish no earlier than 2002-08-30 | T1 | 1120h | 1120h |  |  | Rel-4 | Ingbert |  |  | TP-17 |
| 2736 | 64.7.4 | Testing UMTS 1800 | 180d | 2001-10-08 A | 2002-06-14 A | 100% | 2001-10-08 | 2002-06-14 | 180d | finish no earlier than 2002-06-14 | T1 | 1440h | 1440h |  |  | Rel-4 | Ingbert |  | 34.108, 34,121, 34.122, 34.123-1 |  |
| 2737 | 64.7.5 | Testing UMTS 1900 | 180d | 2001-10-08 A | 2002-06-14 A | 100% | 2001-10-08 | 2002-06-14 | 180d | finish no earlier than 2002-06-14 | T1 | 1440h | 1440h |  |  | Rel-4 | Ingbert |  | 34.108, 34,121, 34.122, 34.123-1 |  |
| 2738 | 64.7.6 | Testing UMTS 1800 - TTCN | 195d | 2002-06-17 A | 2003-03-14 A | 100% | 2002-06-17 | 2003-03-14 | 195d | finish no earlier than 2003-03-14 | T1 | 1560h | 1560h |  |  | Rel-4 | Ingbert |  | 34.123-3 |  |
| 2739 | 64.7.7 | Testing UMTS 1900 - TTCN | 195d | 2002-06-17 A | 2003-03-14 A | 100% | 2002-06-17 | 2003-03-14 | 195d | finish no earlier than 2003-03-14 | T1 | 1560h | 1560h |  |  | Rel-4 | Ingbert |  | 34.123-3 |  |
| 2740 | 65 | **Rel-4 RAN improvements** | 938d? | 2000-08-14 A | 2004-03-17 A | 100% | 2000-08-14 | 2004-03-17 | 938d? |  | RP | 29336h | 29336h |  |  | Rel-4 |  | RANimp |  |  |
| 2741 | 65.1 | Node B synchronization for TDD | 160d | 2000-08-14 A | 2001-03-23 A | 100% | 2000-08-14 | 2001-03-23 | 160d | finish no earlier than 2001-03-23 | R1 | 1280h | 1280h | Siemens | S. Oestreich | Rel-4 | Patrick | RANimp-NBsync |  |  |
| 2742 | 65.2 | RAB support enhancement for Rel-4 | 155d | 2000-08-21 A | 2001-03-23 A | 100% | 2000-08-21 | 2001-03-23 | 155d | finish no earlier than 2001-03-23 | R2 | 1240h | 1240h | Ericsson | M. Israelsson, A. Krishnarajah | Rel-4 | Joern | RANimp-RABSE |  |  |
| 2743 | 65.4 | **Deleted - Conformance Test Aspects - Rel-4 RAN Improvements** | 577d? | 2002-01-01 A | 2004-03-17 A | 100% | 2002-01-01 | 2004-03-17 | 577d? |  | T1 | 19312h | 19312h |  |  | Rel-4 | Ingbert |  |  | TP-23 |
| 2744 | 65.4.1 | Deleted - Testing Radio access bearer support enhancments | 175d | 2002-01-01 A | 2002-09-02 A | 100% | 2002-01-01 | 2002-09-02 | 175d | finish no earlier than 2002-09-02 | T1 | 1400h | 1400h |  |  | Rel-4 | Ingbert |  |  | TP-17 |
| 2745 | 65.4.2 | Deleted - Testing RAB support enhancements-Robust Header Compression | 332d | 2002-05-28 A | 2003-09-03 A | 100% | 2002-05-28 | 2003-09-03 | 332d | finish no earlier than 2003-09-03 | T1 | 2656h | 2656h |  |  | Rel-4 | Ingbert | RABimp-RoCH | 34.123-1, -2 | TP-21 |
| 2746 | 65.4.3 | Deleted - Testing RAB support enhancements-Robust Header Compression - TTCN | 472d | 2002-05-28 A | 2004-03-17 A | 100% | 2002-05-28 | 2004-03-17 | 472d | finish no earlier than 2004-03-17 | T1 | 3776h | 3776h |  |  | Rel-4 | Ingbert |  | 34.123-3 | TP-23 |
| 2747 | 65.4.4 | Testing of Extended Robut Header Compression | 270d | 2002-09-18 A | 2003-09-30 A | 100% | 2002-09-18 | 2003-09-30 | 270d | finish no earlier than 2003-09-30 | T1 | 2160h | 2160h |  |  | Rel-4 | Ingbert | Ext-RoHC | 34.123-1, -2 |  |
| 2748 | 65.4.5 | Deleted - Testing of Extended Robut Header Compression - TTCN | 325d | 2002-09-18 A | 2003-12-16 A | 100% | 2002-09-18 | 2003-12-16 | 325d | finish no earlier than 2003-12-16 | T1 | 2600h | 2600h |  |  | Rel-4 | Ingbert |  | 34.123-3 | TP-22 |
| 2749 | 706.3.6 | Deleted - General changes to TS34.121 corresponding to release 4 | 263d? | 2003-03-03 A | 2004-03-03 A | 100% | 2003-03-03 | 2004-03-03 | 263d? | finish no earlier than 2004-03-03 | T1 | 2104h | 2104h |  |  | Rel-4 | Ingbert | RANimp-test | 34.108, 34.121 | TP-23 |

Notes:
- 2723: -
- 2724: -
- 2725: -
- 2726: -
- 2727: -
- 2728: -
- 2729: -
- 2730: -
- 2731: Stopped at RP#14
- 2732: -
- 2733: Marked as stopped 12/2008
- 2734: Marked as stopped 12/2008
- 2735: Marked as stopped 12/2008
- 2736: -
- 2737: -
- 2738: -
- 2739: -
- 2740: -
- 2741: -
- 2742: 29 Nov 2000: split into ROHC and non-ROHC part; 5 Mar 2001: splitting off of ROHC for Rel-4 agreed by R2
- 2743: Marked as stopped 12/2008
- 2744: Marked as stopped 12/2008
- 2745: UID changed. Marked as stopped 12/2008
- 2746: UID changed. Marked as stopped 12/2008
- 2747: Marked as closed 12/2008 (was marked 15% complete)
- 2748: Marked as stopped 12/2008
- 2749: Marked as stopped 12/2008

| ID | WBS | Task | Duration | Start | Finish | Complete | Baseline start | Baseline finish | Baseline duration | Constraint | Resources | Work | Actual work | Text1 | Text4 | Text6 | Text8 | Text12 | Text3 | Text5 |
| --- | --- | --- | --- | --- | --- | --- | --- | --- | --- | --- | --- | --- | --- | --- | --- | --- | --- | --- | --- | --- |
| 2750 | 66 | **Rel-4 Emergency call enhancements** | 628d | 2000-01-03 A | 2002-05-28 A | 100% | 2000-01-03 | 2002-05-28 | 628d |  | N1,S1,T1 | 3600h | 3600h | EMC1 | Ericsson | Rel-4 | Frederic |  |  |  |
| 2751 | 66.1 | **For CS based calls** | 628d | 2000-01-03 A | 2002-05-28 A | 100% | 2000-01-03 | 2002-05-28 | 628d |  | N1 | 3600h | 3600h | EMC1-CS | Ericsson | Rel-4 | Frederic |  |  |  |
| 2752 | 66.1.1 | Distinction in CS domain of emergency call types to different emergency services | 40d | 2000-05-01 A | 2000-06-23 A | 100% | 2000-05-01 | 2000-06-23 | 40d | finish no earlier than 2000-06-23 | S1 | 320h | 320h | EMC1-CS |  | Rel-4 | Alain |  |  |  |
| 2753 | 66.1.2 | Distinction in CS domain of emergency calls to different emergency types | 22d | 2000-08-24 A | 2000-09-22 A | 100% | 2000-08-24 | 2000-09-22 | 22d | finish no earlier than 2000-09-22 | N1 | 176h | 176h | EMC1-CS |  | Rel-4 | Frederic |  |  |  |
| 2754 | 66.1.3 | Deleted - Conformance Test Aspects - Emergency call enhancements | 151d | 2000-01-03 A | 2000-07-28 A | 100% | 2000-01-03 | 2000-07-28 | 151d |  | T1 [99.3%] | 1200h | 1200h | EMC1-CS |  | Rel-4 | Ingbert | TP-08 |  |  |
| 2755 | 66.1.4 | Testing CS based emergency calls | 67d | 2002-02-25 A | 2002-05-28 A | 100% | 2002-02-25 | 2002-05-28 | 67d | finish no earlier than 2002-05-28 | T1 | 536h | 536h | EMC1-CS |  | Rel-4 | Ingbert |  | 34.123-1 |  |
| 2756 | 66.1.5 | Testing CS based emergency calls - TTCN | 134d | 2001-11-22 A | 2002-05-28 A | 100% | 2001-11-22 | 2002-05-28 | 134d | finish no earlier than 2002-05-28 | T1 | 1072h | 1072h | EMC1-CS |  | Rel-4 | Ingbert |  | 34.123-3 |  |
| 2757 | 67 | **Rel-4 Terminal interfaces** | 315d | 2000-01-03 A | 2001-03-15 A | 100% | 2000-01-03 | 2001-03-15 | 315d |  | T2 | 14296h | 14296h | TI |  | Rel-4 | Kimmo |  |  |  |
| 2758 | 67.1 | **AT commands enhancements** | 314d | 2000-01-03 A | 2001-03-14 A | 100% | 2000-01-03 | 2001-03-14 | 314d |  | T2 | 5016h | 5016h | TI-ATC |  | Rel-4 | Kimmo |  | 27.007 |  |
| 2759 | 67.1.1 | Specification of AT commands for new services | 314d | 2000-01-03 A | 2001-03-14 A | 100% | 2000-01-03 | 2001-03-14 | 314d | finish no earlier than 2001-03-14 | T2 | 2504h | 2504h |  |  | Rel-4 | Kimmo |  | 27.007 |  |
| 2760 | 67.2 | **Wide Area Data Synchronization** | 314d | 2000-01-03 A | 2001-03-14 A | 100% | 2000-01-03 | 2001-03-14 | 314d |  | T2 | 5016h | 5016h | TI-WADS |  | Rel-4 | Kimmo |  |  |  |
| 2761 | 67.2.1 | Continues evolution of Synchronization protocol | 314d | 2000-01-03 A | 2001-03-14 A | 100% | 2000-01-03 | 2001-03-14 | 314d | finish no earlier than 2001-03-14 | T2 | 2504h | 2504h | TI-SYNC-EVOL |  | Rel-4 | Kimmo |  | 27.903, 27.103 |  |
| 2762 | 67.3 | Terminal local model | 218d | 2000-05-16 A | 2001-03-15 A | 100% | 2000-05-16 | 2001-03-15 | 218d | finish no earlier than 2001-03-15 | T2 | 1744h | 1744h | TLM | Ericsson | Rel-4 | Kimmo |  | 23.227 | Olga.Tome@ECS.ERICSSON.SE |
| 2763 | 68 | **Rel-4 Location Services enhancements** | 455d | 2000-04-03 A | 2001-12-28 A | 100% | 2000-04-03 | 2001-12-28 | 455d |  | S2 | 26799.2h | 26799.2h | LCS1 | Nokia | Rel-4 | Maurice |  |  | Jan Kall |
| 2764 | 68.1 | CBS interactions | 455d | 2000-04-03 A | 2001-12-28 A | 100% | 2000-04-03 | 2001-12-28 | 455d | finish no earlier than 2001-12-28 | T2 | 3640h | 3640h | LCS1-CBS |  | Rel-4 |  |  | 23.041 |  |
| 2765 | 68.2 | LCS support in the CS domain | 180d | 2000-05-15 A | 2001-01-19 A | 100% | 2000-05-15 | 2001-01-19 | 180d | finish no earlier than 2001-01-19 | S2 | 1440h | 1440h | LCS1-CS |  | Rel-4 | Maurice |  |  |  |
| 2766 | 68.3 | **LCS support in the PS domain** | 435d | 2000-05-01 A | 2001-12-28 A | 100% | 2000-05-01 | 2001-12-28 | 435d |  | S2 | 13560h | 13560h | LCS1-PS |  | Rel-4 | Maurice |  |  |  |
| 2767 | 68.3.1 | Stage 1 | 40d | 2000-07-03 A | 2000-08-25 A | 100% | 2000-07-03 | 2000-08-25 | 40d | start no earlier than 2000-07-03 | S1 | 320h | 320h |  | Pacific Bell Wireless | Rel-4 | Alain |  | 22.071 | Randolph Wohlert (rwohlert@tri.sbc.com) |
| 2768 | 68.3.2 | Stage 2 | 190d | 2000-05-01 A | 2001-01-19 A | 100% | 2000-05-01 | 2001-01-19 | 190d | finish no earlier than 2001-01-19 | S2 | 1520h | 1520h |  |  | Rel-4 | Maurice |  | 23.271 |  |
| 2769 | 68.3.3 | **Stage 3** | 355d | 2000-08-21 A | 2001-12-28 A | 100% | 2000-08-21 | 2001-12-28 | 355d |  | N1 | 8240h | 8240h |  |  | Rel-4 | Frederic |  |  |  |
| 2770 | 68.3.3.1 | Layer 3 LCS signalling UE (MS) -SGSN (UMTS PS and and GSM-GPRS) | 355d | 2000-08-21 A | 2001-12-28 A | 100% | 2000-08-21 | 2001-12-28 | 355d | finish no earlier than 2001-12-28 | N1 | 2840h | 2840h |  | Nokia | Rel-4 | Frederic |  |  | Janne Muhonen |
| 2771 | 68.3.3.2 | MAP impacts of LCS | 160d | 2000-08-21 A | 2001-03-30 A | 100% | 2000-08-21 | 2001-03-30 | 160d | finish no earlier than 2001-03-30 | N4 | 1280h | 1280h |  |  | Rel-4 | Kimmo |  |  |  |
| 2772 | 68.3.3.3 | GTP signalling for LCS | 160d | 2000-08-21 A | 2001-03-30 A | 100% | 2000-08-21 | 2001-03-30 | 160d | finish no earlier than 2001-03-30 | N4 | 1280h | 1280h |  |  | Rel-4 | Kimmo |  |  |  |
| 2773 | 68.4 | **UE positioning Rel-4** | 260d | 2000-04-03 A | 2001-03-30 A | 100% | 2000-04-03 | 2001-03-30 | 260d |  | RP | 4591.2h | 4591.2h | LCS1-UEpos |  | Rel-4 | Issam |  |  |  |
| 2774 | 68.4.1 | Iub/Iur interfaces for methods Rel 99 | 233.9d | 2000-04-03 A | 2001-03-30 A | 100% | 2000-04-03 | 2001-03-30 | 233.9d | finish no earlier than 2001-03-30 | R3 | 1871.2h | 1871.2h | LCS1-UEpos-IubIur | Ericsson | Rel-4 | Juha |  |  | Yun-Chao Hu |
| 2775 | 68.4.2 | UE positioning enhancements - IPDL for TDD | 150d | 2000-08-28 A | 2001-03-23 A | 100% | 2000-08-28 | 2001-03-23 | 150d | finish no earlier than 2001-03-23 | R2 | 1200h | 1200h | LCS1-UEpos-enh | Siemens | Rel-4 | Joern |  |  | M. Beckmann |

Notes:
- 2750: -
- 2751: WI approved in TSG_10
- 2752: -
- 2753: Calls to different emergency services such as ambulance, fire brigade, police, etc. can be routed to respective different emergency centres. / NP-000447 is the stage 3 changes for CS call control protocol.
- 2754: UID changed. Marked as stopped 12/2008
- 2755: -
- 2756: -
- 2757: -
- 2758: -
- 2759: goal not completely achieved because of missing input
- 2760: AS: Rel5 changed to Rel4 according to SP#10 decision, milestone on testing added
- 2761: -
- 2762: -
- 2763: -
- 2764: -
- 2765: Only MAP impact foreseen so far. To be further split if needed.
- 2766: -
- 2767: To be also considered: External LCS client identity, and Privacy options when PDP-context and when no PDP-context is established
- 2768: AS: 23.271 completed at SP#10
- 2769: -
- 2770: -
- 2771: Missing work task
- 2772: -
- 2773: UID changed
- 2774: 27/11: WG corrected; rapporteur corrected
- 2775: 5 Mar 2001: splitting off of IPDL for TDD for Rel-4 agreed by R2

| ID | WBS | Task | Duration | Start | Finish | Complete | Baseline start | Baseline finish | Baseline duration | Constraint | Resources | Work | Actual work | Text1 | Text6 | Text8 | Text3 | Text4 | Text5 | Text12 |
| --- | --- | --- | --- | --- | --- | --- | --- | --- | --- | --- | --- | --- | --- | --- | --- | --- | --- | --- | --- | --- |
| 2776 | 69 | **Rel-4 UICC/(U)SIM enhancements and interworking** | 175d | 2000-07-24 A | 2001-03-23 A | 100% | 2000-07-24 | 2001-03-23 | 175d |  | T3 | 2800h | 2800h | UICC1 | Rel-4 | Xavier |  |  |  |  |
| 2777 | 69.1 | Common PCN Handset Specification (CPHS) | 175d | 2000-07-24 A | 2001-03-23 A | 100% | 2000-07-24 | 2001-03-23 | 175d | finish no earlier than 2001-03-23 | T3 | 1400h | 1400h | UICC1-CPHS | Rel-4 | Xavier | 27.103 | One2One |  |  |
| 2778 | 70 | **Rel-4 (U)SIM toolkit enhancements** | 210d | 2000-06-05 A | 2001-03-23 A | 100% | 2000-06-05 | 2001-03-23 | 210d |  | T3 | 3360h | 3360h | USAT1-LocLnk | Rel-4 | Xavier |  | Gemplus | Jean-Francois Rubon |  |
| 2779 | 70.1 | USAT local link | 210d | 2000-06-05 A | 2001-03-23 A | 100% | 2000-06-05 | 2001-03-23 | 210d | finish no earlier than 2001-03-23 | T3 | 1680h | 1680h | USAT1-LocLnk | Rel-4 | Xavier |  | Gemplus | Jean-Francois Rubon |  |
| 2780 | 71 | **Rel-4 Security enhancements** | 576d | 2000-01-03 A | 2002-03-15 A | 100% | 2000-01-03 | 2002-03-15 | 576d |  | S3 | 24152h | 24152h |  | Rel-4 | Dionisio |  | Vodafone | Peter.Howard@vodafone.com |  |
| 2781 | 71.1 | Evolution of GSM CS algorithms (e.g. A5/3 development and deployment) | 272d | 2000-01-03 A | 2001-01-15 A | 100% | 2000-01-03 | 2001-01-15 | 272d | finish no earlier than 2001-01-15 | S3 | 2168h | 2168h | SEC1-CSALGO1 | Rel-4 | Dionisio |  |  |  |  |
| 2782 | 71.2 | **Evolution of GSM PS algorithms (e.g. GEA 2 deployment)** | 219d | 2000-02-22 A | 2000-12-22 A | 100% | 2000-02-22 | 2000-12-22 | 219d |  | S3 | 6024h | 6024h | SEC1-PSALGO1 | Rel-4 | Dionisio |  |  |  |  |
| 2783 | 71.2.1 | Main aspects | 199d | 2000-02-22 A | 2000-11-24 A | 100% | 2000-02-22 | 2000-11-24 | 199d | finish no earlier than 2000-11-24 | S3 | 1592h | 1592h | SEC1-PSALGO1 | Rel-4 | Dionisio |  |  |  |  |
| 2784 | 71.2.2 | Impact on GTP | 200d | 2000-03-20 A | 2000-12-22 A | 100% | 2000-03-20 | 2000-12-22 | 200d | finish no earlier than 2000-12-22 | N4 | 1600h | 1600h | SEC1-PSALGO1 | Rel-4 | Kimmo |  |  |  |  |
| 2785 | 71.2.3 | GEA capability indication in MS CM | 135d | 2000-06-19 A | 2000-12-22 A | 100% | 2000-06-19 | 2000-12-22 | 135d | finish no earlier than 2000-12-22 | N1 | 1080h | 1080h | SEC1-PSALGO1-GEACAP | Rel-4 | Frederic |  | Vodafone Airtouch | Duncan Mills |  |
| 2786 | 71.3 | **Deleted - MAP application layer security** | 576d | 2000-01-03 A | 2002-03-15 A | 100% | 2000-01-03 | 2002-03-15 | 576d |  | S3 | 11352h | 11352h | SEC1-MAPAL | Rel-4 | Dionisio |  |  |  | SP-15 |
| 2787 | 71.3.1 | Deleted - Main aspects | 199d | 2000-02-21 A | 2001-03-29 A | 100% | 2000-02-21 | 2001-03-29 | 199d | start no earlier than 2000-02-21 | S3 | 1592h | 1592h |  | Rel-4 | Dionisio |  |  |  | SP-11 |
| 2788 | 71.3.2 | Deleted - Other stage 3 aspects | 199d | 2000-02-22 A | 2000-11-24 A | 100% | 2000-02-22 | 2000-11-24 | 199d | finish no earlier than 2000-11-24 | N4 | 1592h | 1592h |  | Rel-4 | Kimmo |  |  |  | CP-10 |
| 2789 | 71.3.3 | Deleted - Visibility and Configurability of security | 576d | 2000-01-03 A | 2002-03-15 A | 100% | 2000-01-03 | 2002-03-15 | 576d | finish no earlier than 2002-03-15 | S3 | 4600h | 4600h | SEC1-VCS | Rel-4 | Dionisio |  | France Telecom | Sebastien.nguyenngoc@rd.francetelecom.com | SP-15 |
| 2790 | 72 | **Rel-4 Charging and OAM&P** | 221d | 2000-12-01 A | 2001-10-05 A | 100% | 2000-12-01 | 2001-10-05 | 221d |  | S5 | 10472h | 10472h | OAM | Rel-4 | Dionisio |  | VoiceStream, Motorola |  |  |
| 2791 | 72.1 | Rel4 Principles, high level Requirements and Architecture | 145d | 2000-12-01 A | 2001-06-21 A | 100% | 2000-12-01 | 2001-06-21 | 145d | finish no earlier than 2001-06-21 | S5 | 1160h | 1160h | OAM-AR/PR | Rel-4 | Dionisio | 32.101, 32.102 | Motorola, Telia | Michael.Truss@motorola.com, Tommy.R.Berggren@TELIA.SE |  |
| 2792 | 72.2 | Rel4 Performance Management | 216d | 2000-12-01 A | 2001-09-28 A | 100% | 2000-12-01 | 2001-09-28 | 216d | finish no earlier than 2001-06-21 | S5 | 1728h | 1728h |  | Rel-4 | Dionisio | 32.4xy, 52.402 | T-Mobile | karl-heinz.nenner@t-mobile.de |  |
| 2793 | 72.3 | Fault Management | 221d | 2000-12-01 A | 2001-10-05 A | 100% | 2000-12-01 | 2001-10-05 | 221d | finish no earlier than 2001-06-21 | S5 | 1768h | 1768h |  | Rel-4 | Dionisio | 32.111-1/4 | Lucent |  |  |
| 2794 | 72.4 | Configuration Management | 145d | 2000-12-01 A | 2001-06-21 A | 100% | 2000-12-01 | 2001-06-21 | 145d | finish no earlier than 2001-06-21 | S5 | 1160h | 1160h | OAM-CM | Rel-4 | Dionisio | 32.106-1/8 | Ericsson | thomas.tovinger@ericsson.com |  |
| 2795 | 72.5 | Rel4 Charging Management | 216d | 2000-12-01 A | 2001-09-28 A | 100% | 2000-12-01 | 2001-09-28 | 216d | finish no earlier than 2001-06-21 | S5 | 1728h | 1728h | OAM-CH | Rel-4 | Dionisio | 32.200, 32.205, 32.215, 32.235 | T-Mobile | karl-heinz.nenner@t-mobile.de |  |
| 2796 | 72.6 | UTRAN Operations and Maintenance procedures | 145d | 2000-12-01 A | 2001-06-21 A | 100% | 2000-12-01 | 2001-06-21 | 145d | finish no earlier than 2001-06-21 | S5 | 1160h | 1160h | UOAM | Rel-4 | Dionisio | 32.800 | Mannesmann Mobilfunk | bert.boden@d2mannesmann.de |  |
| 2797 | 73 | **Global Text Telephony** | 2537d? | 2000-01-03 A | 2009-09-18 A | 100% | 2000-01-03 | 2009-09-18 | 2537d? |  | S1,S2,S4,T1,R5 | 44928h | 44928h | GTT | Rel-4 | Maurice |  | Ericsson | gunnar.hellstrom@omnitor.se |  |
| 2798 | 73.1 | Stage 1 | 188d | 2000-04-05 A | 2000-12-22 A | 100% | 2000-04-05 | 2000-12-22 | 188d | finish no earlier than 2000-12-22 | S1 | 1504h | 1504h | GTT | Rel-4 | Alain | 22.976, 22.226 |  |  |  |
| 2799 | 73.2 | Stage 2 | 206d | 2000-01-03 A | 2000-10-13 A | 100% | 2000-01-03 | 2000-10-13 | 206d |  | S2 | 1640h | 1640h | GTT | Rel-4 | Maurice | 23.226 |  |  |  |

Notes:
- 2776: -
- 2777: 28/5/2001: CRs approved at TP-11. WI complete.
- 2778: -
- 2779: 25/5/2001:CR was approved at TP-11. WI is complete
- 2780: Added BB UE authentication and rapporteur added. TO BE DELETED
- 2781: Approved SP#17
- 2782: A5/3 development will consider new GEA algorithm based on Kasumi
- 2783: Complete TSG#09 (09/2000). S3#17: Proposed for deletion. TO BE DELETED
- 2784: -
- 2785: -
- 2786: REPLACED BY NDS-MAP and NDS-IP. Completed Auto Key Management -> Rel-6. Marked as stopped 12/2008
- 2787: UID changed. Marked as stopped 12/2008
- 2788: UID changed. Marked as stopped 12/2008
- 2789: CR approved at SA3#21 awaiting comments from CN1. Marked as stopped 12/2008
- 2790: SP#13 approved WID
- 2791: -
- 2792: -
- 2793: -
- 2794: -
- 2795: -
- 2796: -
- 2797: SP#12 updated WID SP-000162=>SP-010340
- 2798: -
- 2799: -

| ID | WBS | Task | Duration | Start | Finish | Complete | Baseline start | Baseline finish | Baseline duration | Constraint | Resources | Work | Actual work | Text1 | Text6 | Text8 | Text9 | Text12 |
| --- | --- | --- | --- | --- | --- | --- | --- | --- | --- | --- | --- | --- | --- | --- | --- | --- | --- | --- |
| 2800 | 73.3 | **Specification of Cellular Text telephone Modem** | 136d | 2000-09-11 A | 2001-03-19 A | 100% | 2000-09-11 | 2001-03-19 | 136d |  | S4 | 2704h | 2704h | GTT-CTM | Rel-4 | Paolo |  |  |
| 2801 | 73.3.1 | General description and C-code | 66d | 2000-09-11 A | 2000-12-11 A | 100% | 2000-09-11 | 2000-12-11 | 66d | finish no earlier than 2000-12-11 | S4 | 528h | 528h | GTT-CTM | Rel-4 | Paolo |  |  |
| 2802 | 73.3.2 | Minimum Performance requirements | 136d | 2000-09-11 A | 2001-03-19 A | 100% | 2000-09-11 | 2001-03-19 | 136d | finish no earlier than 2001-03-19 | S4 | 1088h | 1088h | GTT-CTM | Rel-4 | Paolo |  |  |
| 2803 | 73.5 | Deleted - Conformance Test Aspects - Global Text Telephony | 2348d? | 2000-09-21 A | 2009-09-18 A | 100% | 2000-09-21 | 2009-09-18 | 2348d? | finish no earlier than 2009-09-18 | R5,T1 | 18784h | 18784h | GTT_Test | Rel-4 | Ingbert | PCG-23 | RP-45 |
| 2804 | 715 | Release 1999 Features | 261d? | 1999-01-01 A | 1999-12-31 A | 100% | 1999-01-01 | 1999-12-31 | 261d? |  | NP,SP,TP,SMG | 2088h | 2088h |  | R99 | All |  |  |
| 2805 | 716 | **UMTS Features** | 261d? | 1999-01-01 A | 1999-12-31 A | 100% | 1999-01-01 | 1999-12-31 | 261d? |  | S1,S2,S4,SMG,N3,N4,RP | 25056h | 25056h |  | R99 | Alain |  |  |
| 2806 | 716.1 | UMTS_SERVICES | 261d? | 1999-01-01 A | 1999-12-31 A | 100% | 1999-01-01 | 1999-12-31 | 261d? | start no earlier than 1999-01-01 | S1 | 2088h | 2088h | UMTS_SERVICES | R99 | Alain |  |  |
| 2807 | 716.2 | UMTS phase 1 | 261d? | 1999-01-01 A | 1999-12-31 A | 100% | 1999-01-01 | 1999-12-31 | 261d? | start no earlier than 1999-01-01 | S1 | 2088h | 2088h | UMTS1 | R99 | Alain |  |  |
| 2808 | 716.3 | UMTS Capabilities | 261d? | 1999-01-01 A | 1999-12-31 A | 100% | 1999-01-01 | 1999-12-31 | 261d? | start no earlier than 1999-01-01 | S1 | 2088h | 2088h | UMTS_Capabil | R99 | Alain |  |  |
| 2809 | 716.4 | Architecture of the GSM-UMTS platform | 261d? | 1999-01-01 A | 1999-12-31 A | 100% | 1999-01-01 | 1999-12-31 | 261d? | start no earlier than 1999-01-01 | S2,N4 | 2088h | 2088h |  | R99 | Maurice |  |  |
| 2810 | 716.5 | UMTS Terrestrial Radio Access Network | 261d? | 1999-01-01 A | 1999-12-31 A | 100% | 1999-01-01 | 1999-12-31 | 261d? | start no earlier than 1999-01-01 | RP | 2088h | 2088h | UTRAN | R99 | Joern |  |  |
| 2811 | 716.6 | UMTS 1800, UMTS 1900 | 261d? | 1999-01-01 A | 1999-12-31 A | 100% | 1999-01-01 | 1999-12-31 | 261d? | start no earlier than 1999-01-01 | R2 | 2088h | 2088h | Rlnlmp19, Rlnlmp18 | R99 | Joern |  |  |
| 2812 | 716.7 | Mandatory speech codec for narrowband telephony service | 261d? | 1999-01-01 A | 1999-12-31 A | 100% | 1999-01-01 | 1999-12-31 | 261d? | start no earlier than 1999-01-01 | S4 | 2088h | 2088h | Mandatory_Speech_Codec, AMR-NB, AMR | R99 | Paolo |  |  |
| 2813 | 716.8 | Codec for low bitrate multimedia telephony service | 261d? | 1999-01-01 A | 1999-12-31 A | 100% | 1999-01-01 | 1999-12-31 | 261d? | start no earlier than 1999-01-01 | S4 | 2088h | 2088h | Low_bit_rate_codec_for_MM_Tel., H.324M | R99 | Paolo |  |  |
| 2814 | 716.9 | 3G Audio-Visual Terminal characteristics | 261d? | 1999-01-01 A | 1999-12-31 A | 100% | 1999-01-01 | 1999-12-31 | 261d? | start no earlier than 1999-01-01 | S4 | 2088h | 2088h | WI5TAC, 3G-AVT, Terminal_Acoustic_Characteristics | R99 | Paolo |  |  |
| 2815 | 716.10 | Updates_for_UMTS | 261d? | 1999-01-01 A | 1999-12-31 A | 100% | 1999-01-01 | 1999-12-31 | 261d? | start no earlier than 1999-01-01 | N3 | 2088h | 2088h | Updates_for_UMTS | R99 | Gwiho |  |  |
| 2816 | 716.11 | UMTS | 261d? | 1999-01-01 A | 1999-12-31 A | 100% | 1999-01-01 | 1999-12-31 | 261d? | start no earlier than 1999-01-01 | N3 | 2088h | 2088h | UMTS | R99 | Gwiho |  |  |
| 2817 | 717 | **UMTS and GSM Features** | 261d? | 1999-01-01 A | 1999-12-31 A | 100% | 1999-01-01 | 1999-12-31 | 261d? |  | S1,S2,SMG,T2,N1,N2,N3,N4,R2,R3 | 114840h | 114840h |  | R99 | Alain |  |  |
| 2818 | 717.1 | Multimedia Messaging Service | 261d? | 1999-01-01 A | 1999-12-31 A | 100% | 1999-01-01 | 1999-12-31 | 261d? | start no earlier than 1999-01-01 | T2 | 2088h | 2088h | MMS | R99 |  |  |  |
| 2819 | 717.2 | Location Services | 261d? | 1999-01-01 A | 1999-12-31 A | 100% | 1999-01-01 | 1999-12-31 | 261d? | start no earlier than 1999-01-01 | S1,S2,S3,SMG1,SMG2,SMG12,N1,N2,N4,R2,R3 | 2088h | 2088h | LCS | R99 | Alain |  |  |
| 2820 | 717.3 | **Customised Application for Mobile network Enhanced Logic Phase 3** | 261d? | 1999-01-01 A | 1999-12-31 A | 100% | 1999-01-01 | 1999-12-31 | 261d? |  | S1,S2,N2,N4 | 6264h | 6264h | CAMEL3 | R99 | Alain |  |  |
| 2821 | 717.3.1 | Global view | 261d? | 1999-01-01 A | 1999-12-31 A | 100% | 1999-01-01 | 1999-12-31 | 261d? | start no earlier than 1999-01-01 | S1,S2,N2,N4 | 2088h | 2088h | CAMEL3 | R99 | Alain |  |  |
| 2822 | 717.3.2 | Multiple Subscriber Profile (MSP) based on CAMEL phase 3 | 261d? | 1999-01-01 A | 1999-12-31 A | 100% | 1999-01-01 | 1999-12-31 | 261d? | start no earlier than 1999-01-01 | S1 | 2088h | 2088h | CAMEL3 | R99 | Alain |  |  |
| 2823 | 717.4 | Short Message Service enhancements / Enhanced Messaging Service (EMS) | 261d? | 1999-01-01 A | 1999-12-31 A | 100% | 1999-01-01 | 1999-12-31 | 261d? | start no earlier than 1999-01-01 | T2 | 2088h | 2088h | EMS | R99 |  |  |  |
| 2824 | 717.5 | Mobile Station Execution Environment | 261d? | 1999-01-01 A | 1999-12-31 A | 100% | 1999-01-01 | 1999-12-31 | 261d? | start no earlier than 1999-01-01 | S1,SMG1,T2 | 2088h | 2088h | MExE | R99 | Alain |  |  |
| 2825 | 717.6 | MS_Classmark | 261d? | 1999-01-01 A | 1999-12-31 A | 100% | 1999-01-01 | 1999-12-31 | 261d? | start no earlier than 1999-01-01 | N1 | 2088h | 2088h | MS_Classmark | R99 | Frederic |  |  |

Notes:
- 2800: -
- 2801: - / Text3: 26.226, 26.230
- 2802: - / Text3: 26.231
- 2803: RP#45 work item abandoned/closed (it was never really started)
- 2804: -
- 2805: -
- 2806: - / Text3: 22.101
- 2807: - / Text3: 22.100
- 2808: Requirement for high quality speech in UMTS Phase 1 but not in R99 / Text3: 22.105
- 2809: wid Architecture overview of the GSM-UMTS System, Architecture the GSM-UMTS Platform and New Access Network to Core Network (BSS-NSS) interface / Text3: 23.002, 23.008, 23.060, 23.101, 23.110
- 2810: - / Text3: 22.011, 22.038, 22.060, 22.078, 22.100, 22.101, 22.105, 22.115, 22.129, 23.002, 23.060, 24.007, 24.008, 25.101, 25.102, 25.104, 25.105, 25.113, 25.123, 25.133, 25.141, 25.142, 25.201, 25.211, 25.212, 25.213, 25.214, 25.215, 25.221, 25.222, 25.223, 25.224,
- 2811: - / Text3: 25.307 CR#0002, 0003 Inclusion of release independent RF related information
- 2812: Define the default speech codec for UMTS (both for FDD and TDD). Definition limited to selection of one codec among several existing ones/proposed codecs: GSM AMR, IS127 EVRC, ITU G.729 and MPEG-4 speech codec. / Text3: 04.08, 05.01, 05.02, 05.03, 05.05, 05.08, 05.09, 05.09, 05.50, 08.60, 08.61, 11.21, 26.071, 26.073, 26.074, 26.090, 26.091, 26.092, 26.093, 26.094, 26.101, 26.102, 26.103, 26.104, 26.975
- 2813: - / Text3: 26.104, 26.110, 26.111, 26.911, 26.912, 26.915
- 2814: - / Text3: 26.131, 26.132
- 2815: - / Text3: 24.022, 27.001, 29.007
- 2816: - / Text3: 27.060, 29.061
- 2817: -
- 2818: MMS allows users to send/receive messages e.g. almost unlimited text length, images, audio and video clips and new content types. R99 only includes the concept. MMS stage 3 is not included in 23.140. Rel-4 adds detailed architecture and protocols. / Text3: 22.140, 23.040, 23.140
- 2819: LCS provide ability to localize a terminal. Location data is used to provide services to end-user (e.g. local map indicating closest restaurants), for emergency services or for a UMTS network entity (RNC to direct beam when space diversity is used) / Text3: 02.07, 03.71, 04.31, 04.35, 04.71, 05.05, 08.08, 08.31, 08.71, 09.31, 22.071, 23.002, 23.003, 23.007, 23.008, 23.016, 23.018, 23.032, 23.171, 24.007, 24.008, 24.030, 24.080, 25.305, 25.306, 25.331, 25.413, 25.423, 29.002, 29.010
- 2820: CAMEL is a network feature providing mechanisms to support services of operators which are not covered by standardised services, even when roaming outside the HPLMN. / Text3: 22.101, 23.008, 23.012, 23.016, 23.018, 23.060, 23.072, 23.078, 23.079, 23.082, 23.093, 29.002, 29.078
- 2821: - / Text3: 22.078, 23.078, 29.078
- 2822: MSP is an optional service enabling mobile subscribers to have several profiles associated with a single IMSI, with each profile being a subscription option. Each profile may be used for mobile originated and mobile terminated calls. / Text3: 22.097 (Advanced Addressing)
- 2823: SMS for 3G terminals compatible with GSM SMS. Added Enhanced Messaging Service (EMS) allowing small pictures, sounds, animations to be transferred via SMS. / Text3: 23.038, 23.039, 23.040, 23.042
- 2824: MExE provides a standardized MS execution environment and ability to negotiate its supported capabilities with a MExE SP. R99 enhances SIM MExE certificate management, security clarifications, QoS and defines two MExE classmarks WAP/Personal-Java based. / Text3: 02.57, 22.057, 22.101, 23.057
- 2825: MExE classmark identifies a category of MExE UE supporting MExE functionality with a minimum level of processing, memory, display, and interactive capabilities. Several MExE classmarks may be defined. / Text3: 24.008

| ID | WBS | Task | Duration | Start | Finish | Complete | Baseline start | Baseline finish | Baseline duration | Constraint | Resources | Work | Actual work | Text1 | Text6 | Text8 | Text12 |
| --- | --- | --- | --- | --- | --- | --- | --- | --- | --- | --- | --- | --- | --- | --- | --- | --- | --- |
| 2826 | 717.7 | **MultiCall** | 261d? | 1999-01-01 A | 1999-12-31 A | 100% | 1999-01-01 | 1999-12-31 | 261d? |  | S1,N1,N2,N4 | 4176h | 4176h | Multicall | R99 | Alain |  |
| 2827 | 717.7.1 | Multicall | 261d? | 1999-01-01 A | 1999-12-31 A | 100% | 1999-01-01 | 1999-12-31 | 261d? | start no earlier than 1999-01-01 | S1 | 2088h | 2088h | Multicall | R99 | Alain |  |
| 2828 | 717.8 | Virtual Home Environment | 261d? | 1999-01-01 A | 1999-12-31 A | 100% | 1999-01-01 | 1999-12-31 | 261d? | start no earlier than 1999-01-01 | S1,SMG1,S2 | 2088h | 2088h | VHE | R99 | Alain |  |
| 2829 | 717.9 | Open Service Access | 261d? | 1999-01-01 A | 1999-12-31 A | 100% | 1999-01-01 | 1999-12-31 | 261d? | start no earlier than 1999-01-01 | S1,S2,N5 | 2088h | 2088h | OSA | R99 | Alain |  |
| 2830 | 717.10 | Super Charger mechanism for signalling traffic associated with mobility | 261d? | 1999-01-01 A | 1999-12-31 A | 100% | 1999-01-01 | 1999-12-31 | 261d? | start no earlier than 1999-01-01 | N2,N4 | 2088h | 2088h | Super_Charger | R99 | Kimmo |  |
| 2831 | 717.11 | Follow_Me service | 261d? | 1999-01-01 A | 1999-12-31 A | 100% | 1999-01-01 | 1999-12-31 | 261d? | start no earlier than 1999-01-01 | S1,N2,N4 | 2088h | 2088h | Follow_Me | R99 | Alain |  |
| 2832 | 717.12 | Wide area network Synchronization and object exchange | 261d? | 1999-01-01 A | 1999-12-31 A | 100% | 1999-01-01 | 1999-12-31 | 261d? | start no earlier than 1999-01-01 | T2 | 2088h | 2088h | SYNC | R99 |  |  |
| 2833 | 717.13 | **Terminal Interfaces** | 261d? | 1999-01-01 A | 1999-12-31 A | 100% | 1999-01-01 | 1999-12-31 | 261d? |  | T2 | 8352h | 8352h |  | R99 |  |  |
| 2834 | 717.13.1 | AT commands for 3GPP | 261d? | 1999-01-01 A | 1999-12-31 A | 100% | 1999-01-01 | 1999-12-31 | 261d? | start no earlier than 1999-01-01 | T2 | 2088h | 2088h |  | R99 |  |  |
| 2835 | 717.13.2 | Physical interfaces | 261d? | 1999-01-01 A | 1999-12-31 A | 100% | 1999-01-01 | 1999-12-31 | 261d? | start no earlier than 1999-01-01 | T2 | 2088h | 2088h |  | R99 |  |  |
| 2836 | 717.13.3 | Multiplexer | 261d? | 1999-01-01 A | 1999-12-31 A | 100% | 1999-01-01 | 1999-12-31 | 261d? | start no earlier than 1999-01-01 | T2 | 2088h | 2088h | MUX MS-TE | R99 |  |  |
| 2837 | 717.14 | **Bearer Services** | 261d? | 1999-01-01 A | 1999-12-31 A | 100% | 1999-01-01 | 1999-12-31 | 261d? |  | S1,T2,N1,N3 | 27144h | 27144h |  | R99 | Alain |  |
| 2838 | 717.14.1 | **Circuit Switched Bearer Services** | 261d? | 1999-01-01 A | 1999-12-31 A | 100% | 1999-01-01 | 1999-12-31 | 261d? |  | S1,N3 | 14616h | 14616h | Circuit_switched_Bearer_Services | R99 | Alain |  |
| 2839 | 717.14.1.1 | Circuit Switched Bearer Services | 261d? | 1999-01-01 A | 1999-12-31 A | 100% | 1999-01-01 | 1999-12-31 | 261d? | start no earlier than 1999-01-01 | S1,N3 | 2088h | 2088h | CS_Bearerss_in_UMTS | R99 | Alain |  |
| 2840 | 717.14.1.2 | CS_Bearers | 261d? | 1999-01-01 A | 1999-12-31 A | 100% | 1999-01-01 | 1999-12-31 | 261d? | start no earlier than 1999-01-01 | N3 | 2088h | 2088h | CS_Bearers | R99 | Gwiho |  |
| 2841 | 717.14.1.3 | CS_Bearerss | 261d? | 1999-01-01 A | 1999-12-31 A | 100% | 1999-01-01 | 1999-12-31 | 261d? | start no earlier than 1999-01-01 | N3 | 2088h | 2088h | CS_Bearerss | R99 | Gwiho |  |
| 2842 | 717.14.1.4 | CS_Data | 261d? | 1999-01-01 A | 1999-12-31 A | 100% | 1999-01-01 | 1999-12-31 | 261d? | start no earlier than 1999-01-01 | N3 | 2088h | 2088h | CS_Data | R99 | Gwiho |  |
| 2843 | 717.14.1.5 | CS_Data_Bearers | 261d? | 1999-01-01 A | 1999-12-31 A | 100% | 1999-01-01 | 1999-12-31 | 261d? | start no earlier than 1999-01-01 | N3 | 2088h | 2088h | CS_Data_Bearers | R99 | Gwiho |  |
| 2844 | 717.14.1.6 | Deleted - Circuit Switched Bearer Services | 261d? | 1999-01-01 A | 1999-12-31 A | 100% | 1999-01-01 | 1999-12-31 | 261d? | start no earlier than 1999-01-01 | N3 | 2088h | 2088h | CSBS | R99 | Gwiho | NP-06 |
| 2845 | 717.14.2 | Frame Tunnelling Mode | 261d? | 1999-01-01 A | 1999-12-31 A | 100% | 1999-01-01 | 1999-12-31 | 261d? | start no earlier than 1999-01-01 | T2,N1,N3 | 2088h | 2088h | FTM | R99 | Gwiho |  |
| 2846 | 717.14.3 | Access to ISPs and Intranets – Wireless/Remote access to LANs | 261d? | 1999-01-01 A | 1999-12-31 A | 100% | 1999-01-01 | 1999-12-31 | 261d? | start no earlier than 1999-01-01 | N3 | 2088h | 2088h | Interworking with PDN (DHCP) | R99 | Gwiho |  |
| 2847 | 717.14.4 | **PHS Internet Access Forum Specification** | 261d? | 1999-01-01 A | 1999-12-31 A | 100% | 1999-01-01 | 1999-12-31 | 261d? |  | S1,N3 | 6264h | 6264h | PIAFS | R99 | Alain |  |
| 2848 | 717.14.4.1 | Personal Handyphone System Internet Access Forum Standard (PIAFS) | 261d? | 1999-01-01 A | 1999-12-31 A | 100% | 1999-01-01 | 1999-12-31 | 261d? | start no earlier than 1999-01-01 | S1 | 2088h | 2088h | PIAFS | R99 | Alain |  |
| 2849 | 717.14.4.2 | Support_of_PIAFS_in_UMTS | 261d? | 1999-01-01 A | 1999-12-31 A | 100% | 1999-01-01 | 1999-12-31 | 261d? | start no earlier than 1999-01-01 | N3 | 2088h | 2088h | Support_of_PIAFS_in_UMTS | R99 | Gwiho |  |

Notes:
- 2826: Multicall allows several simultaneous CS calls with dedicated bearers of independent traffic and performance characteristics. R99 Multicall was defined as a supplementary service limited to one CS bearer to be used for speech at any time. / Text3: 22.030, 22.083, 22.087, 23.008, 23.009, 23.016, 23.018, 23.108, 23.135, 24.008, 24.080, 24.135, 29.002, 29.010
- 2827: - / Text3: 22.030, 22.083, 22.087
- 2828: Information exists in SP#5-8 reports & in SP-99416,SP-000095,SP 000155. OSA allows service development by operators and 3rd parties by making use of network functionality through open, standardised, secure, extensible and scalable interfaces. / Text3: 02.01, 22.105, 22.121,23.127
- 2829: Open Service Architecture became in later Releases Open Service Access. Produced by Parlay, ETSI SPAN (TISPAN), 3GPP SA1 (Stage 1), SA2 (Stage 2) and CN5 (Stage 3), resulting in a single set of standard OSA APIs for the whole development community. / Text3: 22.121, 23.127, 29.198, 29.998
- 2830: Super Charger reduces mobility management cost by reducing the volume of location update signalling. It changes subscriber data management associated with inter-VLR and SGSN location updates. It also applies to packet services (SGSN replaces VLR and … / Text3: 21.905, 23.007, 23.008, 23.012, 23.016, 23.018, 23.040, 23.060, 23.116, 23.912, 29.002
- 2831: Follow Me enables a mobile subscriber A to manipulate the Follow Me data of a party B in such a way that - under certain conditions - subsequent calls directed to party B will be forwarded to subscriber A. It is PLMN-specific and control based on USSD / Text3: 21.905, 22.004, 22.030, 22.082, 22.090, 22.094, 23.090, 24.090, 22.094, 23.011, 23.015, 23.082, 29.002
- 2832: Allows data stored in ME/USIM to be synchronized with the outside world. TS 27.103 defines protocols based upon IrMC level 4 and will evaluate new technologies (XML) for inclusion. From Rel-4 IrMC was replaced by SyncML in 27.103. / Text3: 27.103, 27.903
- 2833: -
- 2834: AT commands to control a 3G ME via an external Terminal Equipment (TE), fully compatible with GSM AT commands. R99 adds new AT commands e.g. to control Advanced Speech Call Items (ASCI) services. / Text3: 27.005, 27.007
- 2835: Conclusion: 3GPP should not produce any technical specification for terminal interfaces other than radio interface and USIM interface. SDOs could develop own optional physical connector specification based on market requirements / Text3: 27.901
- 2836: Multiplexing protocol allowing a number of simultaneous sessions between a MS and a terminal; used to send any data (voice, SMS, USSD, fax etc.). 27.010 describes the protocol, but not the commands or data transported with it. / Text3: 27.010
- 2837: -
- 2838: CS and real-time data services provided for interworking with PSTN/ISDN so that user is unaware of access network used (UMTS, GSM or handover between ANs). Transparent(constant delay) & non-transparent(zero error with flow control) services are supported / Text3: 22.002, 23.910, 27.001, 29.007
- 2839: CS and real-time data services provided for interworking with PSTN/ISDN so that user is unaware of access network used (UMTS, GSM or handover between ANs). Transparent(constant delay) & non-transparent(zero error with flow control) services are supported / Text3: 22.002, 23.910, 27.001, 29.007
- 2840: - / Text3: 29.007
- 2841: - / Text3: 04.21, 23.910, 27.001, 29.007
- 2842: - / Text3: 27.001, 27.002, 27.003, 29.007
- 2843: - / Text3: 23.910, 27.001, 29.007
- 2844: No CR or new TS/TR approved under this WI / Text3: 29.007
- 2845: FTM is a type of async non-transparent CS bearer service (22.002). Generic term for HDLC and HDLC-related transmission protocols. Converts async non-transp data stream towards mobile side & sync data stream using X.31 flag stuffing on fixed network side. / Text3: 22.002, 27.001, 27.007, 29.007
- 2846: Access to an Intranet or ISP by running DHCP between the TE and a server in the Intranet/ISP domain. / Text3: 29.061
- 2847: PIAFS is one type of CS bearer data service (22.002). It refers to async CS tx protocol over ISDN 64 kbit/s unrestricted digital line. Facilitates interworking between PHS-MS and UMTS-UE & UMTS-UE and existing PIAFS TA (Terminal Adapter). / Text3: 22.002, 27.001, 27.007, 29.007
- 2848: PIAFS was originally standardised by the PHS Internet Access Forum in Japan. More information can be found at: http://www.infopro.or.jp/piaf / Text3: 22.002
- 2849: - / Text3: 27.001, 27.007, 29.007

| ID | WBS | Task | Duration | Start | Finish | Complete | Baseline start | Baseline finish | Baseline duration | Constraint | Resources | Work | Actual work | Text1 | Text6 | Text8 | Text12 |
| --- | --- | --- | --- | --- | --- | --- | --- | --- | --- | --- | --- | --- | --- | --- | --- | --- | --- |
| 2850 | 717.15 | **Universal Integrated Circuit Card (UICC) and Universal Subscriber Identity Module (USIM)** | 261d? | 1999-01-01 A | 1999-12-31 A | 100% | 1999-01-01 | 1999-12-31 | 261d? |  | T3 | 27144h | 27144h | UICC, USIM | R99 | Xavier |  |
| 2851 | 717.15.1 | UICC / Terminal interface; Physical and logical characteristics | 261d? | 1999-01-01 A | 1999-12-31 A | 100% | 1999-01-01 | 1999-12-31 | 261d? | start no earlier than 1999-01-01 | T3 | 2088h | 2088h | UICC | R99 | Xavier |  |
| 2852 | 717.15.2 | UICC/(U)SIM enhancements and interworking | 261d? | 1999-01-01 A | 1999-12-31 A | 100% | 1999-01-01 | 1999-12-31 | 261d? | start no earlier than 1999-01-01 | T3 | 2088h | 2088h | UICC1 | R99 | Xavier |  |
| 2853 | 717.15.3 | Characteristics of the USIM application | 261d? | 1999-01-01 A | 1999-12-31 A | 100% | 1999-01-01 | 1999-12-31 | 261d? | start no earlier than 1999-01-01 | T3 | 2088h | 2088h | USIM | R99 | Xavier |  |
| 2854 | 717.15.4 | UICC Application Identifiers | 261d? | 1999-01-01 A | 1999-12-31 A | 100% | 1999-01-01 | 1999-12-31 | 261d? | start no earlier than 1999-01-01 | T3 | 2088h | 2088h | AID, Application_Identifiers | R99 | Xavier |  |
| 2855 | 717.15.5 | SIM Application Toolkit | 261d? | 1999-01-01 A | 1999-12-31 A | 100% | 1999-01-01 | 1999-12-31 | 261d? | start no earlier than 1999-01-01 | S1,T3 | 2088h | 2088h | SAT | R99 | Alain |  |
| 2856 | 717.15.6 | USIM Application Toolkit | 261d? | 1999-01-01 A | 1999-12-31 A | 100% | 1999-01-01 | 1999-12-31 | 261d? | start no earlier than 1999-01-01 | T3 | 2088h | 2088h | USAT | R99 | Xavier |  |
| 2857 | 717.15.7 | Bearer Independent Protocol for SAT applications to exchange data over the GSM network | 261d? | 1999-01-01 A | 1999-12-31 A | 100% | 1999-01-01 | 1999-12-31 | 261d? | start no earlier than 1999-01-01 | T3 | 2088h | 2088h | BIP | R99 | Xavier |  |
| 2858 | 717.15.8 | Administrative commands and functions for IC cards | 261d? | 1999-01-01 A | 1999-12-31 A | 100% | 1999-01-01 | 1999-12-31 | 261d? | start no earlier than 1999-01-01 | T3 | 2088h | 2088h |  | R99 | Xavier |  |
| 2859 | 717.15.9 | USIM and UICC requirements | 261d? | 1999-01-01 A | 1999-12-31 A | 100% | 1999-01-01 | 1999-12-31 | 261d? | start no earlier than 1999-01-01 | T3 | 2088h | 2088h |  | R99 | Xavier |  |
| 2860 | 717.15.10 | SIM_API | 261d? | 1999-01-01 A | 1999-12-31 A | 100% | 1999-01-01 | 1999-12-31 | 261d? | start no earlier than 1999-01-01 | T3 | 2088h | 2088h | SIM_API | R99 | Xavier |  |
| 2861 | 717.15.11 | SIM_toolkit_API | 261d? | 1999-01-01 A | 1999-12-31 A | 100% | 1999-01-01 | 1999-12-31 | 261d? | start no earlier than 1999-01-01 | SMG9,T3 | 2088h | 2088h | SIM_toolkit | R99 | Xavier |  |
| 2862 | 717.15.12 | Deleted - 1.8 Volt SIM ME interface | 261d? | 1999-01-01 A | 1999-12-31 A | 100% | 1999-01-01 | 1999-12-31 | 261d? | start no earlier than 1999-01-01 | SMG9 | 2088h | 2088h | SMIME_1.8V | R99 | Xavier | TP-06 |
| 2863 | 717.16 | **USIM/UICC Testing** | 261d? | 1999-01-01 A | 1999-12-31 A | 100% | 1999-01-01 | 1999-12-31 | 261d? |  | T3 | 10440h | 10440h |  | R99 | Xavier |  |
| 2864 | 717.16.1 | Terminal tests for the UICC Interface | 261d? | 1999-01-01 A | 1999-12-31 A | 100% | 1999-01-01 | 1999-12-31 | 261d? | start no earlier than 1999-01-01 | T3 | 2088h | 2088h |  | R99 | Xavier |  |
| 2865 | 717.16.2 | USIM application test specification | 261d? | 1999-01-01 A | 1999-12-31 A | 100% | 1999-01-01 | 1999-12-31 | 261d? | start no earlier than 1999-01-01 | T3 | 2088h | 2088h |  | R99 | Xavier |  |
| 2866 | 717.16.3 | USIM conformance test specification | 261d? | 1999-01-01 A | 1999-12-31 A | 100% | 1999-01-01 | 1999-12-31 | 261d? | start no earlier than 1999-01-01 | T3 | 2088h | 2088h |  | R99 | Xavier |  |
| 2867 | 717.16.4 | SIM toolkit test specification | 261d? | 1999-01-01 A | 1999-12-31 A | 100% | 1999-01-01 | 1999-12-31 | 261d? | start no earlier than 1999-01-01 | T3 | 2088h | 2088h |  | R99 | Xavier |  |
| 2868 | 717.17 | **Security** | 261d? | 1999-01-01 A | 1999-12-31 A | 100% | 1999-01-01 | 1999-12-31 | 261d? |  | S3,N2,N4 | 8352h | 8352h | Security | R99 | Dionisio |  |
| 2869 | 717.17.1 | Fraud Information Gathering Service (for connection-orientated services) | 261d? | 1999-01-01 A | 1999-12-31 A | 100% | 1999-01-01 | 1999-12-31 | 261d? | start no earlier than 1999-01-01 | S3 | 2088h | 2088h | FIGS | R99 | Dionisio |  |
| 2870 | 717.17.2 | Immediate Service Termination / SECurity Immediate Service Termination | 261d? | 1999-01-01 A | 1999-12-31 A | 100% | 1999-01-01 | 1999-12-31 | 261d? | start no earlier than 1999-01-01 | S3,N2,N4 | 2088h | 2088h | IST, SECIST | R99 | Dionisio |  |
| 2871 | 717.17.3 | Core_Network_Security | 261d? | 1999-01-01 A | 1999-12-31 A | 100% | 1999-01-01 | 1999-12-31 | 261d? | start no earlier than 1999-01-01 | N4 | 2088h | 2088h | Core_Network_Security | R99 | Kimmo |  |
| 2872 | 718 | **GSM Features** | 261d? | 1999-01-01 A | 1999-12-31 A | 100% | 1999-01-01 | 1999-12-31 | 261d? |  | S1,S2,SMG,T2,N1,N2,N3,N4 | 50112h | 50112h |  | R99 | Alain |  |
| 2873 | 718.1 | **Dual Transfer Mode within GSM and GPRS** | 261d? | 1999-01-01 A | 1999-12-31 A | 100% | 1999-01-01 | 1999-12-31 | 261d? |  | SMG,N1 | 6264h | 6264h | DTM | R99 | Frederic |  |
| 2874 | 718.1.1 | Class A Dual Transfer Mode | 261d? | 1999-01-01 A | 1999-12-31 A | 100% | 1999-01-01 | 1999-12-31 | 261d? | start no earlier than 1999-01-01 | SMG | 2088h | 2088h | Class_A_Dual_Transfer_Mode_(DTM) | R99 | Frederic |  |
| 2875 | 718.1.2 | Dual Transfer Mode | 261d? | 1999-01-01 A | 1999-12-31 A | 100% | 1999-01-01 | 1999-12-31 | 261d? | start no earlier than 1999-01-01 | SMG,N1 | 2088h | 2088h | DTM | R99 | Frederic |  |

Notes:
- 2850: For 3G, GSM 11.11 was divided into two parts: a platform comprised of basic physical, electrical and logical specification (31.101) and an application specification (31.102)
- 2851: Defines a generic Terminal/Integrated Circuit Card (ICC) interface. Is independent of 3G USIM application => platform for any IC card application. Ensures interoperability between ICC and terminal independently of manufacturer, card issuer or operator. / Text3: 31.101 (Since 10/2000, ETSI EP SCP is responsible for the generic Terminal/Integrated Circuit Card (ICC) interface TS 102 221)
- 2852: - / Text3: 31.102, 31.900
- 2853: Defines Universal Subscriber Identity Module (USIM) application for 3G telecom network operation & resides on UICC, an IC card specified in 31.101. UICC can be used as a multi-application card: several USIMs and/or other applications can co-exist / Text3: 31.102
- 2854: Defines and administers Application IDentifiers (AID) for UICC. AID is used to address an application in the card. Consists of Registered application provider ID (RID) & Proprietary application ID exception (PIX - according to ISO/IEC 7816-5). / Text3: 21.111, 31.110
- 2855: - / Text3: 11.14, 22.030, 22.100, 22.101
- 2856: Defines UICC - ME interface, and mandatory ME procedures for USAT. Based on GSM 11.14 (SIM Application Toolkit). Commands and procedures defined in USIM and 3G Terminal for using USAT. Service and security requirements defined in 22.100 and 22.101. / Text3: 31.111
- 2857: Defines at SIM-ME interface a basic protocol allowing SIM Toolkit applications to determine available bearers and to exchange data by selecting using the most appropriate bearer available (CS data, GPRS, SMS, Unstructured Supplementary Service Data (USSD) / Text3: 03.48, 11.10, 11.14
- 2858: Defines function and syntax of administrative commands for telecommunication IC Card used during installation, activation and de-activation of applications. Compliant to ISO/IEC 7816 series. Handed over to ETSI Project Smart Card Platform (SCP) in 2000. / Text3: ETSI TS 102 222
- 2859: High level requirements for 3GPP IC card and its interface to 3GPP terminal (USIM&UICC reqs). Service&security reqs in 322.01,22.00. USIM is a 3GPP application on an IC card. Inter-operates with 3GPP terminals and provides access to 3GPP services / Text3: 21.111
- 2860: - / Text3: 03.19
- 2861: - / Text3: 03.48, 11.11, 11.14
- 2862: No CR or new TS/TR approved under this WI / Text3: 11.18
- 2863: -
- 2864: Test spec for the interface between UICC and terminal (originally based GSM 11.10-1 clause 27). Ensures UICC - terminal interoperability independently of manufacturer, card issuer or operator. Tests for applications residing on UICC are in 31.121 / Text3: 31.120
- 2865: Application test spec originally based on GSM 11.17. Aspects related to UICC administrative management phase are not defined. Any internal technical realisation of either UICC or terminal is only specified where these are reflected over the interface. / Text3: 31.121
- 2866: Conformance Test specification for UICC defined in 31.101 with USIM defined in 31.102. / Text3: 31.122
- 2867: SIM Application Toolkit (SAT) has major impact on ME design and enhances SIM/ME interface. Contains tests for SIM/ME interface optional features (no network related signalling issues involved). Doesn't form basis for any type approval or regulatory tests. / Text3: 11.10-4
- 2868: - / Text3: 02.09, 03.20, 21.133, 22.022, 23.003, 23.007, 23.008, 23.012, 23.018, 24.007, 24.008, 24.010, 24.011, 29.002, 29.060, 33.102, 33.103, 33.105, 33.107, 35.201
- 2869: HPLMN can monitor its subscribers in VPLMN, which collects info on a defined set of monitored subscribers activities & sends it to HPLMN, which can perform service limitation control eg Operator Determined Barring (ODB) and IST to limit financial exposure / Text3: 22.031, 23.031
- 2870: HPLMN can terminate all activities of its subscriber in VPLMN, if decides (based on info via eg FIGS) that a roaming subscriber is behaving in fraudulent/suspicious way. HPLMN can terminate all subscriber activities including calls in progress. / Text3: 03.35, 22.032, 23.008, 23.016, 23.035, 29.002
- 2871: - / Text3: 29.002
- 2872: -
- 2873: WID on BSS co-ordination of Radio Resource allocation for class A GPRS services - GSM Radio Access (R99) / Text3: 03.55, 03.64, 04.18, 04.60, 05.01, 05.02, 05.08, 08.08, 23.060, 24.007, 24.008
- 2874: - / Text3: 05.10
- 2875: - / Text3: 03.55, 03.64, 04.18, 05.01, 05.02, 05.08, 24.008

| ID | WBS | Task | Duration | Start | Finish | Complete | Baseline start | Baseline finish | Baseline duration | Constraint | Resources | Work | Actual work | Text1 | Text6 | Text8 | Text12 | Text4 | Text5 |
| --- | --- | --- | --- | --- | --- | --- | --- | --- | --- | --- | --- | --- | --- | --- | --- | --- | --- | --- | --- |
| 2876 | 718.2 | **General Packet Radio Service enahancements** | 261d? | 1999-01-01 A | 1999-12-31 A | 100% | 1999-01-01 | 1999-12-31 | 261d? |  | S1,S2,SMG1,SMG2,SMG7,N1,N2,N3,N4,T2 | 8352h | 8352h | GPRS enhancements | R99 | Alain |  |  |  |
| 2877 | 718.2.1 | General Packet Radio Service | 261d? | 1999-01-01 A | 1999-12-31 A | 100% | 1999-01-01 | 1999-12-31 | 261d? | start no earlier than 1999-01-01 | S1,S2,SMG1,SMG2,SMG7,N1,N2,N3,N4,T2 | 2088h | 2088h | GPRS | R99 | Alain |  |  |  |
| 2878 | 718.2.2 | GPRS2 | 261d? | 1999-01-01 A | 1999-12-31 A | 100% | 1999-01-01 | 1999-12-31 | 261d? | start no earlier than 1999-01-01 | SMG1,N2 | 2088h | 2088h | GPRS2 | R99 |  |  |  |  |
| 2879 | 718.2.3 | GPRS Tunnelling Protocol enhancement | 261d? | 1999-01-01 A | 1999-12-31 A | 100% | 1999-01-01 | 1999-12-31 | 261d? | start no earlier than 1999-01-01 | N4,N2 | 2088h | 2088h | GTP_enhancement | R99 | Kimmo |  |  |  |
| 2880 | 718.3 | **Enhanced Data rates for GSM Evolution - Phase 1** | 261d? | 1999-01-01 A | 1999-12-31 A | 100% | 1999-01-01 | 1999-12-31 | 261d? |  | SMG2,SMG1,SMG3,SMG4,SMG7,SMG9,SMG10,N1,N3,T2 | 25056h | 25056h | EDGE - Phase 1 | R99 | Maurice |  |  |  |
| 2881 | 718.3.1 | Enhanced Data rates for GSM Evolution | 261d? | 1999-01-01 A | 1999-12-31 A | 100% | 1999-01-01 | 1999-12-31 | 261d? | start no earlier than 1999-01-01 | SMG2,SMG1,SMG3,SMG4,SMG7,SMG9,SMG10,N1,N3,T2 | 2088h | 2088h | EDGE | R99 | Maurice |  |  |  |
| 2882 | 718.3.2 | EDGE-Layer1 | 261d? | 1999-01-01 A | 1999-12-31 A | 100% | 1999-01-01 | 1999-12-31 | 261d? | start no earlier than 1999-01-01 | SMG2 | 2088h | 2088h | EDGE-Layer1 | R99 |  |  |  |  |
| 2883 | 718.3.3 | High Speed Circuit Switched Data | 261d? | 1999-01-01 A | 1999-12-31 A | 100% | 1999-01-01 | 1999-12-31 | 261d? | start no earlier than 1999-01-01 | SMG1,SMG2,SMG7 | 2088h | 2088h | HSCSD | R99 |  |  |  |  |
| 2884 | 718.3.4 | Enhanced Circuit Switched Data - Phase 1 | 261d? | 1999-01-01 A | 1999-12-31 A | 100% | 1999-01-01 | 1999-12-31 | 261d? | start no earlier than 1999-01-01 | S1,SMG | 2088h | 2088h | ECSD | R99 | Alain |  |  |  |
| 2885 | 718.3.5 | EDGE-Enhanced Circuit Switched Data | 261d? | 1999-01-01 A | 1999-12-31 A | 100% | 1999-01-01 | 1999-12-31 | 261d? | start no earlier than 1999-01-01 | SMG2 | 2088h | 2088h | EDGE-ECSD | R99 |  |  |  |  |
| 2886 | 718.3.6 | Enhanced GPRS - Phase 1 | 261d? | 1999-01-01 A | 1999-12-31 A | 100% | 1999-01-01 | 1999-12-31 | 261d? | start no earlier than 1999-01-01 | SMG,N1 | 2088h | 2088h | EGPRS | R99 |  |  |  |  |
| 2887 | 718.3.7 | EDGE-EGPRS | 261d? | 1999-01-01 A | 1999-12-31 A | 100% | 1999-01-01 | 1999-12-31 | 261d? | start no earlier than 1999-01-01 | SMG2 | 2088h | 2088h | EDGE-EGPRS | R99 |  |  |  |  |
| 2888 | 718.3.8 | Packet Flow Context (PFC) | 261d? | 1999-01-01 A | 1999-12-31 A | 100% | 1999-01-01 | 1999-12-31 | 261d? | start no earlier than 1999-01-01 | SMG2 | 2088h | 2088h | PFC | R99 |  |  |  |  |
| 2889 | 718.3.9 | Support for EGPRS in ANSI-136 networks and EDGE COMPACT | 261d? | 1999-01-01 A | 1999-12-31 A | 100% | 1999-01-01 | 1999-12-31 | 261d? | start no earlier than 1999-01-01 | SMG | 2088h | 2088h | EDGE-Compact | R99 |  |  |  |  |
| 2890 | 718.3.10 | EGPRS COMPACT | 261d? | 1999-01-01 A | 1999-12-31 A | 100% | 1999-01-01 | 1999-12-31 | 261d? | start no earlier than 1999-01-01 | SMG | 2088h | 2088h | EGPRS-Compact | R99 |  |  |  |  |
| 2891 | 718.3.11 | COMPACT | 261d? | 1999-01-01 A | 1999-12-31 A | 100% | 1999-01-01 | 1999-12-31 | 261d? | start no earlier than 1999-01-01 | SMG,N1 | 2088h | 2088h | COMPACT | R99 |  |  |  |  |
| 2892 | 718.4 | GSM_400 | 261d? | 1999-01-01 A | 1999-12-31 A | 100% | 1999-01-01 | 1999-12-31 | 261d? | start no earlier than 1999-01-01 | SMG2,SMG7,T2 | 2088h | 2088h | GSM_400 | R99 | Paolo |  |  |  |
| 2893 | 718.5 | GSM_450 | 261d? | 1999-01-01 A | 1999-12-31 A | 100% | 1999-01-01 | 1999-12-31 | 261d? | start no earlier than 1999-01-01 | SMG2 | 2088h | 2088h | GSM_450 | R99 |  |  |  |  |
| 2894 | 718.6 | GSM_700 | 261d? | 1999-01-01 A | 1999-12-31 A | 100% | 1999-01-01 | 1999-12-31 | 261d? | start no earlier than 1999-01-01 | SMG2 | 2088h | 2088h | GSM_700 | R99 |  |  |  |  |
| 2895 | 718.7 | Deleted - GERAN | 261d? | 1999-01-01 A | 1999-12-31 A | 100% | 1999-01-01 | 1999-12-31 | 261d? | start no earlier than 1999-01-01 | SMG2,S2 | 2088h | 2088h | GERAN | R99 | Maurice | SP-06 |  |  |
| 2896 | 719 | **GSM Features transposed to UMTS** | 261d? | 1999-01-01 A | 1999-12-31 A | 100% | 1999-01-01 | 1999-12-31 | 261d? |  | S1,S3,T2,N2,N4 | 16704h | 16704h |  | R99 | Alain |  |  |  |
| 2897 | 719.1 | Cell Broadcast Service | 261d? | 1999-01-01 A | 1999-12-31 A | 100% | 1999-01-01 | 1999-12-31 | 261d? | start no earlier than 1999-01-01 | T2 | 2088h | 2088h | CBS | R99 |  |  |  |  |
| 2898 | 719.2 | **GSM mobile number portability euro MNP / North American MNP** | 261d? | 1999-01-01 A | 1999-12-31 A | 100% | 1999-01-01 | 1999-12-31 | 261d? |  | S1,N2,N4 | 4176h | 4176h | MNP | R99 | Alain |  |  |  |
| 2899 | 719.2.1 | Mobile Number Portability | 261d? | 1999-01-01 A | 1999-12-31 A | 100% | 1999-01-01 | 1999-12-31 | 261d? | start no earlier than 1999-01-01 | N2,N4 | 2088h | 2088h | MNP | R99 | Kimmo |  |  |  |
| 2900 | 719.3 | Automatic establishment of roaming relations | 261d? | 1999-01-01 A | 1999-12-31 A | 100% | 1999-01-01 | 1999-12-31 | 261d? | start no earlier than 1999-01-01 | S1 | 2088h | 2088h |  | R99 | Alain |  | Telecom Italia | enrico.scarrone@telecomitalia.it |
| 2901 | 719.4 | Advanced addressing | 261d? | 1999-01-01 A | 1999-12-31 A | 100% | 1999-01-01 | 1999-12-31 | 261d? | start no earlier than 1999-01-01 | S1 | 2088h | 2088h |  | R99 | Alain |  |  |  |
| 2902 | 719.5 | UMTS numbering, addressing and identities | 261d? | 1999-01-01 A | 1999-12-31 A | 100% | 1999-01-01 | 1999-12-31 | 261d? | start no earlier than 1999-01-01 | S1 | 2088h | 2088h |  | R99 | Alain |  |  |  |
| 2903 | 719.6 | Lawful Interception | 261d? | 1999-01-01 A | 1999-12-31 A | 100% | 1999-01-01 | 1999-12-31 | 261d? | start no earlier than 1999-01-01 | S3 | 2088h | 2088h | LI | R99 | Dionisio |  |  |  |

Notes:
- 2876: GPRS was introduced in Release 97. Release 99 brings a number of essential corrections e.g. on Downlink Power Control, Timing Advance procedure, Cell reselection delay time, PBCCH scheduling, PTCCH mapping, etc. / Text3: 05.02, 05.05, 05.08, 05.10, 05.50, 11.21, 23.064, 24.008, 24.060
- 2877: - / Text3: 02.60, 03.22, 03.64, 04.18, 04.60, 04.64, 04.65, 05.01, 05.02, 05.05, 05.08, 05.10, 08.08, 08.18, 11.10-1, 11.21, 22.041, 22.060, 23.003, 23.007, 23.060, 23.107, 23.122, 24.007, 24.008, 27.007, 27.060, 29.002, 29.016, 29.018, 29.060, 29.061
- 2878: Introduction of EGPRS (S1) + Introduction of Reserved Service Labels in the APN (N2) / Text3: 02.60, 23.003
- 2879: - / Text3: 23.003, 23.008, 29.060
- 2880: EDGE is independent of the frequency bands, so it can be deployed e.g. in 900 and 1900 MHz bands. The new physical layer based on 8-PSK modulation is introduced and EGPRS and ECSD facilitate the new modulation in single and multi slot constellation. / Text3: 10.59, 02.34, 02.60, 03.30, 05.10, 05.50, 11.26
- 2881: - / Text3: 02.34, 03.10, 03.20, 03.64, 04.03, 04.04, 04.06, 04.08, 04.18, 04.21, 04.22, 04.60, 04.64, 05.01, 05.02, 05.03, 05.04, 05.05, 05.08, 05.10, 05.50, 07.01, 07.02, 07.03, 08.08, 08.20, 08.58, 08.60, 09.07, 09.18, 11.10-1, 11.11, 11.21, 11.26, 23.034, 24.008,
- 2882: - / Text3: 05.05, 05.10, 05.50
- 2883: No additional features for R99. / Text3: 02.34, 04.18, 11.10-1
- 2884: ECSD supports both transparent and non-transparent services, up to 64 kbit/s and 57.6 kbit/s respectively. See Tdoc SMG2 670/99 ECSD Concept Evaluation for more info / Text3: 05.02, 08.58, 22.034
- 2885: - / Text3: 05.03
- 2886: - / Text3: 02.07, 03.64, 04.14, 04.18, 04.60, 05.05, 05.08, 24.008
- 2887: - / Text3: 05.03, 05.05, 05.08
- 2888: - / Text3: 04.18
- 2889: Support for EGPRS in ANSI-136 networks and EDGE Compact (for ANSI-136 networks only). COMPACT = Deployment of services in spectrum below 1 MHz / Text3: 03.22, 03.30, 03.64, 05.01, 05.02, 05.03, 05.05, 05.08, 05.10
- 2890: COMPACT = Deployment of services in spectrum below 1 MHz / Text3: 04.18, 05.02
- 2891: COMPACT = Deployment of services in spectrum below 1 MHz / Text3: 03.22, 04.18, 04.60, 05.08, 23.122, 24.008
- 2892: GSM in the 400 MHz bands allows to deploy GSM within frequency bands in the range 450 to 500 MHz, previously used for analogue cellular systems. See Tdoc SMG2 190/99 and 595/99 for further info. / Text3: 02.17, 03.22, 03.30, 04.04, 04.18, 04.60, 05.01, 05.02, 05.05, 05.08, 05.10, 05.50, 08.18, 08.58, 11.21, 24.008, 27.007
- 2893: - / Text3: 03.22, 03.30, 05.01, 05.05, 05.08
- 2894: - / Text3: 05.05
- 2895: No CR or new TS/TR approved under this WI / Text3: G2: 04.18 CR#A248 , 04.60 CR#B090
- 2896: -
- 2897: Moved to CT1 at TSG-T closure. Applicability of the Cell Broadcast Service (as defined for GSM network) to 3G networks / Text3: 23.041
- 2898: R98 MNP: mobile subscriber ability to change PLMN operator within the same country whilst retaining its original MS ISDN number (MSISDN). IMSI is changed, only MSISDN is kept. R99 adds requirements for North American Service Provider Number Portability. / Text3: 22.066
- 2899: - / Text3: 23.018, 23.066, 29.002
- 2900: framework for commercial and technical interworking between UMTS Home Environments and Serving Networks who have no direct prior commercial agreements with each other. / Text3: 22.101, 22.971
- 2901: - / Text3: 22.101, 22.75U, 22.975
- 2902: Also new requirements for Single and Multiple Numbering scheme was added (CR#20 and 21). Deleted the term International Mobile User Identifier (IMUI) and changed IMSI (International Mobile Station Identifier=>International Mobile Subscriber Identity. / Text3: 22.101
- 2903: Defines an interception system in UMTS that supports a number of regional interception regulations. Regional interception requirements shall be met in using specific (regional) mediation functions allowing only required information to be transported. / Text3: 33.106, 33.107

| ID | WBS | Task | Duration | Start | Finish | Complete | Baseline start | Baseline finish | Baseline duration | Constraint | Resources | Work | Actual work | Text1 | Text6 | Text8 |
| --- | --- | --- | --- | --- | --- | --- | --- | --- | --- | --- | --- | --- | --- | --- | --- | --- |
| 2904 | 720 | **Charging** | 261d? | 1999-01-01 A | 1999-12-31 A | 100% | 1999-01-01 | 1999-12-31 | 261d? |  | S1,S5 | 6264h | 6264h | CH | R99 | Alain |
| 2905 | 720.1 | Charging | 261d? | 1999-01-01 A | 1999-12-31 A | 100% | 1999-01-01 | 1999-12-31 | 261d? | start no earlier than 1999-01-01 | S1 | 2088h | 2088h | Charging | R99 | Alain |
| 2906 | 720.2 | OAM Charging Management | 261d? | 1999-01-01 A | 1999-12-31 A | 100% | 1999-01-01 | 1999-12-31 | 261d? | start no earlier than 1999-01-01 | S5 | 2088h | 2088h | OAMCH, CH | R99 | Dionisio |
| 2907 | 721 | **Operations, Administration, Maintenance and Provisioning (OAM&P)** | 261d? | 1999-01-01 A | 1999-12-31 A | 100% | 1999-01-01 | 1999-12-31 | 261d? |  | S5 | 12528h | 12528h | OAM | R99 | Dionisio |
| 2908 | 721.1 | OAM Principles and High-level Requirements | 261d? | 1999-01-01 A | 1999-12-31 A | 100% | 1999-01-01 | 1999-12-31 | 261d? | start no earlier than 1999-01-01 | S5 | 2088h | 2088h | PR, Princs_&_Reqs_(PR) | R99 | Dionisio |
| 2909 | 721.2 | OAM Architecture | 261d? | 1999-01-01 A | 1999-12-31 A | 100% | 1999-01-01 | 1999-12-31 | 261d? | start no earlier than 1999-01-01 | S5 | 2088h | 2088h | OAMAR, AR, Telecom_Management_Arch_(AR) | R99 | Dionisio |
| 2910 | 721.3 | OAM Configuration Management | 261d? | 1999-01-01 A | 1999-12-31 A | 100% | 1999-01-01 | 1999-12-31 | 261d? | start no earlier than 1999-01-01 | S5 | 2088h | 2088h | OAMCM, CM | R99 | Dionisio |
| 2911 | 721.4 | OAM Fault Management | 261d? | 1999-01-01 A | 1999-12-31 A | 100% | 1999-01-01 | 1999-12-31 | 261d? | start no earlier than 1999-01-01 | S5 | 2088h | 2088h | OAMFM | R99 | Dionisio |
| 2912 | 721.5 | OAM Performance Management | 261d? | 1999-01-01 A | 1999-12-31 A | 100% | 1999-01-01 | 1999-12-31 | 261d? | start no earlier than 1999-01-01 | S5 | 2088h | 2088h | OAMPM, PM | R99 | Dionisio |
| 2913 | 722 | Vocabulary | 261d? | 1999-01-01 A | 1999-12-31 A | 100% | 1999-01-01 | 1999-12-31 | 261d? | start no earlier than 1999-01-01 | S1 | 2088h | 2088h | Vocabulary | R99 | Alain |
| 2914 | 723 | Emergency | 261d? | 1999-01-01 A | 1999-12-31 A | 100% | 1999-01-01 | 1999-12-31 | 261d? | start no earlier than 1999-01-01 | S1 | 2088h | 2088h | Emergency | R99 | Alain |
| 2915 | 724 | GSM General Bearer Services (GBS) and interworking scenarios support in UMTS | 261d? | 1999-01-01 A | 1999-12-31 A | 100% | 1999-01-01 | 1999-12-31 | 261d? | start no earlier than 1999-01-01 | S1 | 2088h | 2088h | GSM_to_UMTS_Evol | R99 | Alain |
| 2916 | 725 | GPRS_Mobile_IP_interworking | 261d? | 1999-01-01 A | 1999-12-31 A | 100% | 1999-01-01 | 1999-12-31 | 261d? | start no earlier than 1999-01-01 | N3 | 2088h | 2088h | GPRS_Mobile_IP_interworking | R99 |  |
| 2917 | 726 | GSM/UMTS interworking | 261d? | 1999-01-01 A | 1999-12-31 A | 100% | 1999-01-01 | 1999-12-31 | 261d? | start no earlier than 1999-01-01 | N1,N2,N4,R3,S1,SMG | 2088h | 2088h | 2G3Ginterworking | R99 | Frederic |
| 2918 | 727 | Handover | 261d? | 1999-01-01 A | 1999-12-31 A | 100% | 1999-01-01 | 1999-12-31 | 261d? | start no earlier than 1999-01-01 | S1,SMG2,N1,N2,N4 | 2088h | 2088h | Handover | R99 | Alain |
| 2919 | 728 | 2G3Ghandover | 261d? | 1999-01-01 A | 1999-12-31 A | 100% | 1999-01-01 | 1999-12-31 | 261d? | start no earlier than 1999-01-01 | SMG2 | 2088h | 2088h | 2G3Ghandover | R99 |  |
| 2920 | 729 | Service Provider Name Indication | 261d? | 1999-01-01 A | 1999-12-31 A | 100% | 1999-01-01 | 1999-12-31 | 261d? | start no earlier than 1999-01-01 | S1 | 2088h | 2088h | SPANME | R99 | Alain |
| 2921 | 730 | Data & Data_CleanUp | 261d? | 1999-01-01 A | 1999-12-31 A | 100% | 1999-01-01 | 1999-12-31 | 261d? | start no earlier than 1999-01-01 | SMG1 | 2088h | 2088h | Data, Data_CleanUp | R99 |  |
| 2922 | 731 | Unstructured Supplementary Service Data | 261d? | 1999-01-01 A | 1999-12-31 A | 100% | 1999-01-01 | 1999-12-31 | 261d? | start no earlier than 1999-01-01 | SMG1,N4 | 2088h | 2088h | USSD | R99 | Kimmo |
| 2923 | 732 | Man-Machine Interface (MMI) of the User Equipment (UE) | 261d? | 1999-01-01 A | 1999-12-31 A | 100% | 1999-01-01 | 1999-12-31 | 261d? | start no earlier than 1999-01-01 | S1 | 2088h | 2088h | MMI | R99 | Alain |
| 2924 | 733 | Network Identity and Timezone (NITZ) | 261d? | 1999-01-01 A | 1999-12-31 A | 100% | 1999-01-01 | 1999-12-31 | 261d? | start no earlier than 1999-01-01 | SMG1,SMG3 | 2088h | 2088h | NITZ | R99 | Alain |
| 2925 | 734 | Operator Determined Barring for Packet Oriented Services | 261d? | 1999-01-01 A | 1999-12-31 A | 100% | 1999-01-01 | 1999-12-31 | 261d? | start no earlier than 1999-01-01 | S1 | 2088h | 2088h | ODB_Enh. | R99 | Alain |
| 2926 | 735 | Packet Flow Management | 261d? | 1999-01-01 A | 1999-12-31 A | 100% | 1999-01-01 | 1999-12-31 | 261d? | start no earlier than 1999-01-01 | SMG2 | 2088h | 2088h | Packet_Flow_Management | R99 |  |
| 2927 | 736 | GPRS_Point-To-Multipoint Group call | 261d? | 1999-01-01 A | 1999-12-31 A | 100% | 1999-01-01 | 1999-12-31 | 261d? | start no earlier than 1999-01-01 | SMG1 | 2088h | 2088h | GPRS_PTMG | R99 |  |

Notes:
- 2904: -
- 2905: WID SP-99271 Charging and accounting / Text3: 22.115, 23.121
- 2906: WID SP-99581 SA5 Year 2000 Work plan / Text3: 32.005, 32.015
- 2907: WID SP-99581 SA5 Year 2000 Work plan
- 2908: WID SP-99581 SA5 Year 2000 Work plan / Text3: 32.101
- 2909: WID SP-99581 SA5 Year 2000 Work plan / Text3: 32.101, 32.102
- 2910: WID SP-99273 Configuration management / Text3: 32.106, 32.106-1, 32.106-2, 32.106-3, 32.106-4, 32.106-5, 32.106-6, 32.106-7, 32.106-8
- 2911: WID SP-99272 Fault management / Text3: 32.111, 32.111-1, 32.111-2, 32.111-3, 32.111-4
- 2912: WID SP-99274 Performance management / Text3: 12.04, 32.104
- 2913: - / Text3: 21.905
- 2914: - / Text3: 22.101
- 2915: UMTS shall support GSM General Bearer Services (GBS) and interworking scenarios as specified in 02.02 / Text3: 22.105
- 2916: - / Text3: 29.061
- 2917: - / Text3: 03.22, 04.18, 04.60, 05.02, 05.08, 05.10, 08.08, 08.18, 08.58, 09.08, 22.011, 23.003, 23.009, 23.014, 23.034, 23.122, 24.007, 24.008, 24.011, 24.080, 29.108
- 2918: - / Text3: 04.18, 08.08, 08.58, 22.129, 23.009, 29.002, 29.010
- 2919: - / Text3: 04.18, 04.60, 05.02, 05.08, 05.10, 08.08, 29.010
- 2920: Service Provider Name Indication included in R98 (02.07) was not carried into R99 (22.101), but is in the SIM/USIM specification for R99 / Text3: 22.101
- 2921: - / Text3: 02.01, 02.02, 02.04, 02.34
- 2922: No additional features for R99. / Text3: 02.04, 02.90, 23.090, 29.002
- 2923: Data services streamlining + Support for Anonymous Call Rejection / Text3: 22.030
- 2924: - / Text3: 02.42, 04.08
- 2925: Remove ODB for Packet Oriented Services from R99 / Text3: 22.041
- 2926: - / Text3: 08.18
- 2927: - / Text3: 02.60

| ID | WBS | Task | Duration | Start | Finish | Complete | Baseline start | Baseline finish | Baseline duration | Constraint | Resources | Work | Actual work | Text6 | Text8 |
| --- | --- | --- | --- | --- | --- | --- | --- | --- | --- | --- | --- | --- | --- | --- | --- |
| 2928 | 737 | **Call Forwarding** | 261d? | 1999-01-01 A | 1999-12-31 A | 100% | 1999-01-01 | 1999-12-31 | 261d? |  | SMG1,N2,N4 | 8352h | 8352h | R99 | Kimmo |
| 2929 | 737.1 | Call Forwarding enhancements | 261d? | 1999-01-01 A | 1999-12-31 A | 100% | 1999-01-01 | 1999-12-31 | 261d? | start no earlier than 1999-01-01 | N4,N2 | 2088h | 2088h | R99 | Kimmo |
| 2930 | 737.2 | Call_Forwarding | 261d? | 1999-01-01 A | 1999-12-31 A | 100% | 1999-01-01 | 1999-12-31 | 261d? | start no earlier than 1999-01-01 | SMG1,N2 | 2088h | 2088h | R99 | Kimmo |
| 2931 | 737.3 | Call_Forwarding_Enhancements | 261d? | 1999-01-01 A | 1999-12-31 A | 100% | 1999-01-01 | 1999-12-31 | 261d? | start no earlier than 1999-01-01 | N4 | 2088h | 2088h | R99 | Kimmo |
| 2932 | 738 | **Quality of Service** | 261d? | 1999-01-01 A | 1999-12-31 A | 100% | 1999-01-01 | 1999-12-31 | 261d? |  | S2,T2,N1,N2,N4 | 10440h | 10440h | R99 | Maurice |
| 2933 | 738.1 | End-to-end UMTS Quality of Service management | 261d? | 1999-01-01 A | 1999-12-31 A | 100% | 1999-01-01 | 1999-12-31 | 261d? | start no earlier than 1999-01-01 | S2,T2,N1,N2,N4 | 2088h | 2088h | R99 | Maurice |
| 2934 | 738.2 | End-to-end QoS for PS Domain including IMS | 261d? | 1999-01-01 A | 1999-12-31 A | 100% | 1999-01-01 | 1999-12-31 | 261d? | start no earlier than 1999-01-01 | S2 | 2088h | 2088h | R99 | Maurice |
| 2935 | 738.3 | GPRS-enhanced_QoS | 261d? | 1999-01-01 A | 1999-12-31 A | 100% | 1999-01-01 | 1999-12-31 | 261d? | start no earlier than 1999-01-01 | T2 | 2088h | 2088h | R99 |  |
| 2936 | 738.4 | QoS_enhancements | 261d? | 1999-01-01 A | 1999-12-31 A | 100% | 1999-01-01 | 1999-12-31 | 261d? | start no earlier than 1999-01-01 | N2,N1,N4 | 2088h | 2088h | R99 | Kimmo |
| 2937 | 739 | Support of Localised Service Area | 261d? | 1999-01-01 A | 1999-12-31 A | 100% | 1999-01-01 | 1999-12-31 | 261d? | start no earlier than 1999-01-01 | SMG2,SMG3,SMG7,N2 | 2088h | 2088h | R99 | Maurice |
| 2938 | 740 | Transcoder_location | 261d? | 1999-01-01 A | 1999-12-31 A | 100% | 1999-01-01 | 1999-12-31 | 261d? | start no earlier than 1999-01-01 | S2 | 2088h | 2088h | R99 | Maurice |
| 2939 | 741 | Antenna_test_methods | 261d? | 1999-01-01 A | 1999-12-31 A | 100% | 1999-01-01 | 1999-12-31 | 261d? | start no earlier than 1999-01-01 | SMG2 | 2088h | 2088h | R99 |  |
| 2940 | 742 | WBAMR / high quality speech in UMTS Phase 1 but not in R99 | 261d? | 1999-01-01 A | 1999-12-31 A | 100% | 1999-01-01 | 1999-12-31 | 261d? | start no earlier than 1999-01-01 | S1 | 2088h | 2088h | R99 | Alain |
| 2941 | 743 | **Codec** | 261d? | 1999-01-01 A | 1999-12-31 A | 100% | 1999-01-01 | 1999-12-31 | 261d? |  | S4 | 14616h | 14616h | R99 | Paolo |
| 2942 | 743.1 | Codec(s)_for_Multimedia_Telephony_Service | 261d? | 1999-01-01 A | 1999-12-31 A | 100% | 1999-01-01 | 1999-12-31 | 261d? | start no earlier than 1999-01-01 | S4 | 2088h | 2088h | R99 | Paolo |
| 2943 | 743.2 | QoS for Speech and Multimedia Codec | 261d? | 1999-01-01 A | 1999-12-31 A | 100% | 1999-01-01 | 1999-12-31 | 261d? | start no earlier than 1999-01-01 | S4 | 2088h | 2088h | R99 | Paolo |
| 2944 | 743.3 | Tandem Free Operation - Adaptive Multi-Rate codec types | 261d? | 1999-01-01 A | 1999-12-31 A | 100% | 1999-01-01 | 1999-12-31 | 261d? | start no earlier than 1999-01-01 | S4 | 2088h | 2088h | R99 | Paolo |
| 2945 | 743.4 | Noise Suppression for AMR | 261d? | 1999-01-01 A | 1999-12-31 A | 100% | 1999-01-01 | 1999-12-31 | 261d? | start no earlier than 1999-01-01 | S4 | 2088h | 2088h | R99 | Paolo |
| 2946 | 743.5 | Out-of-Band Transcoder | 261d? | 1999-01-01 A | 1999-12-31 A | 100% | 1999-01-01 | 1999-12-31 | 261d? | start no earlier than 1999-01-01 | N1 | 2088h | 2088h | R99 | Frederic |
| 2947 | 743.6 | Out-of-Band Transcoder Control | 261d? | 1999-01-01 A | 1999-12-31 A | 100% | 1999-01-01 | 1999-12-31 | 261d? | start no earlier than 1999-01-01 | N1 | 2088h | 2088h | R99 | Frederic |
| 2948 | 744 | Advanced Speech Call Items enhancements | 261d? | 1999-01-01 A | 1999-12-31 A | 100% | 1999-01-01 | 1999-12-31 | 261d? | start no earlier than 1999-01-01 | SMG1,SMG2,SMG3,SMG7,SMG9,N1,C1,N4,S1,T2 | 2088h | 2088h | R99 | Alain |
| 2949 | 745 | Call Control improvements | 261d? | 1999-01-01 A | 1999-12-31 A | 100% | 1999-01-01 | 1999-12-31 | 261d? | start no earlier than 1999-01-01 | N1 | 2088h | 2088h | R99 | Frederic |
| 2950 | 746 | Multimedia | 261d? | 1999-01-01 A | 1999-12-31 A | 100% | 1999-01-01 | 1999-12-31 | 261d? | start no earlier than 1999-01-01 | N1,N3 | 2088h | 2088h | R99 | Frederic |
| 2951 | 747 | Sub-System Number allocation for RANAP, RNSAP | 261d? | 1999-01-01 A | 1999-12-31 A | 100% | 1999-01-01 | 1999-12-31 | 261d? | start no earlier than 1999-01-01 | N2 | 2088h | 2088h | R99 | Frederic |
| 2952 | 748 | Intranet / ISP access with DHCP end-to-end | 261d? | 1999-01-01 A | 1999-12-31 A | 100% | 1999-01-01 | 1999-12-31 | 261d? | start no earlier than 1999-01-01 | N3 | 2088h | 2088h | R99 | Gwiho |
| 2953 | 749 | Point_to_Multipoint_Services | 261d? | 1999-01-01 A | 1999-12-31 A | 100% | 1999-01-01 | 1999-12-31 | 261d? | start no earlier than 1999-01-01 | N3 | 2088h | 2088h | R99 | Gwiho |
| 2954 | 750 | Facsimile | 261d? | 1999-01-01 A | 1999-12-31 A | 100% | 1999-01-01 | 1999-12-31 | 261d? | start no earlier than 1999-01-01 | S1 | 2088h | 2088h | R99 | Alain |
| 2955 | 751 | Realtime_NT_FAX_in_UMTS | 261d? | 1999-01-01 A | 1999-12-31 A | 100% | 1999-01-01 | 1999-12-31 | 261d? | start no earlier than 1999-01-01 | N3 | 2088h | 2088h | R99 | Gwiho |
| 2956 | 752 | Gateway Location Register (GLR) - Mobile Application Part (MAP) specification | 261d? | 1999-01-01 A | 1999-12-31 A | 100% | 1999-01-01 | 1999-12-31 | 261d? | start no earlier than 1999-01-01 | N4 | 2088h | 2088h | R99 | Kimmo |
| 2957 | 753 | Multiple Subscriber Profile phase 2 | 261d? | 1999-01-01 A | 1999-12-31 A | 100% | 1999-01-01 | 1999-12-31 | 261d? | start no earlier than 1999-01-01 | S1,N4 | 2088h | 2088h | R99 | Alain |
| 2958 | 754 | Prepaging | 261d? | 1999-01-01 A | 1999-12-31 A | 100% | 1999-01-01 | 1999-12-31 | 261d? | start no earlier than 1999-01-01 | N2,N4 | 2088h | 2088h | R99 | Kimmo |
| 2959 | 755 | Downlink Advanced Receiver Performance | 261d? | 1999-01-01 A | 1999-12-31 A | 100% | 1999-01-01 | 1999-12-31 | 261d? | start no earlier than 1999-01-01 | SMG | 2088h | 2088h | R99 |  |
| 2960 | 756 | Harmonized Standard | 261d? | 1999-01-01 A | 1999-12-31 A | 100% | 1999-01-01 | 1999-12-31 | 261d? | start no earlier than 1999-01-01 | SMG2 | 2088h | 2088h | R99 |  |
| 2961 | 757 | Streamlining of specifications | 261d? | 1999-01-01 A | 1999-12-31 A | 100% | 1999-01-01 | 1999-12-31 | 261d? | start no earlier than 1999-01-01 | N3 | 2088h | 2088h | R99 | Gwiho |
| 2962 | 758 | R99_Service_Clean_up | 261d? | 1999-01-01 A | 1999-12-31 A | 100% | 1999-01-01 | 1999-12-31 | 261d? | start no earlier than 1999-01-01 | N3 | 2088h | 2088h | R99 | Gwiho |

Notes:
- 2928: -
- 2929: No additional features for R99. / Text1: CF_enhancements / Text3: 23.078, 23.079, 23.082, 29.002, 29.078
- 2930: - / Text1: Call_Forwarding / Text3: 02.82, 29.002
- 2931: - / Text1: Call_Forwarding_Enhancements / Text3: 23.082
- 2932: WID SMG 98-0781 End To End UMTS QoS Management
- 2933: WID SMG 98-0781 End To End UMTS QoS Management / Text1: QoS / Text3: 23.107, 23.907, 24.008
- 2934: - / Text1: E2EQoS / Text3: 23.060, 23.170
- 2935: AT-commands for Enhanced QoS Support management / Text1: GPRS-enhanced_QoS / Text3: 27.007
- 2936: - / Text1: QoS_enhancements / Text3: 23.008, 23.016, 24.008, 29.002, 29.060
- 2937: Mechanism which can be used as a platform for providing special tariffs and/or special set of service features for certain subscribers within a regionally restricted area or areas. No additional features for R99. / Text1: SoLSA / Text3: 04.08, 04.18, 08.08, 11.10-1, 29.002
- 2938: UE location identification: background information and associated primitives 2. Transcoder location at the core network and source depending coding belonging to the non-access stratum. / Text1: Transcoder_location / Text3: 23.110
- 2939: - / Text1: Antenna_test_methods / Text3: 03.30
- 2940: Add requirement for high quality speech in UMTS Phase 1 but not in R99 / Text1: WBAMR / Text3: 22.105
- 2941: -
- 2942: - / Text1: Multimedia_Codec, CSM, WI2MMC, Codec(s)_for_CS_MM_Tel._Serv, Codec(s)_for_MM_Tel_Service, Codec_for_Multimedia_Telephony / Text3: 26.911, 26.104, 26.111
- 2943: - / Text1: QoS_for_Speech_&_MM_Codecs_/_AMR / Text3: 26.102, 26.912
- 2944: UMTS_AMR2 is default Codec Type in R99 dual_mode terminals / Text1: TFOAMR / Text3: 26.103
- 2945: Combination of the AMR speech codec and the Noise Suppression function. TS 06.77 and TR 06.78 only apply to GSM. They apply to UMTS from Rel-4 onwards, when they were converted to TS 26.077 and TR 26.078. / Text1: AMRNS / Text3: 06.77, 06.78
- 2946: Transcoder handling in the CN at inter-system handover and relocation + Introduction of UMTS AMR / Text1: OoBT / Text3: 23.009, 24.008
- 2947: 24.008 CR#0572 in NP-020220 was approved under this WI / Text1: OoBTC / Text3: 24.008 CR#0572 in NP-020220
- 2948: - / Text1: ASCI / Text3: 02.30, 02.68, 03.68, 03.69, 04.18, 08.08, 11.10-1, 11.11, 23.067, 23.094, 24.008, 24.067, 27.007, 29.002
- 2949: Minor improvements to 24.007 and 24.008 to increase the number of simultaneous calls/sessions from the present 7: the TI value is increased (NP-99441). / Text1: CC_Related_items / Text3: 24.007, 24.008
- 2950: - / Text1: Multimedia / Text3: 24.008, 27.001, 29.007
- 2951: Sub-System Number allocation for Radio Access Network Application Part, Radio Network Subsystem Application Part / Text1: SSN_allocation / Text3: 23.003
- 2952: Access to an Intranet/ISP with DHCP end to end / Text1: ISPaccess / Text3: 29.061
- 2953: Support for the IP-Multicast protocol / Text1: Point_to_Multipoint_Services / Text3: 29.061
- 2954: - / Text1: FAX / Text3: 22.003, 22.100
- 2955: Asynchronous Interface for real-time NT Fax + Introduction of Asynchronous interface for Real-time non-transparent FAX / Text1: Realtime_NT_FAX_in_UMTS / Text3: 27.001, 27.003
- 2956: - / Text1: GLR / Text3: 29.120
- 2957: - / Text1: MSP2 / Text3: 22.097, 23.072, 23.083, 23.084, 23.091, 23.093, 23.097
- 2958: - / Text1: Prepaging / Text3: 23.018, 23.082, 29.002
- 2959: Re-definition of channel quality measure used for AMR link adaptation for DARP MS / Text3: 05.09
- 2960: - / Text1: HS / Text3: 13.21
- 2961: - / Text1: Streamlining / Text3: 27.060, 29.061
- 2962: - / Text1: R99_Service_Clean_up / Text3: 03.10, 27.001, 27.002, 27.003, 27.060, 29.007, 29.061

| ID | WBS | Task | Type | Duration | Start | Finish | Complete | Baseline start | Baseline finish | Baseline duration | Constraint | Resources | Work | Actual work | Text1 | Text6 | Text8 | Text3 | Text12 | Text4 | Text5 |
| --- | --- | --- | --- | --- | --- | --- | --- | --- | --- | --- | --- | --- | --- | --- | --- | --- | --- | --- | --- | --- | --- |
| 2963 | 759 | **(Small) Technical Enhancements and Improvements for R99** |  | 261d? | 1999-01-01 A | 1999-12-31 A | 100% | 1999-01-01 | 1999-12-31 | 261d? |  | N3 | 6264h | 6264h | TEI | R99 | Gwiho |  |  |  |  |
| 2964 | 759.1 | TEI_[CS_Data] |  | 261d? | 1999-01-01 A | 1999-12-31 A | 100% | 1999-01-01 | 1999-12-31 | 261d? | start no earlier than 1999-01-01 | N3 | 2088h | 2088h | TEI_[CS_Data] | R99 | Gwiho |  |  |  |  |
| 2965 | 759.2 | TEI_[GPRS] |  | 261d? | 1999-01-01 A | 1999-12-31 A | 100% | 1999-01-01 | 1999-12-31 | 261d? | start no earlier than 1999-01-01 | N3 | 2088h | 2088h | TEI_[GPRS] | R99 | Gwiho |  |  |  |  |
| 2966 | 760 | **R99 UE Conformance Testing** |  | 261d? | 1999-01-01 A | 1999-12-31 A | 100% | 1999-01-01 | 1999-12-31 | 261d? |  | R5,T1 | 4176h | 4176h | TEI_Test | R99 | Ingbert | 34.108, 34.121, 34.122, 34.123-1, 34.123-2, 34.123-3 |  |  |  |
| 2967 | 760.1 | Deleted - RTEI |  | 261d? | 1999-01-01 A | 1999-12-31 A | 100% | 1999-01-01 | 1999-12-31 | 261d? | start no earlier than 1999-01-01 | T1 | 2088h | 2088h | RTEI | R99 | Ingbert | 34.123-1 CR#0650, 0651, 34.123-3 CR#0148, 0149, 0150 | TP-06 |  |  |
| 2968 | 760.2 | Common test environments for User Equipment (UE); Conformance testing | milestone | 0d? | 1999-01-01 A | 1999-01-01 A | 100% | 1999-01-01 | 1999-01-01 | 0d? | start no earlier than 1999-01-01 | R5,T1 |  |  | TEI_Test | R99 | Ingbert | 34.108 |  |  |  |
| 2969 | 760.3 | Terminal conformance specification, Radio transmission and reception (FDD) | milestone | 0d? | 1999-01-01 A | 1999-01-01 A | 100% | 1999-01-01 | 1999-01-01 | 0d? | start no earlier than 1999-01-01 | R5,T1 |  |  | TEI_Test | R99 | Ingbert | 34.121 |  |  |  |
| 2970 | 760.4 | Terminal conformance specification, Radio transmission and reception (TDD) | milestone | 0d? | 1999-01-01 A | 1999-01-01 A | 100% | 1999-01-01 | 1999-01-01 | 0d? | start no earlier than 1999-01-01 | R5,T1 |  |  | TEI_Test | R99 | Ingbert | 34.122 |  |  |  |
| 2971 | 760.5 | UE conformance specification; Part 1: Protocol conformance specification | milestone | 0d? | 1999-01-01 A | 1999-01-01 A | 100% | 1999-01-01 | 1999-01-01 | 0d? | start no earlier than 1999-01-01 | R5,T1 |  |  | TEI_Test | R99 | Ingbert | 34.123-1 |  |  |  |
| 2972 | 760.6 | UE conformance specification; Part 2: Implementation Conformance Statement (ICS) specification | milestone | 0d? | 1999-01-01 A | 1999-01-01 A | 100% | 1999-01-01 | 1999-01-01 | 0d? | start no earlier than 1999-01-01 | R5,T1 |  |  | TEI_Test | R99 | Ingbert | 34.123-2 |  |  |  |
| 2973 | 760.7 | UE conformance specification; Part 3: Abstract test suites (ATSs) | milestone | 0d? | 1999-01-01 A | 1999-01-01 A | 100% | 1999-01-01 | 1999-01-01 | 0d? | start no earlier than 1999-01-01 | R5,T1 |  |  | TEI_Test | R99 | Ingbert | 34.123-3 |  |  |  |
| 2974 | 761 | Deleted - Dual Tone Multi-Frequency signalling : Support in the whole 3GPP system |  | 261d? | 1999-01-01 A | 1999-12-31 A | 100% | 1999-01-01 | 1999-12-31 | 261d? | start no earlier than 1999-01-01 | N1 | 2088h | 2088h | DTMF | R99 | Frederic | 23.014 CR#0004 | NP-06 |  |  |
| 2975 | 762 | Deleted - Intersystem_Change |  | 261d? | 1999-01-01 A | 1999-12-31 A | 100% | 1999-01-01 | 1999-12-31 | 261d? | start no earlier than 1999-01-01 | SMG | 2088h | 2088h | Intersystem_Change | R99 |  | 04.18 CR#A243 | SMG |  |  |
| 2976 | 763 | Deleted - Long_Forwardedto_Numbers |  | 261d? | 1999-01-01 A | 1999-12-31 A | 100% | 1999-01-01 | 1999-12-31 | 261d? | start no earlier than 1999-01-01 | N2 | 2088h | 2088h | Long_Forwardedto_Numbers | R99 | Kimmo | 29.002 | NP-06 |  |  |
| 2977 | 764 | Deleted - RANimp-FSEarlyUE |  | 261d? | 1999-01-01 A | 1999-12-31 A | 100% | 1999-01-01 | 1999-12-31 | 261d? | start no earlier than 1999-01-01 | R3 | 2088h | 2088h | RANimp-FSEarlyUE | R99 | Juha | 25.413 CR#0520, 0538, 0565, 0563, 0541, 0540, 0539, 0547 | RP-06 |  |  |
| 2978 | 765 | Release 1999 Studies |  | 261d? | 1999-01-01 A | 1999-12-31 A | 100% | 1999-01-01 | 1999-12-31 | 261d? |  | S1,T2 | 2088h | 2088h |  | R99 | Alain |  |  |  |  |
| 2979 | 766 | Advanced Addressing/Numbering |  | 261d? | 1999-01-01 A | 1999-12-31 A | 100% | 1999-01-01 | 1999-12-31 | 261d? | start no earlier than 1999-01-01 | S1 | 2088h | 2088h | Numbering | R99 | Alain | 22.975 |  | Vodafone | mona.mustapha@vodafone.com |
| 2980 | 767 | Combined GSM and Mobile IP mobility handling in UMTS IP CN |  | 261d? | 1999-01-01 A | 1999-12-31 A | 100% | 1999-01-01 | 1999-12-31 | 261d? | start no earlier than 1999-01-01 | S2 | 2088h | 2088h |  | R99 | Maurice | 23.923 |  |  |  |
| 2981 | 768 | UE Capabilities Requirements |  | 261d? | 1999-01-01 A | 1999-12-31 A | 100% | 1999-01-01 | 1999-12-31 | 261d? | start no earlier than 1999-01-01 | T2 | 2088h | 2088h | UCR | R99 |  | 21.904 |  |  |  |
| 2982 | 769 | Electrical safety requirements and regulations |  | 261d? | 1999-01-01 A | 1999-12-31 A | 100% | 1999-01-01 | 1999-12-31 | 261d? | start no earlier than 1999-01-01 | T2 | 2088h | 2088h |  | R99 |  | 34.907 |  |  |  |
| 2983 | 770 | Specific Absorbtion Rate (SAR) requirements and regulations in different regions |  | 261d? | 1999-01-01 A | 1999-12-31 A | 100% | 1999-01-01 | 1999-12-31 | 261d? | start no earlier than 1999-01-01 | T2 | 2088h | 2088h |  | R99 |  | 34.925 |  |  |  |
| 2984 | 771 | Multi-mode UE issues |  | 261d? | 1999-01-01 A | 1999-12-31 A | 100% | 1999-01-01 | 1999-12-31 | 261d? | start no earlier than 1999-01-01 | T2 | 2088h | 2088h |  | R99 |  | 21.810, 21.910 |  |  |  |
| 2985 | 772 | Provision of fax service in GSM and UMTS |  | 261d? | 1999-01-01 A | 1999-12-31 A | 100% | 1999-01-01 | 1999-12-31 | 261d? | start no earlier than 1999-01-01 | T2 | 2088h | 2088h |  | R99 |  | 22.945 |  | Ericsson | peter.bleckert@ericsson.com |
| 2986 | 773 | Separating Radio Resources and Mobility Management specific parts of the MS Classmark |  | 650d | 2003-09-19 A | 2006-03-16 A | 100% | 2003-09-19 | 2006-03-16 | 650d |  | T2 | 5200h | 5200h |  | R99 |  | 23.814 |  |  |  |

Notes:
- 2963: -
- 2964: -
- 2965: -
- 2966: Specifies Conformance Tests for a 3G UE to be recognised as 3GPP-standard compliant. A 3GPP-external body, GCF (Global Certification Forum), delivers certificates to prove that a UE has correctly passed tests and is then conform to the 3GPP standard.
- 2967: No CR or new TS/TR approved under this WI
- 2968: -
- 2969: measurement procedures for the conformance test of the UE that contain transmitting characteristics, receiving characteristics and performance requirements in addition to requirements for support of RRM (Radio Resource Management) in FDD mode.
- 2970: measurement procedures for the conformance test of the UE that contain transmitting characteristics, receiving characteristics and performance requirements in addition to requirements for support of RRM (Radio Resource Management) in TDD mode.
- 2971: TS 34.123, composed of three parts, actually specifies the protocol conformance testing for the 3G UE. Part 1 describes the overall test structure.
- 2972: Part 2 contains the applicability of each test case defined as the Implementation Conformance Statement (ICS) proforma, in compliance with the relevant requirements, and in accordance with the relevant guidance given in ISO/IEC 9646-7 and ETS 300 406.
- 2973: Part 3 specifies the protocol conformance testing in TTCN for the 3G UE at the Uu interface. It defines the TTCN test specification and design considerations in Abstract Test Suites based on the test cases specified in prose in part 1.
- 2974: No CR or new TS/TR approved under this WI
- 2975: No CR or new TS/TR approved under this WI
- 2976: -
- 2977: No CR or new TS/TR approved under this WI
- 2978: -
- 2979: Study on requirements for numbering and addressing for UMTS
- 2980: -
- 2981: Moved to CT1 at TSG-T closure
- 2982: Moved to RAN4 at TSG-T closure. TR summarizes differences between international and national standards relevant to IEC60950 and refers to regulations for conformity assessment due to different regulatory environments in different countries / regions.
- 2983: Moved to RAN4 at TSG-T closure.
- 2984: Moved to CT1 at TSG-T closure. Consequences on roaming capabilities and service availability (e.g. handover) of multi-mode UEs while roaming in various regions with various network configurations. Case studies for each of the possible scenarios in specs
- 2985: CP#27: Moved to C1 on closure of T2; see TP-050062. CP#28: C1->C3
- 2986: CP#27: change of WG as a result of closure of CN and T.
